# 3GPP_Release-2000

Schedule from MS Project, 1998-12-07 to 2013-12-11, A marks actual dates.

## Calendars

- Standard: Mon-Fri 08:00-12:00, 13:00-17:00; Sat-Sun off. Exceptions (off unless hours are given): 2000-01-15 08:00-12:00, 13:00-17:00, 2009-05-30 08:00-12:00, 13:00-17:00, 2011-08-27 to 2011-08-28 08:00-12:00, 13:00-17:00, 2011-09-24 08:00-12:00, 13:00-17:00.

## Resources

| Resource |
| --- |
| NP |
| N1 |
| N2 |
| N3 |
| N4 |
| N5 |
| TP |
| T1 |
| T2 |
| T3 |
| RP |
| R1 |
| R2 |
| R3 |
| R4 |
| SP |
| S1 |
| S2 |
| S3 |
| S4 |
| S5 |
| PCG |
| GP |
| No |
| CN4 |
| ? |
| WG G2 |
| G2 |
| G1 |
| G4 |
| G3 |
| All |
| Generic |
| MLST |
| G5 |
| S3, G2 |
| WG T2 |
| GP,G1 |
| G4,G5 |
| OMA |
| GP-G2 |
| Yes |
| GP, |
| N4, |
| GP, N1 |
| CT5 |
| C5 |
| C1 |
| C4 |
| C3 |
| C6 |
| G1, |
| 4 |
| ct |
| c,s,r |
| CT,RAN,SA |
| G2, |
| G1, G3 |
| CT6 |
| CT1 |
| CT1, CT3, CT4 |
| C1, C3, C4 |
| CP |
| R5 |
| C |
| Rel-8 |
| GP, G2 |
| R1,R4 |
| S5,C1 |
| CT,RAN,SA,GERAN |
| S3,C1,C4 |
| 5 |
| S1,C1,C3,C4,S5 |
| S1,C1,C3,C5 |
| S1,C1,C3,C4 |
| S1,S5 |
| S2,S3 |
| RAN,SA |
| RP,S5 |
| S2,CT |
| S1,CT |
| S1,CT,GERAN |
| S1,C5 |
| S3,CT |
| S4,CT |
| C1,SA |
| S1,S2 |
| S1,S4 |
| S2,S2,S3,CT |
| S2,S3,CT |
| S1,CT,GX |
| S1,S4,CT |
| S2,S2,S3,S5,CT |
| S1,S2,CT |
| S1,S2,S3,CT |
| S1,S2,S3,S5CT |
| S1,S2,S3,S5,CT |
| S2,S5,CT |
| S4,S3 |
| S1,C1 |
| CP,C1 |
| C1,C3 |
| C1,C3,C4 |
| S1,S5,CT |
| C4,C3 |
| CP,RAN,SA,GERAN |
| S1,S2,S3,S5,CP |
| S2,S3,CP |
| S2,CP |
| S1,CP,GX |
| S1,CP |
| S1,S4,CP |
| S1,S2,CP |
| S1,S2,S3,CP |
| S2,S5,CP |
| S3,CP |
| S1,S5,CP |
| RAN,SA,GERAN |
| S1,S2,S3,S5,C1,C3,C4,C6 |
| S2,S3,C1,C3,C4 |
| S2,C4 |
| S2,C1,C3,C4 |
| S2,C1,C4 |
| S2,S3,C1,C4 |
| S1,C1,C4,G2 |
| C1,C4 |
| S1,C1,C3 |
| S1,S4,C1,C3,C4 |
| S1,S2,S3,C1,C3,C4 |
| S2,S5,C3 |
| S1,S2,C1,C4 |
| S2,C1 |
| S2,C1,C3 |
| S3,C1,C3,C4 |
| S1,S5,C1,C3,C4 |
| S2,C3,C4 |
| C3,C1 |
| R2,R4 |
| R2,R5 |
| RP,R5 |
| RP,S5,R5 |
| R1,R5 |
| S1,C1,R5 |
| S1,C1,S4,R5 |
| GERAN |
| G3new |
| G1, G3new |
| C4,C1,C3 |
| R1.R4 |
| R1, R4 |
| R2,R3 |
| C3,C4 |
| S4,C3 |
| S4,C3,C1,C4 |
| S1,S2,C1 |
| S1,S2<C1,C3,C4 |
| S1,S2,C1,C3,C4 |
| S5,C1,C3,C4 |
| GP,C4 |
| C4,C1 |
| S2,S1 |
| RP,SP,GP |
| RP,SP,CP,GP |
| CP,GP,RP,SP |
| GP,C4,S4 |
| S1,C1,C4 |
| S1,S2,C3,C1 |
| R2,R4,R3 |
| CP,GP, RP,SP |
| S2,S1,C1,S5 |
| S2,S1,C1 |
| S1,C1,S4 |
| S1,S2,GP,C4,R2 |
| S1,GP,R2 |
| S1,C6 |
| S1,S2,C1,S4 |
| S2,S3,S5,C1,C3,C4 |
| S2,S5,C1 |
| S2,S3,S5 |
| CP,GP, RP,SP,TP |
| S2,C4,C1 |
| S1,C1,C4,S3 |
| S2,S5 |
| S3,C1 |
| S3,C4 |
| S1,C4 |
| S2,S5,C3,C1 |
| S2,S1,S5,C1,C4 |
| S1,R1,C3 |
| S1,C1,R2 |
| S2,S1,C1,C4 |
| S1,C1,C6 |
| GP,S4,C4,C1,C3 |
| C3,C1,C4 |
| S1,C4,C1 |
| S1,S3 |
| S1,S2,S5,C3,C4 |
| R4,G1 |
| G1,R4 |
| RP,GP |
| R4,GP |
| R3,R2 |
| C6,RP,SP |
| R5,C6 |
| CP,RP,SP |
| RP,SP,CP |
| R3,S5 |
| S1,S2,RP |
| S1,S2,S5,RP |
| S2,S1,RP |
| Rel-9 |
| S3,C6 |
| S1,S2,S3,S5,RP |
| S2,S1,S3 |
| S1,S2,S3 |
| S1,S2,S3,S5 |
| C6,R5 |
| S1,S2,RP,GP |
| S1,S2,S4,S5,RP,GP |
| GP,G2 |
| GP,GP, N1 |
| GP,S2,G1,G2 |
| GP,R2,R3,S2,G1,G2 |
| GP,S2,S5,R2,R3,G2,G1 |
| GP,R3 |
| N4,S2 |
| GP,RP |
| GP,S2,RP |
| G5,G4 |
| G4,R3 |
| S2,R2,R4 |
| S1,S2,R2,R4 |
| GP,S5 |
| S1,S2,S5 |
| R4,R5 |
| R4,R2,R3,R5 |
| S2,S5,N4,RP |
| S1,S2,S3,S5,NP |
| S2,S4,S5 |
| T2,S1,S4,S5 |
| SP,RP |
| S2,RP |
| S1,S2,CP,G2 |
| CP,SP |
| S1,G2 |
| SP,CP |
| S1,S2,S5,C3 |
| S1,C1,S3 |
| G1,G3new |
| C4, C3, C1C4 |
| C4,C3,C1 |
| S1,S2,S3,S5,R2,R3,R4 |
| S1,S2,S3,R2 |
| S2,S3,S5,C4,R2 |
| S1,S5,C1 |
| S1,S2,S3,C1,C3,C4,R2 |
| Ggp |
| S3,S2,C1,C4,G2 G3new |
| R1,R2,R3,R4 |
| R4,R1,R2,R3 |
| R4,R2,R3 |
| S1,C1,C4,R2 |
| R4,R2 |
| S2,C4,R2,R4 |
| S2,C4,R2 |
| S2,S3,S5,C3,C4,R2 |
| S1,S2,S4,T2 |
| S1,S2,S4 |
| S1,S2,S4,R5 |
| S3,S2,C1,C4,G2,G3new |
| GP,C1 |
| S1,S5,C4 |
| S1,S2,S3,S5,R2,R3,R4,GP |
| GP,C4,C3,C1 |
| SMG9 |
| SMG1 |
| SMG2 |
| N3,R5 |
| N1, N2, N4, G1, G2, R3, S1, SMG2 |
| S1,SMG1 |
| SMG1,N4 |
| N1,C1,N4,S1,T2,G2,SMG1,SMG2,SMG3,SMG7,SMG9 |
| SMG1,N2 |
| S1,S2,N2,N4 |
| N4,N2 |
| G1,G2 |
| G1,G2,C1 |
| G1,G2,N1 |
| SMG2, SMG1, SMG3, SMG4, SMG7, SMG9, SMG10, G1, G2, G3, N1, N3, T2 |
| SMG2,G1 |
| S1,G1,G2 |
| SMG1,N1,G1,G2 |
| G2,G1 |
| G1,G2,G3,S1,S2,SMG1,SMG2,SMG7,N1,N2,N3,N4,T2 |
| 23.003, 23.008, 29.060 |
| S1, S2, SMG1, SMG2, SMG12, G2, N1, N2, N4 |
| S1,S2,SMG1,SMG2,SMG12,G2,N1,N2,N4 |
| S1,SMG2,N1,N2,N4 |
| SMG1,T2 |
| S1,N1,N2,N4 |
| S1,S2,N5 |
| SMG2,SMG7,G2,T2 |
| S3,N1,N2,N3 |
| S3,N1,N2,N4 |
| SMG9,T3 |
| SMG2,SMG3,SMG7,G2,N2 |
| SMG2,N1,G1,G2 |
| S1,N2 |
| N1,N3 |
| S2,N1 |
| N1,N2,N4 |
| N2,N1,N4 |
| N2,N4 |
| S1,T3 |
| T2,N3 |
| S3,N2 |
| T2,S1 |
| S1,N4 |
| SMG1,SMG2,SMG7 |
| N1,S1,T1 |
| SMG1,SMG3 |
| N4,S2,N1 |
| S1,S2,SMG1,SMG2,SMG7,G1,G2,G3,N1,N2,N3,N4,T2 |
| SMG1,N3 |
| S1,N3 |
| CP,SP,SMG |
| CP,SP,TP,GP,SMG |
| NP,SP,TP,GP,SMG |
| NP,GP, RP,SP,TP |
| SMG2,SMG1,SMG3,SMG4,SMG7,SMG9,SMG10,G1,G2,G3,N1,N3,T2 |
| S1,N2,N4 |
| S1,S2,S3,C1,C3,C4,R2,R3 |
| R2,R3,R1,R4 |
| R2,R3,R4 |
| R2,R1,R3,R4 |
| S2,C4,R2,R3,R4 |
| S2,C4,R2,R1,R3,R4 |
| S2,S3,S5,C3,C4,R2,R3,R4 |
| R1,R2,R4 |
| R3,R1,R4 |
| S2, |
| S2,G2, |
| S1,S2,G2, |
| S1,S2,G2,R2,R3, |
| S1,S2,C4,G2,R2,R3 |
| S1,S2,N4,G2,R2,R3 |
| S1,S2,SMG1,SMG2,SMG12,G2,N1,N2,N4,R2,R3 |
| S1,SMG1,T2 |
| S1,SMG1,S2 |
| S1,N4,N2 |
| T2,N1,N3 |
| S3,N2,N4 |
| SMG1,SMG2,SMG3,SMG7,SMG9,N1,C1,N4,S1,T2,G2 |
| SMG1,N2,N4 |
| S2,T2,N1,N2,N4 |
| S1,T2 |
| S1,S2,C4 |
| S1,S2,N4,RP |
| S2,N4 |
| S1,S2,N3,N4,RP |
| S1,S2,SMG1,SMG2,SMG12,T2,G2,N1,N2,N4,R2,R3 |
| S1,T2,N1,N3 |
| S1,S2,SMG1,SMG2,SMG12,T2,G2,N1,N2,N3,N4,R2,R3 |
| S1,S2,S3,SMG1,SMG2,SMG12,G2,N1,N2,N4,R2,R3 |
| S1,S2,SMG,G1,G2,G3,N1,N2,N3,N4,T2 |
| S1,S2,SMG,T2,G2,N1,N2,N3,N4,R2,R3 |
| S1,S3,SMG,G1,G2,G3,N1,N2,N3,N4,T2 |
| S1,S3,T2,N2,N4 |
| S1,S2,SMG,T2,G1,G2,G3,N1,N2,N3,N4 |
| G2,S2 |
| T1,R5 |
| R5,T1 |
| S1,S2,S4,T1,R5 |
| S1,S2,S4,S5,T1,RP,GP |
| S1,S2,S3,S5,R2,R3,R4,GP,C1 |
| S1,S2,S3,SMG1,SMG2,SMG12,N1,N2,N4,R2,R3 |
| S1,S2,SMG,T2,N1,N2,N3,N4,R2,R3 |
| NP,SP,TP,SMG |
| S1,S2,SMG,T2,N1,N2,N3,N4 |
| SMG,N1 |
| SMG |
| S1,S2,SMG1,SMG2,SMG7,N1,N2,N3,N4,T2 |
| SMG2,SMG1,SMG3,SMG4,SMG7,SMG9,SMG10,N1,N3,T2 |
| S1,SMG |
| SMG2,SMG7,T2 |
| SMG2,S2 |
| N1,N2,N4,R3,S1,SMG |
| SMG2,SMG3,SMG7,N2 |
| SMG1,SMG2,SMG3,SMG7,SMG9,N1,C1,N4,S1,T2 |
| S1,S2,SMG,N3,N4,RP |
| S1,S2,S4,SMG,N3,N4,RP |
| S2,C1,C4,R2,R1,R3,R4 |
| R2,S2,S4 |
| G3new,R5 |
| GP,R4 |
| S2,S4,R2 |
| SP,GP |
| RP,SP |
| S2,S1,S3,S5 |
| S3,S1 |
| N4,N1,N2,S2 |
| S2,G1,G2,R2,R3 |
| S2,G1,G2 |
| G1,G2,R2,R3 |
| N4,T3 |
| S3,S2,N1,N4,T3,OMA |
| T2,S1,S4,S5,OMA |
| S2,N3 |
| S4,S1 |
| N4,N3,S1 |
| R5,G3new |
| R4,R2,R1 |
| S2,R2 |
| C3, C4,C1 |
| S3,C1,C4,C3 |
| C1,C4,C3 |
| S2,C1,C4,C3 |
| R3,R5 |
| S1,S2,C3 |
| R1,R2 |
| S3,C1,C4,G2,G3new |
| R1,R3 |
| GP,N1 |
| R1,R2,R3 |
| R3,R2,R4 |
| R4,R3 |
| S1,S2,R2,R3 |
| S1,S2,S3,C1,C3,C4,R2,R3,R5 |
| S2,S1,S5 |
| C4, C1 |
| C3, C1, C4 |
| S2,S1,S3,S5,C4,C1 |
| S2,C3,C1,C4 |
| S2,S1,S5,C3 |
| GP,S2,C1 |
| GP,S2,C1,G2 |
| G2,S2,C1 |
| v |
| G3new,G1,G2 |
| G1,G2,C1,G3new |
| S2,S1,S5,C1,C3 |
| C1,C3,C4,R5 |
| R2,R1 |
| S1<S2,N1,R2,R5 |
| S1,S2,N1,R2,R5 |
| S2,R5 |
| S1,S2,S5,R5 |
| S2,C1,C4,R2,R1,R3,R4,R5 |
| S1,S2,S3,S5,NP,R5 |
| S1,S2,S4,S5,RP,R5,GP |
| S1,S2,S3,S5,C1,C6,R2,R3,R4 |
| S1,S2,S3,S5,C1,C6,R2,R3,R4,GP |
| S4,R2 |
| S1,S2,C1,C4,G2 |
| S4,C3,C4 |
| S5,C1,C4 |
| S2,C4,C3,C1 |
| C4, C3, C1 |
| S2,S4,R2,C4,C3,C1 |
| GP1,GP2 |
| GP,GP1,GP2 |
| GP,G1,G2 |
| G2,R3 |
| S1,S2,S3,C1,C3,C4,G2 |
| GP,G1,C1 |
| S1,S2,C4,C3,C1 |
| - |
| GP,G1,G2,G3new |
| S1,S2,S3,C1,C3,C4,G2,R2,R3 |
| S1,S2,C1,C3,C4,G2,R2,R3 |
| C1,C6 |
| GP,G2,C4 |
| S2,C3 |
| R5,R4 |
| C4,GP,G2 |
| S1,S2,C1,C4,G2,R2,R3 |
| R1,R2,R4,S3 |
| S2,S5,C3,C1,C4 |
| S2,S4,C4,C3,C1 |
| S2,S4 |
| S3,S1,S2 |
| S1,S2,S3,C1,R2 |
| S3,S1,S2,C1,R2 |
| S2,C3,S5 |
| S1,S2,C1,C4,C3,G2,R2,R3 |
| S5,C4 |
| S2,S1,C3 |
| C1,C4,C3,C6 |
| S1,S2,C1,C4,C3,C6,G2,R2,R3 |
| R1,R2,R4,S3,C4,C6 |
| R4,R1,R4,R1,R2,R3,R3 |
| S2,R3,R2 |
| S1,S2,S5,CP |
| S1,S3,CP |
| C6,C1 |
| R4,R2,R1,R3 |
| R3,R1,R2 |
| R1,R4,R2,R3 |
| S2,C4,C1,C3 |
| R3,R1,R2,R4 |
| C4,S1 |
| S2,S5,R3,GP, |
| S2,S5,R3,GP |
| S1,S2,S3,S5,C1,C3,C4 |
| S2,S3,S5,C1,C3,C4,C6 |
| S5,S1 |
| 03.06.2011 |
| CT1 CT3, CT4 |
| CT3, |
| CT4 |
| CT3 |
| GP,G2,G1 |
| S5,S1,C1 |
| SP,RP,CP |
| SP,CP,GP,RP |
| R1,R2,R4,R3 |
| R4,R2,R5 |
| R2,R4,R5 |
| R1,R2,R4,S2,S3,C4,C6 |
| C1-IETF |
| S4-IETF |
| C1-IETF, C3-IETF, C4-IETF |
| S3-IETF |
| C4-IETF |
| C1-IETF, C3-IETF |
| S2,S4,C1,R2 |
| S2,S4,C3,C4 |
| S2,S4,C1,C3,R2 |
| S1,S2,C1,IETF |
| S4,IETF |
| C1,C4,IETF |
| S2,S4,C1,C3,R2,IETF |
| S3,C1,C4,C3,IETF |
| S3,C4,IETF |
| C1,IETF |
| S1,S2,S3,S5,C1,C3,C4,C6,IETF |
| S2,S3,C1,C4,IETF |
| S1,S2,C1,C3,C4,IETF |
| C1,C3,C4,IETF |
| S1,S5,C1,C3,C4,IETF |
| C1,C3,IETF |
| S2,C1,C3,C4,IETF |
| S2,S4,C3,C4,IETF |
| S5,C1,C4,IETF |
| S5,C1,C3,C4,IETF |
| S2,S3,S5,C1,C3,C4,IETF |
| S2,IETF |
| S3,C1,C3,C4,IETF |
| S2,S3,C1,C3,C4,IETF |
| S3,S2 |
| S3,S2,C1 |
| S3,S1,S2,C1 |
| S2,S5,N3 |
| S1,S2,S3,S5,N1,N3,N4,T3 |
| S5,N4,R3 |
| S1,S2,S5,C1,C4,C3,C6,G2,R2,R3 |
| S2,N1,N4,R3,GP |
| T2,S3 |
| S3,N4,N1 |
| S2,N3,N4 |
| S3,T2 |
| S2,S1,S3,S5,RP,GP |
| S1,S2,S3,S5,R5 |
| S1,S2,S3,S5,NP,T3,T1,R5 |
| S3,T3 |
| GP,S3 |
| S1,S2,S3,S4,S5,RP,R5,GP |
| N1,N4 |
| S1,S2,S3,S4,N1,N3,N4,OMA |
| S2,C1,C3,C4,G2,R2,R3 |
| S1,C4,C3 |
| S2,S1,C1,C4,IETF |
| C1,C3,C4,C6 |
| C4,C1,C6 |
| S1,S2,S3,C1,C3,C4,C6 |
| S2,S1,C1,C3,C4 |
| S1,S2,C1,C3 |
| C1.IETF |
| C1-IETF,C4-IETF |
| G1,C1 |
| G1,S2,C4 |
| G2,S2,C4 |
| R1,R2,R3,R4,R5 |
| R2,R4,R3,R5 |
| R3,R2,R5 |
| R2,R3,C1,C6 |
| S1,S2,S3,C1,C3,C4,C6,R2,R3 |
| R4,R1 |
| S2,S4,C4,C3,C1,IETF |
| S2,C4,C3 |
| S3.C4,C1 |
| G2,C4 |
| R4,G1,G3new |
| C4,G2 |
| S3,C4,C1 |
| R2,R3,R5 |
| R1,R2,R4,R5 |
| S1,S2,S3,S5,C1,C6,R2,R3,R4,R5,GP |
| S1,C1,C4,R2,R5 |
| S2,S3,S5,C3,C4,R2,R3,R4,R5 |
| R2,R1,R3,R4,R5 |
| S3-IETF, C1-IETF |
| S3-IETF,C1-IETF |
| C1-IETF,C3-IETF |
| S2-IETF |
| S2,S1,C1,C3,C4,IETF |
| 25.101, 25.104, 25.141, 25.317 |
| S1,G2,S2,C1 |
| S1,C1,C4,R2,R3,R5 |
| S5,S2 |
| S4,C3,C4,IETF |
| S4,S3,C3,C4,IETF |
| S4,S3,C3,C4 |
| S4,S3,IETF |
| S1,S2,S3,S5,C1,C3,C4,C6,R2,R3 |
| C1,C4,C6 |
| S1,S2,S5,C1,C4,C6,G2,R2,R3 |
| GP,G1,C1,G3new |
| S2,S5,C1,C3 |
| C4,C3,G2 |
| S2,S1,S5,C3,C1,C4 |
| C3,C4,C1 |
| S2,S1,S5,C3,C4,C1 |
| RAN1 |
| RAN2 |
| RAN3 |
| RAN4 |
| R4,R2,R3, |
| Feasibility Study on LTE Device to Device Communications – Radio Aspects |
| SMG1,SMG2,SMG3,SMG7,SMG9,N1,N4,S1,T2 |

## Schedule

| ID | WBS | Task | Type | Duration | Start | Finish | Complete | Remaining | Baseline start | Baseline finish | Baseline duration | Total slack | Constraint | Resources | Work | Actual work | Text6 | Text1 | Text2 | Text4 | Text5 | Text7 | Text8 |
| --- | --- | --- | --- | --- | --- | --- | --- | --- | --- | --- | --- | --- | --- | --- | --- | --- | --- | --- | --- | --- | --- | --- | --- |
| 1 | 1 | Extract for SA1#58 of the Version 2012 Mar 16 of the 3GPP Work Plan | milestone | 0d? | 2000-01-03 | 2000-01-03 |  |  | 2000-01-03 | 2000-01-03 | 0d? | 3643d | finish no earlier than 2000-01-03 | S1 |  |  |  |  |  |  |  |  |  |
| 2 | 2 | Rel-11 Stage 1 frozen 09/2011 | milestone | 0d? | 1998-12-07 | 1998-12-07 |  |  | 2000-01-03 | 2000-01-03 | 0d? | 3923d | finish no earlier than 1998-12-07 | S1 |  |  |  |  |  |  |  |  |  |
| 3 | 3 | Rel-11 Stage 2 frozen 03/2012 | milestone | 0d? | 1998-12-07 | 1998-12-07 |  |  | 2000-01-03 | 2000-01-03 | 0d? | 3923d | finish no earlier than 1998-12-07 | S1 |  |  |  |  |  |  |  |  |  |
| 4 | 4 | Rel-11 Stage 3 freeze 09/2012 | milestone | 0d? | 1998-12-07 | 1998-12-07 |  |  | 2000-01-03 | 2000-01-03 | 0d? | 3923d | finish no earlier than 1998-12-07 | S1 |  |  |  |  |  |  |  |  |  |
| 5 | 5 | Gantt: dark blue=done; light blue=to be done; grey: previous values; black=summary | milestone | 0d? | 1998-12-07 | 1998-12-07 |  |  | 2000-01-03 | 2000-01-03 | 0d? | 3923d | finish no earlier than 1998-12-07 | S1 |  |  |  |  |  |  |  |  |  |
| 6 | 6 | Release 12 Features |  | 321d? | 2011-09-22 A | 2012-12-12 | 10% | 288.9d? | 2011-09-22 | 2012-12-12 | 321d? | 260d | finish no earlier than 2012-12-12 | SP,CP | 2568h | 256.8h | Rel-12 |  |  |  |  |  |  |
| 7 | 7 | **IMS-based Telepresence** |  | 196d? | 2011-09-22 A | 2012-06-20 | 80% | 39.2d? | 2011-09-22 | 2012-06-20 | 196d? | 385d |  | S1 | 3136h | 2508.8h | Rel-12 | IMS_TELEP | PCG-27 | Orange | bruno.tossou@orange-ftgroup.com | SP-53 |  |
| 8 | 7.1 | Stage 1 for IMS-based Telepresence |  | 196d? | 2011-09-22 A | 2012-06-20 | 80% | 39.2d? | 2011-09-22 | 2012-06-20 | 196d? | 385d | finish no earlier than 2012-06-20 | S1 | 1568h | 1254.4h | Rel-12 | IMS_TELEP | PCG-27 | Orange | bruno.tossou@orange-ftgroup.com | SP-53 |  |
| 9 | 8 | **Service and Media Reachability for Users over Restrictive Firewalls** |  | 197d? | 2011-09-21 A | 2012-06-20 | 20% | 157.6d? | 2011-09-21 | 2012-06-20 | 197d? | 385d |  | S1 | 3152h | 630.4h | Rel-12 | SMURFs | PCG-27 | Vodafone | mona.mustapha@vodafone.com | SP-53 |  |
| 10 | 8.1 | Stage 1 for Service and Media Reachability for Users over Restrictive Firewalls |  | 197d? | 2011-09-21 A | 2012-06-20 | 20% | 157.6d? | 2011-09-21 | 2012-06-20 | 197d? | 385d | finish no earlier than 2012-06-20 | S1 | 1576h | 315.2h | Rel-12 | SMURFs | PCG-27 | Vodafone | mona.mustapha@vodafone.com | SP-53 |  |
| 11 | 9 | **Advanced IP Interconnection of Services (IPXS) for national interconnect** |  | 2d? | 2012-03-06 A | 2012-03-07 A | 100% |  | 2012-03-06 | 2012-03-07 | 2d? |  |  | S1 | 32h | 32h | Rel-12 | IPXSNAT | PCG-28 | KPN | toon.norp@tno.nl | SP-55 |  |
| 12 | 9.1 | Stage 1 for Advanced IP Interconnection of Services (IPXS) for national interconnect |  | 2d? | 2012-03-06 A | 2012-03-07 A | 100% |  | 2012-03-06 | 2012-03-07 | 2d? |  | finish no earlier than 2012-03-07 | S1 | 16h | 16h | Rel-12 | IPXSNAT | PCG-28 | KPN | toon.norp@tno.nl | SP-55 |  |
| 13 | 10 | **Integration of Single Sign-On (SSO) frameworks with 3GPP networks** |  | 136d? | 2012-03-07 | 2012-09-12 |  |  | 2012-03-07 | 2012-09-12 | 136d? | 325d |  | S1 | 2176h |  | Rel-12 | SSO_Int | PCG-28 | InterDigital | christopher.wallace@interdigital.com | SP-55 |  |
| 14 | 10.1 | Stage 1 for Integration of Single Sign-On (SSO) frameworks with 3GPP networks |  | 136d? | 2012-03-07 | 2012-09-12 |  |  | 2012-03-07 | 2012-09-12 | 136d? | 325d | finish no earlier than 2012-09-12 | S1 | 1088h |  | Rel-12 | SSO_Int | PCG-28 | InterDigital | christopher.wallace@interdigital.com | SP-55 |  |
| 15 | 11 | **Codec for Enhanced Voice Services** |  | 973d? | 2010-03-25 A | 2013-12-11 | 45% | 534.6d? | 2010-03-25 | 2013-12-11 | 973d? | 0d |  | S4,S1 | 15576h | 7017.99h | Rel-12 | EVS_codec | PCG-24 | Huawei | anisse.taleb@huawei.com | SP-47 | Paolo |
| 16 | 11.1 | Stage 1 for Codec for Enhanced Voice Services |  | 1d? | 2010-03-25 A | 2010-03-25 A | 100% |  | 2010-03-25 | 2010-03-25 | 1d? |  | start no earlier than 2010-03-25 | S1 | 8h | 8h | Rel-12 | EVS_codec | PCG-24 | Huawei | anisse.taleb@huawei.com | SP-47 | Paolo |
| 17 | 11.2 | Stage 2/3 for Codec for Enhanced Voice Services |  | 973d? | 2010-03-25 A | 2013-12-11 | 45% | 535.15d? | 2010-03-25 | 2013-12-11 | 973d? | 0d | finish no earlier than 2013-12-11 | S4 | 7784h | 3502.8h | Rel-12 | EVS_codec | PCG-24 | Huawei | anisse.taleb@huawei.com | SP-47 | Paolo |
| 18 | 12 | **LIPA Mobility and SIPTO at the Local Network** |  | 824d? | 2010-10-15 A | 2013-12-06 | 7% | 766.85d? | 2010-10-15 | 2013-12-06 | 824d? | 3d |  | S2,C4,C1 | 42765.6h | 2321.49h | Rel-12 | LIMONET | PCG-26 | Huawei | patrice.hede@huawei.com | SP-50 | Maurice |
| 19 | 12.1 | TR on Stage 2 for LIPA Mobility and SIPTO at the Local Network |  | 517.85d? | 2010-10-15 A | 2012-12-07 | 45% | 284.82d? | 2010-10-15 | 2012-12-07 | 517.85d? | 263d | finish no earlier than 2012-12-07 | S2 | 4142.8h | 1864.26h | Rel-12 | LIMONET | PCG-26 | Huawei | patrice.hede@huawei.com | SP-50 | Maurice |
| 20 | 12.2 | Stage 2 for LIPA Mobility and SIPTO at the Local Network |  | 517.85d? | 2010-10-15 | 2012-12-07 |  |  | 2010-10-15 | 2012-12-07 | 517.85d? | 263d | finish no earlier than 2012-12-07 | S2 | 4142.8h |  | Rel-12 | LIMONET | PCG-26 | Huawei | patrice.hede@huawei.com | SP-50 | Maurice |
| 21 | 12.3 | **Core Network aspects of SIPTO at the Local Network (Stage 3)** |  | 581d? | 2011-09-19 | 2013-12-06 |  |  | 2011-09-19 | 2013-12-06 | 581d? | 3d |  | C4,C1 | 13944h |  | Rel-12 | LIMONET-SIPTO | PCG-27 | Huawei | caixia.qi@huawei.com | CP-53 |  |
| 22 | 12.3.1 | CT4 part of Core Network aspects of SIPTO at the Local Network |  | 581d? | 2011-09-19 | 2013-12-06 |  |  | 2011-09-19 | 2013-12-06 | 581d? | 3d | finish no earlier than 2013-12-06 | C4 | 4648h |  | Rel-12 | LIMONET-SIPTO | PCG-27 | Huawei | caixia.qi@huawei.com | CP-53 |  |
| 23 | 12.3.2 | CT1 part of Core Network aspects of SIPTO at the Local Network |  | 581d? | 2011-09-19 | 2013-12-06 |  |  | 2011-09-19 | 2013-12-06 | 581d? | 3d | finish no earlier than 2013-12-06 | C1 | 4648h |  | Rel-12 | LIMONET-SIPTO | PCG-27 | Huawei | caixia.qi@huawei.com | CP-53 |  |
| 24 | 12.4 | **Core Network aspects of LIPA Mobility (Stage 3)** |  | 581d? | 2011-09-19 | 2013-12-06 |  |  | 2011-09-19 | 2013-12-06 | 581d? | 3d |  | C1,C4 | 13944h |  | Rel-12 | LIMONET-LIPA | PCG-27 | Huawei | christian.herrero@huawei.com | CP-53 |  |
| 25 | 12.4.1 | CT1 part of Core Network aspects of LIPA Mobility |  | 581d? | 2011-09-19 | 2013-12-06 |  |  | 2011-09-19 | 2013-12-06 | 581d? | 3d | finish no earlier than 2013-12-06 | C1 | 4648h |  | Rel-12 | LIMONET-LIPA | PCG-27 | Huawei | christian.herrero@huawei.com | CP-53 |  |
| 26 | 12.4.2 | CT4 part of Core Network aspects of LIPA Mobility |  | 581d? | 2011-09-19 | 2013-12-06 |  |  | 2011-09-19 | 2013-12-06 | 581d? | 3d | finish no earlier than 2013-12-06 | C4 | 4648h |  | Rel-12 | LIMONET-LIPA | PCG-27 | Huawei | christian.herrero@huawei.com | CP-53 |  |

Notes:
- 1: -
- 2: -
- 3: -
- 4: -
- 5: -
- 6: -
- 7: -
- 8: - / Text3: 22.228
- 9: -
- 10: SP#54 completion 12/11=>06/12 / Text3: 22.278
- 11: SP#55 Stage 1 completed. Linked to Rel-11 Feature Advanced IP Interconnection of Services (IPXS) UID_470051. Source of external requirements: ETSI TISPAN LS_in on Guidelines for National IP Interconnection (S1-120223)
- 12: SP#55 completed / Text3: 22.228 CR#0161
- 13: Triggered by Rel-12 TR 22.895. Linked to SA3 TR 33.8xy (Study on Security aspects of SSO_Int), TR 33.914 (SSO application security for common IMS based on SIP Digest), TR 33.924 (i/w of GBA and OpenID), TR 33.980 (i/w of GBA and Liberty Alliance)
- 14: - / Text3: 22.101
- 15: SP#47 Stage 1 completed. Triggered by UID_370045 Study on enhanced voice service requirements for EPS (TR 22.813)
- 16: SP#47 completed. Covered by general requirements in 22.101, 22.001 / Text3: 22.173
- 17: SP#55 completion 09/13=>12/13 / Text3: 26.xyz, 26.xyz, 26.9yz
- 18: SP#54 moved to Rel-12. Linked to UID_490030 SIPTO Service Continuity of IP Data Session (SIPTO_SC), UID_450035 Local IP Access and Selected IP Traffic Offload (LIPA_SIPTO), UID_460026 Support BBF Accesses Interworking (BBAI)
- 19: SP#54 moved to Rel-12 / Text3: new TR 23.859
- 20: SP#54 moved to Rel-12 / Text3: 23.060, 23.401
- 21: CP#54 updated WID CP-110724=>CP-110801 moved to Rel-12 (completion 09/12=>12/13) / Text3: Stage 3
- 22: - / Text3: 29.002, 29.060, 29.272, 29.274, 29.275, 29.281, 29.282, 29.303, 29.305
- 23: - / Text3: 24.008, 24.301
- 24: CP#54 updated WID CP-110727=>CP-110820 moved to Rel-12 (completion 09/12=>12/13) / Text3: Stage 3
- 25: - / Text3: 24.008, 24.301
- 26: - / Text3: 29.060, 29.274, 29.281, 29.303, 29.002, 29.272, 29.275, 29.282, 29.305

| ID | WBS | Task | Duration | Start | Finish | Complete | Remaining | Baseline start | Baseline finish | Baseline duration | Total slack | Constraint | Resources | Work | Actual work | Text1 | Text2 | Text4 | Text5 | Text6 | Text7 | Text8 | Text9 | Text12 |
| --- | --- | --- | --- | --- | --- | --- | --- | --- | --- | --- | --- | --- | --- | --- | --- | --- | --- | --- | --- | --- | --- | --- | --- | --- |
| 27 | 13 | **Interworking between Mobile Operators using the Evolved Packet System and Data Application Providers** | 520d? | 2010-12-16 A | 2012-12-07 | 28% | 372.83d? | 2010-12-16 | 2012-12-07 | 520d? | 263d |  | S1,S2 | 12104h | 3414.14h | MOSAP | PCG-26 | Cisco | Vojislav Vucetic (vvucetic@cisco.com) | Rel-12 | SP-50 | Alain |  |  |
| 28 | 13.1 | Stage 1 for MOSAP | 202d? | 2010-12-16 A | 2011-09-21 A | 100% |  | 2010-12-16 | 2011-09-21 | 202d? |  | finish no earlier than 2011-09-21 | S1 | 1600h | 1600h | MOSAP | PCG-26 | Cisco | Vojislav Vucetic (vvucetic@cisco.com) | Rel-12 | SP-50 | Alain |  |  |
| 29 | 13.2 | TR on Stage 2 for MOSAP | 398d? | 2011-06-06 A | 2012-12-07 | 20% | 318.4d? | 2011-06-06 | 2012-12-07 | 398d? | 263d | finish no earlier than 2012-12-07 | S2 | 3184h | 636.8h | MOSAP | PCG-27 | Intel | vivek.g.gupta@intel.com | Rel-12 | SP-52 | Maurice |  |  |
| 30 | 13.3 | Stage 2 for MOSAP | 395d? | 2011-06-09 | 2012-12-07 |  |  | 2011-06-09 | 2012-12-07 | 395d? | 263d | finish no earlier than 2012-12-07 | S2 | 3160h |  | MOSAP | PCG-27 | Intel | vivek.g.gupta@intel.com | Rel-12 | SP-52 | Maurice |  |  |
| 31 | 14 | **Operator Policies for IP Interface Selection** | 451d? | 2011-03-23 A | 2012-12-07 | 23% | 349.19d? | 2011-03-23 | 2012-12-07 | 451d? | 263d |  | S2 | 10800h | 2438.11h | OPIIS | PCG-26 | LG Electronics | saso.stojanovski@lge.com | Rel-12 | SP-51 | Maurice |  |  |
| 32 | 14.1 | TR on Stage 2 for Operator Policies for IP Interface Selection | 451d? | 2011-03-23 A | 2012-12-07 | 45% | 248.05d? | 2011-03-23 | 2012-12-07 | 451d? | 263d | finish no earlier than 2012-12-07 | S2 | 3608h | 1623.6h | OPIIS | PCG-26 | LG Electronics | saso.stojanovski@lge.com | Rel-12 | SP-51 | Maurice |  |  |
| 33 | 14.2 | Stage 2 for Operator Policies for IP Interface Selection | 448d? | 2011-03-28 | 2012-12-07 |  |  | 2011-03-28 | 2012-12-07 | 448d? | 263d | finish no earlier than 2012-12-07 | S2 | 3584h |  | OPIIS | PCG-26 | LG Electronics | saso.stojanovski@lge.com | Rel-12 | SP-51 | Maurice |  |  |
| 34 | 15 | **Short Message Service (SMS) submit and delivery without MSISDN in IMS** | 396d? | 2011-06-08 A | 2012-12-07 | 34% | 261.36d? | 2011-06-08 | 2012-12-07 | 396d? | 263d |  | S2 | 9504h | 3231.36h | SMSMI | PCG-27 | Nokia Siemens Networks | curt.wong@nsn.com | Rel-12 | SP-52 | Maurice |  |  |
| 35 | 15.1 | TR on Stage 2 for SMS submit and delivery without MSISDN in IMS | 396d? | 2011-06-08 A | 2012-12-07 | 68% | 126.72d? | 2011-06-08 | 2012-12-07 | 396d? | 263d | finish no earlier than 2012-12-07 | S2 | 3168h | 2154.24h | SMSMI | PCG-27 | Nokia Siemens Networks | curt.wong@nsn.com | Rel-12 | SP-52 | Maurice |  |  |
| 36 | 15.2 | Stage 2 for SMS submit and delivery without MSISDN in IMS | 396d? | 2011-06-08 | 2012-12-07 |  |  | 2011-06-08 | 2012-12-07 | 396d? | 263d | finish no earlier than 2012-12-07 | S2 | 3168h |  | SMSMI | PCG-27 | Nokia Siemens Networks | curt.wong@nsn.com | Rel-12 | SP-52 | Maurice |  |  |
| 37 | 16 | **Security aspects of Public Warning System** | 454d? | 2011-03-23 A | 2012-12-12 | 55% | 205.05d? | 2011-03-23 | 2012-12-12 | 454d? | 260d |  | S3,S1,S2,C1,R2 | 13952h | 7632.37h | PWS_Sec | PCG-26 | ST-Ericsson | john.mattsson@ericsson.com | Rel-12 | SP-51 | Dionisio |  |  |
| 38 | 16.1 | Stage 1 for Security aspects of Public Warning System | 133d? | 2011-03-23 A | 2011-09-21 A | 100% |  | 2011-03-23 | 2011-09-21 | 133d? |  | finish no earlier than 2011-09-21 | S1 | 1048h | 1048h | PWS_Sec | PCG-26 | ST-Ericsson | john.mattsson@ericsson.com | Rel-12 | SP-51 | Alain |  |  |
| 39 | 16.2 | Deleted - Stage 2 for Security aspects of Public Warning System | 133d? | 2011-03-23 A | 2011-09-21 A | 100% |  | 2011-03-23 | 2011-09-21 | 133d? |  | finish no earlier than 2011-09-21 | S2 | 1048h | 1048h | PWS_Sec | PCG-26 | ST-Ericsson | john.mattsson@ericsson.com | Rel-12 | SP-51 | Maurice | PCG-27 | SP-53 |
| 40 | 16.3 | SA3 part for Security aspects of Public Warning System | 452d? | 2011-03-23 A | 2012-12-12 | 60% | 180.8d? | 2011-03-23 | 2012-12-12 | 452d? | 260d | finish no earlier than 2012-12-12 | S3 | 3608h | 2161.6h | PWS_Sec | PCG-26 | ST-Ericsson | john.mattsson@ericsson.com | Rel-12 | SP-51 | Dionisio |  |  |
| 41 | 16.4 | CT1 part for Security aspects of Public Warning System | 449d? | 2011-03-25 A | 2012-12-07 | 10% | 404.1d? | 2011-03-25 | 2012-12-07 | 449d? | 263d | finish no earlier than 2012-12-07 | C1 | 3592h | 359.2h | PWS_Sec | PCG-26 | ST-Ericsson | john.mattsson@ericsson.com | Rel-12 | SP-51 | Frederic |  |  |
| 42 | 16.5 | Deleted - RAN2 part for Security aspects of Public Warning System | 128d? | 2011-03-25 A | 2011-09-16 A | 100% |  | 2011-03-25 | 2011-09-16 | 128d? |  | finish no earlier than 2011-09-16 | R2 | 1024h | 1024h | PWS_Sec | PCG-26 | ST-Ericsson | john.mattsson@ericsson.com | Rel-12 | SP-51 | Joern | PCG-27 | RP-53 |
| 43 | 17 | Release 12 Studies | 321d? | 2011-09-22 A | 2012-12-12 | 20% | 256.8d? | 2011-09-22 | 2012-12-12 | 321d? | 260d | finish no earlier than 2012-12-12 | SP,CP | 2568h | 513.6h |  | PCG-27 |  |  | Rel-12 | SP-53 |  |  |  |
| 44 | 18 | Study on Alternatives to E.164 for Machine-Type Communications | 513d? | 2010-03-25 A | 2012-03-07 A | 100% |  | 2010-03-25 | 2012-03-07 | 513d? |  | finish no earlier than 2012-03-07 | S1 | 4080h | 4080h | FS_AMTC | PCG-24 | T-Mobile USA | gary.jones@T-Mobile.com | Rel-12 | SP-47 | Alain |  |  |
| 45 | 19 | Study on enhancements for Machine-Type Communications (MTC) | 655d? | 2010-06-10 A | 2012-12-12 | 45% | 360.25d? | 2010-06-10 | 2012-12-12 | 655d? | 260d | finish no earlier than 2012-12-12 | S1 | 5240h | 2358h | FS_MTCe | PCG-25 | Huawei | laurence.meriau@huawei.com | Rel-12 | SP-48 | Alain |  |  |
| 46 | 20 | Study on Integration of Single Sign-On (SSO) frameworks with 3GPP networks | 383d? | 2010-09-23 A | 2012-03-07 A | 100% |  | 2010-09-23 | 2012-03-07 | 383d? |  | finish no earlier than 2011-09-08 | S1 | 3041.15h | 3041.15h | FS_SSO_Int | PCG-25 | InterDigital | christopher.wallace@interdigital.com | Rel-12 | SP-49 | Alain |  |  |
| 47 | 21 | Study on Continuity of Data Sessions to Local Networks | 262.85d? | 2010-12-16 A | 2011-12-14 A | 100% |  | 2010-12-16 | 2011-12-14 | 262.85d? |  | finish no earlier than 2011-12-14 | S1 | 2084.27h | 2084.27h | FS_CSN | PCG-26 | NEC | joerg.swetina@nw.neclab.eu | Rel-12 | SP-50 | Alain |  |  |
| 48 | 22 | Study on non-MTC Mobile Data Applications Impacts | 262.77d? | 2010-12-16 A | 2011-12-14 A | 100% |  | 2010-12-16 | 2011-12-14 | 262.77d? |  | finish no earlier than 2011-12-14 | S1 | 2083.59h | 2083.59h | FS_MODAI | PCG-26 | Huawei, China Mobile | Amar Deol (adeol@huawei.com), Gang Li | Rel-12 | SP-50 | Alain |  |  |
| 49 | 23 | Study on Proximity-based Services | 256d? | 2011-09-22 A | 2012-09-12 | 40% | 153.6d? | 2011-09-22 | 2012-09-12 | 256d? | 325d | finish no earlier than 2012-09-12 | S1 | 2048h | 819.2h | FS_ProSe | PCG-27 | Qualcomm | Rich Hovey (rhovey@qualcomm.com) | Rel-12 | SP-53 |  |  |  |
| 50 | 24 | Study on User Plane Congestion management | 136d? | 2011-12-14 A | 2012-06-20 | 55% | 61.2d? | 2011-12-14 | 2012-06-20 | 136d? | 385d | finish no earlier than 2012-06-20 | S1 | 1088h | 598.4h | FS_UPCON | PCG-28 | KDDI | John Visser (xjo-visser@kddi.com) | Rel-12 | SP-54 |  |  |  |
| 51 | 25 | Study on RAN Sharing Enhancements | 196d? | 2011-12-14 A | 2012-09-12 | 5% | 186.2d? | 2011-12-14 | 2012-09-12 | 196d? | 325d | finish no earlier than 2012-09-12 | S1 | 1568h | 78.4h | FS_RSE | PCG-28 | NEC | joerg.swetina@nw.neclab.eu | Rel-12 | SP-54 |  |  |  |

Notes:
- 27: SP#55 moved to Rel-12. Linked to Rel-10 Feature UID_500006 PEST
- 28: SP#53 completed / Text3: 22.278
- 29: SP#55 moved to Rel-12 / Text3: new TR 23.862
- 30: SP#55 moved to Rel-12 / Text3: TBD
- 31: SP#55 moved to Rel-12. Linked to Rel-10 IFOM IP Flow Mobility and seamless WLAN offload (non-seamless WLAN offload aspects) & Rel-11 LIMONET UID_500028 (support traffic offload at local network) / Text3: Stage 2
- 32: SP#55 moved to Rel-12 / Text3: New TR 23.853
- 33: SP#55 moved to Rel-12 / Text3: 23.060, 23.401, 23.402
- 34: SP#55 moved to Rel-12. Linked to Rel-7 SMSIP (Support of SMS over generic 3GPP IP access) UID_32081 & Rel-11 SIMTC (System Improvements to Machine-Type Communications) UID_480030 / Text3: Stage 2
- 35: SP#55 moved to Rel-12. SP#54 TR 23.863v100 for Information / Text3: new TR 23.863
- 36: SP#55 moved to Rel-12 / Text3: 23.204
- 37: SA3 review of PWS security requirements in 22.268 (as per LS S1-102385) and current ETWS security solution (C1 23.041, S2 23.401, R2 36.331) concluded need for further joint S1,S2,S3,C1,R2 work adding HeNB Security extensions to EHNBF UID_450053
- 38: Completed in Rel-9 under PWS. Add HeNB Security extensions to Extended H(e)NB Features (EHNBF) UID_450053 / Text3: 22.268
- 39: SP#53 work stopped as already done in previous releases / Text3: 23.401
- 40: SP#55 moved to Rel-12 (completion 06/12=>12/12). SA3#66 decided: timeline be reconsidered. ST-Ericsson (Rapporteur) estimated work be finalized end of Rel-12. Agreed to finalize such TS by end Dec 2012. / Text3: 33.102, 33.401, 43.020, FFS a New TS 33.xxx PWS security architecture)
- 41: CP#55 moved to Rel-12 in line with SA3 (completion 03/12=>12/12). At CT#56 Jun 2012 CT1 will bring a new WID, Mikael Wass (Ericsson) Rapporteur. / Text3: 23.041 Technical realization of Cell Broadcast Service (CBS)
- 42: RP#53 work stopped as no WI in RAN / Text3: 36.331 E-UTRA Radio Resource Control (RRC) Protocol specification
- 43: -
- 44: SP#55 completed. Determine an alternative to E.164 for identifying individual devices and route messages between those devices / Text3: 22.988
- 45: SP#55 completion 06/12=>12/12. Study Network improvements for MTC Device to MTC Device communications via one or more PLMNs (direct-mode communication between devices is out of scope), etc. Align also with ETSI TC M2M work. / Text3: 22.888
- 46: SP#55 completed. Linked to SA3 Study on Single Sign On (SSO) Application Security for IMS - based on SIP Digest (UID_480048), SA3 TR 33.924 Extended Identity Management (GBA-IdM) and SA3 TR 33.980 (LibSec) / Text3: 22.895
- 47: SP#54 completed. Linked to SA1 Rel-11 Feature UID_490030 SIPTO Service Continuity of IP Data Session (SIPTO_SC) / Text3: 22.896
- 48: SP#54 completed. Linked to UID_490036 SA2 Rel-11 TR 23.843 Study on Core Network Overload solutions (FS_CNO) / Text3: 22.801
- 49: - / Text3: 22.803
- 50: Linked to SAPP (Service Awareness and Privacy Policies) UID_500032, FS_UMONC (Study on Usage Monitoring Control Enhancement) UID_520035, QoS_SSL (QoS Control Based on Subscriber Spending Limits) UID_490031 / Text3: 22.805
- 51: SP#55 completion 06/12=>09/12. Extend Rel-6 Network Sharing UID_31018 (basic scenarios of network/RAN sharing) to cover more complex scenarios that arise due to recent needs for more dynamic co-operation among operators. / Text3: 22.852

| ID | WBS | Task | Duration | Start | Finish | Complete | Remaining | Baseline start | Baseline finish | Baseline duration | Total slack | Constraint | Resources | Work | Actual work | Text1 | Text2 | Text3 | Text4 | Text6 | Text7 | Text8 | Text9 | Text12 |
| --- | --- | --- | --- | --- | --- | --- | --- | --- | --- | --- | --- | --- | --- | --- | --- | --- | --- | --- | --- | --- | --- | --- | --- | --- |
| 52 | 26 | **Study on Multi Access PDN connectivity and IP flow Mobility** | 1134.96d? | 2008-08-08 A | 2012-12-07 | 76% | 267.08d? | 2008-08-08 | 2012-12-07 | 1134.96d? | 263d |  | S2,S1 | 11728h | 8964.41h | FS_MAPIM | PCG-21 | 23.861 | Qualcomm, ZTE | Rel-12 | SP-41 | Maurice |  |  |
| 53 | 26.1 | SA1 part of FS_MAPIM | 22d? | 2008-08-08 A | 2011-09-21 A | 100% |  | 2008-08-08 | 2011-09-21 | 22d? |  | finish no earlier than 2011-09-21 | S1 | 160h | 160h | FS_MAPIM | PCG-21 | 23.861 | Qualcomm, ZTE | Rel-12 | SP-41 | Maurice |  |  |
| 54 | 26.2 | SA2 part of FS_MAPIM | 1106d? | 2008-09-18 A | 2012-12-07 | 76% | 265.44d? | 2008-09-18 | 2012-12-07 | 1106d? | 263d | finish no earlier than 2012-12-07 | S2 | 8848h | 6724.48h | FS_MAPIM | PCG-21 | 23.861 | Qualcomm, ZTE | Rel-12 | SP-41 | Maurice |  |  |
| 55 | 27 | **Study on IMS based Peer-to-Peer Content Distribution Services (Stage 2)** | 458d? | 2010-09-23 A | 2012-06-20 | 80% | 91.22d? | 2010-09-23 | 2012-06-20 | 458d? | 385d |  | S2,S1 | 8512h | 6813.41h | FS_IMS_P2P_CDS | PCG-25 | 23.844 | China Mobile | Rel-12 | SP-49 | Maurice |  |  |
| 56 | 27.1 | SA1 part of FS_IMS_P2P_CDS | 262d? | 2010-09-23 A | 2011-09-21 A | 100% |  | 2010-09-23 | 2011-09-21 | 262d? |  | finish no earlier than 2011-09-21 | S1 | 2080h | 2080h | FS_IMS_P2P_CDS | PCG-25 | 23.844 | China Mobile | Rel-12 | SP-49 | Maurice |  |  |
| 57 | 27.2 | SA2 part of FS_IMS_P2P_CDS | 346d? | 2010-09-23 A | 2012-06-20 | 65% | 121.1d? | 2010-09-23 | 2012-06-20 | 346d? | 385d | finish no earlier than 2012-06-20 | S2 | 2768h | 1799.2h | FS_IMS_P2P_CDS | PCG-25 | 23.844 | China Mobile | Rel-12 | SP-49 | Maurice |  |  |
| 58 | 28 | Study on Core Network Overload solutions | 580d? | 2010-09-23 A | 2012-12-07 | 60% | 232d? | 2010-09-23 | 2012-12-07 | 580d? | 263d | finish no earlier than 2012-12-07 | S2 | 4640h | 2784h | FS_CNO | PCG-25 | 23.843 | Huawei | Rel-12 | SP-49 | Maurice |  |  |
| 59 | 29 | Study on System Enhancements for Energy Efficiency | 520d? | 2010-12-16 A | 2012-12-07 | 15% | 442d? | 2010-12-16 | 2012-12-07 | 520d? | 263d | finish no earlier than 2012-12-07 | S2 | 4160h | 624h | FS_SEEE | PCG-26 | 23.866 | Huawei | Rel-12 | SP-50 | Maurice |  |  |
| 60 | 30 | Study on S2a Mobility based On GTP and WLAN access to EPC | 329d? | 2011-03-23 A | 2012-06-20 | 80% | 65.8d? | 2011-03-23 | 2012-06-20 | 329d? | 385d | finish no earlier than 2011-12-06 | S2 | 2605.93h | 2079.53h | FS_SaMOG | PCG-26 | 23.852 | ZTE | Rel-12 | SP-51 | Maurice |  |  |
| 61 | 31 | **Study on Usage Monitoring Control enhancement** | 396d? | 2011-06-08 A | 2012-12-07 | 26% | 294.92d? | 2011-06-08 | 2012-12-07 | 396d? | 263d |  | S2,S1,S5 | 8594.08h | 3038.27h | FS_UMONC | PCG-27 |  | ZTE, Huawei | Rel-12 | SP-52 | Maurice |  |  |
| 62 | 31.1 | SA1 part of FS_UMONC | 395d? | 2011-06-08 A | 2012-12-07 | 59% | 162.1d? | 2011-06-08 | 2012-12-07 | 395d? | 263d | finish no earlier than 2012-12-07 | S1 | 2168h | 1847.2h | FS_UMONC | PCG-27 | 23.858 | ZTE | Rel-12 | SP-52 | Maurice |  |  |
| 63 | 31.2 | SA2 part of FS_UMONC | 396d? | 2011-06-08 A | 2012-12-07 | 1% | 392.04d? | 2011-06-08 | 2012-12-07 | 396d? | 263d | finish no earlier than 2012-12-07 | S2,S1 | 2170.08h |  | FS_UMONC | PCG-27 | 23.858 | ZTE | Rel-12 | SP-52 | Maurice |  |  |
| 64 | 31.3 | SA5 part of FS_UMONC | 332d? | 2011-06-08 A | 2012-12-07 | 15% | 282.2d? | 2011-06-08 | 2012-12-07 | 332d? | 263d | finish no earlier than 2012-12-07 | S5 | 1088h | 382.4h | FS_UMONC | PCG-27 | 32.858 | Huawei | Rel-12 | SP-52 | Dionisio |  |  |
| 65 | 32 | Study on Security aspects of Integration of Single Sign-On (SSO) frameworks with 3GPP networks | 521d? | 2010-12-16 A | 2012-12-12 | 25% | 390.75d? | 2010-12-16 | 2012-12-12 | 521d? | 260d | finish no earlier than 2012-12-12 | S3 | 4168h | 1042h | FS_SSO_Int_Sec | PCG-26 | 33.8xy | Ericsson | Rel-12 | SP-50 | Dionisio |  |  |
| 66 | 33 | Study on IMS Firewall Traversal | 391d? | 2011-06-17 A | 2012-12-12 | 25% | 293.25d? | 2011-06-17 | 2012-12-12 | 391d? | 260d | finish no earlier than 2012-12-12 | S3 | 2648h | 774h | FS_iFire | PCG-27 | 33.8xy | Acme Packet | Rel-12 | SP-53 |  |  |  |
| 67 | 34 | Study on Security on spoofed call detection and prevention (Stage 2) | 333d? | 2012-03-07 A | 2013-06-14 | 5% | 316.35d? | 2012-03-07 | 2013-06-14 | 333d? | 128d | finish no earlier than 2013-06-14 | S3 | 2664h | 133.2h | FS_SPOOF | PCG-28 | 33.8xy | China Mobile | Rel-12 | SP-55 |  |  |  |
| 68 | 35 | Deleted - Study on UICC/USIM enhancements | 588d? | 2009-12-10 A | 2012-03-07 A | 100% |  | 2009-12-10 | 2012-03-07 | 588d? |  | finish no earlier than 2012-03-07 | S1 | 4704h | 4704h | FS_U2e | PCG-24 | 22.817 | Giesecke & Devrient | Rel-12 | SP-46 | Alain | PCG-28 | SP-55 |
| 69 | 36 | Release 11 Features | 585d? | 2010-03-29 A | 2012-06-20 | 75% | 146.25d? | 2010-03-29 | 2012-06-20 | 585d? | 385d | finish no earlier than 2012-06-20 | SP,CP,GP,RP | 4680h | 3510h |  | PCG-27 |  |  | Rel-11 | SP-53 | All |  |  |
| 70 | 37 | **Inclusion of Media Resource Broker (Stage 2/3)** | 262d? | 2011-09-16 A | 2012-09-14 | 61% | 102.26d? | 2011-09-16 | 2012-09-14 | 262d? | 323d |  | C1,IETF | 7840h | 3649.6h | MRB | PCG-27 | Stage 2/3 | AT&T | Rel-11 | CP-53 |  |  |  |
| 71 | 37.1 | Stage 2 for Inclusion of Media Resource Broker | 262d? | 2011-09-16 A | 2012-09-14 | 80% | 52.4d? | 2011-09-16 | 2012-09-14 | 262d? | 323d | finish no earlier than 2012-09-14 | C1 | 2088h | 1668.8h | MRB | PCG-27 | 23.218 | AT&T | Rel-11 | CP-53 |  |  |  |
| 72 | 37.2 | Stage 3 for Inclusion of Media Resource Broker | 262d? | 2011-09-16 A | 2012-09-14 | 50% | 131d? | 2011-09-16 | 2012-09-14 | 262d? | 323d | finish no earlier than 2012-09-14 | C1 | 2088h | 1040h | MRB | PCG-27 | 24.229 | AT&T | Rel-11 | CP-53 |  |  |  |
| 73 | 37.3 | (IETF) Inclusion of Media Resource Broker (Stage 3) | 197d? | 2011-09-16 A | 2012-06-15 | 50% | 98d? | 2011-09-16 | 2012-06-15 | 197d? | 388d | finish no earlier than 2012-06-15 | C1-IETF | 1568h | 784h | MRB_IETF | PCG-27 | draft-ietf-mediactrl-mrb | Keith Drage | Rel-11 | CP-53 |  |  |  |
| 74 | 38 | **Single Radio Voice Call Continuity (SRVCC) aspect of enhancements for Multimedia Priority Service** | 398d? | 2010-06-10 A | 2011-12-14 A | 100% |  | 2010-06-10 | 2011-12-14 | 398d? |  |  | S2 | 8432h | 8432h | eMPS_SRVCC | PCG-25 | Stage 2 | NTT DoCoMo | Rel-11 | SP-48 | Maurice |  |  |
| 75 | 38.1 | TR on SRVCC for eMPS | 260d? | 2010-06-10 A | 2011-06-08 A | 100% |  | 2010-06-10 | 2011-06-08 | 260d? |  | finish no earlier than 2011-06-08 | S2 | 2080h | 2080h | eMPS_SRVCC | PCG-25 | new TR 23.854 | NTT DoCoMo | Rel-11 | SP-48 | Maurice |  |  |
| 76 | 38.2 | Stage 2 on SRVCC for eMPS | 398d? | 2010-06-10 A | 2011-12-14 A | 100% |  | 2010-06-10 | 2011-12-14 | 398d? |  | finish no earlier than 2011-12-14 | S2 | 3168h | 3168h | eMPS_SRVCC | PCG-25 | 23.216, 23.237 | NTT DoCoMo | Rel-11 | SP-48 | Maurice |  |  |

Notes:
- 52: SP#54 moved to Rel-12. SP#43 TR 23.861v100 for Information. Spin-off UID_430035 MAPCON and UID_450041 IFOM / Text5: Gerardo Giaretta (gerardog@qualcomm.com), Tricci So (tso@zteusa.com)
- 53: SP#53 completed / Text5: Gerardo Giaretta (gerardog@qualcomm.com), Tricci So (tso@zteusa.com)
- 54: SP#54 moved to Rel-12 / Text5: Gerardo Giaretta (gerardog@qualcomm.com), Tricci So (tso@zteusa.com)
- 55: SP#55 moved to Rel-12. Triggered by TR 22.906 SA1 Study on IMS based Peer-to-Peer Content Distribution Services UID_450047 / Text5: Yu Qing (yuqing@chinamobile.com)
- 56: SP#53 completed / Text5: Yu Qing (yuqing@chinamobile.com)
- 57: SP#55 moved to Rel-12 / Text5: Yu Qing (yuqing@chinamobile.com)
- 58: SP#55 moved to Rel-12. Linked to CT4 TR 23.857 Study on EPC Nodes Restoration (UID_490014). Support from CT4 and RAN WGs is anticipated. / Text5: john.kaippallimalil@huawei.com
- 59: SP#55 moved to Rel-12 / Text5: frank.mademann@huawei.com
- 60: SP#55 moved to Rel-12 (completed for no UE Impact aspects). Study covers generic non-3GPP access (e.g. WLAN, WIMAX, CDMA/HRPD). Spin-off Feature SaMOG_WLAN. Linked to Rel-8 Support for non-3GPP accesses, Rel-10 SMOG, Rel-11 BBAI / Text5: Chunhui Zhu (zhu.chunhui@zte.com.cn)
- 61: SP#54 moved to Rel-12
- 62: SP#54 moved to Rel-12 / Text5: SA2 Zaifeng Zong (zong.zaifeng@zte.com.cn), SA1 Mian Li (Li.Mian@zte.com.cn)
- 63: SP#54 moved to Rel-12 / Text5: SA2 Zaifeng Zong (zong.zaifeng@zte.com.cn), SA1 Mian Li (Li.Mian@zte.com.cn)
- 64: SP#54 moved to Rel-12 / Text5: Hui Cai (Sarah.Cai@huawei.com)
- 65: SP#54 moved to Rel-12 (completion 03/12=>12/12) / Text5: vesa.lehtovirta@ericsson.com
- 66: SP#54 moved to Rel-12 (completion 03/12=>12/12) / Text5: Prashant Kumar (PKumar@acmepacket.com)
- 67: Linked to Rel-11 SPUCI TR 33.838 / Text5: lixiangjun@chinamobile.com
- 68: SP#55 work stopped. Triggered by GSMA Smart SIM and 3GNBK projects, and to evolve from traditional USAT to multimedia USIM toolkit support, particularly to Smart Card Web Server / Text5: ilario.macchi@gi-de.com
- 69: -
- 70: Stage 2/3. Stage 1 and TR on Stage 2 specified under Rel-11 Feature OSCAR (Optimized Service Charging and Allocation of Resources in IMS whilst Roaming) UID_490032 / Text5: Martin Dolly (md3135@att.com)
- 71: - / Text5: Martin Dolly (md3135@att.com)
- 72: - / Text5: Martin Dolly (md3135@att.com)
- 73: Publication requested
- 74: SP#54 completed. Analyze and if needed specify mechanisms for the priority handling of SRVCC with regard to LTE/EPC / Text5: Atsushi Minokuchi (minokuchi@nttdocomo.co.jp)
- 75: SP#52 completed / Text5: Atsushi Minokuchi (minokuchi@nttdocomo.co.jp)
- 76: SP#54 completed / Text5: Atsushi Minokuchi (minokuchi@nttdocomo.co.jp)

| ID | WBS | Task | Duration | Start | Finish | Complete | Remaining | Baseline start | Baseline finish | Baseline duration | Total slack | Constraint | Resources | Work | Actual work | Text1 | Text2 | Text4 | Text5 | Text6 | Text7 | Text8 |
| --- | --- | --- | --- | --- | --- | --- | --- | --- | --- | --- | --- | --- | --- | --- | --- | --- | --- | --- | --- | --- | --- | --- |
| 77 | 39 | **Single Radio Video Call Continuity for 3G-CS** | 439d? | 2010-10-15 A | 2012-06-15 | 99% | 4.86d? | 2010-10-15 | 2012-06-15 | 439d? | 388d |  | S2,C1,C3,C4 | 11596.4h | 7985.41h | vSRVCC | PCG-26 | Samsung | Haris Zisimopoulos (haris.z@samsung.com) | Rel-11 | SP-50 | Maurice |
| 78 | 39.1 | Stage 2 for Single Radio Video Call Continuity for 3G-CS | 199.85d? | 2010-10-15 A | 2011-09-21 A | 100% |  | 2010-10-15 | 2011-09-21 | 199.85d? |  | finish no earlier than 2011-12-07 | S2 | 1580.41h | 1580.41h | vSRVCC | PCG-26 | Samsung | Haris Zisimopoulos (haris.z@samsung.com) | Rel-11 | SP-50 | Maurice |
| 79 | 39.2 | **CN aspects of Single Radio Video Call Continuity for 3G-CS** | 274d? | 2011-06-03 A | 2012-06-15 | 98% | 4.15d? | 2011-06-03 | 2012-06-15 | 274d? | 388d |  | C1,C3,C4 | 6504h | 6405h | vSRVCC-CT | PCG-27 | NEC | gottfried.punz@neclab.eu | Rel-11 | CP-52 | Frederic |
| 80 | 39.2.1 | CT1 aspects of Single Radio Video Call Continuity for 3G-CS | 274d? | 2011-06-03 A | 2012-06-15 | 97% | 8.22d? | 2011-06-03 | 2012-06-15 | 274d? | 388d | finish no earlier than 2012-06-15 | C1 | 2184h | 2118.24h | vSRVCC-CT | PCG-27 | NEC | gottfried.punz@neclab.eu | Rel-11 | CP-52 | Frederic |
| 81 | 39.2.2 | CT3 aspects of Single Radio Video Call Continuity for 3G-CS | 134d? | 2011-06-03 A | 2011-12-02 A | 100% |  | 2011-06-03 | 2011-12-02 | 134d? |  | finish no earlier than 2011-12-02 | C3 | 1064h | 1064h | vSRVCC-CT | PCG-27 | NEC | gottfried.punz@neclab.eu | Rel-11 | CP-52 | Jiwan |
| 82 | 39.2.3 | CT4 aspects of Single Radio Video Call Continuity for 3G-CS | 134d? | 2011-06-03 A | 2011-12-02 A | 100% |  | 2011-06-03 | 2011-12-02 | 134d? |  | finish no earlier than 2011-12-02 | C4 | 1064h | 1064h | vSRVCC-CT | PCG-27 | NEC | gottfried.punz@neclab.eu | Rel-11 | CP-52 | Kimmo |
| 83 | 40 | **VPLMN Autonomous CSG Roaming** | 499d? | 2010-10-15 A | 2012-09-07 | 65% | 172.26d? | 2010-10-15 | 2012-09-07 | 499d? | 328d |  | S2,C4 | 7638.61h | 2379.41h | VCSG | PCG-26 | Qualcomm | AC Mahendran (ac@qualcomm.com) | Rel-11 | SP-50 | Maurice |
| 84 | 40.1 | Stage 2 for VPLMN Autonomous CSG Roaming | 260.85d? | 2010-10-15 A | 2011-12-14 A | 100% |  | 2010-10-15 | 2011-12-14 | 260.85d? |  | finish no earlier than 2011-12-07 | S2 | 2062.61h | 2062.61h | VCSG | PCG-26 | Qualcomm | AC Mahendran (ac@qualcomm.com) | Rel-11 | SP-50 | Maurice |
| 85 | 40.2 | CT aspects of VPLMN Autonomous CSG Roaming | 198d? | 2011-12-07 A | 2012-09-07 | 20% | 158.4d? | 2011-12-07 | 2012-09-07 | 198d? | 328d | finish no earlier than 2012-09-07 | C4 | 1584h | 316.8h | VCSG-St3 | PCG-27 | ZTE | Fei Lu (lu.fei1@zte.com.cn) | Rel-11 | CP-53 |  |
| 86 | 41 | **Data Identification in Access Network Discovery and Selection Function (ANDSF)** | 391d? | 2011-03-23 A | 2012-09-14 | 76% | 93.25d? | 2011-03-23 | 2012-09-14 | 391d? | 323d |  | S2,C1 | 6704h | 3576h | DIDA | PCG-26 | Qualcomm | Gerardo Giaretta (gerardo@qualcomm.com) | Rel-11 | SP-51 | Maurice |
| 87 | 41.1 | TR on Stage 2 for Data Identification in ANDSF | 193d? | 2011-03-23 A | 2011-12-14 A | 100% |  | 2011-03-23 | 2011-12-14 | 193d? |  | finish no earlier than 2011-12-07 | S2 | 1544h | 1544h | DIDA | PCG-26 | Qualcomm | Gerardo Giaretta (gerardo@qualcomm.com) | Rel-11 | SP-51 | Maurice |
| 88 | 41.2 | Stage 2 for Data Identification in ANDSF | 253d? | 2011-03-24 A | 2012-03-07 A | 100% |  | 2011-03-24 | 2012-03-07 | 253d? |  | finish no earlier than 2012-03-07 | S2 | 2024h | 2024h | DIDA | PCG-26 | Qualcomm | Gerardo Giaretta (gerardo@qualcomm.com) | Rel-11 | SP-51 | Maurice |
| 89 | 41.3 | CT aspects of Data Identification in Access Network Discovery and Selection Function (ANDSF) Stage 3 | 141d? | 2012-03-02 A | 2012-09-14 | 1% | 140d? | 2012-03-02 | 2012-09-14 | 141d? | 323d | finish no earlier than 2012-09-07 | C1 | 8h | 8h | DIDA-CT | PCG-28 | Qualcomm | Patrick Stupar (pstupar@qualcomm.com) | Rel-11 | CP-55 |  |
| 90 | 42 | **LOcation-Based Selection of gaTEways foR WLAN** | 326d? | 2011-03-23 A | 2012-06-15 | 54% | 149.68d? | 2011-03-23 | 2012-06-15 | 326d? | 388d |  | S2,C4,C1 | 7538.52h | 3718.48h | LOBSTER | PCG-26 | ZTE | zhu.chunhui@zte.com.cn | Rel-11 | SP-51 | Maurice |
| 91 | 42.1 | Stage 2 for LOcation-Based Selection of gaTEways foR WLAN | 194d? | 2011-03-23 A | 2011-12-14 A | 100% |  | 2011-03-23 | 2011-12-14 | 194d? |  | finish no earlier than 2011-12-07 | S2 | 1546.52h | 1546.52h | LOBSTER | PCG-26 | ZTE | zhu.chunhui@zte.com.cn | Rel-11 | SP-51 | Maurice |
| 92 | 42.2 | **CT aspects of LOcation-Based Selection of gaTEways foR WLAN** | 141d? | 2011-12-02 A | 2012-06-15 | 23% | 109.28d? | 2011-12-02 | 2012-06-15 | 141d? | 388d |  | C4,C1 | 3384h | 761.4h | LOBSTER-CT | PCG-28 | ZTE | zhou.xingyue@zte.com.cn | Rel-11 | CP-54 |  |
| 93 | 42.2.1 | CT4 part of CT aspects of LOcation-Based Selection of gaTEways foR WLAN | 141d? | 2011-12-02 A | 2012-06-15 | 45% | 77.55d? | 2011-12-02 | 2012-06-15 | 141d? | 388d | finish no earlier than 2012-06-15 | C4 | 1128h | 507.6h | LOBSTER-CT | PCG-28 | ZTE | zhou.xingyue@zte.com.cn | Rel-11 | CP-54 |  |
| 94 | 42.2.2 | CT1 part of CT aspects of LOcation-Based Selection of gaTEways foR WLAN | 141d? | 2011-12-02 | 2012-06-15 |  |  | 2011-12-02 | 2012-06-15 | 141d? | 388d | finish no earlier than 2012-06-15 | C1 | 1128h |  | LOBSTER-CT | PCG-28 | ZTE | zhou.xingyue@zte.com.cn | Rel-11 | CP-54 |  |
| 95 | 43 | **Single Radio Voice Call Continuity from UTRAN/GERAN to E-UTRAN/HSPA** | 261d? | 2011-09-12 A | 2012-09-07 | 21% | 205.55d? | 2011-09-12 | 2012-09-07 | 261d? | 328d |  | S2,C1,C3,C4,G2,R2,R3 | 17368h | 3529.2h | rSRVCC | PCG-27 | Orange | antoine.mouquet@orange-ftgroup.com | Rel-11 | SP-53 |  |
| 96 | 43.1 | Stage 2 for Single Radio Voice Call Continuity from UTRAN/GERAN to E-UTRAN/HSPA | 121d? | 2011-09-22 A | 2012-03-07 | 98% | 2.42d? | 2011-09-22 | 2012-03-07 | 121d? | 460d | finish no earlier than 2012-03-07 | S2 | 968h | 948.64h | rSRVCC | PCG-27 | Orange | antoine.mouquet@orange-ftgroup.com | Rel-11 | SP-53 |  |
| 97 | 43.2 | **CT aspects for Single Radio Voice Call Continuity from UTRAN/GERAN to E-UTRAN/HSPA (Stage 3)** | 257d? | 2011-09-16 A | 2012-09-07 | 5% | 244.13d? | 2011-09-16 | 2012-09-07 | 257d? | 328d |  | C1,C3,C4 | 8200h | 402.93h | rSRVCC-CT | PCG-27 | Ericsson | ivo.sedlacek@ericsson.com | Rel-11 | CP-53 |  |
| 98 | 43.2.1 | CT1 part for Single Radio Voice Call Continuity from UTRAN/GERAN to E-UTRAN/HSPA | 257d? | 2011-09-16 A | 2012-09-07 | 10% | 231.3d? | 2011-09-16 | 2012-09-07 | 257d? | 328d | finish no earlier than 2012-09-07 | C1 | 2048h | 197.6h | rSRVCC-CT | PCG-27 | Ericsson | ivo.sedlacek@ericsson.com | Rel-11 | CP-53 |  |
| 99 | 43.2.2 | CT3 part for Single Radio Voice Call Continuity from UTRAN/GERAN to E-UTRAN/HSPA | 256d? | 2011-09-19 | 2012-09-07 |  |  | 2011-09-19 | 2012-09-07 | 256d? | 328d | finish no earlier than 2012-09-07 | C3 | 2048h |  | rSRVCC-CT | PCG-27 | Ericsson | ivo.sedlacek@ericsson.com | Rel-11 | CP-53 |  |
| 100 | 43.2.3 | CT4 part for Single Radio Voice Call Continuity from UTRAN/GERAN to E-UTRAN/HSPA | 256d? | 2011-09-19 A | 2012-09-07 | 5% | 243.2d? | 2011-09-19 | 2012-09-07 | 256d? | 328d | finish no earlier than 2012-09-07 | C4 | 2048h | 102.4h | rSRVCC-CT | PCG-27 | Ericsson | ivo.sedlacek@ericsson.com | Rel-11 | CP-53 |  |
| 101 | 43.3 | GERAN aspects of Single Radio Voice Call Continuity from UTRAN/GERAN to E-UTRAN/HSPA | 256d? | 2011-09-12 A | 2012-08-31 | 25% | 192d? | 2011-09-12 | 2012-08-31 | 256d? | 333d | finish no earlier than 2012-08-31 | G2 | 2048h | 512h | rSRVCC-GERAN | PCG-27 | ZTE | li.jing4@zte.com.cn | Rel-11 | GP-51 |  |

Notes:
- 77: Complete Stage 2 to support Single Radio VIDEO Call Continuity from E-UTRAN to UTRAN-CS based on the agreed architecture alternative in TR 23.886
- 78: SP#53 completed. Triggered by Feasibility Study on video call handover capability in TR 23.886 UID_470048 Study on Single Radio Video Call Continuity for 3G-CS (FS_vSRVCC) / Text3: 23.203, 23.216, 23.237
- 79: Stage 3. CP#54 updated WID CP-110438=>CP-110757
- 80: CP#55 completion 03/12=>06/12 / Text3: 24.008, 24.237, 24.301
- 81: CP#54 completed / Text3: 29.211, 29.212, 29.213, 29.215
- 82: CP#54 completed / Text3: 29.280
- 83: SP#54 Stage 2 completed. Linked to Rel-10 UID_450053 Enhanced Home NodeB / eNodeB (EHNB). Implements Rel-9 requirements for CSG support in SA1 TS 22.220
- 84: SP#54 completed / Text3: 23.002, 23.060, 23.401
- 85: CP#55 updated WID CP-110588=>CP-120196 (completion 03/12=>09/12) / Text3: 23.003, 23.007, 23.008, 23.012, 29.002, 29.230, 29.272
- 86: SP#55 completed. Linked to Rel-10 IFOM (IP Flow Mobility and seamless WLAN offload) UID_450041. Defines IP flow mobility, seamless and non seamless WLAN offload and respective ANDSF extensions / Text3: Stage 2
- 87: SP#54 completed (1-step approval) / Text3: New TR 23.855
- 88: SP#55 completed / Text3: 23.402
- 89: Stage 3 / Text3: 24.302, 24.312
- 90: SP#53 Stage 2 completed. Related to UID_350027 SAE for support for non-3GPP accesses (SAES-SA-FP_n3GPP). Enhancements to ePDG and PDN GW selection functions for S2b and S2c based on UE location
- 91: SP#54 completed. Updated WID SP-110083=>SP-110752 (reduced scope) / Text3: 23.402
- 92: - / Text3: Stage 3
- 93: - / Text3: 29.273
- 94: - / Text3: 24.302
- 95: Stage 1 in Rel-8 TS 22.278 clause 7.1.4.2. Triggered by Rel-11 TR 23.885 Study on Single Radio Voice Call Continuity from UTRAN/GERAN to E-UTRAN/HSPA (FS_rSRVCC) UID_460030 / Text3: UTRA
- 96: SP#55 emergency call not supported... / Text3: 23.216, 23.237
- 97: Stage 3 / Text3: Stage 3
- 98: - / Text3: 23.009, 24.008, 24.229, 24.237, 24.292, 24.301
- 99: CP#54 Work can only begin when CT1 has decided the technical solution / Text3: 29.165, 29.292
- 100: - / Text3: 23.003, 23.008, 29.002, 29.230, 29.272, 29.280, 29.303, 29.305, 29.328
- 101: Stage 3 / Text3: 44.018, 48.008

| ID | WBS | Task | Duration | Start | Finish | Complete | Remaining | Baseline start | Baseline finish | Baseline duration | Total slack | Constraint | Resources | Work | Actual work | Text1 | Text2 | Text3 | Text4 | Text6 | Text7 | Text11 | Text8 |
| --- | --- | --- | --- | --- | --- | --- | --- | --- | --- | --- | --- | --- | --- | --- | --- | --- | --- | --- | --- | --- | --- | --- | --- |
| 102 | 43.4 | **UTRAN aspects of Single Radio Voice Call Continuity from UTRAN/GERAN to E-UTRAN/HSPA** | 256d? | 2011-09-19 A | 2012-09-07 | 30% | 179.2d? | 2011-09-19 | 2012-09-07 | 256d? | 328d |  | R3,R2 | 4096h | 1228.8h | rSRVCC-RAN_UTRA | PCG-27 | UTRA | Huawei | Rel-11 | RP-53 |  |  |
| 103 | 43.4.1 | Core part: UTRAN aspects of Single Radio Voice Call Continuity from UTRAN/GERAN to E-UTRAN/HSPA | 256d? | 2011-09-19 A | 2012-09-07 | 30% | 179.2d? | 2011-09-19 | 2012-09-07 | 256d? | 328d | finish no earlier than 2012-09-07 | R3,R2 | 2048h | 614.4h | rSRVCC-RAN_UTRA-Core | PCG-27 | 25.331, 25.401, 25.413 | Huawei | Rel-11 | RP-53 | RP-120070 |  |
| 104 | 44 | **S2a Mobility based On GTP and WLAN access to EPC** | 193d? | 2011-09-22 A | 2012-06-15 | 40% | 115.05d? | 2011-09-22 | 2012-06-15 | 193d? | 388d |  | S2,C4,C1,C3 | 7024h | 2644.36h | SaMOG_WLAN | PCG-27 | Stage 2/3 | ZTE | Rel-11 | SP-53 |  |  |
| 105 | 44.1 | Stage 2 for S2a Mobility based On GTP and WLAN access to EPC | 121d? | 2011-09-22 A | 2012-03-07 A | 100% |  | 2011-09-22 | 2012-03-07 | 121d? |  | finish no earlier than 2012-03-07 | S2 | 968h | 968h | SaMOG_WLAN | PCG-27 | 23.002, 23.203, 23.402 | ZTE | Rel-11 | SP-53 |  |  |
| 106 | 44.2 | **CN aspects of Mobility based On GTP & PMIPv6 for WLAN access to EPC** | 141d? | 2011-12-02 A | 2012-06-15 | 23% | 108.1d? | 2011-12-02 | 2012-06-15 | 141d? | 388d |  | C4,C1,C3 | 4512h | 1052.8h | SaMOG_WLAN-CN | PCG-28 | Stage 3 | Alcatel-Lucent | Rel-11 | CP-54 |  |  |
| 107 | 44.2.1 | CT4 part of CN aspects of Mobility based On GTP & PMIPv6 for WLAN access to EPC | 141d? | 2011-12-02 A | 2012-06-15 | 70% | 42.3d? | 2011-12-02 | 2012-06-15 | 141d? | 388d | finish no earlier than 2012-06-15 | C4 | 1128h | 789.6h | SaMOG_WLAN-CN | PCG-28 | 23.003, 23.007, 23.008, 29.273, 29.274, 29.281, 29.303 | Alcatel-Lucent | Rel-11 | CP-54 |  |  |
| 108 | 44.2.2 | CT1 part of CN aspects of Mobility based On GTP & PMIPv6 for WLAN access to EPC | 141d? | 2011-12-02 | 2012-06-15 |  |  | 2011-12-02 | 2012-06-15 | 141d? | 388d | finish no earlier than 2012-06-15 | C1 | 1128h |  | SaMOG_WLAN-CN | PCG-28 | 24.302 | Alcatel-Lucent | Rel-11 | CP-54 |  |  |
| 109 | 44.2.3 | CT3 part of CN aspects of Mobility based On GTP & PMIPv6 for WLAN access to EPC | 141d? | 2011-12-02 | 2012-06-15 |  |  | 2011-12-02 | 2012-06-15 | 141d? | 388d | finish no earlier than 2012-06-15 | C3 | 1128h |  | SaMOG_WLAN-CN | PCG-28 | 29.212, 29.213, 29.215 | Alcatel-Lucent | Rel-11 | CP-54 |  |  |
| 110 | 45 | **Roaming Architecture for Voice over IMS with Local Breakout** | 207d? | 2011-11-28 A | 2012-09-12 | 8% | 190.25d? | 2011-11-28 | 2012-09-12 | 207d? | 325d |  | S2,S5,C1,C3 | 6584h | 473.03h | RAVEL | PCG-28 | Stage 2/3 | Deutsche Telekom | Rel-11 | SP-54 |  |  |
| 111 | 45.1 | Stage 2 for Roaming Architecture for Voice over IMS with Local Breakout | 12d? | 2011-11-28 A | 2011-12-14 A | 100% |  | 2011-11-28 | 2011-12-14 | 12d? |  | finish no earlier than 2012-03-07 | S2 | 96h | 96h | RAVEL | PCG-28 | 23.002, 23.228 | Deutsche Telekom | Rel-11 | SP-54 |  |  |
| 112 | 45.2 | Charging for Roaming Architecture for Voice over IMS with Local Breakout | 196d? | 2011-12-14 A | 2012-09-12 | 10% | 176.2d? | 2011-12-14 | 2012-09-12 | 196d? | 325d | finish no earlier than 2012-09-12 | S5 | 1568h | 158.4h | RAVEL-CH | PCG-28 | 32.240, 32.260, 32.298, 32.299 | Nokia Siemens Networks | Rel-11 | SP-54 |  |  |
| 113 | 45.3 | **CT aspects of Roaming Architecture for Voice over IMS with Local Breakout (Stage 3)** | 136d? | 2012-03-02 A | 2012-09-07 | 3% | 132.47d? | 2012-03-02 | 2012-09-07 | 136d? | 328d |  | C1,C3 | 3264h | 84.6h | RAVEL-CT | PCG-28 | Stage 3 | Deutsche Telekom | Rel-11 | CP-55 |  |  |
| 114 | 45.3.1 | CT1 part of CT aspects of Roaming Architecture for Voice over IMS with Local Breakout | 136d? | 2012-03-02 | 2012-09-07 |  |  | 2012-03-02 | 2012-09-07 | 136d? | 328d | finish no earlier than 2012-09-07 | C1 | 1088h |  | RAVEL-CT | PCG-28 | 24.229, 24.292, 24.237 | Deutsche Telekom | Rel-11 | CP-55 |  |  |
| 115 | 45.3.2 | CT3 part of CT aspects of Roaming Architecture for Voice over IMS with Local Breakout | 136d? | 2012-03-02 A | 2012-09-07 | 5% | 128.95d? | 2012-03-02 | 2012-09-07 | 136d? | 328d | finish no earlier than 2012-09-07 | C3 | 1088h | 56.4h | RAVEL-CT | PCG-28 | 29.165, 29.162, 29.079 | Deutsche Telekom | Rel-11 | CP-55 |  |  |
| 116 | 46 | **Rel-11 Security small Enhancements** | 858d? | 2009-06-04 A | 2012-09-12 | 74% | 218.87d? | 2009-06-04 | 2012-09-12 | 858d? | 325d |  | S3,C4,C1 | 29536h | 21161.6h | SEC11 | PCG-27 |  |  | Rel-11 | SP-52 |  | Dionisio |
| 117 | 46.1 | EEA3 and EIA3 (new Encryption & Integrity EPS security Algorithms) | 663d? | 2009-06-04 A | 2011-12-14 A | 100% |  | 2009-06-04 | 2011-12-14 | 663d? |  | finish no earlier than 2011-09-21 | S3 | 5288h | 5288h | EEA3_EIA3 | PCG-23 | 33.401, new (35.221, 35.222, 35.223, 35.924) | CATR | Rel-11 | SP-44 |  | Dionisio |
| 118 | 46.2 | Specification of Protection against Unsolicited Communication for IMS (produced TR-only) | 456d? | 2010-06-10 A | 2012-03-07 A | 100% |  | 2010-06-10 | 2012-03-07 | 456d? |  | finish no earlier than 2012-03-07 | S3 | 3640h | 3640h | SPUCI | PCG-25 | new TR 33.838, abandoned new TS 33.237 | NEC | Rel-11 | SP-48 |  | Dionisio |
| 119 | 46.3 | H(e)NB security features for UE mobility scenarios (Stage 2) | 252d? | 2011-03-23 A | 2012-03-07 A | 100% |  | 2011-03-23 | 2012-03-07 | 252d? |  | finish no earlier than 2012-03-07 | S3 | 2008h | 2008h | HNB_mob_Sec | PCG-26 | 33.320 Stage 2 | Huawei | Rel-11 | SP-51 |  | Dionisio |
| 120 | 46.4 | Security enhancements for usage of Generic Bootstrapping Architecture (GBA) from the browser | 271d? | 2011-06-08 A | 2012-06-20 | 50% | 135.5d? | 2011-06-08 | 2012-06-20 | 271d? | 385d | finish no earlier than 2012-06-20 | S3 | 2168h | 1084h | Web_GBA | PCG-27 | 33.220, 33.222, new TR 33.823 | Nokia | Rel-11 | SP-52 |  | Dionisio |
| 121 | 46.5 | **Generic Bootstrapping Architecture (GBA) extensions for re-use of SIP Digest credentials** | 201d? | 2011-12-02 A | 2012-09-07 | 52% | 95.98d? | 2011-12-02 | 2012-09-07 | 201d? | 328d |  | S3,C4,C1 | 6920h | 3498.92h | GBA-ext | PCG-28 |  | Nokia | Rel-11 | SP-54 |  |  |
| 122 | 46.5.1 | Stage 2 for GBA extensions for re-use of SIP Digest credentials | 61d? | 2011-12-14 A | 2012-03-07 A | 100% |  | 2011-12-14 | 2012-03-07 | 61d? |  | finish no earlier than 2012-02-28 | S3 | 488h | 488h | GBA-ext | PCG-28 | 33.220 | Nokia | Rel-11 | SP-54 |  |  |
| 123 | 46.5.2 | **Stage 3 for GBA extensions for re-use of SIP Digest credentials** | 201d? | 2011-12-02 A | 2012-09-07 | 45% | 110.55d? | 2011-12-02 | 2012-09-07 | 201d? | 328d |  | C4,C1 | 4824h | 2170.8h | GBA-ext-St3 | PCG-28 | Stage 3 | Alcatel-Lucent | Rel-11 | CP-54 |  |  |
| 124 | 46.5.2.1 | CT4 part of Stage 3 for GBA extensions for re-use of SIP Digest credentials | 201d? | 2011-12-02 A | 2012-09-07 | 90% | 20.1d? | 2011-12-02 | 2012-09-07 | 201d? | 328d | finish no earlier than 2012-09-07 | C4 | 1608h | 1447.2h | GBA-ext-St3 | PCG-28 | 29.109 | Alcatel-Lucent | Rel-11 | CP-54 |  |  |
| 125 | 46.5.2.2 | CT1 part of Stage 3 for GBA extensions for re-use of SIP Digest credentials | 201d? | 2011-12-02 | 2012-09-07 |  |  | 2011-12-02 | 2012-09-07 | 201d? | 328d | finish no earlier than 2012-09-07 | C1 | 1608h |  | GBA-ext-St3 | PCG-28 | 24.109 | Alcatel-Lucent | Rel-11 | CP-54 |  |  |
| 126 | 46.6 | Lawful Interception in the 3GPP Rel-11 | 331d? | 2011-06-10 A | 2012-09-12 | 20% | 264.8d? | 2011-06-10 | 2012-09-12 | 331d? | 325d | finish no earlier than 2012-09-12 | S3 | 2648h | 529.6h | LI11 | PCG-27 | 33.106, 33.107, 33.108 | PIDS, Alcatel-Lucent | Rel-11 | SP-52 |  | Dionisio |
| 127 | 47 | Extensions of Acoustic Test Specifications in TS 26.131 and TS 26.132 | 331d? | 2011-06-08 A | 2012-09-12 | 30% | 231.7d? | 2011-06-08 | 2012-09-12 | 331d? | 325d | finish no earlier than 2012-09-12 | S4 | 2648h | 794.4h | Ext_ATS | PCG-27 | 26.131, 26.132 | Orange, Qualcomm | Rel-11 | SP-52 |  | Paolo |

Notes:
- 102: - / Text5: liwei.qiu@huawei.com
- 103: - / Text5: liwei.qiu@huawei.com
- 104: Triggered by Rel-11 TR 23.852 FS_SaMOG UID_510061, Rel-8 UID_350027 SAE for support for non-3GPP accesses (defines PMIP-S2a) / Text5: Chunhui Zhu (zhu.chunhui@zte.com.cn)
- 105: SP#55 completed / Text5: zhu.chunhui@zte.com.cn
- 106: Stage 3 / Text5: bruno.landais@alcatel-lucent.com
- 107: - / Text5: bruno.landais@alcatel-lucent.com
- 108: - / Text5: bruno.landais@alcatel-lucent.com
- 109: - / Text5: bruno.landais@alcatel-lucent.com
- 110: SP#54 Stage 2 completed. Triggered by Rel-11 TR 23.850 Study on Roaming Architecture for Voice over IMS with Local Breakout (FS_RAVEL). GSMA CPWP LS_in S5-102806 asked 3GPP SA5 to check if CS voice charging principles also apply to voice over IMS / Text5: michele.zarri@telekom.com
- 111: SP#54 completed / Text5: michele.zarri@telekom.com
- 112: Stage 2/3 / Text5: Gerald.Goermer@nsn.com
- 113: Stage 3 / Text5: reinhard.lauster@)t-mobile.at
- 114: - / Text5: reinhard.lauster@)t-mobile.at
- 115: CP#55 Work can only begin when CT1 has decided the technical solution / Text5: reinhard.lauster@)t-mobile.at
- 116: -
- 117: SP#54 TR 35.924 v200 for Approval. SP#53 completed new EPS algorithms e.g. for China. V100 new 35.221, 35.222, 35.223 for 1-step Approval / Text5: Yuan Qi (yuanqi@catr.cn)
- 118: SP#55 completed (No normative work). TR 33.838v200 for Approval & abandoned new TS 33.237. Continuation of Rel-9 UID_410027/410029. Builds on TR 33.937 Study of Mechanisms for PUCI / Text5: Anand R. Prasad (anand@bq.jp.nec.com)
- 119: SP#55 completed. Add HeNB Security extensions to Extended H(e)NB Features (EHNBF) UID_450053 / Text5: Marcus Wong (mwong@huawei.com)
- 120: Stage 2. SP#55 completion 03/12=>06/12 / Text5: Silke.Holtmanns@nokia.com
- 121: Stage 2/3 / Text5: Silke.Holtmanns@nokia.com
- 122: SP#55 completed / Text5: Silke.Holtmanns@nokia.com
- 123: Stage 3 / Text5: jean-jacques.trottin@alcatel-lucent.com
- 124: - / Text5: jean-jacques.trottin@alcatel-lucent.com
- 125: - / Text5: jean-jacques.trottin@alcatel-lucent.com
- 126: Stage 1/2/3 / Text5: Koen Jaspers (k.b.jaspers@minjus.nl), terry.jacobson@alcatel-lucent.com
- 127: - / Text5: stephane.ragot@orange-ftgroup.com, Andre Schevciw (aschevci@qualcomm.com)

| ID | WBS | Task | Duration | Start | Finish | Complete | Remaining | Baseline start | Baseline finish | Baseline duration | Total slack | Constraint | Resources | Work | Actual work | Text1 | Text2 | Text4 | Text6 | Text7 | Text8 |
| --- | --- | --- | --- | --- | --- | --- | --- | --- | --- | --- | --- | --- | --- | --- | --- | --- | --- | --- | --- | --- | --- |
| 128 | 48 | **Enhancements to Multimedia: PSS, MMS, and MBMS Enhancements and Performance Improvements** | 267d? | 2011-09-07 A | 2012-09-12 | 13% | 231.34d? | 2011-09-07 | 2012-09-12 | 267d? | 325d |  | S4 | 8360h | 1097.65h | EMM | PCG-27 | Qualcomm | Rel-11 | SP-53 |  |
| 129 | 48.1 | Enhancement to FEC for MBMS | 257d? | 2011-09-21 A | 2012-09-12 | 10% | 231.3d? | 2011-09-21 | 2012-09-12 | 257d? | 325d | finish no earlier than 2012-09-12 | S4 | 2048h | 197.6h | EMM-EFEC | PCG-27 | Qualcomm | Rel-11 | SP-53 |  |
| 130 | 48.2 | Download Delivery Enhancements for MBMS | 257d? | 2011-09-21 A | 2012-09-12 | 15% | 218.45d? | 2011-09-21 | 2012-09-12 | 257d? | 325d | start no earlier than 2011-09-21 | S4 | 2048h | 302.4h | EMM-DDE | PCG-27 | Qualcomm | Rel-11 | SP-53 |  |
| 131 | 48.3 | IMS-based PSS and MBMS Streaming Synchronization Enhancements | 267d? | 2011-09-07 A | 2012-09-12 | 15% | 226.95d? | 2011-09-07 | 2012-09-12 | 267d? | 325d | finish no earlier than 2012-09-12 | S4 | 2128h | 312.4h | EMM-IPME | PCG-27 | InterDigital Communications | Rel-11 | SP-53 |  |
| 132 | 49 | **Rel-11 Operations, Administration, Maintenance and Provisioning (OAM&P)** | 454d? | 2011-03-23 A | 2012-12-12 | 46% | 244.17d? | 2011-03-23 | 2012-12-12 | 454d? | 260d |  | S5 | 35682.5h | 16396.2h | OAM11 | PCG-26 |  | Rel-11 | SP-51 | Dionisio |
| 133 | 49.1 | **Rel-11 Network Infrastructure Management** | 389d? | 2011-03-23 A | 2012-09-12 | 26% | 288.96d? | 2011-03-23 | 2012-09-12 | 389d? | 325d |  | S5 | 10296h | 2635.9h | OAM11-NIM | PCG-26 |  | Rel-11 | SP-51 | Dionisio |
| 134 | 49.1.1 | IRP framework enhancements to support Management of Converged Networks | 386d? | 2011-03-23 A | 2012-09-12 | 30% | 270.2d? | 2011-03-23 | 2012-09-12 | 386d? | 325d | finish no earlier than 2012-09-12 | S5 | 3088h | 926.4h | OAM-FMC-IRP | PCG-26 | Nokia Siemens Networks, Ericsson | Rel-11 | SP-51 | Dionisio |
| 135 | 49.1.2 | Management of Carrier Aggregation for LTE | 257d? | 2011-09-21 A | 2012-09-12 | 30% | 179.9d? | 2011-09-21 | 2012-09-12 | 257d? | 325d | finish no earlier than 2012-09-12 | S5 | 2048h | 608.8h | OAM-CA | PCG-27 | Nokia Siemens Networks, Ericsson | Rel-11 | SP-53 |  |
| 136 | 49.1.3 | Network Management for 3GPP Interworking WLAN | 257d? | 2011-09-21 A | 2012-09-12 | 15% | 218.45d? | 2011-09-21 | 2012-09-12 | 257d? | 325d | finish no earlier than 2012-09-12 | S5 | 2048h | 300.4h | OAM-IWLAN | PCG-27 | China Mobile | Rel-11 | SP-53 |  |
| 137 | 49.2 | **Rel-11 Performance Management** | 389d? | 2011-03-23 A | 2012-09-12 | 68% | 125.17d? | 2011-03-23 | 2012-09-12 | 389d? | 325d |  | S5 | 10858.5h | 7357.53h | OAM11-PM | PCG-26 |  | Rel-11 | SP-51 | Dionisio |
| 138 | 49.2.1 | IMS Performance Management enhancements | 252d? | 2011-03-23 A | 2012-03-07 A | 100% |  | 2011-03-23 | 2012-03-07 | 252d? |  | finish no earlier than 2012-09-12 | S5 | 2010.52h | 2010.52h | OAM-ePM-IMS | PCG-26 | ZTE | Rel-11 | SP-51 | Dionisio |
| 139 | 49.2.2 | Enhanced Management of UE based network performance measurements | 387d? | 2011-03-23 A | 2012-09-12 | 45% | 212.85d? | 2011-03-23 | 2012-09-12 | 387d? | 325d | finish no earlier than 2012-09-12 | S5 | 3088h | 1385.2h | OAM-ePM-UE | PCG-26 | Huawei, Ericsson, Nokia Siemens Networks | Rel-11 | SP-51 | Dionisio |
| 140 | 49.2.3 | CN performance measurements enhancement | 332d? | 2011-06-08 A | 2012-09-12 | 70% | 99.6d? | 2011-06-08 | 2012-09-12 | 332d? | 325d | finish no earlier than 2012-09-12 | S5 | 2648h | 1851.2h | OAM-ePM-CN | PCG-27 | China Mobile | Rel-11 | SP-52 | Dionisio |
| 141 | 49.3 | **Rel-11 Self-Organizing Networks (SON) - OAM aspects** | 454d? | 2011-03-23 A | 2012-12-12 | 43% | 256.78d? | 2011-03-23 | 2012-12-12 | 454d? | 260d |  | S5 | 10896h | 4724.12h | OAM11-SON | PCG-26 |  | Rel-11 | SP-51 | Dionisio |
| 142 | 49.3.1 | UTRAN Self-Organizing Networks (SON) management | 387d? | 2011-03-23 A | 2012-09-12 | 75% | 96.75d? | 2011-03-23 | 2012-09-12 | 387d? | 325d | finish no earlier than 2012-09-12 | S5 | 3088h | 2314h | OAM-SON-UTRAN | PCG-26 | Huawei | Rel-11 | SP-51 | Dionisio |
| 143 | 49.3.2 | LTE Self-Organizing Networks (SON) coordination management | 257d? | 2011-09-21 A | 2012-09-12 | 15% | 218.45d? | 2011-09-21 | 2012-09-12 | 257d? | 325d | finish no earlier than 2012-09-12 | S5 | 2048h | 300.4h | OAM-SON-LTE_COORD | PCG-27 | Huawei, Nokia Siemens Networks | Rel-11 | SP-53 |  |
| 144 | 49.3.3 | Inter-RAT Energy Saving Management | 266d? | 2011-12-07 A | 2012-12-12 | 25% | 199.5d? | 2011-12-07 | 2012-12-12 | 266d? | 260d | finish no earlier than 2012-12-12 | S5 | 2128h | 532h | OAM-IRAT-ESM |  | Nokia Siemens Networks, Huawei | Rel-11 |  |  |
| 145 | 50 | **Rel-11 Charging Management small Enhancements** | 713d? | 2010-03-25 A | 2012-12-12 | 72% | 196.86d? | 2010-03-25 | 2012-12-12 | 713d? | 260d |  | S5 | 11496h | 8313.13h | CH11 | PCG-26 |  | Rel-11 | SP-51 | Dionisio |
| 146 | 50.1 | Add solutions for Rc - reference point within the Online Charging System (OCS) | 392d? | 2010-03-25 A | 2011-09-21 A | 100% |  | 2010-03-25 | 2011-09-21 | 392d? |  | finish no earlier than 2011-08-26 | S5 | 3120h | 3120h | CH-Rc | PCG-24 | Huawei | Rel-11 | SP-47 | Dionisio |
| 147 | 50.2 | Charging for Policy Enhancements for Sponsored Connectivity and Coherent Access to Policy related Data Bases | 135d? | 2011-03-21 A | 2011-09-21 A | 100% |  | 2011-03-21 | 2011-09-21 | 135d? |  | finish no earlier than 2011-09-21 | S5 | 1064h | 1064h | PEST-CH | PCG-26 | Ericsson | Rel-11 | SP-51 | Dionisio |
| 148 | 50.3 | Unification of Charging session from SIP AS and SRVCC functions in IMS | 201d? | 2012-03-07 | 2012-12-12 |  |  | 2012-03-07 | 2012-12-12 | 201d? | 260d | finish no earlier than 2012-12-12 | S5 | 1608h |  | UCHIMS_AS-SRVCC | PCG-28 | Alcatel-Lucent | Rel-11 | SP-55 |  |
| 149 | 51 | Definition of the UICC Application for Hosting Party Module | 327d? | 2011-03-18 A | 2012-06-15 | 90% | 32.7d? | 2011-03-18 | 2012-06-15 | 327d? | 388d | finish no earlier than 2012-06-15 | C6 | 2608h | 2346.4h | HPM_UICC | PCG-26 | Gemalto | Rel-11 | CP-51 | Xavier |
| 150 | 52 | Usability improvement of Inter-IMS Network to Network Interface (II-NNI) specification for inter-connection by means of Option Item list | 272d? | 2011-06-07 A | 2012-06-15 | 95% | 13.6d? | 2011-06-07 | 2012-06-15 | 272d? | 388d | finish no earlier than 2012-06-15 | C3 | 2168h | 2059.2h | NNI_OI | PCG-27 | NTT | Rel-11 | CP-52 | Jiwan |
| 151 | 53 | **enhanced Nodes Restoration for EPC** | 274d? | 2011-06-03 A | 2012-06-15 | 36% | 176.52d? | 2011-06-03 | 2012-06-15 | 274d? | 388d |  | C4,C1 | 4904h | 964.8h | eNR_EPC | PCG-27 | ZTE | Rel-11 | CP-52 | Kimmo |
| 152 | 53.1 | CT4 part of enhanced Nodes Restoration for EPC | 273d? | 2011-06-03 A | 2012-06-15 | 20% | 218.4d? | 2011-06-03 | 2012-06-15 | 273d? | 388d | finish no earlier than 2012-06-15 | C4 | 2184h | 436.8h | eNR_EPC | PCG-27 | ZTE | Rel-11 | CP-52 | Kimmo |
| 153 | 53.2 | CT1 part of enhanced Nodes Restoration for EPC | 66d? | 2011-12-02 A | 2012-03-02 A | 100% |  | 2011-12-02 | 2012-03-02 | 66d? |  | finish no earlier than 2012-06-15 | C1 | 528h | 528h | eNR_EPC | PCG-28 | ZTE | Rel-11 | CP-54 |  |

Notes:
- 128: Stage 3. SP#55 updated WID SP-110878=>SP-120025 / Text3: 26.140, 26.234, 26.247 / Text5: Nikolai Leung (nleung@qualcomm.com)
- 129: SP#55 updated WID SP-110555=>SP-120182 / Text3: 26.346, New TR 26.9yz (Evaluation of MBMS FEC Enhancements) / Text5: Thomas Stockhammer (c_tstock@qualcomm.com)
- 130: SP#55 updated WID SP-110556=>SP-120025 / Text3: 26.346, new TR 26.9yz / Text5: Nikolai Leung (nleung@qualcomm.com)
- 131: SP#55 updated WID SP-110557=>SP-120025 / Text3: 26.237, new TR 26.9mn (IMS-based multi-device synchronization) / Text5: hang.liu@interdigital.com
- 132: - / Text3: TR 30.821
- 133: -
- 134: SP#54 completion 03/12=>09/12. Triggered by SA5 Studies TR 32.833, 32.828, 32.831 / Text3: 32.abc (Various existing NRM IRPs), 32.101, 32.152, 32.622, new TS (32.xy1, 32.xy2, 32.xy3) / Text5: thomas.tovinger@ericsson.com, olaf.pollakowski@nsn.com
- 135: Stage 2 in Rel-10 RAN Feature UID_460007 Carrier Aggregation for LTE (LTE_CA). WT under 3 SA5 Rel-11 BBs (NIM, PM, SON) / Text3: 32.425, 32.450, 32.451, 32.501, 32.502, 32.506, 32.511, 32.521, 32.522, 32.526, 32.541, 32.551, 32.761, 32.762, 32.766 / Text5: yizhi.yao@nsn.com, per.elmdahl@ericsson.com
- 136: Stage 2 in Rel-6 WLAN-UMTS Interworking (WLAN) 23.234, Rel-7 WLAN Interworking Private Network access from WLAN 3GPP IP Access (WLANPNA) 23.234, Rel-8 Mobility between 3GPP-WLAN Interworking and 3GPP Systems (IWLAN_Mob) 23.327. WT under 2 SA5 Rel-11 BBs / Text3: 32.632, 32.636, 32.752, 32.756, 4 new TS (3GPP interworking WLAN NRM IRP: Reqs, IS, SS, Performance measurements) / Text5: Chengang@chinamobile.com, lijian@chinamobile.com
- 137: -
- 138: SP#55 completed / Text3: 32.409 / Text5: guo.wenjie1@zte.com.cn
- 139: - / Text3: 32.421, 32.422, 32.423, 32.441, 32.442, 32.446 / Text5: Zou Lan (zlan@huawei.com), ulf.hubinette@ericsson.com, gyula.bodog@nsn.com
- 140: SP#54 completion 12/11=>09/12 / Text3: 32.406, 32.407, 32.426 / Text5: Liang Shuangchun (liangshuangchun@cmdi.chinamobile.com), Li Jian (lijian@chinamobile.com)
- 141: -
- 142: SP#53 updated WID SP-110133=>SP-110518 (Changed Objective) / Text3: UTRA 32.405, 32.500, 32.511, 32.521, 32.522, 32.526, 32.642, 32.646 / Text5: kai.zhangkai@huawei.com
- 143: - / Text3: LTE 32.425, 32.500, 32.521, 32.522, 32.526, 32.762, 32.766 / Text5: kai.zhangkai@huawei.com, clemens.suerbaum@nsn.com
- 144: Triggered by Rel-11 TR 32.834 (Study on OAM aspects of inter-RAT Energy Saving) UID_510045. Needs coordination with RAN WGs / Text3: 32.405, 32.551, 32.522, 32.526, 32.642, 32.646, 32.762, 32.766 / Text5: clemens.suerbaum@nsn.com, xiahaitao@huawei.com
- 145: - / Text3: TR 30.821
- 146: SP#53 completed. Stage 3 (Stage 1 in 22.115). Triggered by Rel-10 TR 32.825 SA5 Study on Rc Reference Point Functionalities and Message Flows (UID_410044) / Text3: 32.296, 32.299 / Text5: shan.mingjun@huawei.com
- 147: SP#53 completed. Stage 3 / Text3: 32.251, 32.298, 32.299 / Text5: patrik.teppo@@ericsson.com
- 148: Stage 2/3 / Text3: 32.260, 32.275, 32.298, 32.299 / Text5: maryse.gardella@alcatel-lucent.com
- 149: CP#55 completion 03/12=>06/12. TS 31.104 v100 for Information. Defines Stage 3 for UICC application residing in Hosting Party Module / Text3: 31.102, new TS 31.104 / Text5: Denis.Lheriteau@gemalto.com
- 150: CP#55 completion 03/12=>06/12. Stage 3 (No architectural change, specify the list of selectable items related to control plane signalling directly for the same architecture) / Text3: 29.165 / Text5: arai.kenjiro@lab.ntt.co.jp
- 151: CP#54 updated WID CP-110385=>CP-110928 (completion 12/11=>06/12). Added CT1 part. Stage 2/3 Triggered by DRAFT TR 23.857 Study on EPC Nodes Restoration UID_490014 / Text5: lu.fei1@zte.com.cn
- 152: - / Text3: 23.007, 23.008, 23.018, 29.274, 29.275 / Text5: lu.fei1@zte.com.cn
- 153: CP#55 completed / Text3: 29.118 / Text5: lu.fei1@zte.com.cn

| ID | WBS | Task | Type | Duration | Start | Finish | Complete | Remaining | Baseline start | Baseline finish | Baseline duration | Total slack | Constraint | Resources | Work | Actual work | Text1 | Text2 | Text4 | Text5 | Text6 | Text7 | Text8 |
| --- | --- | --- | --- | --- | --- | --- | --- | --- | --- | --- | --- | --- | --- | --- | --- | --- | --- | --- | --- | --- | --- | --- | --- |
| 154 | 54 | **Reference Location Information** |  | 78d? | 2011-06-03 A | 2011-09-16 A | 100% |  | 2011-06-03 | 2011-09-16 | 78d? |  |  | C4,C1 | 1236.74h | 1236.74h | RLI | PCG-27 | Huawei | susan.shishufeng@Huawei.com | Rel-11 | CP-52 | Kimmo |
| 155 | 54.1 | CT4 part of Reference Location Information | milestone | 0d? | 2011-06-03 A | 2011-06-03 A | 100% |  | 2011-06-03 | 2011-06-03 | 0d? |  | finish no earlier than 2011-06-03 | C4 |  |  | RLI | PCG-27 | Huawei | susan.shishufeng@Huawei.com | Rel-11 | CP-52 | Kimmo |
| 156 | 54.2 | CT1 part of Reference Location Information |  | 78d? | 2011-06-03 A | 2011-09-16 A | 100% |  | 2011-06-03 | 2011-09-16 | 78d? |  | finish no earlier than 2011-08-30 | C1 | 612.74h | 612.74h | RLI | PCG-27 | Huawei | susan.shishufeng@Huawei.com | Rel-11 | CP-52 | Frederic |
| 157 | 55 | **IMS Stage-3 IETF Protocol Alignment** |  | 337d? | 2011-06-07 A | 2012-09-14 | 43% | 193.71d? | 2011-06-07 | 2012-09-14 | 337d? | 323d |  | C1,C3 | 8072h | 3427.5h | IMSProtoc5 | PCG-27 | Alcatel-Lucent | keith.drage@alcatel-lucent.com | Rel-11 | CP-52 | Frederic |
| 158 | 55.1 | CT1 part of IMS Stage-3 IETF Protocol Alignment |  | 337d? | 2011-06-07 A | 2012-09-14 | 55% | 151.65d? | 2011-06-07 | 2012-09-14 | 337d? | 323d | finish no earlier than 2012-09-14 | C1 | 2688h | 1474.8h | IMSProtoc5 | PCG-27 | Alcatel-Lucent | keith.drage@alcatel-lucent.com | Rel-11 | CP-52 | Frederic |
| 159 | 55.2 | CT3 part of IMS Stage-3 IETF Protocol Alignment |  | 336d? | 2011-06-07 A | 2012-09-14 | 30% | 235.2d? | 2011-06-07 | 2012-09-14 | 336d? | 323d | finish no earlier than 2012-09-14 | C3 | 2688h | 806.4h | IMSProtoc5 | PCG-27 | Alcatel-Lucent | keith.drage@alcatel-lucent.com | Rel-11 | CP-52 | Jiwan |
| 160 | 56 | **Service Identification for RRC Improvements in GERAN (Stage 3)** |  | 196d? | 2011-09-19 A | 2012-06-15 | 11% | 173.76d? | 2011-09-19 | 2012-06-15 | 196d? | 388d |  | C4,C3,G2 | 5840h | 720.84h | SIRIG | PCG-27 | China Mobile | zhanghao@chinamobile.com | Rel-11 | GP-51 |  |
| 161 | 56.1 | **CN aspects of Service Identification for RRC Improvements in GERAN** |  | 141d? | 2011-12-02 A | 2012-06-15 | 16% | 117.74d? | 2011-12-02 | 2012-06-15 | 141d? | 388d |  | C4,C3 | 2864h | 472.49h | SIRIG | PCG-28 | China Mobile | zhanghao@chinamobile.com | Rel-11 | CP-54 |  |
| 162 | 56.1.1 | CT4 part of CN aspects of Service Identification for RRC Improvements in GERAN |  | 141d? | 2011-12-02 A | 2012-06-15 | 20% | 112.8d? | 2011-12-02 | 2012-06-15 | 141d? | 388d | start no earlier than 2011-12-02 | C4 | 1128h | 225.6h | SIRIG | PCG-28 | China Mobile | zhanghao@chinamobile.com | Rel-11 | CP-54 |  |
| 163 | 56.1.2 | CT3 part of CN aspects of Service Identification for RRC Improvements in GERAN |  | 76d? | 2012-03-02 A | 2012-06-15 | 10% | 68.4d? | 2012-03-02 | 2012-06-15 | 76d? | 388d | finish no earlier than 2012-06-15 | C3 | 608h | 60.8h | SIRIG | PCG-28 | China Mobile | zhanghao@chinamobile.com | Rel-11 | CP-55 |  |
| 164 | 56.2 | GERAN2 part of Service Identification for RRC Improvements in GERAN |  | 176d? | 2011-09-19 A | 2012-05-18 | 5% | 167.2d? | 2011-09-19 | 2012-05-18 | 176d? | 408d | finish no earlier than 2012-05-18 | G2 | 1408h | 70.4h | SIRIG | PCG-27 | China Mobile, Huawei | Juan Deng, Yang Zhao | Rel-11 | GP-51 |  |
| 165 | 57 | **IMS Emergency PSAP Callback (Stage 3)** |  | 262d? | 2011-09-16 | 2012-09-14 |  |  | 2011-09-16 | 2012-09-14 | 262d? | 323d |  | C1,C3,IETF | 8368h |  | EMC_PC | PCG-27 | Ericsson | christer.holmberg@ericsson.com | Rel-11 | CP-53 |  |
| 166 | 57.1 | CT1 part of IMS Emergency PSAP Callback |  | 261d? | 2011-09-19 | 2012-09-14 |  |  | 2011-09-19 | 2012-09-14 | 261d? | 323d | finish no earlier than 2012-09-14 | C1 | 2088h |  | EMC_PC | PCG-27 | Ericsson | christer.holmberg@ericsson.com | Rel-11 | CP-53 |  |
| 167 | 57.2 | (IETF) IMS Emergency PSAP Callback (Stage 3) |  | 262d? | 2011-09-16 | 2012-09-14 |  |  | 2011-09-16 | 2012-09-14 | 262d? | 323d | finish no earlier than 2012-09-14 | C1-IETF | 2096h |  | EMC_PC_IETF | PCG-27 | Christer Holmberg | christer.holmberg@ericsson.com | Rel-11 | CP-53 |  |
| 168 | 57.3 | CT3 part of IMS Emergency PSAP Callback |  | 261d? | 2011-09-19 | 2012-09-14 |  |  | 2011-09-19 | 2012-09-14 | 261d? | 323d | finish no earlier than 2012-09-14 | C3 | 2088h |  | EMC_PC | PCG-27 | Ericsson | christer.holmberg@ericsson.com | Rel-11 | CP-53 |  |
| 169 | 58 | **SAE Protocol Development** |  | 262d? | 2011-09-16 A | 2012-09-14 | 60% | 104.8d? | 2011-09-16 | 2012-09-14 | 262d? | 323d |  | C1 | 6272h | 3756.8h | SAES2 | PCG-27 | Nokia Siemens Networks | robert.zaus@nsn.com | Rel-11 | CP-53 |  |
| 170 | 58.1 | SAE Protocol Development (Stage 3) |  | 262d? | 2011-09-16 A | 2012-09-14 | 60% | 104.8d? | 2011-09-16 | 2012-09-14 | 262d? | 323d | start no earlier than 2011-09-16 | C1 | 2088h | 1249.6h | SAES2 | PCG-27 | Nokia Siemens Networks | robert.zaus@nsn.com | Rel-11 | CP-53 |  |
| 171 | 58.2 | CS Fallback in EPS Phase 2 |  | 262d? | 2011-09-16 A | 2012-09-14 | 60% | 104.8d? | 2011-09-16 | 2012-09-14 | 262d? | 323d | start no earlier than 2011-09-16 | C1 | 2088h | 1249.6h | SAES2-CSFB | PCG-27 | Nokia Siemens Networks | robert.zaus@nsn.com | Rel-11 | CP-53 |  |
| 172 | 59 | **GCSMSC and GCR Redundancy for VGCS/VBS (Stage 2/3)** |  | 196d? | 2011-09-19 A | 2012-06-15 | 56% | 86.93d? | 2011-09-19 | 2012-06-15 | 196d? | 388d |  | C1,C4 | 4104h | 2283.74h | RT_VGCS_Red | PCG-27 | Nokia Siemens Networks | robert.zaus@nsn.com | Rel-11 | CP-53 |  |
| 173 | 59.1 | CT1 part of GCSMSC and GCR Redundancy for VGCS/VBS |  | 196d? | 2011-09-19 A | 2012-06-15 | 90% | 19.6d? | 2011-09-19 | 2012-06-15 | 196d? | 388d | finish no earlier than 2012-06-15 | C1 | 1568h | 1411.2h | RT_VGCS_Red | PCG-27 | Nokia Siemens Networks | robert.zaus@nsn.com | Rel-11 | CP-53 |  |
| 174 | 59.2 | CT4 part of GCSMSC and GCR Redundancy for VGCS/VBS |  | 121d? | 2011-09-19 | 2012-03-02 |  |  | 2011-09-19 | 2012-03-02 | 121d? | 463d | finish no earlier than 2012-03-02 | C4 | 968h |  | RT_VGCS_Red | PCG-27 | Nokia Siemens Networks | robert.zaus@nsn.com | Rel-11 | CP-53 |  |
| 175 | 60 | Support of RFC 6140 in IMS |  | 141d? | 2011-12-02 A | 2012-06-15 | 25% | 105.75d? | 2011-12-02 | 2012-06-15 | 141d? | 388d | finish no earlier than 2012-06-15 | C1 | 1128h | 282h | GINI | PCG-28 | Deutsche Telekom | martin.huelsemann@telekom.de | Rel-11 | CP-54 |  |
| 176 | 61 | **Enhancement of the Protocols for SMS over SGs (Stage 3)** |  | 201d? | 2011-12-02 A | 2012-09-07 | 14% | 172.5d? | 2011-12-02 | 2012-09-07 | 201d? | 328d |  | C4,C1 | 5952h | 844.02h | PROTOC_SMS_SGs | PCG-28 | Alcatel-Lucent | jean-jacques.trottin@alcatel-lucent.com | Rel-11 | CP-54 |  |
| 177 | 61.1 | TR Study on enhancement of protocols for SMS service over SGs |  | 141d? | 2011-12-02 A | 2012-06-15 | 40% | 84.6d? | 2011-12-02 | 2012-06-15 | 141d? | 388d | finish no earlier than 2012-06-15 | C4 | 1128h | 451.2h | PROTOC_SMS_SGs | PCG-28 | Alcatel-Lucent | jean-jacques.trottin@alcatel-lucent.com | Rel-11 | CP-54 |  |
| 178 | 61.2 | CT4 part of Enhancement of the Protocols for SMS over SGs |  | 201d? | 2011-12-02 | 2012-09-07 |  |  | 2011-12-02 | 2012-09-07 | 201d? | 328d | finish no earlier than 2012-09-07 | C4 | 1608h |  | PROTOC_SMS_SGs | PCG-28 | Alcatel-Lucent | jean-jacques.trottin@alcatel-lucent.com | Rel-11 | CP-54 |  |
| 179 | 61.3 | CT1 part of Enhancement of the Protocols for SMS over SGs |  | 201d? | 2011-12-02 A | 2012-09-07 | 10% | 180.4d? | 2011-12-02 | 2012-09-07 | 201d? | 328d | finish no earlier than 2012-09-07 | C1 | 1608h | 164.8h | PROTOC_SMS_SGs | PCG-28 | Alcatel-Lucent | jean-jacques.trottin@alcatel-lucent.com | Rel-11 | CP-54 |  |

Notes:
- 154: CP#53 completed. Stage 3. Stage 2 clause C.1.1 of SA2 TS 23.167 CR#0182 (WI code: TEI11)
- 155: CP#52 completed / Text3: 23.008, 29.228, 29.328, 29.329
- 156: CP#53 completed / Text3: 24.229
- 157: Stage 3
- 158: - / Text3: 23.218, 24.229, 24.930
- 159: - / Text3: 29.163, 29.165
- 160: CT define a generic solution (not only for GERAN). Minor Stage 2 impacts expected. S2-114557 recommends GERAN/CT document solution(s) and get SA2 feedback before GERAN/CT finalization. Once GERAN/CT/SA2 a solution agreed, SA2 Stage 2 can be updated / Text3: GERAN
- 161: CP#55 updated WID CP-110929=>P-120033 (added CT3 impact)
- 162: 29.281 [GPRS Tunnelling Protocol User Plane (GTPv1-U)] / Text3: 29.281
- 163: 29.212 (PCC over Gx/Sd reference point) / Text3: 29.212
- 164: GP#53 completion 03/12=>05/12 / Text3: 48.018
- 165: Stage 3 (Dependency IETF ECRIT on PSAP call back). Fulfil SA1/2 Rel-7 EMC1 reqs UID_32045 PS domain and IMS impacts for supporting IMS Emergency calls (related to BB UID_1653 Emergency Call Enhancements for IP& PS Based Calls / Text3: Stage 3
- 166: - / Text3: 24.229
- 167: IETF ECRIT work on PSAP call back / Text3: no internet-draft available yet
- 168: CP#54 Work can only begin when CT1 has decided the technical solution / Text3: 29.163, 29.165
- 169: Stage 3 continuation of Rel-8 Feature SAES (3GPP System Architecture Evolution Specification - Evolved Packet System) UID_320005
- 170: - / Text3: 23.122, 24.008, 24.167, 24.229, 24.301, 24.302, 24.303, 24.304, 24.305, 24.312, 29.018, 29.118
- 171: - / Text3: 23.122, 24.008, 24.167, 24.229, 24.301, 24.302, 24.303, 24.304, 24.305, 24.312, 29.018, 29.118
- 172: Stage 2/3 adding a CN internal functionality, not affecting Voice Group Call Service (VGCS)/VBS as perceived by service subscriber. Hence, no Stage 1 impact for VGCS/VBS (42.068, 42.069) / Text3: Stage 2/3
- 173: CP#55 completion 03/12=>06/12 / Text3: 43.068, 43.069
- 174: - / Text3: 29.002
- 175: Stage 3. Support procedures and protocol extensions in RFC6140 "Registration for Multiple Phone Numbers in SIP" to IMS for complex UEs. Ensure co-existence of this new registration mechanism with NGCN IP-PBX registration procedures already defined in IMS. / Text3: 24.229
- 176: CP#55 updated WID CP-110924=>CP-120034 / Text3: Stage 3
- 177: - / Text3: new TR 29.818
- 178: - / Text3: 29.305, new TS 29.218 (Diameter based protocols for SMS service over SGs)
- 179: - / Text3: 23.040, 24.011, 43.068

| ID | WBS | Task | Duration | Start | Finish | Complete | Remaining | Baseline start | Baseline finish | Baseline duration | Total slack | Constraint | Resources | Work | Actual work | Text1 | Text2 | Text4 | Text5 | Text6 | Text7 | Text8 | Text11 |
| --- | --- | --- | --- | --- | --- | --- | --- | --- | --- | --- | --- | --- | --- | --- | --- | --- | --- | --- | --- | --- | --- | --- | --- |
| 180 | 62 | **Enhancements for Multimedia Priority Service (MPS) – Gateway Control Priority** | 141d? | 2011-12-02 A | 2012-06-15 | 23% | 109.28d? | 2011-12-02 | 2012-06-15 | 141d? | 388d |  | C4,C3 | 3384h | 761.4h | eMPS_Gateway | PCG-28 | Telcordia | Viqar Shaikh | Rel-11 | CP-54 |  |  |
| 181 | 62.1 | CT4 part of Enhancements for Multimedia Priority Service (MPS) – Gateway Control Priority | 141d? | 2011-12-02 A | 2012-06-15 | 25% | 105.75d? | 2011-12-02 | 2012-06-15 | 141d? | 388d | finish no earlier than 2012-06-15 | C4 | 1128h | 282h | eMPS_Gateway | PCG-28 | Telcordia | Viqar Shaikh | Rel-11 | CP-54 |  |  |
| 182 | 62.2 | CT3 part of Enhancements for Multimedia Priority Service (MPS) – Gateway Control Priority | 141d? | 2011-12-02 A | 2012-06-15 | 20% | 112.8d? | 2011-12-02 | 2012-06-15 | 141d? | 388d | finish no earlier than 2012-06-15 | C3 | 1128h | 225.6h | eMPS_Gateway | PCG-28 | Telcordia | Viqar Shaikh | Rel-11 | CP-54 |  |  |
| 183 | 63 | Inter-IMS Network to Network Interface (II-NNI) enhancements: SIP timers applicability (Stage 3) | 136d? | 2012-03-02 A | 2012-09-07 | 80% | 27.2d? | 2012-03-02 | 2012-09-07 | 136d? | 328d | start no earlier than 2012-03-02 | C3 | 1088h | 870.4h | NNI_timers | PCG-28 | Telecom Italia | antonio.ascolese@telecomitalia.it | Rel-11 | CP-55 |  |  |
| 184 | 64 | **Full Support of Multi-Operator Core Network by GERAN** | 404d? | 2011-03-04 A | 2012-09-14 | 68% | 128.31d? | 2011-03-04 | 2012-09-14 | 404d? | 323d |  | G2,S2,C1 | 9452.8h | 5517.44h | Full_MOCN-GERAN | PCG-26 | Alcatel-Lucent | michel.robert@alcatel-lucent.com | Rel-11 | GP-49 | Paolo |  |
| 185 | 64.1 | GERAN part of Full Support of Multi-Operator Core Network by GERAN | 319d? | 2011-03-04 A | 2012-05-18 | 60% | 127.6d? | 2011-03-04 | 2012-05-18 | 319d? | 408d | finish no earlier than 2012-05-18 | G2 | 2544h | 1523.2h | Full_MOCN-GERAN | PCG-26 | Alcatel-Lucent | michel.robert@alcatel-lucent.com | Rel-11 | GP-49 | Gert |  |
| 186 | 64.2 | Stage 2 for Full Support of Multi-Operator Core Network by GERAN | 160.8d? | 2011-06-08 A | 2012-03-07 A | 100% |  | 2011-06-08 | 2012-03-07 | 160.8d? |  | finish no earlier than 2012-03-07 | S2 | 1278.4h | 1278.4h | Full_MOCN-GERAN | PCG-26 | Alcatel-Lucent | nicolas.drevon@alcatel-lucent.com | Rel-11 | GP-49 | Maurice |  |
| 187 | 64.3 | CN Stage 3 for Full Support of Multi-Operator Core Network by GERAN | 300.8d? | 2011-06-03 A | 2012-09-14 | 60% | 120.32d? | 2011-06-03 | 2012-09-14 | 300.8d? | 323d | finish no earlier than 2012-09-14 | C1 | 2398.4h | 1435.84h | Full_MOCN-GERAN | PCG-26 | Alcatel-Lucent | jennifer.liu@alcatel-lucent.com | Rel-11 | GP-49 | Frederic |  |
| 188 | 65 | **Introduction of ER-GSM band for GSM-R** | 257d? | 2011-09-16 A | 2012-09-07 | 10% | 231.5d? | 2011-09-16 | 2012-09-07 | 257d? | 328d |  | G1,C1 | 6112h | 470.67h | RT_ERGSM | PCG-27 | Kapsch Carriercom | thomas.chatelet@kapsch.net | Rel-11 | GP-51 |  |  |
| 189 | 65.1 | GERAN1 part of Introduction of ER-GSM band for GSM-R | 252d? | 2011-09-16 A | 2012-08-31 | 20% | 201.6d? | 2011-09-16 | 2012-08-31 | 252d? | 333d | finish no earlier than 2012-08-31 | G1 | 2008h | 395.2h | RT_ERGSM | PCG-27 | Kapsch Carriercom | thomas.chatelet@kapsch.net | Rel-11 | GP-51 |  |  |
| 190 | 65.2 | CT1 part of Introduction of ER-GSM band for GSM-R | 256d? | 2011-09-19 | 2012-09-07 |  |  | 2011-09-19 | 2012-09-07 | 256d? | 328d | finish no earlier than 2012-09-07 | C1 | 2048h |  | RT_ERGSM | PCG-27 | Kapsch Carriercom | thomas.chatelet@kapsch.net | Rel-11 | CP-53 |  |  |
| 191 | 66 | Domain Specific Access Control in GERAN | 131d? | 2012-03-02 | 2012-08-31 |  |  | 2012-03-02 | 2012-08-31 | 131d? | 333d | finish no earlier than 2012-08-31 | G2 | 1048h |  | GDSAC | PCG-28 | Vodafone | chris.pudney@vodafone.com | Rel-11 | GP-53 |  |  |
| 192 | 67 | **Extending 850 MHz Upper Band (814 – 849 MHz)** | 399d? | 2010-12-10 A | 2012-06-15 | 68% | 128.17d? | 2010-12-10 | 2012-06-15 | 399d? | 388d |  | R4,R2,R3,R5 | 10960h | 5827.6h | e850_UB | PCG-26 | Sprint | John.J.Humbert@Sprint.com | Rel-11 | RP-50 | Issam |  |
| 193 | 67.1 | Core part: Extending 850 MHz Upper Band (814 – 849 MHz) | 322d? | 2010-12-10 A | 2012-03-02 A | 100% |  | 2010-12-10 | 2012-03-02 | 322d? |  | finish no earlier than 2012-03-02 | R4,R2,R3 | 2568h | 2568h | e850_UB-Core | PCG-26 | Sprint | John.J.Humbert@Sprint.com | Rel-11 | RP-50 | Issam | RP-120075 |
| 194 | 67.2 | Perf. part: Extending 850 MHz Upper Band (814 – 849 MHz) | 322d? | 2010-12-10 A | 2012-03-02 A | 100% |  | 2010-12-10 | 2012-03-02 | 322d? |  | finish no earlier than 2012-03-02 | R4,R2,R3 | 2568h | 2568h | e850_UB-Perf | PCG-26 | Sprint | John.J.Humbert@Sprint.com | Rel-11 | RP-50 | Issam | RP-120076 |
| 195 | 67.3 | Test part: Extending 850 MHz Upper Band (814 – 849 MHz) | 329d? | 2011-03-18 A | 2012-06-15 | 5% | 312.55d? | 2011-03-18 | 2012-06-15 | 329d? | 388d | finish no earlier than 2012-06-15 | R5 | 2632h | 131.6h | e850_UB-UEConTest | PCG-26 | Sprint | John.J.Humbert@Sprint.com | Rel-11 | RP-51 | Ingbert | RP-120050 |
| 196 | 68 | **Further Self Optimizing Networks (SON) enhancements** | 256d? | 2011-09-19 A | 2012-09-07 | 25% | 192d? | 2011-09-19 | 2012-09-07 | 256d? | 328d |  | R3,R2 | 4096h | 1024h | SONenh2_LTE_UTRA | PCG-27 | Nokia Siemens Networks | krzysztof.kordybach@nsn.com | Rel-11 | RP-53 |  |  |
| 197 | 68.1 | Core part: Further Self Optimizing Networks (SON) enhancements | 256d? | 2011-09-19 A | 2012-09-07 | 25% | 192d? | 2011-09-19 | 2012-09-07 | 256d? | 328d | finish no earlier than 2012-09-07 | R3,R2 | 2048h | 512h | SONenh2_LTE_UTRA-Core | PCG-27 | Nokia Siemens Networks | krzysztof.kordybach@nsn.com | Rel-11 | RP-53 |  | RP-120079 |
| 198 | 69 | **Enhancement of Minimization of Drive Tests for E-UTRAN and UTRAN** | 256d? | 2011-09-19 A | 2012-09-07 | 20% | 204.8d? | 2011-09-19 | 2012-09-07 | 256d? | 328d |  | R2,R1,R3,R4 | 4096h | 819.2h | eMDT_UMTSLTE | PCG-27 | MediaTek | Johan Johansson | Rel-11 | RP-53 |  |  |
| 199 | 69.1 | Core part: Enhancement of Minimization of Drive Tests for E-UTRAN and UTRAN | 256d? | 2011-09-19 A | 2012-09-07 | 20% | 204.8d? | 2011-09-19 | 2012-09-07 | 256d? | 328d | finish no earlier than 2012-09-07 | R2,R1,R3,R4 | 2048h | 409.6h | eMDT_UMTSLTE-Core | PCG-27 | MediaTek | Johan Johansson | Rel-11 | RP-53 |  | RP-120077 |
| 200 | 70 | **Verification of radiated multi-antenna reception performance of UEs in LTE/UMTS** | 201d? | 2012-03-02 | 2012-12-07 |  |  | 2012-03-02 | 2012-12-07 | 201d? | 263d |  | R4 | 3216h |  | HSPA_LTE_measRP_MIMO | PCG-28 | Vodafone | Luis Anaya | Rel-11 | RP-55 |  |  |
| 201 | 70.1 | Perf. part: Verification of radiated multi-antenna reception performance of UEs in LTE/UMTS | 201d? | 2012-03-02 | 2012-12-07 |  |  | 2012-03-02 | 2012-12-07 | 201d? | 263d | finish no earlier than 2012-12-07 | R4 | 1608h |  | HSPA_LTE_measRP_MIMO-Perf | PCG-28 | Vodafone |  | Rel-11 | RP-55 |  |  |
| 202 | 71 | **E-UTRA medium range and MSR medium range/local area BS class requirements** | 256d? | 2011-09-19 A | 2012-09-07 | 12% | 225.26d? | 2011-09-19 | 2012-09-07 | 256d? | 328d |  | R4,G1 | 7272h | 873.09h | medBS_class_LTE_MSR | PCG-27 | Ericsson | johan.skold@ericsson.com | Rel-11 | RP-53 |  |  |
| 203 | 71.1 | Core part: E-UTRA medium range and MSR medium range/local area BS class requirements | 196d? | 2011-09-19 A | 2012-06-15 | 40% | 117.6d? | 2011-09-19 | 2012-06-15 | 196d? | 388d | finish no earlier than 2012-06-15 | R4 | 1568h | 627.2h | medBS_class_LTE_MSR-Core | PCG-27 | Ericsson | johan.skold@ericsson.com | Rel-11 | RP-53 |  | RP-120080 |
| 204 | 71.2 | Perf. part: E-UTRA medium range and MSR medium range/local area BS class requirements | 256d? | 2011-09-19 | 2012-09-07 |  |  | 2011-09-19 | 2012-09-07 | 256d? | 328d | finish no earlier than 2012-09-07 | R4 | 2048h |  | medBS_class_LTE_MSR-Perf | PCG-27 | Ericsson | johan.skold@ericsson.com | Rel-11 | RP-53 |  | RP-120081 |
| 205 | 71.3 | GERAN part: E-UTRA medium range and MSR medium range/local area BS class requirements | 201d? | 2011-11-25 | 2012-08-31 |  |  | 2011-11-25 | 2012-08-31 | 201d? | 333d | finish no earlier than 2012-08-31 | G1 | 1608h |  | medBS_class_LTE_MSR-GERAN | PCG-28 | Ericsson | Eric Nordström | Rel-11 | GP-52 |  |  |

Notes:
- 180: Stage 3. Stage 1 for MPS in 22.153. Details of any MGW actions for priority needs to be further studied within the scope of this WI. / Text3: Stage 3
- 181: - / Text3: 23.333, 23.334, 29.232, 29.238, 29.332, 29.333, 29.334
- 182: - / Text3: 29.162, 29.163, 29.292
- 183: Stage 3 / Text3: 29.165
- 184: GP#51 updated WID GP-110332=>GP-111459. GP#49 approved WID. Standardization of management of MOCN supporting MSs/UEs in GERAN. Continuation of Rel-10 MOCN-GERAN UID_490001 / Text3: GERAN
- 185: GP#51 completion 11/11=>05/12. Updated WID GP-110332=>GP-111459. GP#49 approved WID / Text3: 43.022, 44.018, 45.002
- 186: SP#55 completed / Text3: 23.251
- 187: CP#54 updated WID CP-110439=>CP-110758 (completion 12/11=>09/12) / Text3: 24.008
- 188: Use of band 870-876/915-921 MHz for land mobile service on national possibilities/market demand - as per ECC/DEC/(04)06 "CEPT ECC Decision on the availability of frequency bands for the introduction of Wide Band Digital Land Mobile PMR/PAMR in the 400 MHz / Text3: GERAN
- 189: GP#53 completion 03/12=>08/12. Introduction of ERGSM band, Performance requirements and Deployment scenarios / Text3: 45.001, 45.005, 45.050
- 190: GP#53 completion 03/12=>08/12. ERGSM capability indication / Text3: 24.008
- 191: Work is dependent upon Full_MOCN-GERAN (UID_510001) / Text3: GERAN 44.018
- 192: Stage 3 Triggered by R4 Rel-10 LTE TR 37.806 Study on Extending 850 MHz (UID_440016) / Text3: UTRA, LTE
- 193: RP#55 completed / Text3: 25.101, 25.104, 25.113, 25.133, 25.141, 25.461, 25.466, 36.101, 36.104, 36.113, 36.124, 36.133, 36.141, 36.307, 36.331, 37.104, 37.113, 37.141
- 194: RP#55 completed / Text3: 25.101, 25.104, 25.113, 25.133, 25.141, 25.461, 25.466, 36.101, 36.104, 36.124, 36.133, 36.141, 36.307, 36.331, 37.104, 37.113, 37.141
- 195: - / Text3: 34.108, 34.121-1, 34.121-2, 34.123-1, 34.123-2, 34.123-3, 36.508, 36.521-1, 36.521-2, 36.521-3, 36.523-1, 36.523-2, 36.523-3
- 196: Stage 1,2,3 / Text3: UTRA, LTE
- 197: RP#55 updated WID RP-111629=>RP-120314 / Text3: 25.331, 25.401, 25.410, 25.413, 25.423, 25.433, 36.300, 36.331, 36.413, 36.423
- 198: Stage 2,3. RP#55 updated WID RP-111361=>RP-120277 / Text3: UTRA, LTE
- 199: RP#55 updated WID RP-111361=>RP-120277 / Text3: 25.123, 25.133, 25.215, 25.225, 25.304, 25.306, 25.331, 25.413, 25.423, 36.133, 36.214, 36.304, 36.306, 36.331, 36.413, 36.423, 37.320
- 200: Triggered by FS_HSPA_LTE_measRP_MIMO_multi-antenna. Core functionality exists since Rel-6 & Rel-7 (MIMO). Adds a very generic test method to test UEs with 2 or more Rx antennas / Text3: UTRA, LTE
- 201: Rx diversity (defined as Rel-6 HSDPA RAN4 enhanced type 1 req.) & MIMO (defined as Rel-7 HSDPA MIMO for HSPA). Rx diversity & MIMO (defined as part of Rel-8 basic LTE WI) / Text3: new TR 37.9xy
- 202: Stage 3. GERAN BS RF requirements specs need aligned with RAN4 ongoing Rel-11 Feature UID_530037 E-UTRA medium range and MSR medium range/local area BS class requirements (medBS_class_LTE_MSR) / Text3: UTRA, LTE, GERAN
- 203: - / Text3: 25.104, 36.104, 37.104
- 204: - / Text3: 25.141, 36.141, 37.141
- 205: - / Text3: 45.005, 51.021

| ID | WBS | Task | Duration | Start | Finish | Complete | Remaining | Baseline start | Baseline finish | Baseline duration | Total slack | Constraint | Resources | Work | Actual work | Text1 | Text2 | Text4 | Text5 | Text6 | Text7 | Text8 | Text11 |
| --- | --- | --- | --- | --- | --- | --- | --- | --- | --- | --- | --- | --- | --- | --- | --- | --- | --- | --- | --- | --- | --- | --- | --- |
| 206 | 72 | **Medium range/local area requirements for multicarrier BTS** | 201d? | 2011-11-25 A | 2012-08-31 | 2% | 197.13d? | 2011-11-25 | 2012-08-31 | 201d? | 333d |  | G1 | 4224h | 81.38h | MRLA | PCG-28 | Ericsson | Eric Nordström | Rel-11 | GP-52 |  |  |
| 207 | 72.1 | Core part: Medium range/local area requirements for multicarrier BTS | 126d? | 2011-11-25 A | 2012-05-18 | 5% | 119.7d? | 2011-11-25 | 2012-05-18 | 126d? | 408d | finish no earlier than 2012-05-18 | G1 | 1008h | 50.4h | MRLA-Core | PCG-28 | Ericsson | Eric Nordström | Rel-11 | GP-52 |  |  |
| 208 | 72.2 | Perf. part: Medium range/local area requirements for multicarrier BTS | 201d? | 2011-11-25 | 2012-08-31 |  |  | 2011-11-25 | 2012-08-31 | 201d? | 333d | finish no earlier than 2012-08-31 | G1 | 1608h |  | MRLA-Perf | PCG-28 | Ericsson | Eric Nordström | Rel-11 | GP-52 |  |  |
| 209 | 73 | **RF Requirements for Multi-Band and Multi-Standard Radio (MB-MSR) Base Station** | 201d? | 2012-03-02 | 2012-12-07 |  |  | 2012-03-02 | 2012-12-07 | 201d? | 263d |  | R4,G1 | 4304h |  | MB_MSR_RF | PCG-28 | Huawei | Liu Ye (leo.liuye@huawei.com) | Rel-11 | RP-55 |  |  |
| 210 | 73.1 | Core part: RF Requirements for Multi-Band and Multi-Standard Radio (MB-MSR) Base Station | 136d? | 2012-03-02 | 2012-09-07 |  |  | 2012-03-02 | 2012-09-07 | 136d? | 328d | finish no earlier than 2012-09-07 | R4 | 1088h |  | MB_MSR_RF-Core | PCG-28 | Huawei | Liu Ye (leo.liuye@huawei.com) | Rel-11 | RP-55 |  |  |
| 211 | 73.2 | Perf. part: RF Requirements for Multi-Band and Multi-Standard Radio (MB-MSR) Base Station | 201d? | 2012-03-02 | 2012-12-07 |  |  | 2012-03-02 | 2012-12-07 | 201d? | 263d | finish no earlier than 2012-12-07 | R4 | 1608h |  | MB_MSR_RF-Perf | PCG-28 | Huawei | Liu Ye (leo.liuye@huawei.com) | Rel-11 | RP-55 |  |  |
| 212 | 74 | **Network-Based Positioning Support in LTE** | 919d? | 2009-03-09 A | 2012-09-07 | 29% | 648d? | 2009-03-09 | 2012-09-07 | 919d? | 328d |  | R2,R1,R3,R4 | 17304h | 5102.64h | LCS_LTE-NBPS | PCG-22 | TruePosition | terri.brooks@trueposition.com | Rel-11 | RP-43 | Joern |  |
| 213 | 74.1 | Core part: Network-Based Positioning Support in LTE | 593.5d? | 2009-03-09 A | 2012-06-15 | 75% | 148.38d? | 2009-03-09 | 2012-06-15 | 593.5d? | 388d | finish no earlier than 2012-06-15 | R2,R1,R3,R4 | 4748h | 3561h | LCS_LTE-NBPS-Core | PCG-22 | TruePosition | terri.brooks@trueposition.com | Rel-11 | RP-43 | Joern | RP-120082 |
| 214 | 74.2 | Perf. part: Network-Based Positioning Support in LTE | 916d? | 2009-03-12 | 2012-09-07 |  |  | 2009-03-12 | 2012-09-07 | 916d? | 328d | finish no earlier than 2012-09-07 | R4 | 7328h |  | LCS_LTE-NBPS-Perf | PCG-22 | TruePosition | terri.brooks@trueposition.com | Rel-11 | RP-43 | Joern | RP-120083 |
| 215 | 75 | **Service continuity improvements for MBMS for LTE** | 534d? | 2010-06-04 A | 2012-06-15 | 60% | 213.6d? | 2010-06-04 | 2012-06-15 | 534d? | 388d |  | R2,R3 | 8520h | 5112h | MBMS_LTE_SC | PCG-25 | Huawei | David.Lecompte@huawei.com | Rel-11 | RP-48 | Joern |  |
| 216 | 75.1 | Core part: Service continuity improvements for MBMS for LTE | 531d? | 2010-06-04 A | 2012-06-15 | 60% | 212.4d? | 2010-06-04 | 2012-06-15 | 531d? | 388d | finish no earlier than 2012-06-15 | R2,R3 | 4248h | 2548.8h | MBMS_LTE_SC-Core | PCG-25 | Huawei | David.Lecompte@huawei.com | Rel-11 | RP-48 | Joern | RP-120084 |
| 217 | 76 | **LTE Advanced Carrier Aggregation of Band 3 and Band 7** | 524d? | 2010-12-10 A | 2012-12-07 | 21% | 413.94d? | 2010-12-10 | 2012-12-07 | 524d? | 263d |  | R4 | 12008h | 2522.05h | LTE_CA_B3_B7 | PCG-25 | TeliaSonera | Ralf.Schuh@TeliaSonera.com | Rel-11 | RP-48 | Issam |  |
| 218 | 76.1 | Core part: LTE-Advanced Carrier Aggregation of Band 3 and Band 7 | 456d? | 2010-12-10 A | 2012-09-07 | 45% | 250.8d? | 2010-12-10 | 2012-09-07 | 456d? | 328d | finish no earlier than 2012-09-07 | R4 | 3648h | 1641.6h | LTE_CA_B3_B7-Core | PCG-25 | TeliaSonera | Ralf.Schuh@TeliaSonera.com | Rel-11 | RP-48 | Issam | RP-120102 |
| 219 | 76.2 | Perf. part: LTE-Advanced Carrier Aggregation of Band 3 and Band 7 | 521d? | 2010-12-15 | 2012-12-07 |  |  | 2010-12-15 | 2012-12-07 | 521d? | 263d | finish no earlier than 2012-12-07 | R4 | 4168h |  | LTE_CA_B3_B7-Perf | PCG-25 | TeliaSonera | Ralf.Schuh@TeliaSonera.com | Rel-11 | RP-48 | Issam | RP-120103 |
| 220 | 77 | **LTE Advanced Carrier Aggregation of Band 4 and Band 17** | 524d? | 2010-12-10 A | 2012-12-07 | 14% | 450.37d? | 2010-12-10 | 2012-12-07 | 524d? | 263d |  | R4 | 12032h | 1690.62h | LTE_CA_B4_B17 | PCG-26 | AT&T | marc.grant@att.com | Rel-11 | RP-50 | Issam |  |
| 221 | 77.1 | Core part: LTE Advanced Carrier Aggregation of Band 4 and Band 17 | 459d? | 2010-12-10 A | 2012-09-07 | 30% | 321.3d? | 2010-12-10 | 2012-09-07 | 459d? | 328d | finish no earlier than 2012-09-07 | R4 | 3672h | 1101.6h | LTE_CA_B4_B17-Core | PCG-26 | AT&T | marc.grant@att.com | Rel-11 | RP-50 | Issam | RP-120104 |
| 222 | 77.2 | Perf. part: LTE Advanced Carrier Aggregation of Band 4 and Band 17 | 521d? | 2010-12-15 | 2012-12-07 |  |  | 2010-12-15 | 2012-12-07 | 521d? | 263d | finish no earlier than 2012-12-07 | R4 | 4168h |  | LTE_CA_B4_B17-Perf | PCG-26 | AT&T | marc.grant@att.com | Rel-11 | RP-50 | Issam | RP-120105 |
| 223 | 78 | **LTE Advanced Carrier Aggregation of Band 4 and Band 13** | 524d? | 2010-12-10 A | 2012-12-07 | 19% | 426.17d? | 2010-12-10 | 2012-12-07 | 524d? | 263d |  | R4 | 12008h | 2241.82h | LTE_CA_B4_B13 | PCG-26 | Ericsson | christian.bergljung@stericsson.com | Rel-11 | RP-50 | Issam |  |
| 224 | 78.1 | Core part: LTE Advanced Carrier Aggregation of Band 4 and Band 13 | 456d? | 2010-12-10 A | 2012-09-07 | 40% | 273.6d? | 2010-12-10 | 2012-09-07 | 456d? | 328d | finish no earlier than 2012-09-07 | R4 | 3648h | 1459.2h | LTE_CA_B4_B13-Core | PCG-26 | Ericsson | christian.bergljung@stericsson.com | Rel-11 | RP-50 | Issam | RP-120106 |
| 225 | 78.2 | Perf. part: LTE Advanced Carrier Aggregation of Band 4 and Band 13 | 521d? | 2010-12-15 | 2012-12-07 |  |  | 2010-12-15 | 2012-12-07 | 521d? | 263d | finish no earlier than 2012-12-07 | R4 | 4168h |  | LTE_CA_B4_B13-Perf | PCG-26 | Ericsson | christian.bergljung@stericsson.com | Rel-11 | RP-50 | Issam | RP-120107 |
| 226 | 79 | **LTE Carrier Aggregation Enhancements** | 522d? | 2011-03-22 A | 2013-03-15 | 15% | 444.25d? | 2011-03-22 | 2013-03-15 | 522d? | 193d |  | R1,R2,R3,R4 | 11432h | 1702.83h | LTE_CA_enh | PCG-26 | Nokia | lars.e.lindh@nokia.com | Rel-11 | RP-51 | Patrick |  |
| 227 | 79.1 | Core part: LTE Carrier Aggregation Enhancements | 386d? | 2011-03-22 A | 2012-09-07 | 35% | 250.9d? | 2011-03-22 | 2012-09-07 | 386d? | 328d | finish no earlier than 2012-09-07 | R1,R2,R4,R3 | 3088h | 1080.8h | LTE_CA_enh-Core | PCG-26 | Nokia | lars.e.lindh@nokia.com | Rel-11 | RP-51 | Patrick | RP-120087 |
| 228 | 79.2 | Perf. part: LTE Carrier Aggregation Enhancements | 521d? | 2011-03-23 | 2013-03-15 |  |  | 2011-03-23 | 2013-03-15 | 521d? | 193d | finish no earlier than 2013-03-15 | R4 | 4168h |  | LTE_CA_enh-Perf | PCG-26 | Nokia | lars.e.lindh@nokia.com | Rel-11 | RP-51 | Issam | RP-120088 |
| 229 | 80 | **LTE Advanced Carrier Aggregation of Band 4 and Band 12** | 452d? | 2011-03-22 A | 2012-12-07 | 16% | 379.04d? | 2011-03-22 | 2012-12-07 | 452d? | 263d |  | R4,R2 | 10312h | 1664.46h | LTE_CA_B4_B12 | PCG-26 | Cox Communications | Lewis.Roberts@cox.com | Rel-11 | RP-51 | Issam |  |
| 230 | 80.1 | Core part: LTE Advanced Carrier Aggregation of Band 4 and Band 12 | 386d? | 2011-03-22 A | 2012-09-07 | 35% | 250.9d? | 2011-03-22 | 2012-09-07 | 386d? | 328d | finish no earlier than 2012-09-07 | R4,R2 | 3088h | 1080.8h | LTE_CA_B4_B12-Core | PCG-26 | Cox Communications | Lewis.Roberts@cox.com | Rel-11 | RP-51 | Issam | RP-120108 |
| 231 | 80.2 | Perf. part: LTE Advanced Carrier Aggregation of Band 4 and Band 12 | 451d? | 2011-03-23 | 2012-12-07 |  |  | 2011-03-23 | 2012-12-07 | 451d? | 263d | finish no earlier than 2012-12-07 | R4 | 3608h |  | LTE_CA_B4_B12-Perf | PCG-26 | Cox Communications | Lewis.Roberts@cox.com | Rel-11 | RP-51 | Issam | RP-120109 |

Notes:
- 206: - / Text3: GERAN
- 207: Stage 3 / Text3: 45.005
- 208: Test spec / Text3: 51.021
- 209: - / Text3: UTRA, LTE, GERAN
- 210: - / Text3: 25.104, 36.104, 37.104
- 211: - / Text3: 25.141, 36.141, 37.141, new TR 37.8xy
- 212: - / Text3: LTE
- 213: RP#55 completion 03/12=>06/12 / Text3: 36.111, 36.133, 36.214, 36.300, 36.305, 36.331, 36.413, 36.423, 36.455
- 214: - / Text3: 36.104, 36.111, 36.133, 36.141
- 215: - / Text3: LTE
- 216: RP#55 completion 03/12=>06/12 / Text3: 25.446, 36.300, 36.304, 36.321, 36.322, 36.323, 36.331, 36.440, 36.441, 36.442, 36.443, 36.444, 36.445
- 217: In Europe Band 3,7,20 are interesting for LTE and LTE-Advanced deployment. Different CA combinations for these bands are of high priority for Region 1 / Text3: LTE
- 218: - / Text3: 36.101, 36.104, 36.113, 36.124, 36.133, 36.141, 36.307, 36.331, 36.807, 36.808
- 219: - / Text3: 36.101, 36.104, 36.133, 36.307
- 220: Stage 3. RP#54 updated WID RP-101391=>RP-111750 / Text3: LTE
- 221: - / Text3: 36.101, 36.104, 36.133, 36.141, 36.307, new TR 36.8xy (LTE-Advanced CA of Band 4 and Band 13 for the DL/UL with 20 MHz/10 MHz), TR 36.8ab (LTE-Advanced CA of Band 4 and Band 13 for the DL/UL with 20 MHz/20 MHz)
- 222: - / Text3: 36.101, 36.104, 36.133, 36.307
- 223: Stage 3. RP#54 updated WID RP-101435=>RP-111678 / Text3: LTE
- 224: - / Text3: 36.101, 36.104, 36.133, 36.307, new TR 36.8xy (LTE-Advanced CA of Band 4 and Band 13 for the DL/UL with 20 MHz/10 MHz), TR 36.8ab (LTE-Advanced CA of Band 4 and Band 13 for the DL/UL with 20 MHz/20 MHz)
- 225: - / Text3: 36.101, 36.104, 36.133, 36.141, 36.307
- 226: Stage 3. Triggered by Rel-11 UID_500015 Study on HSDPA Multipoint Transmission (FS_HSDPA_MP_TX) / Text3: LTE
- 227: - / Text3: 36.101, 36.104, 36.133, 36.201, 36.211, 36.212, 36.213, 36.300, 36.302, 36.306, 36.321, 36.331, 36.413, 36.423, new TR 36.823
- 228: - / Text3: 36.101, 36.104, 36.133, 36.141
- 229: Stage 3 / Text3: LTE
- 230: - / Text3: 36.101, 36.104, 36.133, 36.141, 36.307, new TR 36.8xy (DL/UL 20/10MHz)
- 231: - / Text3: 36.101, 36.104, 36.133, 36.307

| ID | WBS | Task | Duration | Start | Finish | Complete | Remaining | Baseline start | Baseline finish | Baseline duration | Total slack | Constraint | Resources | Work | Actual work | Text1 | Text2 | Text4 | Text5 | Text6 | Text7 | Text8 | Text11 |
| --- | --- | --- | --- | --- | --- | --- | --- | --- | --- | --- | --- | --- | --- | --- | --- | --- | --- | --- | --- | --- | --- | --- | --- |
| 232 | 81 | **LTE Advanced Carrier Aggregation of Band 5 and Band 12** | 452d? | 2011-03-22 A | 2012-12-07 | 16% | 379.04d? | 2011-03-22 | 2012-12-07 | 452d? | 263d |  | R4,R2 | 10312h | 1664.46h | LTE_CA_B5_B12 | PCG-26 | US Cellular | Sebastian THALANANY | Rel-11 | RP-51 | Issam |  |
| 233 | 81.1 | Core part: LTE Advanced Carrier Aggregation of Band 5 and Band 12 | 386d? | 2011-03-22 A | 2012-09-07 | 35% | 250.9d? | 2011-03-22 | 2012-09-07 | 386d? | 328d | finish no earlier than 2012-09-07 | R4,R2 | 3088h | 1080.8h | LTE_CA_B5_B12-Core | PCG-26 | US Cellular | Sebastian THALANANY | Rel-11 | RP-51 | Issam | RP-120110 |
| 234 | 81.2 | Perf. part: LTE Advanced Carrier Aggregation of Band 5 and Band 12 | 451d? | 2011-03-23 | 2012-12-07 |  |  | 2011-03-23 | 2012-12-07 | 451d? | 263d | finish no earlier than 2012-12-07 | R4 | 3608h |  | LTE_CA_B5_B12-Perf | PCG-26 | US Cellular | Sebastian THALANANY | Rel-11 | RP-51 | Issam | RP-120111 |
| 235 | 82 | **LTE Advanced Carrier Aggregation of Band 7 and Band 20** | 452d? | 2011-03-22 A | 2012-12-07 | 21% | 358.2d? | 2011-03-22 | 2012-12-07 | 452d? | 263d |  | R4 | 10312h | 2140.02h | LTE_CA_B7_B20 | PCG-26 | Huawei | Steven Chen | Rel-11 | RP-51 | Issam |  |
| 236 | 82.1 | Core part: LTE Advanced Carrier Aggregation of Band 7 and Band 20 | 386d? | 2011-03-22 A | 2012-09-07 | 45% | 212.3d? | 2011-03-22 | 2012-09-07 | 386d? | 328d | finish no earlier than 2012-09-07 | R4 | 3088h | 1389.6h | LTE_CA_B7_B20-Core | PCG-26 | Huawei | Steven Chen | Rel-11 | RP-51 | Issam | RP-120112 |
| 237 | 82.2 | Perf. part: LTE Advanced Carrier Aggregation of Band 7 and Band 20 | 451d? | 2011-03-23 | 2012-12-07 |  |  | 2011-03-23 | 2012-12-07 | 451d? | 263d | finish no earlier than 2012-12-07 | R4 | 3608h |  | LTE_CA_B7_B20-Perf | PCG-26 | Huawei | Steven Chen | Rel-11 | RP-51 | Issam | RP-120113 |
| 238 | 83 | **LTE Advanced Carrier Aggregation of Band 2 and Band 17** | 451d? | 2011-03-23 A | 2012-12-07 | 9% | 409.4d? | 2011-03-23 | 2012-12-07 | 451d? | 263d |  | R4 | 10304h | 950.38h | LTE_CA_B2_B17 | PCG-26 | AT&T | marc.grant@att.com | Rel-11 | RP-51 | Issam |  |
| 239 | 83.1 | Core part: LTE Advanced Carrier Aggregation of Band 2 and Band 17 | 386d? | 2011-03-23 A | 2012-09-07 | 20% | 308.8d? | 2011-03-23 | 2012-09-07 | 386d? | 328d | finish no earlier than 2012-09-07 | R4 | 3088h | 617.6h | LTE_CA_B2_B17-Core | PCG-26 | AT&T | marc.grant@att.com | Rel-11 | RP-51 | Issam | RP-120114 |
| 240 | 83.2 | Perf. part: LTE Advanced Carrier Aggregation of Band 2 and Band 17 | 451d? | 2011-03-23 | 2012-12-07 |  |  | 2011-03-23 | 2012-12-07 | 451d? | 263d | finish no earlier than 2012-12-07 | R4 | 3608h |  | LTE_CA_B2_B17-Perf | PCG-26 | AT&T | marc.grant@att.com | Rel-11 | RP-51 | Issam | RP-120115 |
| 241 | 84 | **LTE Advanced Carrier Aggregation of Band 4 and Band 5** | 451d? | 2011-03-23 A | 2012-12-07 | 9% | 409.4d? | 2011-03-23 | 2012-12-07 | 451d? | 263d |  | R4 | 10304h | 950.38h | LTE_CA_B4_B5 | PCG-26 | AT&T | marc.grant@att.com | Rel-11 | RP-51 | Issam |  |
| 242 | 84.1 | Core part: LTE Advanced Carrier Aggregation of Band 4 and Band 5 | 386d? | 2011-03-23 A | 2012-09-07 | 20% | 308.8d? | 2011-03-23 | 2012-09-07 | 386d? | 328d | finish no earlier than 2012-09-07 | R4 | 3088h | 617.6h | LTE_CA_B4_B5-Core | PCG-26 | AT&T | marc.grant@att.com | Rel-11 | RP-51 | Issam | RP-120116 |
| 243 | 84.2 | Perf. part: LTE Advanced Carrier Aggregation of Band 4 and Band 5 | 451d? | 2011-03-23 | 2012-12-07 |  |  | 2011-03-23 | 2012-12-07 | 451d? | 263d | finish no earlier than 2012-12-07 | R4 | 3608h |  | LTE_CA_B4_B5-Perf | PCG-26 | AT&T | marc.grant@att.com | Rel-11 | RP-51 | Issam | RP-120117 |
| 244 | 85 | **LTE Advanced Carrier Aggregation of Band 5 and Band 17** | 451d? | 2011-03-23 A | 2012-12-07 | 9% | 409.4d? | 2011-03-23 | 2012-12-07 | 451d? | 263d |  | R4 | 10304h | 950.38h | LTE_CA_B5_B17 | PCG-26 | AT&T | marc.grant@att.com | Rel-11 | RP-51 | Issam |  |
| 245 | 85.1 | Core part: LTE Advanced Carrier Aggregation of Band 5 and Band 17 | 386d? | 2011-03-23 A | 2012-09-07 | 20% | 308.8d? | 2011-03-23 | 2012-09-07 | 386d? | 328d | finish no earlier than 2012-09-07 | R4 | 3088h | 617.6h | LTE_CA_B5_B17-Core | PCG-26 | AT&T | marc.grant@att.com | Rel-11 | RP-51 | Issam | RP-120118 |
| 246 | 85.2 | Perf. part: LTE Advanced Carrier Aggregation of Band 5 and Band 17 | 451d? | 2011-03-23 | 2012-12-07 |  |  | 2011-03-23 | 2012-12-07 | 451d? | 263d | finish no earlier than 2012-12-07 | R4 | 3608h |  | LTE_CA_B5_B17-Perf | PCG-26 | AT&T | marc.grant@att.com | Rel-11 | RP-51 | Issam | RP-120119 |
| 247 | 86 | **Further Enhanced Non CA-based ICIC for LTE** | 327d? | 2011-03-22 A | 2012-06-15 | 33% | 220.72d? | 2011-03-22 | 2012-06-15 | 327d? | 388d |  | R1,R2,R3,R4 | 7832h | 2545.4h | eICIC_enh_LTE | PCG-26 | China Mobile | Xiaodong Xu (xuxiaodong@chinamobile.com) | Rel-11 | RP-51 | Patrick |  |
| 248 | 86.1 | Core part: Further Enhanced Non CA-based ICIC for LTE | 326d? | 2011-03-22 A | 2012-06-15 | 60% | 130.4d? | 2011-03-22 | 2012-06-15 | 326d? | 388d | finish no earlier than 2012-06-15 | R1,R2,R3,R4 | 2608h | 1564.8h | eICIC_enh_LTE-Core | PCG-26 | China Mobile | Xiaodong Xu (xuxiaodong@chinamobile.com) | Rel-11 | RP-51 | Patrick | RP-120085 |
| 249 | 86.2 | Perf. part: Further Enhanced Non CA-based ICIC for LTE | 326d? | 2011-03-23 A | 2012-06-15 | 5% | 309.7d? | 2011-03-23 | 2012-06-15 | 326d? | 388d | finish no earlier than 2012-06-15 | R4 | 2608h | 130.4h | eICIC_enh_LTE-Perf | PCG-26 | China Mobile | Xiaodong Xu (xuxiaodong@chinamobile.com) | Rel-11 | RP-51 | Issam | RP-120086 |
| 250 | 87 | **New Band LTE Downlink FDD 716-728 MHz** | 452d? | 2011-03-22 A | 2012-12-07 | 9% | 410.25d? | 2011-03-22 | 2012-12-07 | 452d? | 263d |  | R4 | 10320h | 953.18h | LTE_DL_FDD700 | PCG-26 | AT&T | marc.grant@att.com | Rel-11 | RP-51 | Issam |  |
| 251 | 87.1 | Core part: New Band LTE Downlink FDD 716-728 MHz | 387d? | 2011-03-22 A | 2012-09-07 | 20% | 309.6d? | 2011-03-22 | 2012-09-07 | 387d? | 328d | finish no earlier than 2012-09-07 | R4 | 3096h | 619.2h | LTE_DL_FDD700-Core | PCG-26 | AT&T | marc.grant@att.com | Rel-11 | RP-51 | Issam | RP-120120 |
| 252 | 87.2 | Perf. part: New Band LTE Downlink FDD 716-728 MHz | 451d? | 2011-03-23 | 2012-12-07 |  |  | 2011-03-23 | 2012-12-07 | 451d? | 263d | finish no earlier than 2012-12-07 | R4 | 3608h |  | LTE_DL_FDD700-Perf | PCG-26 | AT&T | marc.grant@att.com | Rel-11 | RP-51 | Issam | RP-120121 |
| 253 | 88 | **LTE RAN Enhancements for Diverse Data Applications** | 389d? | 2011-03-18 A | 2012-09-07 | 30% | 272.3d? | 2011-03-18 | 2012-09-07 | 389d? | 328d |  | R2 | 6224h | 1867.2h | LTE_eDDA | PCG-26 | Research In Motion | Gordon Young (gyoung@rim.com) | Rel-11 | RP-51 | Joern |  |
| 254 | 88.1 | Core part: LTE RAN Enhancements for Diverse Data Applications | 389d? | 2011-03-18 A | 2012-09-07 | 30% | 272.3d? | 2011-03-18 | 2012-09-07 | 389d? | 328d | finish no earlier than 2012-09-07 | R2 | 3112h | 933.6h | LTE_eDDA-Core | PCG-26 | Research In Motion | Gordon Young (gyoung@rim.com) | Rel-11 | RP-51 | Joern | RP-120089 |
| 255 | 89 | **LTE E850 - Lower Band for Region 2 (non-US)** | 452d? | 2011-03-22 A | 2012-12-07 | 29% | 319.85d? | 2011-03-22 | 2012-12-07 | 452d? | 263d |  | R1,R2,R4 | 10320h | 3017.18h | LTE_e850_LB | PCG-26 | NII Holdings | bill.shvodian@nii.com | Rel-11 | RP-51 | Patrick |  |
| 256 | 89.1 | Core part: LTE E850 - Lower Band for Region 2 (non-US) | 387d? | 2011-03-22 A | 2012-09-07 | 40% | 232.2d? | 2011-03-22 | 2012-09-07 | 387d? | 328d | finish no earlier than 2012-09-07 | R1,R2,R4 | 3096h | 1238.4h | LTE_e850_LB-Core | PCG-26 | NII Holdings | bill.shvodian@nii.com | Rel-11 | RP-51 | Patrick | RP-120122 |
| 257 | 89.2 | Perf. part: LTE E850 - Lower Band for Region 2 (non-US) | 451d? | 2011-03-23 A | 2012-12-07 | 20% | 360.8d? | 2011-03-23 | 2012-12-07 | 451d? | 263d | finish no earlier than 2012-12-07 | R4 | 3608h | 721.6h | LTE_e850_LB-Perf | PCG-26 | NII Holdings | bill.shvodian@nii.com | Rel-11 | RP-51 | Issam | RP-120123 |

Notes:
- 232: Stage 3 (DL/UL 20/10MHz & (DL/UL 20/20MHz) / Text3: LTE
- 233: RP#55 updated WID RP-110372=>RP-120221 / Text3: 36.101, 36.104, 36.133, 36.141, 36.307, new TR 36.8xy (DL/UL 20/10MHz)
- 234: - / Text3: 36.101, 36.104, 36.133, 36.307
- 235: Stage 3 (DL/UL 30/20MHz; 1 UL active & DL/UL 30/30MHz; 2 UL active) / Text3: LTE
- 236: - / Text3: 36.101, 36.104, 36.133, 36.141, 36.307, 37.104, 37.141, new TR 36.8xy (DL/UL 30/20MHz; 1 UL active)
- 237: - / Text3: 36.101, 36.104, 36.133, 36.141, 36.307
- 238: Stage 3 / Text3: LTE
- 239: - / Text3: 36.101, 36.104, 36.133, 36.141, 36.307, new TR 36.8xy (DL/UL 10/15/20MHz)
- 240: - / Text3: 36.101, 36.104, 36.133, 36.307
- 241: Stage 3 / Text3: LTE
- 242: - / Text3: 36.101, 36.104, 36.133, 36.141, 36.307, new TR 36.8xy (DL/UL 10/15/20MHz)
- 243: - / Text3: 36.101, 36.104, 36.133, 36.307
- 244: Stage 3 / Text3: LTE
- 245: - / Text3: 36.101, 36.104, 36.133, 36.141, 36.307, new TR 36.8xy (DL/UL 10/15/20MHz)
- 246: - / Text3: 36.101, 36.104, 36.133, 36.141, 36.307
- 247: Stage 2/3 / Text3: LTE
- 248: - / Text3: 36.101, 36.133, 36.201, 36.211, 36.212, 36.213, 36.214, 36.300, 36.304, 36.321, 36.331, 36.413, 36.423
- 249: - / Text3: 36.101, 36.104, 36.133, 36.141
- 250: Stage 3 / Text3: LTE
- 251: - / Text3: 36.101, 36.104, 36.141, 36.307
- 252: - / Text3: 36.101, 36.104, 36.133, 36.141, 36.307
- 253: Stage 3 ? RP#55 updated WID RP-111372=>RP-120256 / Text3: LTE
- 254: RP#55 updated WID RP-111372=>RP-120256 / Text3: 36.300, 36.321, 36.331, new TR 36.822
- 255: Stage 3 / Text3: LTE
- 256: RP#55 completion 06/12=>09/12 / Text3: 25.461, 25.466, 36.101, 36.104, 36.113, 36.124, 36.133, 36.307, 36.331
- 257: RP#55 completion 06/12=>12/12 / Text3: 36.101, 36.104, 36.133, 36.141

| ID | WBS | Task | Duration | Start | Finish | Complete | Remaining | Baseline start | Baseline finish | Baseline duration | Total slack | Constraint | Resources | Work | Actual work | Text1 | Text2 | Text4 | Text5 | Text6 | Text7 | Text8 | Text11 |
| --- | --- | --- | --- | --- | --- | --- | --- | --- | --- | --- | --- | --- | --- | --- | --- | --- | --- | --- | --- | --- | --- | --- | --- |
| 258 | 90 | **Carrier based HetNet ICIC for LTE** | 329d? | 2011-03-18 A | 2012-06-15 | 30% | 230.3d? | 2011-03-18 | 2012-06-15 | 329d? | 388d |  | R3,R1,R2 | 5240h | 1572h | LTE_CA_HetNet_ICIC | PCG-26 | Nokia Siemens Networks | krzysztof.kordybach@nsn.com | Rel-11 | RP-51 | Juha |  |
| 259 | 90.1 | Core part: Carrier based HetNet ICIC for LTE | 326d? | 2011-03-18 A | 2012-06-15 | 30% | 228.2d? | 2011-03-18 | 2012-06-15 | 326d? | 388d | finish no earlier than 2012-06-15 | R3,R1,R2 | 2608h | 782.4h | LTE_CA_HetNet_ICIC-Core | PCG-26 | Nokia Siemens Networks | krzysztof.kordybach@nsn.com | Rel-11 | RP-51 | Juha | RP-120090 |
| 260 | 91 | **LTE Advanced Carrier Aggregation in Band 38** | 397d? | 2011-06-07 A | 2012-12-07 | 66% | 133.63d? | 2011-06-07 | 2012-12-07 | 397d? | 263d |  | R4 | 8992h | 5965.39h | LTE_CA_B38 | PCG-27 | Huawei | ronnie.zhang@huawei.com | Rel-11 | RP-52 | Issam |  |
| 261 | 91.1 | Core part: LTE Advanced Carrier Aggregation in Band 38 | 331d? | 2011-06-07 A | 2012-09-07 | 50% | 165.5d? | 2011-06-07 | 2012-09-07 | 331d? | 328d | finish no earlier than 2012-09-07 | R4 | 2648h | 1324h | LTE_CA_B38-Core | PCG-27 | Huawei | ronnie.zhang@huawei.com | Rel-11 | RP-52 | Issam | RP-120124 |
| 262 | 91.2 | Perf. part: LTE Advanced Carrier Aggregation in Band 38 | 396d? | 2011-06-08 A | 2012-12-07 | 80% | 79.2d? | 2011-06-08 | 2012-12-07 | 396d? | 263d | finish no earlier than 2012-12-07 | R4 | 3168h | 2534.4h | LTE_CA_B38-Perf | PCG-27 | Huawei | ronnie.zhang@huawei.com | Rel-11 | RP-52 | Issam | RP-120125 |
| 263 | 92 | **LTE Advanced Carrier Aggregation in Band 41** | 197d? | 2011-06-07 A | 2012-03-02 A | 100% |  | 2011-06-07 | 2012-03-02 | 197d? |  |  | R4 | 4720h | 4720h | LTE_CA_B41 | PCG-27 | Clearwire | michael.hart@clearwire.com | Rel-11 | RP-52 | Issam |  |
| 264 | 92.1 | Core part: LTE Advanced Carrier Aggregation in Band 41 | 196d? | 2011-06-07 A | 2012-03-02 A | 100% |  | 2011-06-07 | 2012-03-02 | 196d? |  | finish no earlier than 2012-02-23 | R4 | 1568h | 1568h | LTE_CA_B41-Core | PCG-27 | Clearwire | michael.hart@clearwire.com | Rel-11 | RP-52 | Issam | RP-120126 |
| 265 | 92.2 | Perf. part: LTE Advanced Carrier Aggregation in Band 41 | 197d? | 2011-06-07 A | 2012-03-02 A | 100% |  | 2011-06-07 | 2012-03-02 | 197d? |  | finish no earlier than 2012-03-02 | R4 | 1576h | 1576h | LTE_CA_B41-Perf | PCG-27 | Clearwire | michael.hart@clearwire.com | Rel-11 | RP-52 | Issam | RP-120127 |
| 266 | 93 | **LTE for 700 MHz Digital Dividend** | 272d? | 2011-06-07 A | 2012-06-15 | 33% | 183.6d? | 2011-06-07 | 2012-06-15 | 272d? | 388d |  | R4,R2,R3 | 6512h | 2116.4h | LTE_APAC700 | PCG-27 | Ericsson | olav.queseth@ericsson.com | Rel-11 | RP-52 | Issam |  |
| 267 | 93.1 | Core part: LTE for 700 MHz Digital Dividend | 271d? | 2011-06-07 A | 2012-06-15 | 65% | 94.85d? | 2011-06-07 | 2012-06-15 | 271d? | 388d | finish no earlier than 2012-06-15 | R4,R2,R3 | 2168h | 1409.2h | LTE_APAC700-Core | PCG-27 | Ericsson | olav.queseth@ericsson.com | Rel-11 | RP-52 | Issam | RP-120128 |
| 268 | 93.2 | Perf. part: LTE for 700 MHz Digital Dividend | 271d? | 2011-06-08 | 2012-06-15 |  |  | 2011-06-08 | 2012-06-15 | 271d? | 388d | finish no earlier than 2012-06-15 | R4 | 2168h |  | LTE_APAC700-Perf | PCG-27 | Ericsson | olav.queseth@ericsson.com | Rel-11 | RP-52 | Issam | RP-120129 |
| 269 | 94 | **Relays for LTE (part 2)** | 724d? | 2009-12-04 A | 2012-09-07 | 74% | 190.92d? | 2009-12-04 | 2012-09-07 | 724d? | 328d |  | R4 | 13728.4h | 10106.3h | LTE_Relay2 | PCG-24 | Ericsson | christian.hoymann@ericsson.com | Rel-11 | RP-46 | Patrick |  |
| 270 | 94.1 | Core part: Relays for LTE (part 2) | 272d? | 2011-06-07 A | 2012-06-15 | 70% | 81.6d? | 2011-06-07 | 2012-06-15 | 272d? | 388d | finish no earlier than 2012-06-15 | R4 | 2168.39h | 1515.59h | LTE_Relay2-Core | PCG-27 | Ericsson | christian.hoymann@ericsson.com | Rel-11 | RP-52 | Issam | RP-120091 |
| 271 | 94.2 | Perf. part: Relays for LTE (part 2) | 721d? | 2009-12-04 A | 2012-09-07 | 75% | 180.25d? | 2009-12-04 | 2012-09-07 | 721d? | 328d | finish no earlier than 2012-09-07 | R4 | 5768h | 4326h | LTE_Relay2-Perf | PCG-24 | Ericsson | christian.hoymann@ericsson.com | Rel-11 | RP-46 | Issam | RP-120092 |
| 272 | 95 | **LTE Advanced Carrier Aggregation of Band 3 and Band 20** | 321d? | 2011-09-19 A | 2012-12-07 | 20% | 256.91d? | 2011-09-19 | 2012-12-07 | 321d? | 263d |  | R4 | 7184h | 1434.31h | LTE_CA_B3_B20 | PCG-27 | Vodafone | tim.frost@vodafone.com | Rel-11 | RP-53 |  |  |
| 273 | 95.1 | Core part: LTE Advanced Carrier Aggregation of Band 3 and Band 20 | 256d? | 2011-09-19 A | 2012-09-07 | 45% | 140.8d? | 2011-09-19 | 2012-09-07 | 256d? | 328d | finish no earlier than 2012-09-07 | R4 | 2048h | 921.6h | LTE_CA_B3_B20-Core | PCG-27 | Vodafone | tim.frost@vodafone.com | Rel-11 | RP-53 |  | RP-120138 |
| 274 | 95.2 | Perf. part: LTE Advanced Carrier Aggregation of Band 3 and Band 20 | 321d? | 2011-09-19 | 2012-12-07 |  |  | 2011-09-19 | 2012-12-07 | 321d? | 263d | finish no earlier than 2012-12-07 | R4 | 2568h |  | LTE_CA_B3_B20-Perf | PCG-27 | Vodafone | tim.frost@vodafone.com | Rel-11 | RP-53 |  | RP-120139 |
| 275 | 96 | **LTE Advanced Carrier Aggregation of Band 8 and Band 20** | 321d? | 2011-09-19 A | 2012-12-07 | 4% | 306.76d? | 2011-09-19 | 2012-12-07 | 321d? | 263d |  | R4 | 7184h | 318.74h | LTE_CA_B8_B20 | PCG-27 | Vodafone | tim.frost@vodafone.com | Rel-11 | RP-53 |  |  |
| 276 | 96.1 | Core part: LTE Advanced Carrier Aggregation of Band 8 and Band 20 | 256d? | 2011-09-19 A | 2012-09-07 | 10% | 230.4d? | 2011-09-19 | 2012-09-07 | 256d? | 328d | finish no earlier than 2012-09-07 | R4 | 2048h | 204.8h | LTE_CA_B8_B20-Core | PCG-27 | Vodafone | tim.frost@vodafone.com | Rel-11 | RP-53 |  | RP-120140 |
| 277 | 96.2 | Perf. part: LTE Advanced Carrier Aggregation of Band 8 and Band 20 | 321d? | 2011-09-19 | 2012-12-07 |  |  | 2011-09-19 | 2012-12-07 | 321d? | 263d | finish no earlier than 2012-12-07 | R4 | 2568h |  | LTE_CA_B8_B20-Perf | PCG-27 | Vodafone | tim.frost@vodafone.com | Rel-11 | RP-53 |  | RP-120141 |
| 278 | 97 | **LTE Advanced Carrier Aggregation of Band 1 and Band 7** | 321d? | 2011-09-19 A | 2012-12-07 | 16% | 271.15d? | 2011-09-19 | 2012-12-07 | 321d? | 263d |  | R4 | 7184h | 1115.57h | LTE_CA_B1_B7 | PCG-27 | China Telecom | Dong Zhao (zhaodong@ctbri.com.cn) | Rel-11 | RP-53 |  |  |
| 279 | 97.1 | Core part: LTE Advanced Carrier Aggregation of Band 1 and Band 7 | 256d? | 2011-09-19 A | 2012-09-07 | 35% | 166.4d? | 2011-09-19 | 2012-09-07 | 256d? | 328d | finish no earlier than 2012-09-07 | R4 | 2048h | 716.8h | LTE_CA_B1_B7-Core | PCG-27 | China Telecom | Dong Zhao (zhaodong@ctbri.com.cn) | Rel-11 | RP-53 |  | RP-120130 |
| 280 | 97.2 | Perf. part: LTE Advanced Carrier Aggregation of Band 1 and Band 7 | 321d? | 2011-09-19 | 2012-12-07 |  |  | 2011-09-19 | 2012-12-07 | 321d? | 263d | finish no earlier than 2012-12-07 | R4 | 2568h |  | LTE_CA_B1_B7-Perf | PCG-27 | China Telecom | Dong Zhao (zhaodong@ctbri.com.cn) | Rel-11 | RP-53 |  | RP-120131 |
| 281 | 98 | **LTE Advanced Carrier Aggregation of Band 3 and Band 5** | 321d? | 2011-09-19 A | 2012-12-07 | 27% | 235.55d? | 2011-09-19 | 2012-12-07 | 321d? | 263d |  | R4 | 7184h | 1912.41h | LTE_CA_B3_B5 | PCG-27 | SK Telecom | Haesung PARK | Rel-11 | RP-53 |  |  |
| 282 | 98.1 | Core part: LTE Advanced Carrier Aggregation of Band 3 and Band 5 | 256d? | 2011-09-19 A | 2012-09-07 | 60% | 102.4d? | 2011-09-19 | 2012-09-07 | 256d? | 328d | finish no earlier than 2012-09-07 | R4 | 2048h | 1228.8h | LTE_CA_B3_B5-Core | PCG-27 | SK Telecom | Haesung PARK | Rel-11 | RP-53 |  | RP-120132 |
| 283 | 98.2 | Perf. part: LTE Advanced Carrier Aggregation of Band 3 and Band 5 | 321d? | 2011-09-19 | 2012-12-07 |  |  | 2011-09-19 | 2012-12-07 | 321d? | 263d | finish no earlier than 2012-12-07 | R4 | 2568h |  | LTE_CA_B3_B5-Perf | PCG-27 | SK Telecom | Haesung PARK | Rel-11 | RP-53 |  | RP-120133 |

Notes:
- 258: Stage 2/3 / Text3: LTE
- 259: - / Text3: 36.300, 36.413, 36.420, 36.423
- 260: Stage 3 / Text3: LTE
- 261: - / Text3: 36.101, 36.104, 36.133, 36.141, 36.307, 37.104, 37.141, new TR 36.830
- 262: - / Text3: 36.101, 36.104, 36.133, 36.141, 36.307, 37.104, 37.141
- 263: RP#55 completed. Stage 3 linked to Rel-10 Carrier Aggregation for LTE UID_460007 / Text3: LTE
- 264: RP#55 completed. Updated WID RP-110673=>RP-120249. TR 36.827 v100 for Information + Approval / Text3: 36.101, 36.104, 36.133, 36.141, 36.307, 37.104, new TR 36.827
- 265: RP#55 completed / Text3: 36.101, 36.104, 36.133, 36.141, 36.307
- 266: Stage 3 Asian Pacific American Caucus (APAC) Asia-Pacific Telecommunity (APT) Wireless Forum (APT/AWF/REP-14 "APT Report on Harmonised Frequency Arrangements for the Band 698-806 MHz", Sep 2010) / Text3: LTE
- 267: RP#55 completion 03/12=>06/12 / Text3: 25.461, 25.466, 36.101, 36.104, 36.113, 36.124, 36.133, 36.307, 37.104, 37.113, new TR 36.820
- 268: RP#55 completion 03/12=>06/12 / Text3: 36.133, 36.141, 37.141
- 269: Continuation of Rel-10 (open RAN4 Core & Perf parts) / Text3: LTE
- 270: RP#55 completion 03/12=>06/12. RP#52 Core part not completed in Rel-10 / Text3: 36.116, 36.133, 36.826
- 271: RP#55 completion 06/12=>09/12. RP#52 transferred completely from Rel-10 UID_460213 / Text3: 36.133, new TS 36.117 (E-UTRA Relay conformance testing)
- 272: Stage 3. RP#55 updated WID RP-111212=>RP-120269 / Text3: LTE
- 273: RP#55 updated WID RP-111212=>RP-120269 / Text3: 36.101, 36.104, 36.133, 36.307, new TR 36.8xy
- 274: - / Text3: 36.101, 36.104, 36.133, 36.141, 36.307
- 275: Stage 3 / Text3: LTE
- 276: - / Text3: 36.101, 36.104, 36.133, 36.307, new TR 36.8xy
- 277: - / Text3: 36.101, 36.104, 36.133, 36.141
- 278: Stage 3 / Text3: LTE
- 279: - / Text3: 36.101, 36.104, 36.113, 36.124, 36.133, 36.307, 37.104, new TR 36.8xy
- 280: - / Text3: 36.101, 36.104, 36.113, 36.124, 36.133, 36.141, 36.307, 37.104, 37.141
- 281: Stage 3. RP#54 updated WID RP-111339=>RP-111603 / Text3: LTE
- 282: RP#54 updated WID RP-111339=>RP-111603 / Text3: 36.101, 36.104, 36.133, 36.307, new TR 36.8xy
- 283: - / Text3: 36.101, 36.104, 36.133, 36.141, 36.307

| ID | WBS | Task | Duration | Start | Finish | Complete | Remaining | Baseline start | Baseline finish | Baseline duration | Total slack | Constraint | Resources | Work | Actual work | Text1 | Text2 | Text4 | Text6 | Text7 | Text11 |
| --- | --- | --- | --- | --- | --- | --- | --- | --- | --- | --- | --- | --- | --- | --- | --- | --- | --- | --- | --- | --- | --- |
| 284 | 99 | **LTE Advanced Carrier Aggregation of Band 4 and Band 7** | 321d? | 2011-09-19 A | 2012-12-07 | 9% | 292.52d? | 2011-09-19 | 2012-12-07 | 321d? | 263d |  | R4 | 7184h | 637.47h | LTE_CA_B4_B7 | PCG-27 | Rogers Wireless | Rel-11 | RP-53 |  |
| 285 | 99.1 | Core part: LTE Advanced Carrier Aggregation of Band 4 and Band 7 | 256d? | 2011-09-19 A | 2012-09-07 | 20% | 204.8d? | 2011-09-19 | 2012-09-07 | 256d? | 328d | finish no earlier than 2012-09-07 | R4 | 2048h | 409.6h | LTE_CA_B4_B7-Core | PCG-27 | Rogers Wireless | Rel-11 | RP-53 | RP-120136 |
| 286 | 99.2 | Perf. part: LTE Advanced Carrier Aggregation of Band 4 and Band 7 | 321d? | 2011-09-19 | 2012-12-07 |  |  | 2011-09-19 | 2012-12-07 | 321d? | 263d | finish no earlier than 2012-12-07 | R4 | 2568h |  | LTE_CA_B4_B7-Perf | PCG-27 | Rogers Wireless | Rel-11 | RP-53 | RP-120137 |
| 287 | 100 | **LTE Advanced Carrier Aggregation in Band 7** | 321d? | 2011-09-19 A | 2012-12-07 | 18% | 264.03d? | 2011-09-19 | 2012-12-07 | 321d? | 263d |  | R4 | 7184h | 1274.94h | LTE_CA_B7 | PCG-27 | China Unicom | Rel-11 | RP-53 |  |
| 288 | 100.1 | Core part: LTE Advanced Carrier Aggregation in Band 7 | 256d? | 2011-09-19 A | 2012-09-07 | 40% | 153.6d? | 2011-09-19 | 2012-09-07 | 256d? | 328d | finish no earlier than 2012-09-07 | R4 | 2048h | 819.2h | LTE_CA_B7-Core | PCG-27 | China Unicom | Rel-11 | RP-53 | RP-120134 |
| 289 | 100.2 | Perf. part: LTE Advanced Carrier Aggregation in Band 7 | 321d? | 2011-09-19 | 2012-12-07 |  |  | 2011-09-19 | 2012-12-07 | 321d? | 263d | finish no earlier than 2012-12-07 | R4 | 2568h |  | LTE_CA_B7-Perf | PCG-27 | China Unicom | Rel-11 | RP-53 | RP-120135 |
| 290 | 101 | **LTE Advanced Carrier Aggregation Intra-Band, Non-Contiguous in Band 25** | 456d? | 2011-09-19 A | 2013-06-14 | 5% | 433.2d? | 2011-09-19 | 2013-06-14 | 456d? | 128d |  | R4 | 10944h | 547.2h | LTE_CA_NC_B25 | PCG-27 | Sprint | Rel-11 | RP-53 |  |
| 291 | 101.1 | Core part: Intra-band, Non-contiguous CA for Band 25 for LTE | 456d? | 2011-09-19 A | 2013-06-14 | 5% | 433.2d? | 2011-09-19 | 2013-06-14 | 456d? | 128d | finish no earlier than 2013-06-14 | R4 | 3648h | 182.4h | LTE_CA_NC_B25-Core | PCG-27 | Sprint | Rel-11 | RP-53 | RP-120142 |
| 292 | 101.2 | Perf. part: Intra-band, Non-contiguous CA for Band 25 for LTE | 456d? | 2011-09-19 A | 2013-06-14 | 5% | 433.2d? | 2011-09-19 | 2013-06-14 | 456d? | 128d | finish no earlier than 2013-06-14 | R4 | 3648h | 182.4h | LTE_CA_NC_B25-Perf | PCG-27 | Sprint | Rel-11 | RP-53 | RP-120143 |
| 293 | 102 | **Signalling and Procedure for Interference Avoidance for in-device coexistence** | 256d? | 2011-09-19 A | 2012-09-07 | 9% | 233.8d? | 2011-09-19 | 2012-09-07 | 256d? | 328d |  | R2,R4 | 5664h | 491.21h | SPIA_IDC_LTE | PCG-27 | China Mobile | Rel-11 | RP-53 |  |
| 294 | 102.1 | Core part: Signalling and Procedure for Interference Avoidance for in-device coexistence | 196d? | 2011-09-19 A | 2012-06-15 | 20% | 156.8d? | 2011-09-19 | 2012-06-15 | 196d? | 388d | finish no earlier than 2012-06-15 | R2,R4 | 1568h | 313.6h | SPIA_IDC_LTE-Core | PCG-27 | China Mobile | Rel-11 | RP-53 | RP-120093 |
| 295 | 102.2 | Perf. part: Signalling and Procedure for Interference Avoidance for in-device coexistence | 256d? | 2011-09-19 | 2012-09-07 |  |  | 2011-09-19 | 2012-09-07 | 256d? | 328d | finish no earlier than 2012-09-07 | R4 | 2048h |  | SPIA_IDC_LTE-Perf | PCG-27 | China Mobile | Rel-11 | RP-53 | RP-120094 |
| 296 | 103 | **Coordinated Multi-Point Operation for LTE** | 321d? | 2011-09-19 A | 2012-12-07 | 13% | 278.27d? | 2011-09-19 | 2012-12-07 | 321d? | 263d |  | R1,R2,R3,R4 | 11800h | 1570.61h | COMP_LTE | PCG-27 | Samsung, Huawei | Rel-11 | RP-53 |  |
| 297 | 103.1 | Core part: Coordinated Multi-Point Operation for LTE – Uplink | 256d? | 2011-09-19 A | 2012-09-07 | 20% | 204.8d? | 2011-09-19 | 2012-09-07 | 256d? | 328d | finish no earlier than 2012-09-07 | R1,R2,R3,R4 | 2048h | 409.6h | COMP_LTE_UL-Core | PCG-27 | Huawei | Rel-11 | RP-53 | RP-120095 |
| 298 | 103.2 | Perf. part: Coordinated Multi-Point Operation for LTE – Uplink | 321d? | 2011-09-19 | 2012-12-07 |  |  | 2011-09-19 | 2012-12-07 | 321d? | 263d | finish no earlier than 2012-12-07 | R4 | 2568h |  | COMP_LTE_UL-Perf | PCG-27 | Huawei | Rel-11 | RP-53 | RP-120096 |
| 299 | 103.3 | Core part: Coordinated Multi-Point Operation for LTE – Downlink | 256d? | 2011-09-19 A | 2012-09-07 | 40% | 153.6d? | 2011-09-19 | 2012-09-07 | 256d? | 328d | finish no earlier than 2012-09-07 | R1,R2,R3,R4 | 2048h | 819.2h | COMP_LTE_DL-Core | PCG-27 | Samsung | Rel-11 | RP-53 | RP-120097 |
| 300 | 103.4 | Perf. part: Coordinated Multi-Point Operation for LTE – Downlink | 321d? | 2011-09-19 | 2012-12-07 |  |  | 2011-09-19 | 2012-12-07 | 321d? | 263d | finish no earlier than 2012-12-07 | R4 | 2568h |  | COMP_LTE_DL-Perf | PCG-27 | Samsung | Rel-11 | RP-53 | RP-120098 |
| 301 | 104 | **Network Energy Saving for E-UTRAN** | 196d? | 2011-09-19 A | 2012-06-15 | 30% | 137.2d? | 2011-09-19 | 2012-06-15 | 196d? | 388d |  | R3 | 3136h | 940.8h | Netw_Energy_LTE | PCG-27 | China Mobile | Rel-11 | RP-53 |  |
| 302 | 104.1 | Core part: Network Energy Saving for E-UTRAN | 196d? | 2011-09-19 A | 2012-06-15 | 30% | 137.2d? | 2011-09-19 | 2012-06-15 | 196d? | 388d | finish no earlier than 2012-06-15 | R3 | 1568h | 470.4h | Netw_Energy_LTE-Core | PCG-27 | China Mobile | Rel-11 | RP-53 | RP-120099 |
| 303 | 105 | **LTE Advanced Carrier Aggregation of Band 11 and Band 18** | 261d? | 2011-12-09 A | 2012-12-07 | 9% | 238.61d? | 2011-12-09 | 2012-12-07 | 261d? | 263d |  | R4,R2 | 5744h | 492.7h | LTE_CA_B11_B18 | PCG-28 | KDDI | Rel-11 | RP-54 |  |
| 304 | 105.1 | Core part: LTE Advanced Carrier Aggregation of Band 11 and Band 18 | 196d? | 2011-12-09 A | 2012-09-07 | 20% | 156.8d? | 2011-12-09 | 2012-09-07 | 196d? | 328d | finish no earlier than 2012-09-07 | R4,R2 | 1568h | 313.6h | LTE_CA_B11_B18-Core | PCG-28 | KDDI | Rel-11 | RP-54 | RP-120144 |
| 305 | 105.2 | Perf. part: LTE Advanced Carrier Aggregation of Band 11 and Band 18 | 261d? | 2011-12-09 | 2012-12-07 |  |  | 2011-12-09 | 2012-12-07 | 261d? | 263d | finish no earlier than 2012-12-07 | R4 | 2088h |  | LTE_CA_B11_B18-Perf | PCG-28 | KDDI | Rel-11 | RP-54 | RP-120145 |
| 306 | 106 | **LTE Advanced Carrier Aggregation of Band 1 and Band 18** | 261d? | 2011-12-09 A | 2012-12-07 | 9% | 238.61d? | 2011-12-09 | 2012-12-07 | 261d? | 263d |  | R4,R2 | 5744h | 492.7h | LTE_CA_B1_B18 | PCG-28 | KDDI | Rel-11 | RP-54 |  |
| 307 | 106.1 | Core part: LTE Advanced Carrier Aggregation of Band 1 and Band 18 | 196d? | 2011-12-09 A | 2012-09-07 | 20% | 156.8d? | 2011-12-09 | 2012-09-07 | 196d? | 328d | finish no earlier than 2012-09-07 | R4,R2 | 1568h | 313.6h | LTE_CA_B1_B18-Core | PCG-28 | KDDI | Rel-11 | RP-54 | RP-120146 |
| 308 | 106.2 | Perf. part: LTE Advanced Carrier Aggregation of Band 1 and Band 18 | 261d? | 2011-12-09 | 2012-12-07 |  |  | 2011-12-09 | 2012-12-07 | 261d? | 263d | finish no earlier than 2012-12-07 | R4 | 2088h |  | LTE_CA_B1_B18-Perf | PCG-28 | KDDI | Rel-11 | RP-54 | RP-120147 |

Notes:
- 284: Stage 3 / Text3: LTE / Text5: put.ng@rci.rogers.com
- 285: - / Text3: 36.101, 36.104, 36.133, 36.141, 36.307, 37.104, new TR 36.8xy / Text5: put.ng@rci.rogers.com
- 286: - / Text3: 36.101, 36.104, 36.133, 36.141, 36.307 / Text5: put.ng@rci.rogers.com
- 287: Stage 3 / Text3: LTE / Text5: Zhangchao Ma (mazc@chinaunicom.cn), Zhonghao Zhang (zhangzh306@chinaunicom.cn)
- 288: - / Text3: 36.101, 36.104, 36.133, 36.141, 36.307, 37.104, 37.141, new TR 36.831 / Text5: Zhangchao Ma (mazc@chinaunicom.cn), Zhonghao Zhang (zhangzh306@chinaunicom.cn)
- 289: - / Text3: 36.101, 36.104, 36.133, 36.141, 36.307, 37.104, 37.141 / Text5: Zhangchao Ma (mazc@chinaunicom.cn), Zhonghao Zhang (zhangzh306@chinaunicom.cn)
- 290: Stage 3. RP#55 updated WID RP-111371=>RP-120366 / Text3: LTE / Text5: George.Cummings@sprint.com
- 291: RP#55 updated WID RP-111371=>RP-120366 / Text3: 36.101, 36.104, 36.133, 36.141, 36.307, new TR 36.841 / Text5: George.Cummings@sprint.com
- 292: RP#55 updated WID RP-111371=>RP-120366 / Text3: 36.101, 36.104, 36.133, 36.141, 36.307 / Text5: George.Cummings@sprint.com
- 293: Stage 2,3 / Text3: LTE / Text5: Zhenping HU
- 294: - / Text3: 36.133, 36.300, 36.306, 36.321, 36.331 / Text5: Zhenping HU
- 295: - / Text3: 36.133 / Text5: Zhenping HU
- 296: Stage 3. Triggered by Rel-11 TR 36.819 Study on Coordinated Multi-Point Operation for LTE (FS_CoMP_LTE) / Text3: LTE / Text5: Juho Lee (juho95.lee@samsung.com), david.mazzarese@huawei.com
- 297: - / Text3: 36.101, 36.104, 36.133, 36.201, 36.211, 36.212, 36.213, 36.214, 36.300, 36.306, 36.321, 36.331, 36.423 / Text5: david.mazzarese@huawei.com
- 298: - / Text3: 36.101, 36.104, 36.133, 36.141 / Text5: Xinwei Zhi (zhixinwei@huawei.com)
- 299: - / Text3: 36.101, 36.104, 36.133, 36.201, 36.211, 36.212, 36.213, 36.214, 36.300, 36.306, 36.321, 36.331, 36.423 / Text5: Juho Lee (juho95.lee@samsung.com)
- 300: - / Text3: 36.101, 36.104, 36.133, 36.141, 36.307 / Text5: xutao.zhou@samsung.com
- 301: Stage 2,3 / Text3: LTE / Text5: YANG Ning (yangning@chinamobile.com)
- 302: RP#55 completion 03/12=>06/12. Inter-RAT aspect can affect UTRA and GERAN as well / Text3: 25.413, 36.300, 36.413, 36.423 / Text5: YANG Ning (yangning@chinamobile.com)
- 303: Stage 3 / Text3: LTE / Text5: Masaaki Obara
- 304: - / Text3: 36.101, 36.104, 36.133, 36.307, new TR 36.8xy (2DL/1UL, 2DL/2UL) / Text5: Masaaki Obara
- 305: - / Text3: 36.101, 36.104, 36.133, 36.141, 36.307 / Text5: Masaaki Obara
- 306: Stage 3 / Text3: LTE / Text5: Masaaki Obara
- 307: - / Text3: 36.101, 36.104, 36.133, 36.307, new TR 36.8xy (2DL/1UL, 2DL/2UL) / Text5: Masaaki Obara
- 308: - / Text3: 36.101, 36.104, 36.133, 36.141, 36.307 / Text5: Masaaki Obara

| ID | WBS | Task | Duration | Start | Finish | Complete | Remaining | Baseline start | Baseline finish | Baseline duration | Total slack | Constraint | Resources | Work | Actual work | Text1 | Text2 | Text4 | Text5 | Text6 | Text7 | Text11 |
| --- | --- | --- | --- | --- | --- | --- | --- | --- | --- | --- | --- | --- | --- | --- | --- | --- | --- | --- | --- | --- | --- | --- |
| 309 | 107 | **LTE Advanced Carrier Aggregation of Band 1 and Band 19** | 261d? | 2011-12-09 A | 2012-12-07 | 34% | 171.45d? | 2011-12-09 | 2012-12-07 | 261d? | 263d |  | R4,R2 | 5744h | 1970.81h | LTE_CA_B1_B19 | PCG-28 | NTT DoCoMo | Hiromasa Umeda (umedah@nttdocomo.co.jp) | Rel-11 | RP-54 |  |
| 310 | 107.1 | Core part: LTE Advanced Carrier Aggregation of Band 1 and Band 19 | 196d? | 2011-12-09 A | 2012-09-07 | 80% | 39.2d? | 2011-12-09 | 2012-09-07 | 196d? | 328d | finish no earlier than 2012-09-07 | R4,R2 | 1568h | 1254.4h | LTE_CA_B1_B19-Core | PCG-28 | NTT DoCoMo | Hiromasa Umeda (umedah@nttdocomo.co.jp) | Rel-11 | RP-54 | RP-120148 |
| 311 | 107.2 | Perf. part: LTE Advanced Carrier Aggregation of Band 1 and Band 19 | 261d? | 2011-12-09 | 2012-12-07 |  |  | 2011-12-09 | 2012-12-07 | 261d? | 263d | finish no earlier than 2012-12-07 | R4 | 2088h |  | LTE_CA_B1_B19-Perf | PCG-28 | NTT DoCoMo | Hiromasa Umeda (umedah@nttdocomo.co.jp) | Rel-11 | RP-54 | RP-120149 |
| 312 | 108 | **LTE Advanced Carrier Aggregation of Band 1 and Band 21** | 261d? | 2011-12-09 A | 2012-12-07 | 9% | 238.61d? | 2011-12-09 | 2012-12-07 | 261d? | 263d |  | R4,R2 | 5744h | 492.7h | LTE_CA_B1_B21 | PCG-28 | NTT DoCoMo | Hiromasa Umeda (umedah@nttdocomo.co.jp) | Rel-11 | RP-54 |  |
| 313 | 108.1 | Core part: LTE Advanced Carrier Aggregation of Band 1 and Band 21 | 196d? | 2011-12-09 A | 2012-09-07 | 20% | 156.8d? | 2011-12-09 | 2012-09-07 | 196d? | 328d | finish no earlier than 2012-09-07 | R4,R2 | 1568h | 313.6h | LTE_CA_B1_B21-Core | PCG-28 | NTT DoCoMo | Hiromasa Umeda (umedah@nttdocomo.co.jp) | Rel-11 | RP-54 | RP-120150 |
| 314 | 108.2 | Perf. part: LTE Advanced Carrier Aggregation of Band 1 and Band 21 | 261d? | 2011-12-09 | 2012-12-07 |  |  | 2011-12-09 | 2012-12-07 | 261d? | 263d | finish no earlier than 2012-12-07 | R4 | 2088h |  | LTE_CA_B1_B21-Perf | PCG-28 | NTT DoCoMo | Hiromasa Umeda (umedah@nttdocomo.co.jp) | Rel-11 | RP-54 | RP-120151 |
| 315 | 109 | **Enhanced downlink control channel(s) for LTE Advanced** | 331d? | 2011-12-09 A | 2013-03-15 | 5% | 315.85d? | 2011-12-09 | 2013-03-15 | 331d? | 193d |  | R1,R2,R4 | 6864h | 314.15h | LTE_enh_dl_ctrl | PCG-28 | Alcatel-Lucent | sigen.ye@alcatel-lucent.com | Rel-11 | RP-54 |  |
| 316 | 109.1 | Core part: Enhanced downlink control channel(s) for LTE Advanced | 196d? | 2011-12-09 A | 2012-09-07 | 12% | 171.88d? | 2011-12-09 | 2012-09-07 | 196d? | 328d | finish no earlier than 2012-09-07 | R1,R2,R4 | 1568h | 192.96h | LTE_enh_dl_ctrl-Core | PCG-28 | Alcatel-Lucent | sigen.ye@alcatel-lucent.com | Rel-11 | RP-54 | RP-120100 |
| 317 | 109.2 | Perf. part: Enhanced downlink control channel(s) for LTE Advanced | 331d? | 2011-12-09 | 2013-03-15 |  |  | 2011-12-09 | 2013-03-15 | 331d? | 193d | finish no earlier than 2013-03-15 | R4 | 2648h |  | LTE_enh_dl_ctrl-Perf | PCG-28 | Alcatel-Lucent | teck.hu@alcatel-lucent.com | Rel-11 | RP-54 | RP-120101 |
| 318 | 110 | **LTE Advanced Carrier Aggregation of Band 3 and Band 5 with 2UL** | 336d? | 2012-03-02 | 2013-06-14 |  |  | 2012-03-02 | 2013-06-14 | 336d? | 128d |  | R4 | 7544h |  | LTE_CA_B3_B5_2UL | PCG-28 | SK Telecom | Seungpyo Hong | Rel-11 | RP-55 |  |
| 319 | 110.1 | Core part: LTE Advanced Carrier Aggregation of Band 3 and Band 5 with 2UL | 271d? | 2012-03-02 | 2013-03-15 |  |  | 2012-03-02 | 2013-03-15 | 271d? | 193d | finish no earlier than 2013-03-15 | R4 | 2168h |  | LTE_CA_B3_B5_2UL-Core | PCG-28 | SK Telecom | Seungpyo Hong | Rel-11 | RP-55 |  |
| 320 | 110.2 | Perf. part: LTE Advanced Carrier Aggregation of Band 3 and Band 5 with 2UL | 336d? | 2012-03-02 | 2013-06-14 |  |  | 2012-03-02 | 2013-06-14 | 336d? | 128d | finish no earlier than 2013-06-14 | R4 | 2688h |  | LTE_CA_B3_B5_2UL-Perf | PCG-28 | SK Telecom | Seungpyo Hong | Rel-11 | RP-55 |  |
| 321 | 111 | **Intra-band, Non-contiguous CA for Band 3 for LTE Advanced** | 336d? | 2012-03-02 | 2013-06-14 |  |  | 2012-03-02 | 2013-06-14 | 336d? | 128d |  | R4 | 7544h |  | LTE_CA_NC_B3 | PCG-28 | SK Telecom | Haesung PARK | Rel-11 | RP-55 |  |
| 322 | 111.1 | Core part: Intra-band, Non-contiguous CA for Band 3 for LTE Advanced | 271d? | 2012-03-02 | 2013-03-15 |  |  | 2012-03-02 | 2013-03-15 | 271d? | 193d | finish no earlier than 2013-03-15 | R4 | 2168h |  | LTE_CA_NC_B3-Core | PCG-28 | SK Telecom | Haesung PARK | Rel-11 | RP-55 |  |
| 323 | 111.2 | Perf. part: Intra-band, Non-contiguous CA for Band 3 for LTE Advanced | 336d? | 2012-03-02 | 2013-06-14 |  |  | 2012-03-02 | 2013-06-14 | 336d? | 128d | finish no earlier than 2013-06-14 | R4 | 2688h |  | LTE_CA_NC_B3-Perf | PCG-28 | SK Telecom | Haesung PARK | Rel-11 | RP-55 |  |
| 324 | 112 | **Public Safety Broadband High Power UE for Band 14 for Region 2** | 201d? | 2012-03-02 | 2012-12-07 |  |  | 2012-03-02 | 2012-12-07 | 201d? | 263d |  | R4 | 3216h |  | LTE_B14_PSBB_HPUE | PCG-28 | Motorola Solutions | xiaowei.jin@motorolasolutions.com | Rel-11 | RP-55 |  |
| 325 | 112.1 | Core part: Public Safety Broadband High Power UE for Band 14 for Region 2 | 201d? | 2012-03-02 | 2012-12-07 |  |  | 2012-03-02 | 2012-12-07 | 201d? | 263d | finish no earlier than 2012-12-07 | R4 | 1608h |  | LTE_B14_PSBB_HPUE-Core | PCG-28 | Motorola Solutions | xiaowei.jin@motorolasolutions.com | Rel-11 | RP-55 |  |
| 326 | 113 | **Improved Minimum Performance Requirements for E-UTRA: Interference Rejection** | 201d? | 2012-03-02 | 2012-12-07 |  |  | 2012-03-02 | 2012-12-07 | 201d? | 263d |  | R4 | 3216h |  | LTE_Interf_Rej | PCG-28 | Renesas Mobile | Timo Roman | Rel-11 | RP-55 |  |
| 327 | 113.1 | Perf. part: Improved Minimum Performance Requirements for E-UTRA: Interference Rejection | 201d? | 2012-03-02 | 2012-12-07 |  |  | 2012-03-02 | 2012-12-07 | 201d? | 263d | finish no earlier than 2012-12-07 | R4 | 1608h |  | LTE_Interf_Rej-Perf | PCG-28 | Renesas Mobile | Timo Roman | Rel-11 | RP-55 |  |
| 328 | 114 | **Additional special subframe configuration for LTE TDD** | 76d? | 2012-03-02 | 2012-06-15 |  |  | 2012-03-02 | 2012-06-15 | 76d? | 388d |  | R4,R2,R3 | 1216h |  | LTE_TDD_add_subframe | PCG-28 | China Mobile | Xiaodong Shen | Rel-11 | RP-55 |  |
| 329 | 114.1 | Core part: Additional special subframe configuration for LTE TDD | 76d? | 2012-03-02 | 2012-06-15 |  |  | 2012-03-02 | 2012-06-15 | 76d? | 388d | finish no earlier than 2012-06-15 | R4,R2,R3 | 608h |  | LTE_TDD_add_subframe-Core | PCG-28 | China Mobile | Xiaodong Shen | Rel-11 | RP-55 |  |
| 330 | 115 | **LTE in the 1670-1675 MHz Band for US** | 271d? | 2012-03-02 | 2013-03-15 |  |  | 2012-03-02 | 2013-03-15 | 271d? | 193d |  | R4,R2,R3 | 5944h |  | LTE_FDD_1670_US | PCG-28 | LightSquared | Masoud.Olfat@LightSquared.com | Rel-11 | RP-55 |  |
| 331 | 115.1 | Core part: LTE in the 1670-1675 MHz Band for US | 201d? | 2012-03-02 | 2012-12-07 |  |  | 2012-03-02 | 2012-12-07 | 201d? | 263d | finish no earlier than 2012-12-07 | R4,R2,R3 | 1608h |  | LTE_FDD_1670_US-Core | PCG-28 | LightSquared | Masoud.Olfat@LightSquared.com | Rel-11 | RP-55 |  |
| 332 | 115.2 | Perf. part: LTE in the 1670-1675 MHz Band for US | 271d? | 2012-03-02 | 2013-03-15 |  |  | 2012-03-02 | 2013-03-15 | 271d? | 193d | finish no earlier than 2013-03-15 | R4 | 2168h |  | LTE_FDD_1670_US-Perf | PCG-28 | LightSquared | Masoud.Olfat@LightSquared.com | Rel-11 | RP-55 |  |

Notes:
- 309: Stage 3 / Text3: LTE
- 310: - / Text3: 36.101, 36.104, 36.133, 36.307, new TR 36.8xy
- 311: - / Text3: 36.133, 36.141
- 312: Stage 3 / Text3: LTE
- 313: - / Text3: 36.101, 36.104, 36.133, 36.307, new TR 36.8xy
- 314: - / Text3: 36.133, 36.141
- 315: Stage 3. Triggered by UID_510037 Rel-11 TR 36.871 Study on further Downlink MIMO enhancements for LTE-Advanced (FS_LTE_eDL_MIMO_enh) / Text3: LTE
- 316: - / Text3: 36.101, 36.211, 36.212, 36.213, 36.331
- 317: - / Text3: 36.101, 36.104, 36.133, 36.141
- 318: Stage 3. Exists already for 1UL a WI LTE_CA_B3_B5 / Text3: LTE
- 319: - / Text3: 36.101, 36.104, 36.133, 36.307, new TR 36.8ab
- 320: - / Text3: 36.101, 36.104, 36.133, 36.141, 36.307
- 321: Stage 3 / Text3: LTE
- 322: - / Text3: 36.101, 36.104, 36.133, 36.307, new TR 36.8ab
- 323: - / Text3: 36.101, 36.104, 36.133, 36.141, 36.307
- 324: Stage 3 / Text3: LTE
- 325: - / Text3: 36.101, new TR 36.837
- 326: Triggered by FS_enh_perf_UE_LTE. Adds Perf. requirements for demodulation of the already specified PDSCH with the transmission modes defined in Rel-8 to Rel-10 / Text3: LTE
- 327: - / Text3: 36.101
- 328: Stage 3. Exists already for 1UL a WI LTE_CA_B3_B5 / Text3: LTE
- 329: - / Text3: 36.211, 36.213, 36.331, 36.423
- 330: LTE / Text3: LTE
- 331: - / Text3: 25.101, 25.104, 25.113, 25.133, 25.306, 25.307, 25.331, 25.461, 25.466, 34.124, 36.101, 36.104, 36.113, 36.124, 36.133, 36.307, new TR 36.8xy (LTE in 1670-1675 MHz Band for US)
- 332: - / Text3: 25.133, 25.306, 25.307, 25.331, 25.461, 25.466, 34.124, 36.113, 36.124, 36.133, 36.141, 36.307

| ID | WBS | Task | Duration | Start | Finish | Complete | Remaining | Baseline start | Baseline finish | Baseline duration | Total slack | Constraint | Resources | Work | Actual work | Text1 | Text2 | Text4 | Text5 | Text6 | Text7 | Text8 | Text11 |
| --- | --- | --- | --- | --- | --- | --- | --- | --- | --- | --- | --- | --- | --- | --- | --- | --- | --- | --- | --- | --- | --- | --- | --- |
| 333 | 116 | **LTE Advanced Carrier Aggregation of Band 3 and Band 8** | 336d? | 2012-03-02 | 2013-06-14 |  |  | 2012-03-02 | 2013-06-14 | 336d? | 128d |  | R4 | 7544h |  | LTE_CA_B3_B8 | PCG-28 | KT | Chungwoo HWANG (cwhwang@kt.com) | Rel-11 | RP-55 |  |  |
| 334 | 116.1 | Core part: LTE Advanced Carrier Aggregation of Band 3 and Band 8 | 271d? | 2012-03-02 | 2013-03-15 |  |  | 2012-03-02 | 2013-03-15 | 271d? | 193d | finish no earlier than 2013-03-15 | R4 | 2168h |  | LTE_CA_B3_B8-Core | PCG-28 | KT | Chungwoo HWANG (cwhwang@kt.com) | Rel-11 | RP-55 |  |  |
| 335 | 116.2 | Perf. part: LTE Advanced Carrier Aggregation of Band 3 and Band 8 | 336d? | 2012-03-02 | 2013-06-14 |  |  | 2012-03-02 | 2013-06-14 | 336d? | 128d | finish no earlier than 2013-06-14 | R4 | 2688h |  | LTE_CA_B3_B8-Perf | PCG-28 | KT | Chungwoo HWANG (cwhwang@kt.com) | Rel-11 | RP-55 |  |  |
| 336 | 117 | **UE Over The Air (Antenna) conformance testing methodology - Laptop mounted equipment Free Space test** | 719d? | 2009-09-18 A | 2012-06-15 | 90% | 68.45d? | 2009-09-18 | 2012-06-15 | 719d? | 388d |  | R4,R5 | 12584h | 11386h | UEAnt_FSTest | PCG-23 | CATR | Guo Lin (guolin@emcite.com) | Rel-11 | RP-45 | Issam |  |
| 337 | 117.1 | Core part: UE Over The Air (Antenna) conformance testing methodology - Laptop mounted equipment Free Space test | 583d? | 2009-09-18 A | 2011-12-09 A | 100% |  | 2009-09-18 | 2011-12-09 | 583d? |  | finish no earlier than 2011-12-09 | R4 | 4664h | 4664h | UEAnt_FSTest | PCG-23 | CATR | Guo Lin (guolin@emcite.com) | Rel-11 | RP-45 | Issam | RP-111456 |
| 338 | 117.2 | Test part: UE Over The Air (Antenna) conformance testing methodology - Laptop mounted equipment Free Space test | 271d? | 2011-06-07 A | 2012-06-15 | 70% | 81.3d? | 2011-06-07 | 2012-06-15 | 271d? | 388d | finish no earlier than 2012-06-15 | R5 | 2168h | 1517.6h | UEAnt_FSTest-UEConTest | PCG-27 | ZTE | carolyn.tayl@zte.com.cn | Rel-11 | RP-52 | Ingbert | RP-120051 |
| 339 | 118 | **Eight carrier HSDPA** | 524d? | 2010-12-10 A | 2012-12-07 | 40% | 316.51d? | 2010-12-10 | 2012-12-07 | 524d? | 263d |  | R1,R2,R3,R4 | 11528h | 2924h | 8C_HSDPA | PCG-26 | Ericsson | johan.hultell@ericsson.com | Rel-11 | RP-50 | Patrick |  |
| 340 | 118.1 | Core part: Eight carrier HSDPA | 397d? | 2010-12-10 A | 2012-06-15 | 85% | 59.55d? | 2010-12-10 | 2012-06-15 | 397d? | 388d | finish no earlier than 2012-06-15 | R1,R2,R3,R4 | 3168h | 2691.6h | 8C_HSDPA-Core | PCG-26 | Ericsson | johan.hultell@ericsson.com | Rel-11 | RP-50 | Patrick | RP-120055 |
| 341 | 118.2 | Perf. part: Eight carrier HSDPA | 521d? | 2010-12-15 A | 2012-12-07 | 5% | 494.95d? | 2010-12-15 | 2012-12-07 | 521d? | 263d | finish no earlier than 2012-12-07 | R4 | 4168h | 208.4h | 8C_HSDPA-Perf | PCG-26 | Ericsson | johan.hultell@ericsson.com | Rel-11 | RP-50 | Issam | RP-120056 |
| 342 | 119 | **UE demodulation performance requirements under multiple-cell scenario for 1.28Mcps TDD** | 324d? | 2010-12-10 A | 2012-03-02 A | 100% |  | 2010-12-10 | 2012-03-02 | 324d? |  |  | R4,R5 | 3552h | 3552h | LCR_TDD_UE_demod_mc | PCG-26 | China Mobile | Li Nan (linan@chinamobile.com) | Rel-11 | RP-50 | Issam |  |
| 343 | 119.1 | Perf. part: UE demodulation performance requirements under multiple-cell scenario for 1.28Mcps TDD | 201d? | 2010-12-10 A | 2011-09-16 A | 100% |  | 2010-12-10 | 2011-09-16 | 201d? |  | finish no earlier than 2011-09-16 | R4 | 1608h | 1608h | LCR_TDD_UE_demod_mc-Perf | PCG-26 | China Mobile | Li Nan (linan@chinamobile.com) | Rel-11 | RP-50 | Issam | RP-110996 |
| 344 | 119.2 | Test part: UE demodulation performance requirements under multiple-cell scenario for 1.28Mcps TDD | 121d? | 2011-09-19 A | 2012-03-02 A | 100% |  | 2011-09-19 | 2012-03-02 | 121d? |  | finish no earlier than 2012-02-23 | R5 | 968h | 968h | LCR_TDD_UE_demod_mc-UEConTest | PCG-27 | China Mobile | Ma Shuai (mashuai@chinamobile.com) | Rel-11 | RP-53 |  | RP-120052 |
| 345 | 120 | **Uplink Transmit Diversity for HSPA** | 459d? | 2010-12-10 A | 2012-09-07 | 73% | 124.89d? | 2010-12-10 | 2012-09-07 | 459d? | 328d |  | R1,R4,R2,R3 | 17312h | 12597.9h | HSPA_UL_TxDiv | PCG-26 | Huawei | zongjie.wang@huawei.com | Rel-11 | RP-50 | Patrick |  |
| 346 | 120.1 | Core part: Uplink Transmit Diversity for HSPA - Closed Loop | 397d? | 2010-12-10 A | 2012-06-15 | 90% | 39.7d? | 2010-12-10 | 2012-06-15 | 397d? | 388d | finish no earlier than 2012-03-02 | R1,R4,R2,R3 | 3168h | 2850.4h | HSPA_UL_TxDiv-CL-Core | PCG-26 | Huawei | zongjie.wang@huawei.com | Rel-11 | RP-50 | Patrick | RP-120333 |
| 347 | 120.2 | Perf. part: Uplink Transmit Diversity for HSPA - Closed Loop | 457d? | 2010-12-14 A | 2012-09-07 | 60% | 182.8d? | 2010-12-14 | 2012-09-07 | 457d? | 328d | finish no earlier than 2012-09-07 | R4 | 3648h | 2186.22h | HSPA_UL_TxDiv-CL-Perf | PCG-26 | Huawei | zongjie.wang@huawei.com | Rel-11 | RP-50 | Issam | RP-120333 |
| 348 | 120.3 | Core part: Uplink Transmit Diversity for HSPA - Open Loop | 397d? | 2010-12-10 A | 2012-06-15 | 85% | 59.55d? | 2010-12-10 | 2012-06-15 | 397d? | 388d | finish no earlier than 2012-06-15 | R4,R1,R2,R3 | 3176h | 2699.6h | HSPA_UL_TxDiv-OL-Core | PCG-26 | Huawei | zongjie.wang@huawei.com | Rel-11 | RP-50 | Patrick | RP-120059 |
| 349 | 120.4 | Perf. part: Uplink Transmit Diversity for HSPA - Open Loop | 456d? | 2010-12-14 A | 2012-09-07 | 60% | 182.4d? | 2010-12-14 | 2012-09-07 | 456d? | 328d | finish no earlier than 2012-09-07 | R4 | 3648h | 2188.8h | HSPA_UL_TxDiv-OL-Perf | PCG-26 | Huawei | zongjie.wang@huawei.com | Rel-11 | RP-50 | Issam | RP-120060 |
| 350 | 121 | **Introduction of New Configuration for 4C-HSDPA** | 327d? | 2011-03-22 A | 2012-06-15 | 37% | 206.19d? | 2011-03-22 | 2012-06-15 | 327d? | 388d |  | R4,R2 | 6752h | 2494.45h | 4C_HSDPA_Config | PCG-26 | Telus Communications | jorge.delrio@telus.com | Rel-11 | RP-51 | Issam |  |
| 351 | 121.1 | Core part: Introduction of New Configuration for 4C-HSDPA | 191d? | 2011-03-22 A | 2011-12-09 A | 100% |  | 2011-03-22 | 2011-12-09 | 191d? |  | finish no earlier than 2011-12-09 | R4,R2 | 1528h | 1528h | 4C_HSDPA_Config-Core | PCG-26 | Telus Communications | jorge.delrio@telus.com | Rel-11 | RP-51 | Issam | RP-111463 |
| 352 | 121.2 | Perf. part: Introduction of New Configuration for 4C-HSDPA | 326d? | 2011-03-23 | 2012-06-15 |  |  | 2011-03-23 | 2012-06-15 | 326d? | 388d | finish no earlier than 2012-06-15 | R4 | 2608h |  | 4C_HSDPA_Config-Perf | PCG-26 | Telus Communications | jorge.delrio@telus.com | Rel-11 | RP-51 | Issam | RP-120061 |
| 353 | 122 | **Non-contiguous 4C-HSDPA operation** | 452d? | 2011-03-22 A | 2012-12-07 | 28% | 325.1d? | 2011-03-22 | 2012-12-07 | 452d? | 263d |  | R4,R2,R3 | 9832h | 2760.43h | NC_4C_HSDPA | PCG-26 | Ericsson | muhammad.kazmi@ericsson.com | Rel-11 | RP-51 | Issam |  |
| 354 | 122.1 | Core part: Non-contiguous 4C-HSDPA operation | 326d? | 2011-03-22 A | 2012-06-15 | 60% | 130.4d? | 2011-03-22 | 2012-06-15 | 326d? | 388d | finish no earlier than 2012-06-15 | R4,R2,R3 | 2608h | 1564.8h | NC_4C_HSDPA-Core | PCG-26 | Ericsson | muhammad.kazmi@ericsson.com | Rel-11 | RP-51 | Issam | RP-120062 |
| 355 | 122.2 | Perf. part: Non-contiguous 4C-HSDPA operation | 451d? | 2011-03-23 A | 2012-12-07 | 5% | 428.45d? | 2011-03-23 | 2012-12-07 | 451d? | 263d | finish no earlier than 2012-12-07 | R4 | 3608h | 180.4h | NC_4C_HSDPA-Perf | PCG-26 | Ericsson | muhammad.kazmi@ericsson.com | Rel-11 | RP-51 | Issam | RP-120063 |
| 356 | 123 | **Further Enhancements to CELL_FACH** | 454d? | 2011-03-18 A | 2012-12-07 | 18% | 370.19d? | 2011-03-18 | 2012-12-07 | 454d? | 263d |  | R1,R2,R3,R4 | 9848h | 1818.01h | Cell_FACH_enh | PCG-26 | Qualcomm | Ravi Agarwal | Rel-11 | RP-51 | Patrick |  |
| 357 | 123.1 | Core part: Further Enhancements to CELL_FACH | 326d? | 2011-03-18 A | 2012-06-15 | 44% | 182.56d? | 2011-03-18 | 2012-06-15 | 326d? | 388d | finish no earlier than 2012-06-15 | R2,R1,R3,R4 | 2608h | 1147.52h | Cell_FACH_enh-Core | PCG-26 | Qualcomm | Ravi Agarwal | Rel-11 | RP-51 | Joern | RP-120064 |
| 358 | 123.2 | Perf. part: Further Enhancements to CELL_FACH | 451d? | 2011-03-23 | 2012-12-07 |  |  | 2011-03-23 | 2012-12-07 | 451d? | 263d | finish no earlier than 2012-12-07 | R4 | 3608h |  | Cell_FACH_enh-Perf | PCG-26 | Qualcomm | Heechoon Lee | Rel-11 | RP-51 | Issam | RP-120065 |

Notes:
- 333: Stage 3 / Text3: LTE
- 334: - / Text3: 36.101, 36.104, 36.133, 36.307, new TR 36.8xy
- 335: - / Text3: 36.133, 36.141
- 336: RP#54 Core completed / Text3: UTRA
- 337: RP#54 completed / Text3: 25.144, 25.914, 34.114
- 338: - / Text3: 34.114
- 339: Stage 3 / Text3: UTRA
- 340: - / Text3: 25.101, 25.104, 25.133, 25.211, 25.212, 25.213, 25.214, 25.215, 25.308, 25.331, 25.423, 25.433, 26.306
- 341: - / Text3: 25.101, 25.104, 25.133, 25.141
- 342: RP#53 Perf completed. Stage 3 / Text3: UTRA
- 343: RP#53 completed. TR 25.873v100 for Approval / Text3: 25.102, new TR 25.873
- 344: RP#55 completed / Text3: 34.108, 34.122
- 345: Stage 2/3 / Text3: UTRA
- 346: RP#55 completion 03/12=>06/12. Updated WID RP-110374=>RP-120367 / Text3: 25.101, 25.104, 25.133, 25.211, 25.212, 25.213, 25.214, 25.215, 25.306, 25.319, 25.321, 25.331, 25.423, 25.433
- 347: - / Text3: 25.101, 25.104, 25.133, 25.141
- 348: RP#55 completion 03/12=>06/12. Updated WID RP-110374=>RP-120367 / Text3: 25.101, 25.133, 25.306, 25.319, 25.321, 25.331, 25.423, 25.433
- 349: - / Text3: 25.101, 25.133
- 350: UTRA / Text3: UTRA
- 351: RP#54 completed / Text3: 25.101, 25.104, 25.141, 25.317
- 352: - / Text3: 25.101, 25.104, 25.141, 25.317
- 353: UTRA / Text3: UTRA
- 354: - / Text3: 25.101, 25.104, 25.133, 25.331, 25.423, 25.433
- 355: - / Text3: 25.101, 25.104, 25.133, 25.141
- 356: Stage 2/3 / Text3: UTRA
- 357: - / Text3: 25.101, 25.104, 25.133, 25.211, 25.212, 25.213, 25.214, 25.306, 25.308, 25.319, 25.321, 25.331, 25.423, 25.433
- 358: - / Text3: 25.101, 25.104, 25.133, 25.141

| ID | WBS | Task | Duration | Start | Finish | Complete | Remaining | Baseline start | Baseline finish | Baseline duration | Total slack | Constraint | Resources | Work | Actual work | Text1 | Text2 | Text4 | Text6 | Text7 | Text11 | Text8 |
| --- | --- | --- | --- | --- | --- | --- | --- | --- | --- | --- | --- | --- | --- | --- | --- | --- | --- | --- | --- | --- | --- | --- |
| 359 | 124 | **HSDPA Multiflow Data Transmission** | 391d? | 2011-09-19 A | 2013-03-15 | 20% | 313.65d? | 2011-09-19 | 2013-03-15 | 391d? | 193d |  | R2,R1,R3,R4 | 8304h | 1642.83h | HSDPA_MFTX | PCG-27 | Nokia Siemens Networks | Rel-11 | RP-53 |  |  |
| 360 | 124.1 | Core part: HSDPA Multiflow Data Transmission | 256d? | 2011-09-19 A | 2012-09-07 | 50% | 128d? | 2011-09-19 | 2012-09-07 | 256d? | 328d | finish no earlier than 2012-09-07 | R2,R1,R3,R4 | 2048h | 1024h | HSDPA_MFTX-Core | PCG-27 | Nokia Siemens Networks | Rel-11 | RP-53 | RP-120068 |  |
| 361 | 124.2 | Perf. part: HSDPA Multiflow Data Transmission | 391d? | 2011-09-19 | 2013-03-15 |  |  | 2011-09-19 | 2013-03-15 | 391d? | 193d | finish no earlier than 2013-03-15 | R4 | 3128h |  | HSDPA_MFTX-Perf | PCG-27 | Nokia Siemens Networks | Rel-11 | RP-53 | RP-120069 |  |
| 362 | 125 | **Four Branch MIMO transmission for HSDPA** | 391d? | 2011-09-19 A | 2013-03-15 | 4% | 375.53d? | 2011-09-19 | 2013-03-15 | 391d? | 193d |  | R1,R2,R3,R4 | 8304h | 328.56h | 4Tx_HSDPA | PCG-27 | Ericsson | Rel-11 | RP-53 |  |  |
| 363 | 125.1 | Core part: Four Branch MIMO transmission for HSDPA | 256d? | 2011-09-19 A | 2012-09-07 | 10% | 230.4d? | 2011-09-19 | 2012-09-07 | 256d? | 328d | finish no earlier than 2012-09-07 | R1,R2,R3,R4 | 2048h | 204.8h | 4Tx_HSDPA-Core | PCG-27 | Ericsson | Rel-11 | RP-53 | RP-120066 |  |
| 364 | 125.2 | Perf. part: Four Branch MIMO transmission for HSDPA | 391d? | 2011-09-19 | 2013-03-15 |  |  | 2011-09-19 | 2013-03-15 | 391d? | 193d | finish no earlier than 2013-03-15 | R4 | 3128h |  | 4Tx_HSDPA-Perf | PCG-27 | Ericsson | Rel-11 | RP-53 | RP-120067 |  |
| 365 | 126 | **MIMO with 64QAM for HSUPA** | 396d? | 2011-12-09 A | 2013-06-14 | 8% | 364.54d? | 2011-12-09 | 2013-06-14 | 396d? | 128d |  | R1,R2,R3,R4 | 8424h | 669.3h | MIMO_64QAM_HSUPA | PCG-28 | Nokia Siemens Networks | Rel-11 | RP-54 |  |  |
| 366 | 126.1 | Core part: MIMO with 64QAM for HSUPA | 261d? | 2011-12-09 A | 2012-12-07 | 20% | 208.8d? | 2011-12-09 | 2012-12-07 | 261d? | 263d | finish no earlier than 2012-12-07 | R1,R2,R3,R4 | 2088h | 417.6h | MIMO_64QAM_HSUPA-Core | PCG-28 | Nokia Siemens Networks | Rel-11 | RP-54 | RP-120071 |  |
| 367 | 126.2 | Perf. part: MIMO with 64QAM for HSUPA | 396d? | 2011-12-09 | 2013-06-14 |  |  | 2011-12-09 | 2013-06-14 | 396d? | 128d | finish no earlier than 2013-06-14 | R4 | 3168h |  | MIMO_64QAM_HSUPA-Perf | PCG-28 | Nokia Siemens Networks | Rel-11 | RP-54 | RP-120072 |  |
| 368 | 127 | **HSDPA Dual-Band Multi-Carrier combinations** | 261d? | 2011-12-09 A | 2012-12-07 | 24% | 197.61d? | 2011-12-09 | 2012-12-07 | 261d? | 263d |  | R4,R2 | 5744h | 1395.15h | HSDPA_DB_MC | PCG-28 | Ericsson | Rel-11 | RP-54 |  |  |
| 369 | 127.1 | Core part: HSDPA Dual-Band Multi-Carrier combinations | 196d? | 2011-12-09 A | 2012-09-07 | 30% | 137.2d? | 2011-12-09 | 2012-09-07 | 196d? | 328d | finish no earlier than 2012-09-07 | R4,R2 | 1568h | 470.4h | HSDPA_DB_MC-Core | PCG-28 | Ericsson | Rel-11 | RP-54 | RP-120073 |  |
| 370 | 127.2 | Perf. part: HSDPA Dual-Band Multi-Carrier combinations | 261d? | 2011-12-09 A | 2012-12-07 | 20% | 208.8d? | 2011-12-09 | 2012-12-07 | 261d? | 263d | finish no earlier than 2012-12-07 | R4 | 2088h | 417.6h | HSDPA_DB_MC-Perf | PCG-28 | Ericsson | Rel-11 | RP-54 | RP-120074 |  |
| 371 | 128 | (Small) Technical Enhancements and Improvements for Rel-11 | 402d? | 2010-06-10 A | 2011-12-23 | 20% | 321.6d? | 2010-06-10 | 2011-12-23 | 402d? | 513d | finish no earlier than 2011-12-23 | All | 3216h | 643.2h | TEI11 | PCG-25 |  | Rel-11 | SP-48 |  | All |
| 372 | 129 | Release 11 Studies | 723d? | 2009-12-10 A | 2012-09-12 | 70% | 216.9d? | 2009-12-10 | 2012-09-12 | 723d? | 325d | finish no earlier than 2012-09-12 | SP,CP,GP,RP | 2606.4h | 1351.2h |  |  |  | Rel-11 |  |  | All |
| 373 | 130 | Study on IMS based Peer-to-Peer Content Distribution Services | 284d? | 2009-05-12 A | 2010-06-10 A | 100% |  | 2009-05-12 | 2010-06-10 | 284d? |  | finish no earlier than 2010-06-10 | S1,S2 | 2272h | 2272h | FS_IMS_P2P | PCG-23 | China Mobile | Rel-11 | SP-45 |  | Alain |
| 374 | 131 | Study on Support for 3GPP Voice Interworking with Enterprise IP-PBX | 130d? | 2010-09-23 A | 2011-03-23 A | 100% |  | 2010-09-23 | 2011-03-23 | 130d? |  | finish no earlier than 2011-02-21 | S1,S2 | 1040h | 1040h | FS_VINE | PCG-25 | Tatara Systems | Rel-11 | SP-48 |  | Alain |
| 375 | 132 | Study on IMS Evolution | 849d? | 2008-09-18 A | 2011-12-14 A | 100% |  | 2008-09-18 | 2011-12-14 | 849d? |  | finish no earlier than 2011-12-07 | S2 | 6784h | 6784h | FS_eIMS | PCG-21 | China Mobile | Rel-11 | SP-41 |  | Maurice |
| 376 | 133 | Study on Policy solutions and enhancements | 525d? | 2009-06-04 A | 2011-06-08 A | 100% |  | 2009-06-04 | 2011-06-08 | 525d? |  |  | S2,S1 | 4200h | 4200h | FS_PP | PCG-23 | AT&T | Rel-11 | SP-44 |  | Maurice |
| 377 | 134 | Study on IPv6 Migration | 525d? | 2009-06-04 A | 2011-06-08 A | 100% |  | 2009-06-04 | 2011-06-08 | 525d? |  | finish no earlier than 2011-06-08 | S2 | 4200h | 4200h | FS_IP6M | PCG-23 | China Mobile | Rel-11 | SP-44 |  | Maurice |
| 378 | 135 | Study on Single Radio Voice Call Continuity from UTRAN/GERAN to E-UTRAN/HSPA | 528d? | 2009-12-10 A | 2011-12-14 A | 100% |  | 2009-12-10 | 2011-12-14 | 528d? |  | finish no earlier than 2011-09-21 | S2 | 4208h | 4208h | FS_rSRVCC | PCG-24 | Orange | Rel-11 | SP-46 |  | Maurice |
| 379 | 136 | Study on Roaming Architecture for Voice over IMS with Local Breakout | 194d? | 2011-03-23 A | 2011-12-14 A | 100% |  | 2011-03-23 | 2011-12-14 | 194d? |  | finish no earlier than 2011-12-07 | S2 | 1535.79h | 1535.79h | FS_RAVEL | PCG-26 | Deutsche Telekom | Rel-11 | SP-51 |  | Maurice |
| 380 | 137 | Study on UTRAN key management enhancements | 1102d? | 2007-12-20 A | 2012-03-07 A | 100% |  | 2007-12-20 | 2012-03-07 | 1102d? |  | finish no earlier than 2012-02-20 | S3 | 8808.12h | 8808.12h | FS_UKM | PCG-21 | Ericsson | Rel-11 | SP-38 |  | Dionisio |
| 381 | 138 | Study on Extended IMS Media Plane Security features | 531d? | 2010-06-10 A | 2012-06-20 | 75% | 132.75d? | 2010-06-10 | 2012-06-20 | 531d? | 385d | finish no earlier than 2012-06-20 | S3 | 4240h | 3178h | FS_eMEDIASEC | PCG-25 | Vodafone | Rel-11 | SP-48 |  | Dionisio |
| 382 | 139 | Study on Single Sign On (SSO) Application Security for IMS - based on SIP Digest | 531d? | 2010-06-10 A | 2012-06-20 | 95% | 26.55d? | 2010-06-10 | 2012-06-20 | 531d? | 385d | finish no earlier than 2012-03-07 | S3 | 4239.11h | 4027.16h | FS_SSO_APS | PCG-25 | Nokia | Rel-11 | SP-48 |  | Dionisio |
| 383 | 140 | Study on Mobile 3D Video Coding | 272d? | 2011-06-08 A | 2012-06-20 | 70% | 81.6d? | 2011-06-08 | 2012-06-20 | 272d? | 385d | finish no earlier than 2012-06-20 | S4 | 2168h | 1515.2h | FS_M3DVC | PCG-27 | Orange | Rel-11 | SP-52 |  | Paolo |
| 384 | 141 | Study on Improved Support for Dynamic Adaptive Streaming over HTTP in 3GPP | 196d? | 2011-12-14 A | 2012-09-12 | 5% | 186.2d? | 2011-12-14 | 2012-09-12 | 196d? | 325d | finish no earlier than 2012-09-12 | S4 | 1568h | 78.4h | FS_IS_DASH | PCG-28 | Qualcomm | Rel-11 | RP-54 |  |  |
| 385 | 142 | Study on version handling | 648d? | 2010-03-25 A | 2012-09-12 | 85% | 97.2d? | 2010-03-25 | 2012-09-12 | 648d? | 325d | finish no earlier than 2012-09-12 | S5 | 5176h | 4398.4h | FS_OAM_VH | PCG-24 | Ericsson | Rel-11 | SP-47 |  | Dionisio |
| 386 | 143 | Study on Management of Converged Networks | 590d? | 2010-06-10 A | 2012-09-12 | 30% | 413d? | 2010-06-10 | 2012-09-12 | 590d? | 325d | finish no earlier than 2012-09-12 | S5 | 4720h | 1416h | FS_ManCon | PCG-25 | Nokia Siemens Networks | Rel-11 | SP-48 |  | Dionisio |
| 387 | 144 | Study on User Data Convergence (UDC) information model handling and provisioning: Example Use Cases | 321d? | 2010-09-23 A | 2011-12-14 A | 100% |  | 2010-09-23 | 2011-12-14 | 321d? |  | finish no earlier than 2011-12-14 | S5 | 2560h | 2560h | FS_UDC_AppUseCase | PCG-25 | Alcatel-Lucent | Rel-11 | SP-49 |  | Dionisio |
| 388 | 145 | Study on OAM aspects of inter-RAT Energy Saving | 194d? | 2011-03-23 A | 2011-12-14 A | 100% |  | 2011-03-23 | 2011-12-14 | 194d? |  | start no earlier than 2011-03-23 | S5 | 1528h | 1528h | FS_OAM_ES_iRAT | PCG-26 | Nokia Siemens Networks | Rel-11 | SP-51 |  | Dionisio |
| 389 | 146 | Study on management of Heterogeneous Networks | 388d? | 2011-03-23 A | 2012-09-12 | 20% | 310.4d? | 2011-03-23 | 2012-09-12 | 388d? | 325d | finish no earlier than 2012-09-12 | S5 | 3104h | 620.8h | FS_OAM_HetNet | PCG-26 | Ericsson | Rel-11 | SP-51 |  | Dionisio |
| 390 | 147 | Study on OAM aspects of Network Sharing | 201d? | 2011-12-07 A | 2012-09-12 | 10% | 180.4d? | 2011-12-07 | 2012-09-12 | 201d? | 325d | finish no earlier than 2012-09-12 | S5 | 1608h | 164.8h | FS_OAM_SHARE | PCG-28 | Alcatel-Lucent, Huawei | Rel-11 | SP-54 |  |  |
| 391 | 148 | Study on impacts on UE-Core Network signalling from Energy Saving | 261d? | 2010-06-04 A | 2011-06-03 A | 100% |  | 2010-06-04 | 2011-06-03 | 261d? |  | finish no earlier than 2011-06-03 | C1 | 2088h | 2088h | FS_UE-CN_ES | PCG-25 | NEC | Rel-11 | CP-48 |  | Frederic |
| 392 | 149 | Study on EPC Nodes Restoration | 459d? | 2010-09-17 A | 2012-06-15 | 80% | 91.8d? | 2010-09-17 | 2012-06-15 | 459d? | 388d | finish no earlier than 2012-06-15 | C4 | 3664h | 2929.6h | FS_EPC_NR | PCG-25 | ZTE | Rel-11 | CP-49 |  | Kimmo |
| 393 | 150 | Study on GERAN improvements for Machine-Type Communications | 513.5d? | 2010-05-24 A | 2012-05-18 | 25% | 385.12d? | 2010-05-24 | 2012-05-18 | 513.5d? | 408d | finish no earlier than 2012-05-18 | G1,G2 | 4108h | 1027h | FS_NIMTC_GERAN | PCG-24 | Ericsson | Rel-11 | GP-44 |  | Paolo |
| 394 | 151 | Study on Signal Precoding enhancements for EGPRS2 DL | 392d? | 2010-09-03 A | 2012-03-02 A | 100% |  | 2010-09-03 | 2012-03-02 | 392d? |  | finish no earlier than 2012-03-02 | G1,G2 | 3128h | 3128h | FS_SPEED | PCG-25 | Ericsson | Rel-11 | GP-46 |  | Paolo |
| 395 | 152 | Study on Solutions for GSM/EDGE BTS Energy Saving | 446d? | 2010-09-03 A | 2012-05-18 | 75% | 111.5d? | 2010-09-03 | 2012-05-18 | 446d? | 408d | finish no earlier than 2012-05-18 | G1,G2 | 3568h | 2676h | FS_Energy_BTS | PCG-25 | Nokia Siemens Networks, Vodafone | Rel-11 | GP-47 |  | Paolo |
| 396 | 153 | Study on Voice services over Adaptive Multi-user channels on One Slot (VAMOS) enhancements | 261d? | 2011-05-20 A | 2012-05-15 | 30% | 182.7d? | 2011-05-20 | 2012-05-15 | 261d? | 411d | start no earlier than 2011-05-20 | GP,G2,G1 | 2088h | 626.4h | FS_eVAMOS | PCG-27 | China Mobile, Huawei | Rel-11 | GP-50 |  | Paolo |
| 397 | 154 | Study on GERAN enhancements for Mobile Data Applications | 336d? | 2011-05-24 A | 2012-08-31 | 30% | 235.2d? | 2011-05-24 | 2012-08-31 | 336d? | 333d | finish no earlier than 2012-08-31 | G2,G1 | 2688h | 806.4h | FS_GERAN_eMDA | PCG-27 | Huawei | Rel-11 | GP-50 |  | Gert |
| 398 | 155 | Study on Coordinated Multi-Point operation for LTE | 203d? | 2010-12-10 A | 2011-09-16 A | 100% |  | 2010-12-10 | 2011-09-16 | 203d? |  | finish no earlier than 2011-09-16 | R1,R2,R3 | 1624h | 1624h | FS_CoMP_LTE | PCG-24 | Samsung | Rel-11 | RP-47 | RP-111343 | Patrick |
| 399 | 156 | Study on Signalling and procedure for interference avoidance for in-device coexistence | 336d? | 2010-06-04 A | 2011-09-16 A | 100% |  | 2010-06-04 | 2011-09-16 | 336d? |  | finish no earlier than 2011-09-16 | R2,R4 | 2688h | 2688h | FS_SPIA_IDC | PCG-25 | China Mobile | Rel-11 | RP-48 | RP-111057 | Joern |
| 400 | 157 | Study on Inclusion of RF Pattern Matching Technologies as a positioning method in the E-UTRAN | 397d? | 2010-12-10 A | 2012-06-15 | 50% | 198.5d? | 2010-12-10 | 2012-06-15 | 397d? | 388d | finish no earlier than 2012-06-15 | R4 | 3176h | 1588h | FS_LCS_LTE_RFPMT | PCG-26 | Polaris Wireless | Rel-11 | RP-50 | RP-120159 | Issam |
| 401 | 158 | Study on HetNet mobility enhancements for LTE | 386d? | 2011-03-18 A | 2012-09-07 | 45% | 212.3d? | 2011-03-18 | 2012-09-07 | 386d? | 328d | finish no earlier than 2012-09-07 | R2,R1,R3,R4 | 3088h | 1389.6h | FS_HetNet_eMOB_LTE | PCG-26 | Alcatel-Lucent | Rel-11 | RP-51 | RP-120160 | Joern |
| 402 | 159 | Study on Enhanced Uplink Transmission for LTE | 387d? | 2011-03-22 A | 2012-09-07 | 5% | 367.65d? | 2011-03-22 | 2012-09-07 | 387d? | 328d | finish no earlier than 2012-09-07 | R1 | 3096h | 154.8h | FS_eUL_TX_LTE | PCG-26 | Huawei | Rel-11 | RP-51 | RP-120161 | Patrick |
| 403 | 160 | Study on further Downlink MIMO enhancements for LTE-Advanced | 193d? | 2011-03-18 A | 2011-12-09 A | 100% |  | 2011-03-18 | 2011-12-09 | 193d? |  | finish no earlier than 2011-12-09 | R1 | 1544h | 1544h | FS_LTE_eDL_MIMO_enh | PCG-26 | Alcatel-Lucent | Rel-11 | RP-51 | RP-111550 | Patrick |
| 404 | 161 | Study on Interference analysis between 800~900 MHz bands | 326d? | 2011-03-23 A | 2012-06-15 | 50% | 163d? | 2011-03-23 | 2012-06-15 | 326d? | 388d | finish no earlier than 2012-06-15 | R4 | 2608h | 1304h | FS_B800_B900_Interf_LTE | PCG-26 | LG Uplus | Rel-11 | RP-51 | RP-120162 | Issam |
| 405 | 162 | Study on Further Enhancements to LTE TDD for DL-UL Interference Management and Traffic Adaptation | 326d? | 2011-03-22 A | 2012-06-15 | 30% | 228.2d? | 2011-03-22 | 2012-06-15 | 326d? | 388d | finish no earlier than 2012-06-15 | R1,R4 | 2608h | 782.4h | FS_LTE_TDD_eIMTA | PCG-26 | CATT | Rel-11 | RP-51 | RP-120163 | Patrick |
| 406 | 163 | Study on Provision of low-cost MTC UEs based on LTE | 196d? | 2011-09-19 A | 2012-06-15 | 50% | 98d? | 2011-09-19 | 2012-06-15 | 196d? | 388d | finish no earlier than 2012-06-15 | R1,R2,R4 | 1568h | 784h | FS_LC_MTC_LTE | PCG-27 | Vodafone | Rel-11 | RP-53 | RP-120164 |  |
| 407 | 164 | Study on LTE Coverage Enhancements | 196d? | 2011-09-19 A | 2012-06-15 | 70% | 58.8d? | 2011-09-19 | 2012-06-15 | 196d? | 388d | finish no earlier than 2012-06-15 | R1,R2 | 1568h | 1097.6h | FS_Cov_Enh_LTE | PCG-27 | China Telecom | Rel-11 | RP-53 | RP-120165 |  |
| 408 | 165 | Study on Mobile Relay for E-UTRA | 196d? | 2011-09-19 A | 2012-06-15 | 35% | 127.4d? | 2011-09-19 | 2012-06-15 | 196d? | 388d | finish no earlier than 2012-06-15 | R3,R1,R2,R4 | 1568h | 548.8h | FS_LTE_mobRelay | PCG-27 | CATT | Rel-11 | RP-53 | RP-120166 |  |
| 409 | 166 | Study on LTE-HRPD (High Rate Packet Data in 3GPP2) inter-RAT SON | 201d? | 2012-03-02 | 2012-12-07 |  |  | 2012-03-02 | 2012-12-07 | 201d? | 263d | start no earlier than 2012-03-02 | R3 | 1608h |  | FS_LTE_HRPD_SON | PCG-28 | China Telecom | Rel-11 | RP-55 |  |  |
| 410 | 167 | Study on Measurements of radio performances for LTE terminals - Total Radiated Power (TRP) and Total Radiated Sensitivity (TRS) test methodology | 76d? | 2012-03-02 | 2012-06-15 |  |  | 2012-03-02 | 2012-06-15 | 76d? | 388d | finish no earlier than 2012-06-15 | R4 | 608h |  | FS_LTE_OTA | PCG-28 | CATR | Rel-11 | RP-55 |  |  |
| 411 | 168 | Study on Enhanced performance requirement for LTE UE | 121d? | 2011-09-19 A | 2012-03-02 A | 100% |  | 2011-09-19 | 2012-03-02 | 121d? |  | finish no earlier than 2012-03-02 | R4,R1 | 968h | 968h | FS_enh_perf_UE_LTE | PCG-27 | NTT DoCoMo | Rel-11 | RP-53 | RP-120167 |  |
| 412 | 169 | Study on Measurement of Radiated Performance for MIMO and multi-antenna reception for HSPA and LTE terminals | 712.8d? | 2009-03-06 A | 2012-03-02 A | 100% |  | 2009-03-06 | 2012-03-02 | 712.8d? |  | finish no earlier than 2012-03-02 | R4 | 5702.4h | 5702.4h | FS_HSPA_LTE_measRP_MIMO_multi-antenna | PCG-22 | Vodafone | Rel-11 | RP-43 | RP-120154 | Issam |
| 413 | 170 | Study on Extending 850 MHz | 799d? | 2009-05-30 A | 2012-06-15 | 80% | 159.8d? | 2009-05-30 | 2012-06-15 | 799d? | 388d | finish no earlier than 2012-06-15 | R4 | 6392h | 5113.6h | FS_e850 | PCG-23 | Ericsson | Rel-11 | RP-44 | RP-120155 | Issam |
| 414 | 171 | Study on RAN improvements for Machine-Type Communications | 521d? | 2009-09-18 A | 2011-09-16 A | 100% |  | 2009-09-18 | 2011-09-16 | 521d? |  | finish no earlier than 2011-09-16 | R2,R1,R3,R4 | 4168h | 4168h | FS_NIMTC_RAN | PCG-23 | Huawei | Rel-11 | RP-45 | RP-111052 | Joern |
| 415 | 172 | Study on UE Application Layer Data Throughput Performance | 264d? | 2010-12-10 A | 2011-12-09 A | 100% |  | 2010-12-10 | 2011-12-09 | 264d? |  | finish no earlier than 2011-09-16 | R5,R4 | 2104h | 2104h | FS_UE_App_Data_Perf | PCG-26 | Spirent | Rel-11 | RP-50 | RP-111543 | Ingbert |
| 416 | 173 | Study on further enhancements for HNB and HeNB | 329d? | 2011-03-18 A | 2012-06-15 | 70% | 98.7d? | 2011-03-18 | 2012-06-15 | 329d? | 388d | finish no earlier than 2012-06-15 | R3,R2 | 2632h | 1842.4h | FS_EHNB_enh | PCG-26 | Alcatel-Lucent | Rel-11 | RP-51 | RP-120156 | Juha |
| 417 | 174 | Study on UMTS/LTE in 900 MHz band (Japan, Korea) | 272d? | 2011-06-07 A | 2012-06-15 | 55% | 122.4d? | 2011-06-07 | 2012-06-15 | 272d? | 388d | finish no earlier than 2012-06-15 | R4 | 2176h | 1196.8h | FS_UTRA_LTE_900MHz | PCG-27 | NTT DoCoMo | Rel-11 | SP-52 | RP-120157 | Issam |
| 418 | 175 | Study on RF and EMC requirements for active Antenna Array System (AAS) Base Station | 256d? | 2011-09-19 A | 2012-09-07 | 20% | 204.8d? | 2011-09-19 | 2012-09-07 | 256d? | 328d | finish no earlier than 2012-09-07 | R4,R1 | 2048h | 409.6h | FS_AAS_BS_LTE_UTRA | PCG-27 | Huawei | Rel-11 | RP-53 | RP-120158 |  |
| 419 | 176 | Study on Passive InterModulation (PIM) handling for for UTRA and LTE Base Stations | 136d? | 2012-03-02 | 2012-09-07 |  |  | 2012-03-02 | 2012-09-07 | 136d? | 328d | finish no earlier than 2012-09-07 | R4,G1 | 1088h |  | FS_BS_PIM | PCG-28 | Ericsson | Rel-11 | RP-55 |  |  |
| 420 | 177 | Study on Uplink MIMO | 203d? | 2010-12-10 A | 2011-09-16 A | 100% |  | 2010-12-10 | 2011-09-16 | 203d? |  | finish no earlier than 2011-09-16 | R1 | 1624h | 1624h | FS_UTRA_UL_MIMO | PCG-26 | Qualcomm | Rel-11 | RP-50 | RP-111048 | Patrick |
| 421 | 178 | Study on HSDPA Multipoint Transmission | 201d? | 2010-12-10 A | 2011-09-16 A | 100% |  | 2010-12-10 | 2011-09-16 | 201d? |  | finish no earlier than 2011-09-16 | R1,R2,R3 | 1608h | 1608h | FS_HSDPA_MP_TX | PCG-26 | Nokia Siemens Networks | Rel-11 | RP-50 | RP-111049 | Patrick |
| 422 | 179 | Study on UE Over The Air (OTA) test method with Head and Hand Phantoms | 196d? | 2011-09-19 A | 2012-06-15 | 25% | 147d? | 2011-09-19 | 2012-06-15 | 196d? | 388d | finish no earlier than 2012-06-15 | R4,R5 | 1568h | 392h | FS_OTA_phantoms_UTRA | PCG-27 | Nokia | Rel-11 | RP-53 | RP-120152 |  |
| 423 | 180 | Study on HSPA feedback and signalling efficiency enhancements for LCR TDD | 198d? | 2011-12-07 A | 2012-09-07 | 5% | 188.1d? | 2011-12-07 | 2012-09-07 | 198d? | 328d | finish no earlier than 2012-09-07 | R1 | 1584h | 79.2h | FS_LCRTDD_HSPAenh | PCG-28 | TD Tech | Rel-11 | RP-54 | RP-120153 |  |
| 424 | 181 | Release 10 Features | 370.2d? | 2008-12-11 A | 2011-09-21 A | 100% |  | 2008-12-11 | 2011-09-21 | 370.2d? |  | finish no earlier than 2011-09-21 | CP,GP,RP,SP | 2961.6h | 2961.6h |  |  |  | Rel-10 |  |  |  |

Notes:
- 359: Stage 2,3 / Text3: UTRA / Text5: Alexander Sayenko
- 360: - / Text3: 25.101, 25.104, 25.133, 25.211, 25.212, 25.214, 25.306, 25.308, 25.321, 25.331, 25.423, 25.433 / Text5: Alexander Sayenko
- 361: - / Text3: 25.101, 25.104, 25.133, 25.141 / Text5: Kamil Bechta
- 362: Stage 3 / Text3: UTRA / Text5: johan.hultell@ericsson.com
- 363: - / Text3: 25.101, 25.104, 25.133, 25.211, 25.212, 25.213, 25.214, 25.215, 25.308, 25.331, 25.423, 25.433, 26.306 / Text5: johan.hultell@ericsson.com
- 364: - / Text3: 25.101, 25.104, 25.133, 25.141 / Text5: johan.hultell@ericsson.com
- 365: Stage 3 / Text3: UTRA / Text5: Karri Ranta-aho
- 366: - / Text3: 25.101, 25.104, 25.133, 25.211, 25.212, 25.213, 25.214, 25.215, 25.308, 25.321, 25.331, 25.423, 25.433, 26.306 / Text5: Karri Ranta-aho
- 367: - / Text3: 25.101, 25.104, 25.133, 25.141 / Text5: Kamil Bechta
- 368: Stage 3 / Text3: UTRA / Text5: muhammad.kazmi@ericsson.com
- 369: - / Text3: 25.101, 25.104, 25.141, 25.317 / Text5: muhammad.kazmi@ericsson.com
- 370: - / Text3: 25.101, 25.104, 25.141 / Text5: muhammad.kazmi@ericsson.com
- 371: SP#50 EU-Alert is introduced under Public Warning System in parallel with the already existing ETWS and CMAS. SA1 22.268 CR#9r1 adds EU-ALERT specific requirements & CT1 23.041 CRs#
- 372: -
- 373: SP#48 completed / Text3: 22.906 / Text5: Li Gang (ligangyf@chinamobile.com)
- 374: SP#51 TR 22.809 approved. Support Interworking between 3GPP networks and Enterprise environments to provide enterprise voice services via 3GPP mobile devices / Text3: 22.809 / Text5: Phillip Brown (pbrown@tatarasystems.com)
- 375: SP#54 completed / Text3: 23.812 / Text5: Li Gang (ligangyf@chinamobile.com), Yu Qing (yuqing@chinamobile.com)
- 376: SP#52 completed / Text3: 23.813 / Text5: farooq.bari@att.com
- 377: SP#52 completed / Text3: 23.975 / Text5: Li Lianyuan (lilianyuan@chinamobile.com), Liu Hong (liuhongyfw@chinamobile.com)
- 378: SP#54 completed. Study on "reverse direction" from UTRAN/GERAN to E-UTRAN/HSPA (Rel-8 SRVCC was in the other direction E-UTRAN/HSPA to GERAN/UTRAN) / Text3: 23.885 / Text5: delphin.barankanira@orange-ftgroup.com
- 379: SP#54 completed. Linked to Rel-11 OSCAR (Optimized Service Charging and Allocation of Resources in IMS whilst Roaming) UID_490032. Related to LBO/home routing decision / Text3: 23.850 / Text5: michele.zarri@telekom.com
- 380: SP#55 completed. SP#54 TR 33.859v200 for Approval / Text3: 33.859 / Text5: karl.norrman@ericsson.com
- 381: Continuation of Rel-9 Feature UID_430036 IMS Media Plane Security (MEDIASEC). Study solutions and extensions to features and functionality described in TR 33.828 and TS 33.328. / Text3: 33.829 / Text5: peter.howard@vodafone.com
- 382: SP#55 33.914v200 for Approval converted 33.804 on SA3 request. Study reuse of non-UICC credentials (in particular SIP Digest) to provide security for the access to applications. Provide reference material for IMS based non-UICC based SSO to applications / Text3: 33.914 converted to 33.804 / Text5: Silke.Holtmanns@nokia.com
- 383: SP#55 completion 03/12=>06/12. Extends Rel-10 work on 3D video formats UID_480044 Improved Video Coding Support for PSS and MBMS / Text3: 26.905 (Mobile stereoscopic 3D video) / Text5: gilles.teniou@orange-ftgroup.com
- 384: Linked to Feaqture UID_470034 HTTP-based Streaming and Download Services / Text3: 26.938 / Text5: c_tstock@qualcomm.com
- 385: SP#54 completion 12/11=>09/12 / Text3: 32.830 / Text5: thomas.tovinger@ericsson.com
- 386: SP#54 completion 12/11=>09/12 / Text3: 32.833 / Text5: olaf.pollakowski@nsn.com
- 387: SP#54 completed / Text3: 32.901 / Text5: Nick Mazzarella (njmazzarella@alcatel-lucent.com)
- 388: SP#54 completed. Triggered by Rel-10 UID_430044 TR 32.826 Study on Energy Savings Management (FS_OAM_ESM) and UID_470037 OAM aspects of Energy Saving in Radio Networks (OAM-ES) / Text3: 32.834 / Text5: clemens.suerbaum@nsn.com
- 389: SP#54 completion 12/11=>09/12 / Text3: 32.8xy / Text5: brendan.hassett@ericsson.com
- 390: Linked to SP-110433 (LS on Equivalent PLMN identities and MDT) and Network Sharing UID_31018, SA1 TR 22.951 (Service aspects and requirements for network sharing), SA2 TS 23.251 (Network Sharing; Architecture and functional description) / Text3: 32.851 / Text5: Padma.Sudarsan@alcatel-lucent.com, zoulan@huawei.com
- 391: CP#52 completed. Linked to SA5 UID_430044 (FS_OAM-ESM) & UID_470037 (OAM-ES), RAN3 UID_470015 (FS_Energy_LTE), RAN1 UID_460016 (FS_Energy_UMTS) / Text3: 24.826 / Text5: gottfried.punz@nw.neclab.eu
- 392: CP#54 completion 12/11=>06/12. Continue work in Rel-11 especially to cover handling of Idle mode Signalling Reduction (ISR). Linked to SA2 UID_490036 Study on Core Network Overload solutions / Text3: 23.857 / Text5: lu.fei1@zte.com.cn
- 393: GP#53 completion 03/12=>05/12. GP#44 approved WID / Text3: GERAN 43.868 / Text5: paul.schliwa-bertling@ericsson.com
- 394: GP#53 completed (03/12). GP#46 approved WID. / Text3: GERAN 45.860 / Text5: marten.sundberg@ericsson.com
- 395: GP#52 completion 11/11=>05/12. GP#47 approved WID / Text3: GERAN 45.926 / Text5: juergen.hofmann@nsn.com, leo.patanapongpibul@vodafone.com
- 396: GP#50 approved WID. Triggered by Rel-8 TR 45.914 Study Multi-User-Reusing One Timeslot (MUROS) UID_50590 and Rel-9 VAMOS UID_420002 / Text3: GERAN 45.8xy / Text5: dengjuan@chinamobile.com, Chao Luo (chluo@huawei.com)
- 397: GP#51 completion 03/12=>08/12 (mobile coucou). GP#50 approved WID. Triggered by RAN#51 (Mar 2011) WID in RP-110454 (LTE RAN Enhancements for Diverse Data Applications) UID_510031 / Text3: GERAN 45.8xy / Text5: ming.fang@huawei.com
- 398: RP#53 completed / Text3: LTE 36.819 / Text5: bruno.clerckx@samsung.com
- 399: RP#53 completed. Studied coexistence scenario of LTE and Industrial, Scientific and Medical (ISM) Radio within the same device working in adjacent frequencies / Text3: LTE 36.816 / Text5: Zhenping Hu (huzhenping@chinamobile.com)
- 400: RP#55 updated WID RP-110385=>RP-120374 / Text3: LTE 36.809 / Text5: Scot Gordon (sgordon@polariswireless.com)
- 401: - / Text3: LTE 36.8xy / Text5: Sudeep Palat
- 402: RP#55 put on HOLD. Updated WID RP-110448=>RP-120259 / Text3: LTE 36.8xy / Text5: Yongxing Zhou
- 403: RP#54 completed / Text3: LTE 36.871 / Text5: federico.boccardi@alcatel-lucent.com
- 404: RP#55 completion 03/12=>06/12. Impacts TR 37.804 Study on UMTS/LTE in 900 MHz band (Japan, Korea) UID_520018 / Text3: LTE impacts TR 37.804 / Text5: Koo Yeon Sang (yskoo@lguplus.co.kr)
- 405: - / Text3: LTE 36.828 / Text5: Zukang Shen (shenzukang@datangmobile.cn)
- 406: RP#55 TR 36.888 v100 for Information / Text3: LTE TR 36.888 / Text5: Prakash Bhat
- 407: RP#55 completion 03/12=>06/12. Updated WID RP-111359=>RP-120225. TR 36.824 v100 for Information / Text3: LTE TR 36.824 / Text5: Peng Chen (chenpeng@ctbri.com.cn)
- 408: RP#55 completion 03/12=>06/12 / Text3: LTE TR 36.8xy / Text5: Haijing Hu
- 409: RP#55 LS_in RP-120004. Input may be required from SA2/SA5 / Text3: LTE new TR / Text5: Wu Jinlian (wujl@gsta.com)
- 410: - / Text3: LTE 25.914, new TR 37.9vw / Text5: Xudong An (anxudong@emcite.com)
- 411: RP#55 completed. TR 36.829 v100 for Information + Approval / Text3: LTE TR 36.829 / Text5: Yuta Sagae
- 412: RP#55 completed. TR 37.976 v200 for Approval / Text3: UTRA, LTE 37.976 / Text5: Tim.frost@vodafone.com
- 413: RP#55 completion 03/12=>06/12 / Text3: UTRA, LTE 37.806 / Text5: christian.bergljung@stericsson.com
- 414: RP#53 completed. TR 37.868v100 for Approval (No WID change: RAN overload only). Triggered by TR 22.868 Study on Facilitating Machine to Machine Communication in GSM and UMTS (M2M) UID_7027 and Rel-10 NIMTC UID_410030 / Text3: UTRA, LTE 37.868 / Text5: Jeff Gao (gaoyq@huawei.com)
- 415: RP#54 completed / Text3: UTRA, LTE 37.901 / Text5: ron.borsato@spirent.com
- 416: RP#55 completion 03/12=>06/12. Updated WID RP-111623=>RP-120279. TR 37.803 v100 for Information / Text3: UTRA, LTE 37.803 / Text5: Martin.Warner@alcatel-lucent.com
- 417: RP#55 completion 03/12=>06/12. Linked to Study on Interference analysis between 800~900 MHz bands UID_510038 / Text3: UTRA, LTE 37.804 / Text5: Masahiro Fujii (fujiima@nttdocomo.co.jp)
- 418: - / Text3: UTRA, LTE 37.840 / Text5: Ronnie.zhang@huawei.com
- 419: Linked to Rel-10 WI on Multi-standard radio Base Station RF requirements for non-contiguous spectrum deployments (MSR_NC) UID_480025 / Text3: UTRA, LTE, GERAN 37.xxx / Text5: johan.skold@ericsson.com
- 420: RP#53 completed (1-step Approval) / Text3: UTRA 25.871 / Text5: Sharad Sambhwani
- 421: RP#53 completed / Text3: UTRA 25.872 / Text5: karri.ranta-aho@nsn.com
- 422: RP#55 completion 03/12=>06/12. Updated WID RP-111380=>RP-120208 / Text3: UTRA 25.914 / Text5: petri.j.vasenkari@nokia.com
- 423: - / Text3: UTRA 25.8xy / Text5: limei.wei@td-tech.com
- 424: -

| ID | WBS | Task | Type | Duration | Start | Finish | Complete | Remaining | Baseline start | Baseline finish | Baseline duration | Total slack | Constraint | Resources | Work | Actual work | Text1 | Text2 | Text4 | Text5 | Text6 | Text7 | Text8 | Text3 | Text9 | Text12 |
| --- | --- | --- | --- | --- | --- | --- | --- | --- | --- | --- | --- | --- | --- | --- | --- | --- | --- | --- | --- | --- | --- | --- | --- | --- | --- | --- |
| 425 | 182 | **Multi Access PDN Connectivity** |  | 527d? | 2009-03-13 A | 2011-03-18 A | 100% |  | 2009-03-13 | 2011-03-18 | 527d? |  |  | S2,C4,C1,C3 | 9592h | 9592h | MAPCON | PCG-22 | Telecom Italia | ivano.guardini@telecomitalia.it | Rel-10 | SP-43 | Maurice |  |  |  |
| 426 | 182.1 | Stage 2 for Multi Access PDN Connectivity |  | 401d? | 2009-03-13 A | 2010-09-23 A | 100% |  | 2009-03-13 | 2010-09-23 | 401d? |  |  | S2 | 3208h | 3208h | MAPCON |  | Telecom Italia | ivano.guardini@telecomitalia.it | Rel-10 |  | Maurice | 23.237, 23.401, 23.402 |  |  |
| 427 | 182.2 | **CT aspects of Multi Access PDN Connectivity** |  | 90d? | 2010-11-15 A | 2011-03-18 A | 100% |  | 2010-11-15 | 2011-03-18 | 90d? |  |  | C4,C1,C3 | 2168h | 2168h | MAPCON-St3 | PCG-26 | ZTE | Xingyue (Joy) Zhou (zhou.xingyue@zte.com.cn) | Rel-10 | CP-50 | Kimmo |  |  |  |
| 428 | 182.2.1 | CT4 aspects of Multi Access PDN Connectivity |  | 20d? | 2010-11-15 A | 2010-12-10 A | 100% |  | 2010-11-15 | 2010-12-10 | 20d? |  | start no earlier than 2010-12-10 | C4 | 160h | 160h | MAPCON-St3 | PCG-26 | ZTE | Xingyue (Joy) Zhou (zhou.xingyue@zte.com.cn) | Rel-10 | CP-50 | Kimmo | 29.273, 29.272, 29.002, 23.008 |  |  |
| 429 | 182.2.2 | CT1 aspects of Multi Access PDN Connectivity |  | 71d? | 2010-12-10 A | 2011-03-18 A | 100% |  | 2010-12-10 | 2011-03-18 | 71d? |  | start no earlier than 2010-12-10 | C1 | 568h | 568h | MAPCON-St3 | PCG-26 | ZTE | Xingyue (Joy) Zhou (zhou.xingyue@zte.com.cn) | Rel-10 | CP-50 | Frederic | 24.302, 24.312 |  |  |
| 430 | 182.2.3 | CT3 aspects of Multi Access PDN Connectivity |  | 90d? | 2010-11-15 A | 2011-03-18 A | 100% |  | 2010-11-15 | 2011-03-18 | 90d? |  | finish no earlier than 2011-03-18 | C3 | 720h | 720h | MAPCON-St3 | PCG-26 | ZTE | Xingyue (Joy) Zhou (zhou.xingyue@zte.com.cn) | Rel-10 | CP-50 | Jiwan | 29.215 |  |  |
| 431 | 183 | **Enabling Coder Selection and Rate Adaptation for UTRAN and E-UTRAN for Load Adaptive Applications** |  | 640d? | 2009-09-24 A | 2012-03-02 | 96% | 26.66d? | 2009-09-24 | 2012-03-02 | 640d? | 463d |  | S2,S4,C4,C3,C1,IETF | 22896h | 17064.5h | ECSRA_LAA | PCG-23 | Qualcomm | AC Mahendran (ac@qualcomm.com) | Rel-10 | SP-45 | Maurice | UTRA, LTE |  |  |
| 432 | 183.1 | TR on Enabling Coder Selection and Rate Adaptation for UTRAN and E-UTRAN for Load Adaptive Applications |  | 186d? | 2009-09-24 A | 2010-06-10 A | 100% |  | 2009-09-24 | 2010-06-10 | 186d? |  | finish no earlier than 2010-09-23 | S2,S4 | 1488h | 1488h | ECSRA_LAA | PCG-23 | Qualcomm | AC Mahendran (ac@qualcomm.com) | Rel-10 | SP-45 | Maurice | new 23.860 |  |  |
| 433 | 183.2 | SA4 review of TR on Enabling Coder Selection and Rate Adaptation for UTRAN and E-UTRAN for Load Adaptive Applications |  | 320d? | 2009-09-24 A | 2010-12-15 A | 100% |  | 2009-09-24 | 2010-12-15 | 320d? |  | finish no earlier than 2010-12-15 | S4 | 2560h | 2560h | ECSRA_LAA | PCG-23 | Qualcomm | AC Mahendran (ac@qualcomm.com) | Rel-10 | SP-45 | Paolo | new 23.860 |  |  |
| 434 | 183.3 | Stage 2 for Enabling Coder Selection and Rate Adaptation for UTRAN and E-UTRAN for Load Adaptive Applications |  | 261d? | 2009-09-24 A | 2010-09-23 A | 100% |  | 2009-09-24 | 2010-09-23 | 261d? |  | finish no earlier than 2010-09-23 | S2 | 2088h | 2088h | ECSRA_LAA | PCG-23 | Qualcomm | AC Mahendran (ac@qualcomm.com) | Rel-10 | SP-45 | Maurice | 23.060, 23.203, 23.228, 23.401 |  |  |
| 435 | 183.4 | SA4 aspects of Enabling Coder Selection and Rate Adaptation for UTRAN and E-UTRAN for Load Adaptive Applications |  | 130d? | 2010-09-23 A | 2011-03-23 A | 100% |  | 2010-09-23 | 2011-03-23 | 130d? |  | finish no earlier than 2011-03-23 | S4 | 1040h | 1040h | ECSRA_LAA | PCG-25 | Qualcomm | AC Mahendran (ac@qualcomm.com) | Rel-10 | SP-49 | Paolo | 26.114 |  |  |
| 436 | 183.5 | **CN aspects of Enabling Coder Selection and Rate Adaptation for UTRAN and E-UTRAN for Load Adaptive Applications** |  | 384d? | 2010-09-17 A | 2012-03-02 | 92% | 31.23d? | 2010-09-17 | 2012-03-02 | 384d? | 463d |  | C4,C3,C1 | 10600h | 8400.54h | ECSRA_LAA-CN | PCG-25 | Ericsson | Philip.hodges@ericsson.com | Rel-10 | CP-49 | Kimmo | Stage 2/3 |  |  |
| 437 | 183.5.1 | CT4 part of CN aspects of Enabling Coder Selection and Rate Adaptation for UTRAN and E-UTRAN for Load Adaptive Applications |  | 186d? | 2010-09-17 A | 2011-06-03 A | 100% |  | 2010-09-17 | 2011-06-03 | 186d? |  | start no earlier than 2010-09-17 | C4 | 1488h | 1488h | ECSRA_LAA-CN | PCG-25 | Ericsson | Philip.hodges@ericsson.com | Rel-10 | CP-49 | Kimmo | 23.334, 29.334, 29.238, 23.333, 29.333, 29.232, 29.332 |  |  |
| 438 | 183.5.2 | (IETF) CT4 part of CN aspects of Enabling Coder Selection and Rate Adaptation for UTRAN and E-UTRAN for Load Adaptive Applications |  | 384d? | 2010-09-17 A | 2012-03-02 | 80% | 76.6d? | 2010-09-17 | 2012-03-02 | 384d? | 463d | finish no earlier than 2012-03-02 | C4-IETF | 3064h | 2451.2h | ECSRA_LAA-CN_IETF | PCG-27 | Mark Jones |  | Rel-10 | CP-53 |  | draft-ietf-avtcore-ecn-for-rtp |  |  |
| 439 | 183.5.3 | CT3 part of CN aspects of Enabling Coder Selection and Rate Adaptation for UTRAN and E-UTRAN for Load Adaptive Applications |  | 186d? | 2010-09-17 A | 2011-06-03 A | 100% |  | 2010-09-17 | 2011-06-03 | 186d? |  | finish no earlier than 2011-06-03 | C3 | 1488h | 1488h | ECSRA_LAA-CN | PCG-25 | Ericsson | Philip.hodges@ericsson.com | Rel-10 | CP-49 | Jiwan | 29.162, 29.163, 29.213, 29.235, 29.292 |  |  |
| 440 | 183.5.4 | CT1 part of CN aspects of Enabling Coder Selection and Rate Adaptation for UTRAN and E-UTRAN for Load Adaptive Applications |  | 186d? | 2010-09-17 A | 2011-06-03 A | 100% |  | 2010-09-17 | 2011-06-03 | 186d? |  | start no earlier than 2010-09-17 | C1 | 1488h | 1488h | ECSRA_LAA-CN | PCG-25 | Ericsson | Philip.hodges@ericsson.com | Rel-10 | CP-49 | Frederic | 24.229 |  |  |
| 441 | 184 | **Optimal Media Routing** |  | 314d? | 2010-03-25 A | 2011-06-08 A | 100% |  | 2010-03-25 | 2011-06-08 | 314d? |  |  | S2,S5,C3,C1 | 10984h | 10984h | OMR | PCG-24 | Alcatel-Lucent | andy.bennett@alcatel-lucent.com | Rel-10 | SP-46 | Maurice |  |  |  |
| 442 | 184.1 | Stage 2 for Optimal Media Routing | milestone | 0d? | 2010-03-25 A | 2010-03-25 A | 100% |  | 2010-03-25 | 2010-03-25 | 0d? |  |  | S2 |  |  | OMR | PCG-24 | Alcatel-Lucent | andy.bennett@alcatel-lucent.com | Rel-10 | SP-46 | Maurice | 23.228 |  |  |
| 443 | 184.2 | **Stage 3 for Optimal Media Routing** |  | 261d? | 2010-06-04 A | 2011-06-03 A | 100% |  | 2010-06-04 | 2011-06-03 | 261d? |  |  | C3,C1,C4 | 7472h | 7472h | OMR | PCG-25 | Alcatel-Lucent | jim.calme@alcatel-lucent.com | Rel-10 | CP-48 | Jiwan |  |  |  |
| 444 | 184.2.1 | CT3 part of Stage 3 for Optimal Media Routeing |  | 261d? | 2010-06-04 A | 2011-06-03 A | 100% |  | 2010-06-04 | 2011-06-03 | 261d? |  | finish no earlier than 2011-06-03 | C3 | 2088h | 2088h | OMR | PCG-25 | Alcatel-Lucent | jim.calme@alcatel-lucent.com | Rel-10 | CP-48 | Jiwan | 29.162, 29.163, 29.165, 29.235, new TS 29.079 |  |  |
| 445 | 184.2.2 | CT1 part of Stage 3 for Optimal Media Routeing |  | 206d? | 2010-06-04 A | 2011-03-18 A | 100% |  | 2010-06-04 | 2011-03-18 | 206d? |  | finish no earlier than 2011-03-18 | C1 | 1648h | 1648h | OMR | PCG-25 | Alcatel-Lucent | jim.calme@alcatel-lucent.com | Rel-10 | CP-48 | Frederic | 24.229 |  |  |
| 446 | 184.2.3 | Deleted - CT4 part of Stage 3 for Optimal Media Routeing |  | 206d? | 2010-06-04 A | 2011-03-18 A | 100% |  | 2010-06-04 | 2011-03-18 | 206d? |  | finish no earlier than 2011-03-18 | C4 | 1648h | 1648h | OMR | PCG-25 | Alcatel-Lucent | jim.calme@alcatel-lucent.com | Rel-10 | CP-48 | Kimmo |  | PCG-26 | CP-51 |
| 447 | 184.3 | Charging for Optimal Media Routing |  | 125d? | 2010-12-16 A | 2011-06-08 A | 100% |  | 2010-12-16 | 2011-06-08 | 125d? |  | finish no earlier than 2011-06-08 | S5 | 1000h | 1000h | OMR | PCG-26 | Alcatel-Lucent | maryse.gardella@alcatel-lucent.com | Rel-10 | SP-50 | Dionisio | 32.260, 32.298, 32.299 |  |  |
| 448 | 185 | **S2b Mobility based on GTP** |  | 202d? | 2010-06-10 A | 2011-03-18 A | 100% |  | 2010-06-10 | 2011-03-18 | 202d? |  |  | S2,C4,C3,C1 | 5856h | 5856h | SMOG | PCG-25 | Alcatel-Lucent | bruno.landais@alcatel-lucent.com | Rel-10 | SP-48 | Maurice |  |  |  |
| 449 | 185.1 | Stage 2 for S2b Mobility based on GTP |  | 76d? | 2010-06-10 A | 2010-09-23 A | 100% |  | 2010-06-10 | 2010-09-23 | 76d? |  | finish no earlier than 2010-09-23 | S2 | 608h | 608h | SMOG | PCG-25 | Alcatel-Lucent | bruno.landais@alcatel-lucent.com | Rel-10 | SP-48 | Maurice | 23.002, 23.203, 23.402 |  |  |

Notes:
- 425: CP#51 completed. SP#49 Stage 2 completed. Triggered by TR 23.861 UID_410043 FS_MAPIM. Stage 1 in Rel-9 22.278 (6.2 - IP session control)
- 426: SP#49 completed. Triggered by TR 23.861 UID_410043 FS_MAPIM. Stage 1 in Rel-9 22.278 (6.2 - IP session control)
- 427: CP#51 completed
- 428: CP#50 completed
- 429: CP#51 completed
- 430: CP#51 completed
- 431: CP#52 completed. Triggered by Rel-9 UID_440013 Vocoder rate adaptation for LTE
- 432: SP#48 completed
- 433: SP#50 completed
- 434: SP#49 completed
- 435: SP#51 completed
- 436: CP#52 completed
- 437: CP#52 completed
- 438: Not completed internet-draft
- 439: CP#52 completed
- 440: CP#52 completed
- 441: CP#52 completed. SP#47 Stage 2 completed. Triggered by TR 23.894 (UID_370050 Study on System enhancements for the use of IMS services in local breakout)
- 442: SP#47 completed
- 443: CP#51 completion 03/11=>06/11. WID updated CP-100327=>CP-110134
- 444: CP#52 completed
- 445: CP#51 completed. WID updated CP-100327=>CP-110134
- 446: CP#51 stopped (CT4 specs not impacted). WID updated CP-100327=>CP-110134
- 447: SP#52 completed. Stage 3: Linked to CT3 TS 29.079 OMR within the IMS; Stage 3 (UID_480110)
- 448: CP#51 completed. SP#49 Stage 2 completed. Related to Rel-10 UID_470049 Study on S2b mobility based on GTP (TR23.834), UID_350027 SAE for support for non-3GPP accesses. Stage1 in Rel-8 UID_320022 Reqs for evolution of 3GPP system architecture (AIPN-SAE)
- 449: SP#49 completed

| ID | WBS | Task | Type | Duration | Start | Finish | Complete | Baseline start | Baseline finish | Baseline duration | Constraint | Resources | Work | Actual work | Text1 | Text2 | Text4 | Text5 | Text6 | Text7 | Text8 | Text9 | Text12 |
| --- | --- | --- | --- | --- | --- | --- | --- | --- | --- | --- | --- | --- | --- | --- | --- | --- | --- | --- | --- | --- | --- | --- | --- |
| 450 | 185.2 | **Stage 3 for S2b Mobility based on GTP** |  | 131d? | 2010-09-17 A | 2011-03-18 A | 100% | 2010-09-17 | 2011-03-18 | 131d? |  | C4,C3,C1 | 3632h | 3632h | SMOG-St3 | PCG-25 | Alcatel-Lucent | bruno.landais@alcatel-lucent.com | Rel-10 | CP-49 | Kimmo |  |  |
| 451 | 185.2.1 | CT4 part of Stage 3 for S2b Mobility based on GTP |  | 131d? | 2010-09-17 A | 2011-03-18 A | 100% | 2010-09-17 | 2011-03-18 | 131d? | finish no earlier than 2011-03-18 | C4 | 1048h | 1048h | SMOG-St3 | PCG-25 | Alcatel-Lucent | bruno.landais@alcatel-lucent.com | Rel-10 | CP-49 | Kimmo |  |  |
| 452 | 185.2.2 | CT3 part of Stage 3 for S2b Mobility based on GTP |  | 131d? | 2010-09-17 A | 2011-03-18 A | 100% | 2010-09-17 | 2011-03-18 | 131d? | finish no earlier than 2011-03-18 | C3 | 1048h | 1048h | SMOG-St3 | PCG-25 | Alcatel-Lucent | bruno.landais@alcatel-lucent.com | Rel-10 | CP-49 | Jiwan |  |  |
| 453 | 185.2.3 | CT1 part of Stage 3 for S2b Mobility based on GTP |  | 61d? | 2010-09-17 A | 2010-12-10 A | 100% | 2010-09-17 | 2010-12-10 | 61d? | finish no earlier than 2010-12-10 | C1 | 488h | 488h | SMOG-St3 | PCG-25 | Alcatel-Lucent | bruno.landais@alcatel-lucent.com | Rel-10 | CP-49 | Frederic |  |  |
| 454 | 186 | **Policy Enhancements for Sponsored Connectivity and Coherent Access to Policy related Databases** |  | 113.15d? | 2010-10-12 A | 2011-03-18 A | 100% | 2010-10-12 | 2011-03-18 | 113.15d? |  | S2,C3 | 1473.2h | 1473.2h | PEST | PCG-26 | Qualcomm | AC Mahendran (ac@qualcomm.com) | Rel-10 | SP-50 | Maurice |  |  |
| 455 | 186.1 | Stage 2 for Policy Enhancements for Sponsored Connectivity and Coherent Access to Policy related Databases | milestone | 0d? | 2010-10-12 A | 2010-12-15 A | 100% | 2010-10-12 | 2010-12-15 | 0d? | finish no earlier than 2010-12-15 | S2 |  |  | PEST | PCG-26 | Qualcomm | AC Mahendran (ac@qualcomm.com) | Rel-10 | SP-50 | Maurice |  |  |
| 456 | 186.2 | CT3 aspects of Policy Enhancements for Sponsored Connectivity and Coherent Access to Policy related Databases |  | 71d? | 2010-12-10 A | 2011-03-18 A | 100% | 2010-12-10 | 2011-03-18 | 71d? | finish no earlier than 2011-03-18 | C3 | 568h | 568h | PEST-CT3 | PCG-26 | ZTE | zhou.xiaoyun@zte.com.cn | Rel-10 | CP-50 | Jiwan |  |  |
| 457 | 187 | **Lawful Interception in the 3GPP Rel-10** |  | 315d? | 2010-03-25 A | 2011-06-08 A | 100% | 2010-03-25 | 2011-06-08 | 315d? |  | S3 | 20480h | 20480h | LI10 | PCG-24 | PIDS, BT | Koen Jaspers (k.b.jaspers@minjus.nl), alex.leadbeater@bt.com | Rel-10 | SP-47 | Dionisio |  |  |
| 458 | 187.1 | LI for CAT (Customer Alerting Tones) |  | 315d? | 2010-03-25 A | 2011-06-08 A | 100% | 2010-03-25 | 2011-06-08 | 315d? | finish no earlier than 2011-03-23 | S3 | 2520h | 2520h | LI10 | PCG-24 | PIDS, BT | Koen Jaspers (k.b.jaspers@minjus.nl), alex.leadbeater@bt.com | Rel-10 | SP-47 | Dionisio |  |  |
| 459 | 187.2 | LI for CRS (Customized Ringing Signal) |  | 315d? | 2010-03-25 A | 2011-06-08 A | 100% | 2010-03-25 | 2011-06-08 | 315d? | finish no earlier than 2011-03-23 | S3 | 2520h | 2520h | LI10 | PCG-24 | PIDS, BT | Koen Jaspers (k.b.jaspers@minjus.nl), alex.leadbeater@bt.com | Rel-10 | SP-47 | Dionisio |  |  |
| 460 | 187.3 | LI for EPS enhancements |  | 315d? | 2010-03-25 A | 2011-06-08 A | 100% | 2010-03-25 | 2011-06-08 | 315d? | finish no earlier than 2011-03-23 | S3 | 2520h | 2520h | LI10 | PCG-24 | PIDS, BT | Koen Jaspers (k.b.jaspers@minjus.nl), alex.leadbeater@bt.com | Rel-10 | SP-47 | Dionisio |  |  |
| 461 | 187.4 | LI for VCC (Voice Call Continuity) |  | 260d? | 2010-03-25 A | 2011-03-23 A | 100% | 2010-03-25 | 2011-03-23 | 260d? | finish no earlier than 2011-03-23 | S3 | 2080h | 2080h | LI10 | PCG-24 | PIDS, BT | Koen Jaspers (k.b.jaspers@minjus.nl), alex.leadbeater@bt.com | Rel-10 | SP-47 | Dionisio |  |  |
| 462 | 187.5 | LI for MEDIASEC (IMS Media security) |  | 260d? | 2010-03-25 A | 2011-03-23 A | 100% | 2010-03-25 | 2011-03-23 | 260d? | finish no earlier than 2011-03-23 | S3 | 2080h | 2080h | LI10 | PCG-24 | PIDS, BT | Koen Jaspers (k.b.jaspers@minjus.nl), alex.leadbeater@bt.com | Rel-10 | SP-47 | Dionisio |  |  |
| 463 | 187.6 | LI for H(e)NB also with Local IP Access and Selected IP Traffic Offload (LIPA, SIPTO) |  | 260d? | 2010-03-25 A | 2011-03-23 A | 100% | 2010-03-25 | 2011-03-23 | 260d? | finish no earlier than 2011-03-23 | S3 | 2080h | 2080h | LI10 | PCG-24 | PIDS, BT | Koen Jaspers (k.b.jaspers@minjus.nl), alex.leadbeater@bt.com | Rel-10 | SP-47 | Dionisio |  |  |
| 464 | 187.7 | LI for MBMS_LTE_enh (Multimedia Broadcast and Multicast Service enhancements) |  | 260d? | 2010-03-25 A | 2011-03-23 A | 100% | 2010-03-25 | 2011-03-23 | 260d? | finish no earlier than 2011-03-23 | S3 | 2080h | 2080h | LI10 | PCG-24 | PIDS, BT | Koen Jaspers (k.b.jaspers@minjus.nl), alex.leadbeater@bt.com | Rel-10 | SP-47 | Dionisio |  |  |
| 465 | 187.8 | LI for LCLS (Local Call Local Switch) |  | 260d? | 2010-03-25 A | 2011-03-23 A | 100% | 2010-03-25 | 2011-03-23 | 260d? | finish no earlier than 2011-03-23 | S3 | 2080h | 2080h | LI10 | PCG-24 | PIDS, BT | Koen Jaspers (k.b.jaspers@minjus.nl), alex.leadbeater@bt.com | Rel-10 | SP-47 | Dionisio |  |  |
| 466 | 188 | Optimization of IMS based PSS and MBMS User Service |  | 260d? | 2010-03-25 A | 2011-03-23 A | 100% | 2010-03-25 | 2011-03-23 | 260d? | finish no earlier than 2011-03-23 | S4 | 2080h | 2080h | OPT_IMS_PSS_MBMS_US | PCG-24 | Ericsson | markus.kampmann@ericsson.com | Rel-10 | SP-47 | Paolo |  |  |
| 467 | 189 | **HTTP-based Streaming and Download Services** |  | 392d? | 2010-03-25 A | 2011-09-21 A | 100% | 2010-03-25 | 2011-09-21 | 392d? |  | S4,IETF | 5356.4h | 5356.4h | HTTP_SDS | PCG-24 | Qualcomm | Thomas Stockhammer (c_tstock@qualcomm.com) | Rel-10 | SP-47 | Paolo |  |  |
| 468 | 189.1 | HTTP-based Streaming and Download Services in 3GPP |  | 315d? | 2010-03-25 A | 2011-06-08 A | 100% | 2010-03-25 | 2011-06-08 | 315d? | finish no earlier than 2011-05-26 | S4 | 2520h | 2520h | HTTP_SDS | PCG-24 | Qualcomm | Thomas Stockhammer (c_tstock@qualcomm.com) | Rel-10 | SP-47 | Paolo |  |  |
| 469 | 189.2 | (IETF) HTTP-based Streaming and Download Services in 3GPP |  | 211.6d? | 2010-03-25 A | 2011-09-21 A | 100% | 2010-03-25 | 2011-09-21 | 211.6d? | start no earlier than 2010-03-25 | S4-IETF | 1676.8h | 1676.8h | HTTP_SDS_IETF | PCG-27 |  |  | Rel-10 | CP-52 | Paolo |  |  |
| 470 | 190 | PSS and MBMS enhancements |  | 205d? | 2010-06-10 A | 2011-03-23 A | 100% | 2010-06-10 | 2011-03-23 | 205d? | finish no earlier than 2011-03-23 | S4 | 1640h | 1640h | MBS_Enh | PCG-25 | Ericsson | Markus.Kampmann@ericsson.com | Rel-10 | SP-48 | Paolo |  |  |
| 471 | 191 | Enhancements and Addition of Audio Tests to 26.131 and 26.132 |  | 260d? | 2010-06-10 A | 2011-06-08 A | 100% | 2010-06-10 | 2011-06-08 | 260d? | finish no earlier than 2011-06-08 | S4 | 2080h | 2080h | EAAT | PCG-25 | Vodafone | ramin.afchar@vodafone.com | Rel-10 | SP-48 | Paolo |  |  |
| 472 | 192 | Video Coding Enhancements in MTSI |  | 3d? | 2011-03-21 A | 2011-03-23 A | 100% | 2011-03-21 | 2011-03-23 | 3d? | start no earlier than 2011-03-21 | S4 | 24h | 24h | VCEM | PCG-26 | Ericsson | frederic.gabin@ericsson.com | Rel-10 | SP-51 | Paolo |  |  |
| 473 | 193 | **Rel-10 Operations, Administration, Maintenance and Provisioning (OAM&P)** |  | 467d? | 2009-12-10 A | 2011-09-21 A | 100% | 2009-12-10 | 2011-09-21 | 467d? |  | S5,C4 | 45368h | 45368h | OAM10 | PCG-24 |  |  | Rel-10 | SP-46 | Dionisio |  |  |
| 474 | 193.1 | **Rel-10 Network Infrastructure Management** |  | 467d? | 2009-12-10 A | 2011-09-21 A | 100% | 2009-12-10 | 2011-09-21 | 467d? |  | S5 | 14592h | 14592h | OAM10-NIM | PCG-24 |  |  | Rel-10 | SP-46 | Dionisio |  |  |
| 475 | 193.1.1 | Common RAT Network Resource Model (NRM) |  | 390d? | 2009-12-10 A | 2011-06-08 A | 100% | 2009-12-10 | 2011-06-08 | 390d? | finish no earlier than 2011-06-08 | S5 | 3120h | 3120h | RAT_NRM_common | PCG-24 | Ericsson | robert.petersen@ericsson.com | Rel-10 | SP-46 | Dionisio |  |  |
| 476 | 193.1.2 | IRP Solution Set specification organisation improvements |  | 260d? | 2010-03-25 A | 2011-03-23 A | 100% | 2010-03-25 | 2011-03-23 | 260d? | finish no earlier than 2011-03-23 | S5 | 2080h | 2080h | OAM-IRP-SS | PCG-24 | Nokia Siemens Networks, Huawei | Jörg Schmidt (joerg@cox.net), Lan Zou (zlan@huawei.com) | Rel-10 | SP-47 | Dionisio |  |  |
| 477 | 193.1.3 | Deleted - Service Oriented Architecture (SOA) for IRP continuation from Rel-9 |  | 260d? | 2010-03-25 A | 2011-03-23 A | 100% | 2010-03-25 | 2011-03-23 | 260d? | finish no earlier than 2011-06-08 | S5 | 2080h | 2080h | OAM-SOA-IRP | PCG-24 | Nokia Siemens Networks, Ericsson | Jörg Schmidt (joerg@cox.net), edwin.tse@ericsson.com | Rel-10 | SP-47 | Dionisio | PCG-26 | SP-51 |
| 478 | 193.1.4 | IRP Overview, Profiles & Usage Guide |  | 260d? | 2010-06-10 A | 2011-06-08 A | 100% | 2010-06-10 | 2011-06-08 | 260d? | finish no earlier than 2011-06-08 | S5 | 2080h | 2080h | OAM-NIM-IRP_OPU | PCG-25 | Nokia Siemens Networks | Jörg Schmidt (joerg@cox.net) | Rel-10 | SP-48 | Dionisio |  |  |
| 479 | 193.1.5 | Alarm Correlation and Root Cause Analysis |  | 133d? | 2011-03-23 A | 2011-09-21 A | 100% | 2011-03-23 | 2011-09-21 | 133d? | finish no earlier than 2011-09-21 | S5 | 1048h | 1048h | OAM-AC-RCA | PCG-26 | Ericsson | brendan.hassett@ericsson.com | Rel-10 | SP-51 | Dionisio |  |  |
| 480 | 193.1.6 | Inventory Management Network Resource Model enhancements |  | 56d? | 2011-03-23 A | 2011-06-08 A | 100% | 2011-03-23 | 2011-06-08 | 56d? | start no earlier than 2011-03-23 | S5 | 448h | 448h | OAM-IM-NMR | PCG-26 | Nokia Siemens Networks | olaf.pollakowski@nsn.com | Rel-10 | SP-51 | Dionisio |  |  |

Notes:
- 450: CP#51 Stage 3 completed
- 451: CP#51 completed / Text3: 23.003, 23.007, 23.008, 29.273, 29.274, 29.281, 29.303
- 452: CP#51 completed / Text3: 29.212, 29.213, 29.215
- 453: CP#50 completed / Text3: 24.302
- 454: CP#51 completed. SP#50 Stage 2 completed. Triggered by the SA1,SA2 Rel-10 TR 23.813 Study on Policy solutions and enhancements (FS_PP) UID_440047. Provides Video Call seamless service continuity for 3G/LTE terminal user
- 455: SP#51 updated WID SP-100702=>SP-110196. SA#49 work completed as SA2 CRs approved under TEI10 (SP-10557) / Text3: 23.002, 23.203
- 456: CP#51 completed / Text3: 29.212, 29.213, 29.214, 29.215
- 457: SP#52 completed / Text3: 33.106 (LI requirements), 33.107 (LI architecture and functions), 33.108 (Handover interface for LI)
- 458: SP#52 completed / Text3: 33.106, 33.107, 33.108
- 459: SP#52 completed / Text3: 33.106, 33.107, 33.108
- 460: SP#52 completed / Text3: 33.106, 33.107, 33.108
- 461: SP#51 completed / Text3: 33.106, 33.107, 33.108
- 462: SP#51 completed / Text3: 33.106, 33.107, 33.108
- 463: SP#51 completed / Text3: 33.106, 33.107, 33.108
- 464: SP#51 completed / Text3: 33.106, 33.107, 33.108
- 465: SP#51 completed / Text3: 33.106, 33.107, 33.108
- 466: SP#51 completed. Work to enhance UID_430046 Rel-9 IMS_PSS_MBMS_US_EXT / Text3: 26.237
- 467: SP#52 completed. Work to enhance UID_430038 Rel-9 PSS and MBMS extensions
- 468: SP#52 completed / Text3: 26.234, 26.244, 26.346, new TS 26.247
- 469: SP#53/IETF#81: Draft not included in 3GPP documentation / Text3: draft-gellens-mime-bucket-bis
- 470: SP#51 completed. Linked to Rel-9 Feature UID_430038 PSS and MBMS extensions (PMA-MBS_Ext). / Text3: 26.234, 26.346
- 471: SP#52 completed. Reduce fragmentation in acoustic testing (3GPP SA4, ETSI STQ, GCF CAG, CTIA) & Review existing acoustic tests to determine need for new spec / Text3: 26.131, 26.132
- 472: SP#51 completed. Linked to Rel-7 UID_7040 Multimedia Telephony Service for IMS - Media handling and interaction in MTSI (MTSI-MHI) / Text3: 26.114
- 473: umbrella Feature / Text3: TR 30.820
- 474: umbrella BB
- 475: SP#52 completed. Share equipment btw several RATs (RET,TMA,repeaters) to reduce costs. With existing modelling is difficult to see that several cells are affected when an antenna tilt is changed etc / Text3: 32.616, 32.642, 32.646, 32.652, 32.656, 32.762, 32.766 new (32.791, 32.792, 32.796)
- 476: SP#51 completed / Text3: 32.153, new (32.111-6,32.126,32.176,32.306,32.316,32.326,32.336,32.346,32.356,32.366,32.376,32.386,32.396,32.416,32.446,32.506/26/36,32.606,32.616,32.626,32.636,32.646,32.656,32.666,32.676,32.696,32.716,32.726,32.736,32.746,32.756,32.766,32.776,32.786)
- 477: SP#51 work stopped (Reason: lack of progress). Continuation of Rel-9 UID_440065 SOA for IRP (covering SOA Architecture & SOA-supporting Solution Set) to address SOA conforming Registration & Discovery capabilities / Text3: 32.101, 32.150
- 478: SP#52 completed. Updated WID SP-100777=>SP-110277 / Text3: new TS 32.103
- 479: SP#53 completed. Triggered by Rel-10 TR 32.832 Study on Alarm Correlation and Alarm Root Cause Analysis UID_480045 & TR 32.829 Study on Harmonization of 3GPP Alarm IRP and TMF Interface Program Fault Management UID_460038 / Text3: 32.111-1, 32.111-2, 32.111-6
- 480: SP#52 completed. Inventory NRM specified in Rel-6 is mainly hardware related. Rel-10 TR 32.828 recommends extending the scope of inventory NRM. Additionally, NGMN Top OPE Recs, v1.0 sets inventory enhancements as one of top 10 priority items / Text3: 32.690, 32.691, 32.692, 32.696

| ID | WBS | Task | Duration | Start | Finish | Complete | Baseline start | Baseline finish | Baseline duration | Constraint | Resources | Work | Actual work | Text1 | Text2 | Text6 | Text7 | Text8 | Text4 |
| --- | --- | --- | --- | --- | --- | --- | --- | --- | --- | --- | --- | --- | --- | --- | --- | --- | --- | --- | --- |
| 481 | 193.2 | **Rel-10 Self-Organizing Networks (SON) - OAM aspects** | 390d? | 2009-12-10 A | 2011-06-08 A | 100% | 2009-12-10 | 2011-06-08 | 390d? |  | S5 | 11000h | 11000h | OAM10-SON | PCG-24 | Rel-10 | SP-46 | Dionisio |  |
| 482 | 193.2.1 | SON Self-optimization management continuation | 390d? | 2009-12-10 A | 2011-06-08 A | 100% | 2009-12-10 | 2011-06-08 | 390d? | finish no earlier than 2011-03-23 | S5 | 3120h | 3120h | LTE-SON-OAM_SO | PCG-24 | Rel-10 | SP-46 | Dionisio | Huawei |
| 483 | 193.2.2 | SON Self-healing management | 335d? | 2009-12-10 A | 2011-03-23 A | 100% | 2009-12-10 | 2011-03-23 | 335d? | finish no earlier than 2011-03-23 | S5 | 2680h | 2680h | LTE-SON-OAM_SH | PCG-24 | Rel-10 | SP-46 | Dionisio | ZTE |
| 484 | 193.2.3 | OAM aspects of Energy Saving in Radio Networks | 260d? | 2010-03-25 A | 2011-03-23 A | 100% | 2010-03-25 | 2011-03-23 | 260d? | finish no earlier than 2011-03-23 | S5 | 2080h | 2080h | OAM-ES | PCG-24 | Rel-10 | SP-47 | Dionisio | Nokia Siemens Networks |
| 485 | 193.3 | Rel-10 Subscription Management (SuM) evolution | 260d? | 2010-03-25 A | 2011-03-23 A | 100% | 2010-03-25 | 2011-03-23 | 260d? | finish no earlier than 2011-03-23 | S5 | 2080h | 2080h | OAM10-SuM | PCG-24 | Rel-10 | SP-47 | Dionisio | Ericsson |
| 486 | 193.4 | **Rel-10 Performance Management** | 315d? | 2010-03-25 A | 2011-06-08 A | 100% | 2010-03-25 | 2011-06-08 | 315d? |  | S5,C4 | 13960h | 13960h | OAM10-PM | PCG-24 | Rel-10 | SP-47 | Dionisio |  |
| 487 | 193.4.1 | Key Performance Indicators (KPIs) for IMS | 260d? | 2010-03-25 A | 2011-03-23 A | 100% | 2010-03-25 | 2011-03-23 | 260d? | finish no earlier than 2011-03-23 | S5 | 2080h | 2080h | OAM-PM-KPI_IMS | PCG-24 | Rel-10 | SP-47 | Dionisio | China Mobile |
| 488 | 193.4.2 | Key Performance Indicators (KPIs) for EPC | 260d? | 2010-03-25 A | 2011-03-23 A | 100% | 2010-03-25 | 2011-03-23 | 260d? | finish no earlier than 2011-03-23 | S5 | 2080h | 2080h | OAM-PM-KPI_EPC | PCG-24 | Rel-10 | SP-47 | Dionisio | China Mobile |
| 489 | 193.4.3 | **Management of UE based network performance measurements** | 315d? | 2010-03-25 A | 2011-06-08 A | 100% | 2010-03-25 | 2011-06-08 | 315d? |  | S5,C4 | 5200h | 5200h | OAM-PM-UE | PCG-24 | Rel-10 | SP-47 | Dionisio | Huawei, Nokia Siemens Networks, Ericsson |
| 490 | 193.4.3.1 | SA5 aspects of Management of UE based network performance measurements | 315d? | 2010-03-25 A | 2011-06-08 A | 100% | 2010-03-25 | 2011-06-08 | 315d? | finish no earlier than 2011-06-08 | S5 | 2520h | 2520h | OAM-PM-UE | PCG-24 | Rel-10 | SP-47 | Dionisio | Huawei, Nokia Siemens Networks, Ericsson |
| 491 | 193.4.3.2 | CN aspects of Management of UE based network performance measurements | 20d? | 2011-02-21 A | 2011-03-18 A | 100% | 2011-02-21 | 2011-03-18 | 20d? | start no earlier than 2011-02-21 | C4 | 160h | 160h | OAM-PM-UE | PCG-26 | Rel-10 | CP-51 | Kimmo | Nokia Siemens Networks |
| 492 | 193.4.4 | 3G HNB and LTE HeNB Subsystem performance measurements | 260d? | 2010-03-25 A | 2011-03-23 A | 100% | 2010-03-25 | 2011-03-23 | 260d? | finish no earlier than 2011-03-23 | S5 | 2080h | 2080h | OAM-PM-HeNS | PCG-24 | Rel-10 | SP-47 | Dionisio | China Mobile |
| 493 | 194 | **Rel-10 Charging Management small Enhancements** | 470d? | 2009-06-04 A | 2011-03-23 A | 100% | 2009-06-04 | 2011-03-23 | 470d? |  | S5 | 7520h | 7520h | CH10 | PCG-24 | Rel-10 | SP-47 | Dionisio |  |
| 494 | 194.1 | IWLAN mobility charging | 470d? | 2009-06-04 A | 2011-03-23 A | 100% | 2009-06-04 | 2011-03-23 | 470d? | finish no earlier than 2011-03-23 | S5 | 3760h | 3760h | eIWLAN_Mob | PCG-23 | Rel-10 | SP-44 | Dionisio | Orange |
| 495 | 195 | **Advice of Charge (AoC) service support enhancements** | 312d? | 2010-03-25 A | 2011-06-03 A | 100% | 2010-03-25 | 2011-06-03 | 312d? |  | S5,C1 | 6064h | 6064h | eAoC | PCG-24 | Rel-10 | SP-47 | Dionisio | Deutsche Telekom |
| 496 | 195.1 | SA5 part - AoC enhancements | 260d? | 2010-03-25 A | 2011-03-23 A | 100% | 2010-03-25 | 2011-03-23 | 260d? | finish no earlier than 2011-03-23 | S5 | 2080h | 2080h | eAoC | PCG-24 | Rel-10 | SP-47 | Dionisio | Deutsche Telekom |
| 497 | 195.2 | CT1 part - AoC enhancements (Stage 3) | 186d? | 2010-09-17 A | 2011-06-03 A | 100% | 2010-09-17 | 2011-06-03 | 186d? | finish no earlier than 2011-06-03 | C1 | 1488h | 1488h | eAoC | PCG-25 | Rel-10 | CP-49 | Frederic | Deutsche Telekom |
| 498 | 196 | IMS Stage 3 - IETF Protocol Alignment - phase 4 | 261d? | 2010-03-19 A | 2011-03-18 A | 100% | 2010-03-19 | 2011-03-18 | 261d? | finish no earlier than 2011-03-18 | C1 | 2088h | 2088h | IMSProtoc4 | PCG-24 | Rel-10 | CP-47 | Frederic | Alcatel-Lucent |
| 499 | 197 | Enhanced User Data Convergence (UDC) Model | 206d? | 2010-06-04 A | 2011-03-18 A | 100% | 2010-06-04 | 2011-03-18 | 206d? | finish no earlier than 2011-03-18 | C4 | 1648h | 1648h | eUDC | PCG-25 | Rel-10 | CP-48 | Kimmo | China Mobile |
| 500 | 198 | Further improvements of II-NNI Stage 3 based on operational feedback and evolution of other specifications | 206d? | 2010-06-04 A | 2011-03-18 A | 100% | 2010-06-04 | 2011-03-18 | 206d? | start no earlier than 2010-06-04 | C3 | 1648h | 1648h | II-NNI2 | PCG-25 | Rel-10 | CP-48 | Jiwan | Orange |
| 501 | 199 | AT Commands for IMS-configuration | 206d? | 2010-06-04 A | 2011-03-18 A | 100% | 2010-06-04 | 2011-03-18 | 206d? |  | C1 | 1648h | 1648h | AT_IMS | PCG-25 | Rel-10 | CP-48 | Frederic | Ericsson |
| 502 | 200 | AT Commands for USIM Application Toolkit (USAT) | 131d? | 2010-09-17 A | 2011-03-18 A | 100% | 2010-09-17 | 2011-03-18 | 131d? |  | C1 | 52.4h | 52.4h | AT_UICC | PCG-25 | Rel-10 | CP-49 | Frederic | ST-Ericsson |
| 503 | 201 | Communication Control for IMS by USIM (Stage 3) | 131d? | 2010-09-17 A | 2011-03-18 A | 100% | 2010-09-17 | 2011-03-18 | 131d? | start no earlier than 2010-09-17 | C6 | 1048h | 1048h | CC_IMS_USIM | PCG-25 | Rel-10 | CP-49 | Xavier | Gemalto |
| 504 | 202 | Dynamic view of SIP message for Inter-IMS Network to Network Interface (II-NNI) (Stage 3) | 126d? | 2010-12-10 A | 2011-06-03 A | 100% | 2010-12-10 | 2011-06-03 | 126d? | finish no earlier than 2011-06-03 | C3 | 1008h | 1008h | NNI_DV | PCG-26 | Rel-10 | CP-50 | Jiwan | NTT |
| 505 | 203 | Introduction of Smart Card Web Server launch functionality | 71d? | 2010-12-10 A | 2011-03-18 A | 100% | 2010-12-10 | 2011-03-18 | 71d? | finish no earlier than 2011-03-18 | C6 | 568h | 568h | SCWS_L | PCG-26 | Rel-10 | CP-50 | Xavier | Telecom Italia |
| 506 | 204 | USAT using AT Commands | 71d? | 2010-12-10 A | 2011-03-18 A | 100% | 2010-12-10 | 2011-03-18 | 71d? | finish no earlier than 2011-03-18 | C6 | 568h | 568h | USAT_AT | PCG-26 | Rel-10 | CP-50 | Xavier | Giesecke & Devrient |

Notes:
- 481: umbrella BB
- 482: SP#52 completed. Cont'd Rel-9 SON self-optimization management UID_390007 / Text3: 32.425, 32.521, 32.522, 32.526, 32.762, 32.766 / Text5: Lan Zou (zlan@huawei.com)
- 483: SP#51 completed. WID updated SP-100776=>SP-110150. Work moved to Rel-10 after split of the Rel-9 UID_390007 SON self-optimization (removed Self-Healing handling) / Text3: 32.522, 32.526, 32.762, 32.766, new TS 32.541 / Text5: zhu.weihong@zte.com.cn
- 484: SP#51 completed. WID updated SP-100226=>SP-110128. Triggered by Rel-10 TR 32.826 Study on Telecommunication Management; Energy Savings Management (FS_OAM_ESM) UID_430044 / Text3: 32.425, 32.522, 32.526, 32.626, 32.762, 32.766, new TS 32.551 / Text5: clemens.suerbaum@nsn.com
- 485: SP#51 completed / Text3: 32.172, 32.175, 32.176 / Text5: leo.yang@ericsson.com
- 486: umbrella BB
- 487: SP#51 completed / Text3: new 32.454 / Text5: Li Jian (lijian@chinamobile.com), Liang Shuangchun (liangshuangchun@cmdi.chinamobile.com)
- 488: SP#51 completed / Text3: new 32.455 / Text5: Li Jian (lijian@chinamobile.com), Liang Shuangchun (liangshuangchun@cmdi.chinamobile.com)
- 489: SP#52 completed. Stage 2/3. Linked to UID_460003 Minimization of drive tests for E-UTRAN and UTRAN (MDT_UMTSLTE) / Text5: Zou Lan (zlan@huawei.com), gyula.bodog@nsn.com, ulf.hubinette@ericsson.com
- 490: SP#52 completed / Text3: 32.421, 32.422, 32.423, 32.441, 32.442, 32.446 / Text5: Zou Lan (zlan@huawei.com), gyula.bodog@nsn.com, ulf.hubinette@ericsson.com
- 491: CP#51 completed under the SA5 WI code / Text3: 23.008 (CR#0330), 29.002 (CR#1007), 29.230 (CR#0207), 29.272 (CR#0329) / Text5: ulrich.wiehe@nsn.com
- 492: SP#51 completed / Text3: 32.582, 32.592, new (32.452, 32.453) / Text5: Chen Gang (chengang@chinamobile.com)
- 493: umbrella Feature / Text3: TR 30.820
- 494: SP#51 completed. RAT differentiation for charging. Completes Rel-8 Feature IWLAN_Mob UID_370049 Mobility between 3GPP-WLAN Interworking and 3GPP Systems. Cooperation with CT1,CT3 on affected protocols / Text3: 32.240, 32.252, 32.298, 32.299 / Text5: Jean-Luc Garcia (jl.garcia@orange-ftgroup.com)
- 495: CP#52 completed. SP#51 completed SA5. Continuation of Rel-8 BB UID_80042: Advice of Charge (AoC) support in IMS Charging (IMSTSS). Stage 2/3 work / Text5: matthias.seibel@telekom.de
- 496: SP#51 completed. SA1 Stage 1 in 22.115 / Text3: 32.275, 32.280, 32.298, 32.299 / Text5: matthias.seibel@telekom.de
- 497: CP#52 completed. SA1 Stage 1 in 22.115, 22.173, 22.024. Add mobile-specific CAI format and volume charging elements. Extensions to existing AoC XML / Text3: 24.647 / Text5: reinhard.lauster@t-mobile.at
- 498: CP#51 completed. Ensure protocol alignment between 3GPP Stage 3 IMS work and IETF. Review capabilities provided in SIP by IETF and document whether these capabilities are supported in the IM CN Subsystem or not / Text3: 23.218, 24.229, 24.930 / Text5: keith.drage@alcatel-lucent.com
- 499: CP#51 completed. Specify CRUD (Create/Read/Update/Delete) operations based on SOAP protocol, which may be used by the applications having no high real-time requirement to the data access operations / Text3: 29.335 / Text5: Lan Sizhong (lansizhong@chinamobile.com)
- 500: CP#51 completed. Improvements of Rel-9 Feature UID_440027 Operational description of the Inter-IMS Network to Network Interface (II-NNI) / Text3: 29.165 / Text5: beata.dobrowolska@orange-ftgroup.com
- 501: CP#51 completed. Specify 1) IMS-related AT-commands to configure MT and 2) IMS-related unsolicited response codes from MT to present to end-user / Text3: 27.007 / Text5: atle.monrad@ericsson.com
- 502: CP#51 completed / Text3: 27.007 / Text5: magnus.mk.karlsson@stericsson.com
- 503: CT#51 completed. Stage 1 in TS 22.038 USAT service description. Linked to CT6's UID_1273 Rel-5 BB Provisioning of IP-based multimedia services (24.229, 31.103) and UID_390021 Rel-8 BB CT6 aspects of SAE (31.102, 31.111) / Text3: 31.102, 31.103, 31.111 / Text5: Denis.Lheriteau@gemalto.com
- 504: CP#52 completed. Linked to CT3 Rel-10 Feature UID_480014 Further improvements of II-NNI Stage 3 based on operational feedback and evolution of other specifications (II-NNI2) / Text3: 29.165 / Text5: arai.kenjiro@lab.ntt.co.jp
- 505: CP#51 completed. Define a solution which allows enabling to launch Smart Card Web Server services in an easy and simple manner / Text3: 31.102 / Text5: davide.pratone@telecomitalia.it
- 506: CP#51 completed. Stage 3 based on SA1 22.038CR#37r1 (Make USAT proactive capability reqs applicable to ME as a whole without regard to any particular configuration; e.g. a modem connected to an external display) / Text3: Stage 3 31.102, 31.111 / Text5: enric.fort@gi-de.com

| ID | WBS | Task | Type | Duration | Start | Finish | Complete | Remaining | Baseline start | Baseline finish | Baseline duration | Total slack | Constraint | Resources | Work | Actual work | Text1 | Text2 | Text4 | Text5 | Text6 | Text7 | Text8 | Text9 | Text12 |
| --- | --- | --- | --- | --- | --- | --- | --- | --- | --- | --- | --- | --- | --- | --- | --- | --- | --- | --- | --- | --- | --- | --- | --- | --- | --- |
| 507 | 205 | **Single Radio Voice Call Continuity (SRVCC) enhancements (Stage 3)** |  | 464d? | 2010-12-10 A | 2012-09-14 | 64% | 168.13d? | 2010-12-10 | 2012-09-14 | 464d? | 323d |  | C1,C4,IETF | 7270.4h | 2631.2h | eSRVCC | PCG-26 | China Mobile | Jiang Y (jiangyi@chinamobile.com) | Rel-10 | CP-50 | Frederic |  |  |
| 508 | 205.1 | CT1 part of Stage 3 for SRVCC enhancements |  | 71d? | 2010-12-10 A | 2011-03-18 A | 100% |  | 2010-12-10 | 2011-03-18 | 71d? |  | finish no earlier than 2011-03-18 | C1 | 568h | 568h | eSRVCC | PCG-26 | China Mobile | Jiang Y (jiangyi@chinamobile.com) | Rel-10 | CP-50 | Frederic |  |  |
| 509 | 205.2 | CT4 part of Stage 3 for SRVCC enhancements |  | 71d? | 2010-12-10 A | 2011-03-18 A | 100% |  | 2010-12-10 | 2011-03-18 | 71d? |  | finish no earlier than 2011-03-18 | C4 | 568h | 568h | eSRVCC | PCG-26 | China Mobile | Jiang Y (jiangyi@chinamobile.com) | Rel-10 | CP-50 | Kimmo |  |  |
| 510 | 205.3 | (IETF) CT1 part of Stage 3 for SRVCC enhancements |  | 373.8d? | 2010-12-10 A | 2012-09-14 | 50% | 186.9d? | 2010-12-10 | 2012-09-14 | 373.8d? | 323d | finish no earlier than 2012-09-14 | C1-IETF | 2990.4h | 1495.2h | eSRVCC_IETF | PCG-27 | Christer Holmberg | christer.holmberg@ericsson.com | Rel-10 | CP-52 | Frederic |  |  |
| 511 | 206 | Single Radio Voice Call Continuity (SRVCC) in alerting phase (Stage 3) |  | 126d? | 2010-12-10 A | 2011-06-03 A | 100% |  | 2010-12-10 | 2011-06-03 | 126d? |  | finish no earlier than 2011-06-03 | C1 | 1008h | 1008h | aSRVCC | PCG-26 | ZTE | li.shitao@zte.com.cn | Rel-10 | CP-50 | Frederic |  |  |
| 512 | 207 | **PCRF failure and restoration** |  | 71d? | 2010-12-10 A | 2011-03-18 A | 100% |  | 2010-12-10 | 2011-03-18 | 71d? |  |  | C4,C3 | 1562h | 1562h | PCRF_FR | PCG-26 | NEC | Toshiyuki Tamura (tamurato@aj.jp.nec.com) | Rel-10 | CP-50 | Kimmo |  |  |
| 513 | 207.1 | CT4 part of PCRF failure and restoration |  | 71d? | 2010-12-10 A | 2011-03-18 A | 100% |  | 2010-12-10 | 2011-03-18 | 71d? |  | finish no earlier than 2011-03-18 | C4 | 568h | 568h | PCRF_FR | PCG-26 | NEC | Toshiyuki Tamura (tamurato@aj.jp.nec.com) | Rel-10 | CP-50 | Kimmo |  |  |
| 514 | 207.2 | CT3 part of PCRF failure and restoration |  | 53.25d? | 2010-12-10 A | 2011-03-18 A | 100% |  | 2010-12-10 | 2011-03-18 | 53.25d? |  | start no earlier than 2010-12-10 | C3 | 426h | 426h | PCRF_FR | PCG-26 | NEC | Toshiyuki Tamura (tamurato@aj.jp.nec.com) | Rel-10 | CP-50 | Jiwan |  |  |
| 515 | 208 | Formalization of WLAN Files | milestone | 0d? | 2011-02-23 A | 2011-03-18 A | 100% |  | 2011-02-23 | 2011-03-18 | 0d? |  | start no earlier than 2011-03-16 | C1 |  |  | FoWF | PCG-26 | Deutsche Telekom | dieter.jacobsohn@telekom.de | Rel-10 | CP-51 | Frederic |  |  |
| 516 | 209 | CS and IMS Interworking for CAT service - Early Session model |  | 58d? | 2011-03-16 A | 2011-06-03 A | 100% |  | 2011-03-16 | 2011-06-03 | 58d? |  |  | C3 | 464h | 464h | CIIC_ES | PCG-26 | ZTE | li.shitao@zte.com.cn | Rel-10 | CP-51 | Jiwan |  |  |
| 517 | 210 | EPC Node Restoration without Idle mode Signalling Reduction (ISR) activated |  | 3d? | 2011-03-16 A | 2011-03-18 A | 100% |  | 2011-03-16 | 2011-03-18 | 3d? |  | finish no earlier than 2011-03-18 | C4 | 24h | 24h | EPC_NR | PCG-26 | Alcatel-Lucent | bruno.landais@alcatel-lucent.com | Rel-10 | CP-51 | Kimmo |  |  |
| 518 | 211 | EPC Node Restoration with Idle mode Signalling Reduction (ISR) activated |  | 58d? | 2011-03-16 A | 2011-06-03 A | 100% |  | 2011-03-16 | 2011-06-03 | 58d? |  | finish no earlier than 2011-03-18 | C4 | 464h | 464h | EPC_NR_ISR | PCG-26 | NEC | Toshiyuki Tamura (tamurato@aj.jp.nec.com) | Rel-10 | CP-51 | Kimmo |  |  |
| 519 | 212 | Mobile Terminating Roaming Forwarding with pre-paging |  | 58d? | 2011-03-16 A | 2011-06-03 A | 100% |  | 2011-03-16 | 2011-06-03 | 58d? |  | finish no earlier than 2011-03-18 | C4 | 464h | 464h | MTRF | PCG-26 | Ericsson | philip.hodges@ericsson.com | Rel-10 | CP-51 | Kimmo |  |  |
| 520 | 213 | **UICC access to IMS Specification** |  | 58d? | 2011-03-16 A | 2011-06-03 A | 100% |  | 2011-03-16 | 2011-06-03 | 58d? |  |  | C6,C1 | 952h | 952h | IMS-UICC-S | PCG-26 | Gemalto | Denis.Lheriteau@gemalto.com | Rel-10 | CP-51 | Xavier |  |  |
| 521 | 213.1 | CT6 part of UICC access to IMS Specification |  | 3d? | 2011-03-16 A | 2011-03-18 A | 100% |  | 2011-03-16 | 2011-03-18 | 3d? |  | start no earlier than 2011-03-16 | C6 | 24h | 24h | IMS-UICC-S | PCG-26 | Gemalto | Denis.Lheriteau@gemalto.com | Rel-10 | CP-51 | Xavier |  |  |
| 522 | 213.2 | CT1 part of UICC access to IMS Specification |  | 58d? | 2011-03-16 A | 2011-06-03 A | 100% |  | 2011-03-16 | 2011-06-03 | 58d? |  | start no earlier than 2011-03-16 | C1 | 464h | 464h | IMS-UICC-S | PCG-26 | Gemalto | Denis.Lheriteau@gemalto.com | Rel-10 | CP-51 | Frederic |  |  |
| 523 | 214 | Testing for Terminal support of Rel-10 USIM, ISIM and USAT features |  | 201d? | 2012-03-02 | 2012-12-07 |  |  | 2012-03-02 | 2012-12-07 | 201d? | 263d | finish no earlier than 2012-12-07 | C6 | 1608h |  | USIM_R10_Test | PCG-28 | Gemalto | Denis.Lheriteau@gemalto.com | Rel-10 | CP-55 |  |  |  |
| 524 | 215 | **CN aspects of Local Call Local Switch** |  | 472d? | 2009-05-29 A | 2011-03-18 A | 100% |  | 2009-05-29 | 2011-03-18 | 472d? |  |  | C4 | 13008h | 13008h | LCLS-CN | PCG-23 | Vodafone | David.Hutton@vodafone.com | Rel-10 | CP-44 | Kimmo |  |  |
| 525 | 215.1 | TR on CN aspects of Local Call Local Switch |  | 341d? | 2009-05-29 A | 2010-09-16 A | 100% |  | 2009-05-29 | 2010-09-16 | 341d? |  | finish no earlier than 2010-09-17 | C4 | 2728h | 2728h | LCLS-CN | PCG-23 | Vodafone | David.Hutton@vodafone.com | Rel-10 | CP-44 | Kimmo |  |  |
| 526 | 215.2 | Stage 2/3 for CN aspects of Local Call Local Switch |  | 131d? | 2010-09-17 A | 2011-03-18 A | 100% |  | 2010-09-17 | 2011-03-18 | 131d? |  | finish no earlier than 2011-03-18 | C4 | 1048h | 1048h | LCLS-CN | PCG-25 | Vodafone | David.Hutton@vodafone.com | Rel-10 | CP-49 | Kimmo |  |  |
| 527 | 215.3 | Deleted - CT3 aspects of Local Call Local Switch |  | 341d? | 2009-05-29 A | 2010-09-16 A | 100% |  | 2009-05-29 | 2010-09-16 | 341d? |  | finish no earlier than 2010-09-17 | C3 | 2728h | 2728h | LCLS-CN | PCG-23 | Vodafone | David.Hutton@vodafone.com | Rel-10 | CP-44 | Jiwan | PCG-25 | CP-49 |
| 528 | 215.4 | Deleted - CT1 aspects of Local Call Local Switch |  | 341d? | 2009-05-29 A | 2010-09-16 A | 100% |  | 2009-05-29 | 2010-09-16 | 341d? |  | finish no earlier than 2010-09-17 | C1 | 2728h | 2728h | LCLS-CN | PCG-23 | Vodafone | David.Hutton@vodafone.com | Rel-10 | CP-44 | Frederic | PCG-25 | CP-49 |
| 529 | 216 | Local Call Local Switch |  | 1055.8d? | 2007-05-07 A | 2011-05-20 A | 100% |  | 2007-05-07 | 2011-05-20 | 1055.8d? |  |  | GP,G2 | 8446.4h | 8446.4h | LCLS | PCG-22 | Huawei | wang_zhixi@huawei.com | Rel-10 | GP-41 | Paolo |  |  |
| 530 | 217 | **Tightened Link Level Performance Requirements for Single Antenna MS** |  | 584d? | 2010-09-03 A | 2012-11-23 | 49% | 299.49d? | 2010-09-03 | 2012-11-23 | 584d? | 273d |  | G1,G2,C1,G3new | 12376h | 6029.28h | TIGHTER | PCG-25 | Renesas Mobile | carsten.juncker@renesasmobile.com | Rel-10 | GP-46 | Paolo |  |  |
| 531 | 217.1 | CT1 part for TIGHTER |  | 196d? | 2010-09-03 A | 2011-06-03 A | 100% |  | 2010-09-03 | 2011-06-03 | 196d? |  | finish no earlier than 2011-06-03 | C1 | 1568h | 1568h | TIGHTER | PCG-25 | Renesas Mobile | marko.niemi@renesasmobile.com | Rel-10 | GP-46 | Frederic |  |  |
| 532 | 217.2 | TIGHTER Performance Requirements |  | 186d? | 2010-09-03 A | 2011-05-20 A | 100% |  | 2010-09-03 | 2011-05-20 | 186d? |  | finish no earlier than 2011-05-20 | G1,G2 | 1488h | 1488h | TIGHTER | PCG-25 | Renesas Mobile | carsten.juncker@renesasmobile.com | Rel-10 | GP-46 | Paolo |  |  |
| 533 | 217.3 | TIGHTER Testing |  | 581d? | 2010-09-08 A | 2012-11-23 | 15% | 493.85d? | 2010-09-08 | 2012-11-23 | 581d? | 273d | finish no earlier than 2012-11-23 | G3new | 4648h | 697.2h | TIGHTER | PCG-25 | Renesas Mobile | carsten.juncker@renesasmobile.com | Rel-10 | GP-46 | Ingbert |  |  |

Notes:
- 507: CP#51 completed, Triggered by SA2 TR 23.856 Study on Single Radio Voice Call Continuity enhancements (FS_eSRVCC) UID_440049 / Text3: Stage 3
- 508: CP#51 completed / Text3: 24.229, 24.237
- 509: CP#51 completed / Text3: 23.003, 23.008, 29.002, 29.230, 29.272, 29.305, 29.328, 29.329
- 510: Not completed internet-draft / Text3: draft-ietf-sipcore-proxy-feature
- 511: CP#52 completed. Builds on Rel-8 UID_390057 (IMS-Cont) TS 23.216 Stage 2. Provide Stage 3 for SRVCC PS-CS transfer of a call in alerting phase. Stage 2 TEI10 in TS 23.237 (6.3.2.1.4c/d, 6.3.2.1.7a/b) / Text3: 24.008, 24.237
- 512: CP#51 completed. Triggered by CT3 TR 29.816 Study on Policy and Charging Rules Function (PCRF) failure and restoration (FS_PCRF-FR) UID_450013 / Text3: Stage 2/3 work
- 513: CP#51 completed / Text3: Stage 2 23.007, Stage 3 29.230
- 514: CP#51 completed / Text3: Stage 3 29.212, 29.213, 29.214, 29.215
- 515: CP#51 completed. TS 24.235 for Info+Approval. Define the ME files as specified in 24.234 in OMA Device Management structure / Text3: Stage 3: 24.234, new 24.235
- 516: CP#52 completed. Stage 1 in Rel-8 TS 22.182 Customized Alerting Tones (CAT) service. Stage 3 TS 24.182 defines 3 impl models: Gateway, Forking, Early Session. Specify missing CAT service interworking procedures btw CS & IMS networks / Text3: Stage 3 29.163, 29.235, 29.292
- 517: CP#51 completed. Triggered by DRAFT TR 23.857 Study on EPC Nodes Restoration (FS_EPC_NR) UID_490014 / Text3: Stage 2/3: 23.007, 29.274
- 518: CP#52 completed. Triggered by DRAFT TR 23.857 Study on EPC Nodes Restoration (FS_EPC_NR) UID_490014 / Text3: Stage 2/3: 23.007, 29.274
- 519: CP#52 completed. Provides Stage 2/3 alternative solution to Mobile Terminating Roaming Retry to solve roaming events during paging, in particular to support CSFB. Hence, no new Stage 1 requirements exist / Text3: Stage 2/3: 23.012, 23.018, 23.116, 29.002
- 520: CP#52 completed. Triggered by Rel-10 TR 31.828 Study on UICC access to IMS (FS_IMS-UICC) UID_480017. Specify mechanism in UICC and ME to make use of IMS functionality implemented in ME for case a) an ISIM is present b) no ISIM is present in UICC
- 521: CP#51 completed / Text3: 31.102, 31.103, 31.111
- 522: CP#52 completed / Text3: 24.229
- 523: Testing for New features in Rel-10 specifications for USIM, ISIM applications and USIM Application Toolkit (USAT) in TS 31.102, 31.103, 31.111 / Text3: 31.121, 31.124, new TS 31.ABC (Conformance Testing of specific features)
- 524: CP#51 completed / Text3: GERAN Stage 2/3
- 525: CT#49 completed / Text3: new TR 23.889
- 526: CP#51 completed / Text3: 23.003, 23.009, 23.205, 23.231, 29.002, 29.205, 29.232, new TS 23.284
- 527: CP#49 stopped. Result of study TR 23.889: no CT3 specification impact
- 528: CP#49 stopped. Result of study TR 23.889: no CT1 specification impact
- 529: GP#50 completed. GP#41 WID approved / Text3: GERAN Stage 3: 48.008, 48.103
- 530: CP#52 completed. GP#50 completed (except Testing). GP#46 approved WID / Text3: GERAN
- 531: CP#52 completed / Text3: 24.008
- 532: GP#50 completed / Text3: 45.005, 45.015
- 533: GP#53 completion 09/12=>11/12 / Text3: 51.010

| ID | WBS | Task | Duration | Start | Finish | Complete | Remaining | Baseline start | Baseline finish | Baseline duration | Total slack | Constraint | Resources | Work | Actual work | Text1 | Text2 | Text4 | Text6 | Text7 | Text8 | Text11 |
| --- | --- | --- | --- | --- | --- | --- | --- | --- | --- | --- | --- | --- | --- | --- | --- | --- | --- | --- | --- | --- | --- | --- |
| 534 | 218 | **Support of Multi-Operator Core Network by GERAN** | 206d? | 2010-05-21 A | 2011-03-04 A | 100% |  | 2010-05-21 | 2011-03-04 | 206d? |  |  | G2,S2,C1 | 5096h | 5096h | MOCN-GERAN | PCG-25 | Alcatel-Lucent | Rel-10 | GP-47 | Gert |  |
| 535 | 218.1 | Stage 2 for Support of Multi-Operator Core Network by GERAN | 150d? | 2010-05-21 A | 2010-12-16 A | 100% |  | 2010-05-21 | 2010-12-16 | 150d? |  | finish no earlier than 2010-12-15 | S2 | 1200h | 1200h | MOCN-GERAN | PCG-25 | Alcatel-Lucent | Rel-10 | GP-47 | Maurice |  |
| 536 | 218.2 | CT1 part of Stage 3 for Support of Multi-Operator Core Network by GERAN | 146d? | 2010-05-21 A | 2010-12-10 A | 100% |  | 2010-05-21 | 2010-12-10 | 146d? |  | finish no earlier than 2010-12-10 | C1 | 1168h | 1168h | MOCN-GERAN | PCG-25 | Alcatel-Lucent | Rel-10 | GP-47 | Frederic |  |
| 537 | 218.3 | GERAN2 part of Stage 3 for Support of Multi-Operator Core Network by GERAN | 135d? | 2010-08-30 A | 2011-03-04 A | 100% |  | 2010-08-30 | 2011-03-04 | 135d? |  | finish no earlier than 2011-03-04 | G2 | 1080h | 1080h | MOCN-GERAN | PCG-25 | Alcatel-Lucent | Rel-10 | GP-47 | Gert |  |
| 538 | 219 | **Enhancements of Iur-g interface** | 196d? | 2010-09-03 A | 2011-06-03 A | 100% |  | 2010-09-03 | 2011-06-03 | 196d? |  |  | G2,R3 | 4184h | 4184h | eIurg | PCG-25 | China Mobile, ZTE | Rel-10 | GP-47 | Gert |  |
| 539 | 219.1 | GERAN part for Enhancements of Iur-g interface (Stage 2/3) | 131d? | 2010-09-03 A | 2011-03-04 A | 100% |  | 2010-09-03 | 2011-03-04 | 131d? |  | finish no earlier than 2011-03-04 | G2 | 1048h | 1048h | eIurg-GERAN | PCG-25 | China Mobile, ZTE | Rel-10 | GP-47 | Gert |  |
| 540 | 219.2 | Core part: Enhancements of Iur-g interface (Stage 2/3) | 196d? | 2010-09-03 A | 2011-06-03 A | 100% |  | 2010-09-03 | 2011-06-03 | 196d? |  | finish no earlier than 2011-06-03 | R3 | 1568h | 1568h | eIurg-RAN | PCG-25 | ZTE | Rel-10 | RP-49 | Juha | RP-110526 |
| 541 | 220 | 1.28 Mcps TDD Repeater | 599d? | 2007-12-04 A | 2010-03-19 A | 100% |  | 2007-12-04 | 2010-03-19 | 599d? |  | finish no earlier than 2010-03-19 | R4 | 4792h | 4792h | RANimp-Repeaters1.28TDD | PCG-21 | RITT | Rel-10 | RP-38 | Issam | RP-100039 |
| 542 | 221 | 1.28 Mcps TDD Multi-carrier HSUPA | 321d? | 2009-09-18 A | 2010-12-10 A | 100% |  | 2009-09-18 | 2010-12-10 | 321d? |  | finish no earlier than 2010-12-10 | R1,R2,R3,R4 | 2568h | 2568h | TDD_MC_HSUPA | PCG-23 | CATR | Rel-10 | RP-45 | Patrick | RP-101079 |
| 543 | 222 | **1.28 Mcps TDD Home NodeB RF requirements** | 266d? | 2009-12-04 A | 2010-12-10 A | 100% |  | 2009-12-04 | 2010-12-10 | 266d? |  |  | R4 | 5304h | 5304h | HNB_LCRTDD_RF | PCG-24 | TD Tech | Rel-10 | RP-46 | Issam |  |
| 544 | 222.1 | Core part: 1.28Mcps TDD Home NodeB RF requirements | 131d? | 2009-12-04 A | 2010-06-04 A | 100% |  | 2009-12-04 | 2010-06-04 | 131d? |  | finish no earlier than 2010-12-10 | R4 | 1048h | 1048h | HNB_LCRTDD_RF-Core | PCG-24 | TD Tech | Rel-10 | RP-46 | Issam | RP-100446 |
| 545 | 222.2 | Perf. part: 1.28Mcps TDD Home NodeB RF requirements | 266d? | 2009-12-04 A | 2010-12-10 A | 100% |  | 2009-12-04 | 2010-12-10 | 266d? |  | finish no earlier than 2010-12-10 | R4 | 2128h | 2128h | HNB_LCRTDD_RF-Perf | PCG-24 | TD Tech | Rel-10 | RP-46 | Issam | RP-101081 |
| 546 | 223 | **Multi-User Multiple-Input and Multiple-Output (MU-MIMO) for 1.28Mcps TDD** | 316d? | 2010-03-19 A | 2011-06-03 A | 100% |  | 2010-03-19 | 2011-06-03 | 316d? |  |  | R1,R2,R3,R4 | 6584h | 6584h | MUMIMO_LCR_TDD | PCG-24 | CATT | Rel-10 | RP-47 | Patrick |  |
| 547 | 223.1 | Core part: MU-MIMO for 1.28Mcps TDD | 191d? | 2010-03-19 A | 2010-12-10 A | 100% |  | 2010-03-19 | 2010-12-10 | 191d? |  | finish no earlier than 2010-12-10 | R1,R2,R3 | 1528h | 1528h | MUMIMO_LCR_TDD-Core | PCG-24 | CATT | Rel-10 | RP-47 | Patrick | RP-101085 |
| 548 | 223.2 | Perf. part: MU-MIMO for 1.28Mcps TDD | 316d? | 2010-03-19 A | 2011-06-03 A | 100% |  | 2010-03-19 | 2011-06-03 | 316d? |  | finish no earlier than 2011-06-03 | R4 | 2528h | 2528h | MUMIMO_LCR_TDD-Perf | PCG-24 | CATT | Rel-10 | RP-47 | Issam | RP-110520 |
| 549 | 224 | **AGNSS Minimum Performance for UTRAN** | 523d? | 2009-09-18 A | 2011-09-16 A | 100% |  | 2009-09-18 | 2011-09-16 | 523d? |  |  | R4,R5 | 9440h | 9440h | AGNSSPerf_UTRAN | PCG-23 | Thales | Rel-10 | RP-45 | Issam |  |
| 550 | 224.1 | AGNSS Minimum Performance Specification Development | 321d? | 2009-09-18 A | 2010-12-10 A | 100% |  | 2009-09-18 | 2010-12-10 | 321d? |  | finish no earlier than 2010-12-10 | R4 | 2568h | 2568h | AGNSSPerf_UTRAN | PCG-23 | Thales | Rel-10 | RP-45 | Issam | RP-101078 |
| 551 | 224.2 | AGNSS test case development for UMTS | 336d? | 2010-06-04 A | 2011-09-16 A | 100% |  | 2010-06-04 | 2011-09-16 | 336d? |  | finish no earlier than 2011-09-16 | R5 | 2688h | 2688h | AGNSSTest_UTRAN | PCG-25 | Thales | Rel-10 | RP-48 | Ingbert | RP-110979 |
| 552 | 225 | **Inclusion of RF Pattern Matching Technologies as positioning method in the UTRAN** | 336d? | 2009-12-04 A | 2011-03-18 A | 100% |  | 2009-12-04 | 2011-03-18 | 336d? |  |  | R2,R3 | 5376h | 5376h | LCS_UMTS_RFPMT | PCG-24 | Polaris Wireless | Rel-10 | RP-46 | Joern | RP-110048 |
| 553 | 225.1 | Core part: Inclusion of RF Pattern Matching Technologies as positioning method in the UTRAN | 336d? | 2009-12-04 A | 2011-03-18 A | 100% |  | 2009-12-04 | 2011-03-18 | 336d? |  | finish no earlier than 2011-03-18 | R2,R3 | 2688h | 2688h | LCS_UMTS_RFPMT-Core | PCG-24 | Polaris Wireless | Rel-10 | RP-46 | Joern | RP-110048 |
| 554 | 226 | **Four carrier HSDPA** | 789d? | 2009-12-04 A | 2012-12-07 | 76% | 186.69d? | 2009-12-04 | 2012-12-07 | 789d? | 263d |  | R1,R2,R3,R4,R5 | 14856h | 9210.4h | 4C_HSDPA | PCG-24 | Qualcomm | Rel-10 | RP-46 | Patrick |  |
| 555 | 226.1 | Core part: Four carrier HSDPA | 336d? | 2009-12-04 A | 2011-03-18 A | 100% |  | 2009-12-04 | 2011-03-18 | 336d? |  | finish no earlier than 2011-03-18 | R1,R2,R3,R4 | 2688h | 2688h | 4C_HSDPA-Core | PCG-24 | Qualcomm | Rel-10 | RP-46 | Patrick | RP-110046 |
| 556 | 226.2 | Perf. part: Four carrier HSDPA | 466d? | 2009-12-04 A | 2011-09-16 A | 100% |  | 2009-12-04 | 2011-09-16 | 466d? |  | finish no earlier than 2011-09-16 | R4 | 3728h | 3728h | 4C_HSDPA-Perf | PCG-24 | Qualcomm | Rel-10 | RP-46 | Issam | RP-110986 |
| 557 | 226.3 | Test part: Four carrier HSDPA | 266d? | 2011-12-02 A | 2012-12-07 | 5% | 252.7d? | 2011-12-02 | 2012-12-07 | 266d? | 263d | finish no earlier than 2012-12-07 | R5 | 2128h | 106.4h | 4C_HSDPA-UEConTest | PCG-28 | Qualcomm | Rel-10 | RP-54 |  | RP-120047 |

Notes:
- 534: GP#49 completed. SP/CP#50 completed. GP#47 approved WID. 900 MHz spectrum re-farming to other RATs lead operators to reduce GSM capacity and therefore share their GSM networks. Hence the need for the most suitable (GE)RAN sharing method / Text3: GERAN / Text5: michel.robert@alcatel-lucent.com
- 535: SP#50 completed / Text3: 23.251 / Text5: michel.robert@alcatel-lucent.com
- 536: CP#50 completed / Text3: 24.008 CR#1644 / Text5: michel.robert@alcatel-lucent.com
- 537: GP#49 completed / Text3: 48.008 CR#0325, 48.018 CR#0303 / Text5: michel.robert@alcatel-lucent.com
- 538: RP#52 completed. GP#49 completed. GP#47 approved WID / Text3: GERAN,UTRA / Text5: Ms Juan Deng (dengjuan@chinamobile.com), Xinhui Wang (wangxinhui@zte.com.cn)
- 539: GP#49 completed. GP#48 updated WID GP-101659=>GP-101758 (restricting the scope to GERAN BSC and TD-SCDMA RNC only). GP#47 approved WID / Text3: 43.130, 48.008 / Text5: Ms Juan Deng (dengjuan@chinamobile.com), Xinhui Wang (wangxinhui@zte.com.cn)
- 540: RP#52 completed / Text3: UTRA Stage 2 (25.401, 25.420), Stage 3 (25.423) / Text5: Liu Junqiang (liu.junqiang@zte.com.cn)
- 541: RP#47 completed / Text3: UTRA 25.113, new 25.116, 25.153 (testing) / Text5: qinyan@chinattl.com
- 542: RP#50 completed / Text3: UTRA 25.102, 25.105, 25.123, 25.221, 25.222, 25.223, 25.224, 25.225, 25.306, 25.319, 25.321, 25.331, 25.423, 25.427, 25.433 / Text5: Aihui Song (songaihui@mail.ritt.com.cn)
- 543: RP#50 completed. Triggered by FS_RAN-HNBLCRTDD UID_410016 Study on 1.28 Mcps TDD Home NodeB (TR 25.866) / Text3: UTRA / Text5: Li Rong (lirong@td-tech.com)
- 544: RP#48 completed / Text3: 25.105 / Text5: Li Rong (lirong@td-tech.com)
- 545: RP#50 completed. TR 25.968 v100 for Approval / Text3: 25.142, new TR 25.968 / Text5: Li Rong (lirong@td-tech.com)
- 546: RP#52 completed / Text3: UTRA / Text5: Yanping Xing (xingyanping@datangmobile.cn)
- 547: RP#50 completed / Text3: 25.221, 25.222, 25.224, 25.306, 25.308, 25.319, 25.331, 25.423, 25.425, 25.433, 25.435 / Text5: Yanping Xing (xingyanping@datangmobile.cn)
- 548: RP#52 completed / Text3: 25.102, 25.105, 25.142 / Text5: Sanjun Feng (fengsanjun@datangmobile.cn)
- 549: RP#53 completed. Triggered by Rel-7 UID_20050 (GNSS in UTRAN) and Rel-8 UID_400051 (Support for Additional NSS). Linked to GERAN Rel-9 UID_38002 (A-GNSS Performances and Testing Procedures) / Text3: UTRA / Text5: Michel.monnerat@thalesaleniaspace.com
- 550: RP#50 completed / Text3: new 25.172 / Text5: Michel.monnerat@thalesaleniaspace.com
- 551: RP#53 completed / Text3: 34.108, 34.109, 34.123-1, 34.123-2, 34.123-3, 36.37.571-5, new 34.172 / Text5: Michel.monnerat@thalesaleniaspace.com
- 552: RP#51 completed. Triggered by Study UID_380079 Evaluation of the inclusion of Path Loss Based Technology in the UTRAN (25.907) / Text3: UTRA / Text5: Norman Shaw (nshaw@polariswireless.com)
- 553: RP#51 completed / Text3: 25.305, 25.453 / Text5: Norman Shaw (nshaw@polariswireless.com)
- 554: RP#53 completed / Text3: UTRA / Text5: Arjun Bharadwaj (arjunb@qualcomm.com)
- 555: RP#51 completed. RP#52 TR 25.864 v200 for Approval / Text3: 25.101, 25.104, 25.133, 25.211, 25.212, 25.213, 25.214, 25.215, 25.308, 25.331, 25.423, 25.433, 26.306, new TR 25.864 / Text5: Arjun Bharadwaj (arjunb@qualcomm.com)
- 556: RP#53 completed / Text3: 25.101, 25.104, 25.133, 25.141 / Text5: Arjun Bharadwaj (arjunb@qualcomm.com)
- 557: - / Text3: 34.108, 34.121-1, 34.121-2, 34.123-1, 34.123-2, 34.123-3 / Text5: Shubhang Vora (svora@qualcomm.com)

| ID | WBS | Task | Duration | Start | Finish | Complete | Remaining | Baseline start | Baseline finish | Baseline duration | Total slack | Constraint | Resources | Work | Actual work | Text1 | Text2 | Text4 | Text5 | Text6 | Text7 | Text8 | Text11 | Text9 | Text12 |
| --- | --- | --- | --- | --- | --- | --- | --- | --- | --- | --- | --- | --- | --- | --- | --- | --- | --- | --- | --- | --- | --- | --- | --- | --- | --- |
| 558 | 227 | **Performance Requirements for two-antenna 1.28Mcps TDD Type 1 and Type 2 UE receiver** | 316d? | 2010-03-19 A | 2011-06-03 A | 100% |  | 2010-03-19 | 2011-06-03 | 316d? |  |  | R4 | 5504h | 5504h | 2ant_UE_LCR_TDD | PCG-24 | TD Tech | dafei.wang@td-tech.com | Rel-10 | RP-47 | Issam |  |  |  |
| 559 | 227.1 | Core part: Performance Requirements for two-antenna 1.28Mcps TDD Type 1 and Type 2 UE receiver | 56d? | 2010-03-19 A | 2010-06-04 A | 100% |  | 2010-03-19 | 2010-06-04 | 56d? |  | finish no earlier than 2010-06-04 | R4 | 448h | 448h | 2ant_UE_LCR_TDD-Core | PCG-24 | TD Tech | dafei.wang@td-tech.com | Rel-10 | RP-47 | Issam | RP-100454 |  |  |
| 560 | 227.2 | Perf. part: Performance Requirements for two-antenna 1.28Mcps TDD Type 1 and Type 2 UE receiver | 316d? | 2010-03-19 A | 2011-06-03 A | 100% |  | 2010-03-19 | 2011-06-03 | 316d? |  | finish no earlier than 2011-06-03 | R4 | 2528h | 2528h | 2ant_UE_LCR_TDD-Perf | PCG-24 | TD Tech | dafei.wang@td-tech.com | Rel-10 | RP-47 | Issam | RP-110521 |  |  |
| 561 | 228 | **Automatic Neighbour Relation (ANR) for UTRAN** | 534d? | 2010-06-04 A | 2012-06-15 | 59% | 217.57d? | 2010-06-04 | 2012-06-15 | 534d? | 388d |  | R3,R2,R5 | 5840h | 2166.4h | ANR_UTRAN | PCG-25 | ZTE | Zhai.hengxing@zte.com.cn | Rel-10 | RP-48 | Juha |  |  |  |
| 562 | 228.1 | Core part: Automatic Neighbour Relation (ANR) for UTRAN | 261d? | 2010-06-04 A | 2011-06-03 A | 100% |  | 2010-06-04 | 2011-06-03 | 261d? |  | finish no earlier than 2011-06-03 | R3,R2 | 2088h | 2088h | ANR_UTRAN-Core | PCG-25 | ZTE | Zhai.hengxing@zte.com.cn | Rel-10 | RP-48 | Juha | RP-110522 |  |  |
| 563 | 228.2 | Test part: Automatic Neighbour Relation (ANR) for UTRAN | 196d? | 2011-09-19 A | 2012-06-15 | 5% | 186.2d? | 2011-09-19 | 2012-06-15 | 196d? | 388d | finish no earlier than 2012-06-15 | R5 | 1568h | 78.4h | ANR_UTRAN-UEConTest | PCG-27 | Ericsson | leif.mattisson@ericsson.com | Rel-10 | RP-53 |  | RP-120046 |  |  |
| 564 | 229 | **Support of New Band Combinations for Dual-Band Dual Cell HSDPA** | 261d? | 2010-06-04 A | 2011-06-03 A | 100% |  | 2010-06-04 | 2011-06-03 | 261d? |  |  | R4,R2 | 4784h | 4784h | DB_DC_HSDPA | PCG-25 | AT&T | Vince Spatafora (vs5785@att.com) | Rel-10 | RP-48 | Issam |  |  |  |
| 565 | 229.1 | Core part: Support of New Band Combinations for Dual-Band Dual Cell HSDPA | 261d? | 2010-06-04 A | 2011-06-03 A | 100% |  | 2010-06-04 | 2011-06-03 | 261d? |  | finish no earlier than 2011-06-03 | R4,R2 | 2088h | 2088h | DB_DC_HSDPA-Core | PCG-25 | AT&T | Vince Spatafora (vs5785@att.com) | Rel-10 | RP-48 | Issam | RP-110523 |  |  |
| 566 | 229.2 | Deleted - Perf. part: Support of New Band Combinations for Dual-Band Dual Cell HSDPA | 76d? | 2010-06-04 A | 2010-09-17 A | 100% |  | 2010-06-04 | 2010-09-17 | 76d? |  | finish no earlier than 2010-09-17 | R4,R2 | 608h | 608h | DB_DC_HSDPA-Perf | PCG-25 | AT&T | Vince Spatafora (vs5785@att.com) | Rel-10 | RP-48 | Issam | RP-100759 | PCG-25 | RP-49 |
| 567 | 230 | **MIMO operation with non-MIMO coexistence in HSDPA** | 459d? | 2010-06-04 A | 2012-03-02 A | 100% |  | 2010-06-04 | 2012-03-02 | 459d? |  |  | R4,R5 | 9264h | 9264h | MIMO_HSDPA | PCG-25 | Qualcomm | Heechoon Lee | Rel-10 | RP-48 | Issam |  |  |  |
| 568 | 230.1 | Core part: MIMO operation with non-MIMO coexistence in HSDPA | 186d? | 2010-09-17 A | 2011-06-03 A | 100% |  | 2010-09-17 | 2011-06-03 | 186d? |  | finish no earlier than 2011-06-03 | R4 | 1488h | 1488h | MIMO_HSDPA-Core | PCG-25 | Qualcomm | Heechoon Lee | Rel-10 | RP-49 | Issam | RP-110524 |  |  |
| 569 | 230.2 | Perf. part: MIMO operation with non-MIMO coexistence in HSDPA | 261d? | 2010-06-04 A | 2011-06-03 A | 100% |  | 2010-06-04 | 2011-06-03 | 261d? |  | finish no earlier than 2011-06-03 | R4 | 2088h | 2088h | MIMO_HSDPA-Perf | PCG-25 | Qualcomm | Heechoon Lee | Rel-10 | RP-48 | Issam | RP-110525 |  |  |
| 570 | 230.3 | Test part: MIMO operation with non-MIMO coexistence in HSDPA | 252d? | 2011-03-18 A | 2012-03-02 A | 100% |  | 2011-03-18 | 2012-03-02 | 252d? |  | finish no earlier than 2012-03-02 | R5 | 2016h | 2016h | MIMO_HSDPA-UEConTest | PCG-26 | Qualcomm | Shubhang Vora (svora@qualcomm.com) | Rel-10 | RP-51 | Ingbert | RP-120042 |  |  |
| 571 | 231 | Interfrequency detected set measurements for UMTS | 61d? | 2010-09-17 A | 2010-12-10 A | 100% |  | 2010-09-17 | 2010-12-10 | 61d? |  | finish no earlier than 2010-12-10 | R2,R4 | 488h | 488h | Interf_dset_meas_UMTS | PCG-25 | Nokia | Chris.callender@nokia.com | Rel-10 | RP-49 | Joern | RP-101093 |  |  |
| 572 | 232 | **Carrier Aggregation for LTE** | 789d? | 2009-12-04 A | 2012-12-07 | 77% | 183.82d? | 2009-12-04 | 2012-12-07 | 789d? | 263d |  | R1,R2,R3,R4,R5 | 16232h | 9845.6h | LTE_CA | PCG-24 | Nokia | Asbjorn.grovlen@nokia.com | Rel-10 | RP-46 | Patrick |  |  |  |
| 573 | 232.1 | Core part: Carrier Aggregation for LTE | 391d? | 2009-12-04 A | 2011-06-03 A | 100% |  | 2009-12-04 | 2011-06-03 | 391d? |  | finish no earlier than 2011-06-03 | R1,R2,R3,R4 | 3128h | 3128h | LTE_CA-Core | PCG-24 | Nokia | lars.e.lindh@nokia.com | Rel-10 | RP-46 | Patrick | RP-110535 |  |  |
| 574 | 232.2 | Perf. part: Carrier Aggregation for LTE | 528d? | 2009-12-04 A | 2011-12-09 A | 100% |  | 2009-12-04 | 2011-12-09 | 528d? |  | finish no earlier than 2011-12-09 | R4 | 4224h | 4224h | LTE_CA-Perf | PCG-24 | Nokia | lars.e.lindh@nokia.com | Rel-10 | RP-46 | Issam | RP-111452 |  |  |
| 575 | 232.3 | Test part: Carrier Aggregation for LTE | 321d? | 2011-09-19 A | 2012-12-07 | 10% | 288.9d? | 2011-09-19 | 2012-12-07 | 321d? | 263d | finish no earlier than 2012-12-07 | R5 | 2568h | 256.8h | LTE_CA-UEConTest | PCG-27 | Nokia | jussi.kuusisto@nokia.com | Rel-10 | RP-53 |  | RP-120045 |  |  |
| 576 | 233 | **Enhanced Downlink Multiple Antenna Transmission for LTE** | 589d? | 2009-12-04 A | 2012-03-02 A | 100% |  | 2009-12-04 | 2012-03-02 | 589d? |  |  | R1,R2,R4 | 12112h | 12112h | LTE_eDL_MIMO | PCG-24 | NTT DoCoMo | Hidekazu Taoka (taoka@nttdocomo.com) | Rel-10 | RP-46 | Patrick |  |  |  |
| 577 | 233.1 | Core part: Enhanced Downlink Multiple Antenna Transmission for LTE | 336d? | 2009-12-04 A | 2011-03-18 A | 100% |  | 2009-12-04 | 2011-03-18 | 336d? |  | finish no earlier than 2011-03-18 | R1,R2,R4 | 2688h | 2688h | LTE_eDL_MIMO-Core | PCG-24 | NTT DoCoMo | Hidekazu Taoka (taoka@nttdocomo.com) | Rel-10 | RP-46 | Patrick | RP-110067 |  |  |
| 578 | 233.2 | Perf. part: Enhanced Downlink Multiple Antenna Transmission for LTE | 589d? | 2009-12-04 A | 2012-03-02 A | 100% |  | 2009-12-04 | 2012-03-02 | 589d? |  | finish no earlier than 2012-03-02 | R4 | 4712h | 4712h | LTE_eDL_MIMO-Perf | PCG-24 | NTT DoCoMo | Hidekazu Taoka (taoka@nttdocomo.com) | Rel-10 | RP-46 | Issam | RP-120053 |  |  |
| 579 | 234 | **Uplink Multiple Antenna Transmission for LTE** | 789d? | 2009-12-04 A | 2012-12-07 | 79% | 168.2d? | 2009-12-04 | 2012-12-07 | 789d? | 263d |  | R1,R2,R4,R5 | 15296h | 10196.8h | LTE_UL_MIMO | PCG-24 | Huawei | Mattias.wennstrom@huawei.com | Rel-10 | RP-46 | Patrick |  |  |  |
| 580 | 234.1 | Core part: UL multiple antenna transmission for LTE | 391d? | 2009-12-04 A | 2011-06-03 A | 100% |  | 2009-12-04 | 2011-06-03 | 391d? |  |  | R1,R2,R4 | 3128h | 3128h | LTE_UL_MIMO-Core | PCG-24 | Huawei | Mattias.wennstrom@huawei.com | Rel-10 | RP-46 | Patrick | RP-110537 |  |  |
| 581 | 234.2 | Perf. part: UL multiple antenna transmission for LTE | 466d? | 2009-12-04 A | 2011-09-16 A | 100% |  | 2009-12-04 | 2011-09-16 | 466d? |  | finish no earlier than 2011-09-16 | R4 | 3728h | 3728h | LTE_UL_MIMO-Perf | PCG-24 | Huawei | Mattias.wennstrom@huawei.com | Rel-10 | RP-46 | Issam | RP-110992 |  |  |
| 582 | 234.3 | Test part: UL multiple antenna transmission for LTE | 266d? | 2011-12-02 A | 2012-12-07 | 10% | 239.4d? | 2011-12-02 | 2012-12-07 | 266d? | 263d | finish no earlier than 2012-12-07 | R5 | 2128h | 212.8h | LTE_UL_MIMO-UEConTest | PCG-28 | Huawei | Zhang Xin (suzanna.zhang@huawei.com) | Rel-10 | RP-54 |  | RP-120048 |  |  |

Notes:
- 558: Stage 3. RP#52 completed / Text3: UTRA
- 559: RP#48 completed / Text3: 25.102
- 560: RP#52 completed / Text3: 25.102
- 561: RP#52 Core completed. Automatic Neighbour Relation (ANR) function for UTRAN relieves operators from the burden of manually managing the Neighbour cell Relations (NRs) / Text3: UTRA
- 562: RP#52 completed / Text3: 25.331, 25.413, 25.423, new TS 25.484 (Stage 2)
- 563: - / Text3: 34.108, 34.123-1, 34.123-2, 34.123-3
- 564: RP#52 completed. Rel-9 Dual-Band Dual-Cell HSDPA (UID_430015 Support for different bands for Dual-Cell HSDPA) has one combination per region in principle. This work adds additional combinations: Band I and XI (Region 3) and Band II and V (Region 2) / Text3: UTRA
- 565: RP#52 completed / Text3: 25.101, 25.104, 25.141, 25.317
- 566: RP#49 stopped (Reason: no need for Performance work) / Text3: 25.101, 25.104, 25.141, 25.317
- 567: RP#52 completed. RP#49 updated WID RP-100687=>RP-100993 (changed Title: MIMO Testing in HSDPA => MIMO operation with non-MIMO coexistence in HSDPA) / Text3: UTRA
- 568: RP#52 completed / Text3: 25.104
- 569: RP#52 completed / Text3: 25.101, 25.141
- 570: RP#55 completed / Text3: 34.108, 34.121-1, 34.121-2, 34.123-1, 34.123-2, 34.123-3
- 571: RP#50 completed / Text3: UTRA 25.133, 25.331
- 572: RP#52 Core completed / Text3: LTE
- 573: RP#52 completed / Text3: 36.101, 36.104, 36.133, 36.211, 36.212, 36.213, 36.300, 36.302, 36.306, 36.321, 36.331, 36.413, 36.423, 37.104
- 574: RP#54 completed / Text3: 36.101, 36.104, 36.133, 36.141, 37.141, new TR (36.807, 36.808)
- 575: - / Text3: 36.508, 36.521-1, 36.521-2, 36.521-3, 36.523-1, 36.523-2, 36.523-3
- 576: - / Text3: LTE
- 577: RP#51 completed / Text3: 36.101, 36.104, 36.133, 36.201, 36.211, 36.212, 36.213, 36.300, 36.306, 36.321, 36.331
- 578: RP#55 completed / Text3: 36.101, 36.104, 36.133, 36.141
- 579: RP#53 completed / Text3: LTE
- 580: RP#52 completed. TR 36.817 v110 for Approval / Text3: 36.101, 36.104, 36.133, 36.201, 36.211, 36.212, 36.213, 36.300, 36.306, 36.321, 36.331, new RAN4 TR 36.817
- 581: RP#53 completed / Text3: 36.101, 36.104, 36.133, 36.141, 36.817
- 582: - / Text3: 36.508, 36.521-1, 36.521-2, 36.521-3, 36.523-1, 36.523-2, 36.523-3

| ID | WBS | Task | Duration | Start | Finish | Complete | Remaining | Baseline start | Baseline finish | Baseline duration | Total slack | Constraint | Resources | Work | Actual work | Text1 | Text2 | Text4 | Text5 | Text6 | Text7 | Text8 | Text11 | Text9 | Text12 |
| --- | --- | --- | --- | --- | --- | --- | --- | --- | --- | --- | --- | --- | --- | --- | --- | --- | --- | --- | --- | --- | --- | --- | --- | --- | --- |
| 583 | 235 | **Relays for LTE** | 394d? | 2009-12-04 A | 2011-06-08 A | 100% |  | 2009-12-04 | 2011-06-08 | 394d? |  |  | R1,R2,R4,S2,S3,C4,C6 | 10584h | 10584h | LTE_Relay | PCG-24 | Ericsson | christian.hoymann@ericsson.com | Rel-10 | RP-46 | Patrick |  |  |  |
| 584 | 235.1 | Core part: Relays for LTE | 391d? | 2009-12-04 A | 2011-06-03 A | 100% |  | 2009-12-04 | 2011-06-03 | 391d? |  | finish no earlier than 2011-06-03 | R1,R2,R4 | 3128h | 3128h | LTE_Relay-Core | PCG-24 | Ericsson | christian.hoymann@ericsson.com | Rel-10 | RP-46 | Patrick | RP-110540 |  |  |
| 585 | 235.2 | Deleted - Perf. part: Relays for LTE | 391d? | 2009-12-04 A | 2011-06-03 A | 100% |  | 2009-12-04 | 2011-06-03 | 391d? |  | finish no earlier than 2011-09-16 | R4 | 3128h | 3128h | LTE_Relay-Perf | PCG-24 | Ericsson | christian.hoymann@ericsson.com | Rel-10 | RP-46 | Issam | RP-110541 | PCG-27 | RP-52 |
| 586 | 235.3 | Stage 2 for Relays for LTE | 3d? | 2011-06-06 A | 2011-06-08 A | 100% |  | 2011-06-06 | 2011-06-08 | 3d? |  | start no earlier than 2011-06-06 | S2 | 24h | 24h | LTE_Relay | PCG-27 | Vodafone | Chris Pudney | Rel-10 | SP-52 | Maurice |  |  |  |
| 587 | 235.4 | TR on LTE Relay Nodes Security | 69d? | 2010-12-16 A | 2011-03-22 A | 100% |  | 2010-12-16 | 2011-03-22 | 69d? |  | finish no earlier than 2011-03-23 | S3 | 552h | 552h | LTE_Relay-Sec | PCG-26 | Qualcomm | Adrian Escott (aescott@qualcomm.com) | Rel-10 | SP-50 | Dionisio |  |  |  |
| 588 | 235.5 | Security for LTE Relay Nodes (Stage 2) | 69d? | 2010-12-16 A | 2011-03-22 A | 100% |  | 2010-12-16 | 2011-03-22 | 69d? |  | finish no earlier than 2011-03-23 | S3 | 552h | 552h | LTE_Relay-Sec | PCG-26 | Qualcomm | Adrian Escott (aescott@qualcomm.com) | Rel-10 | SP-50 | Dionisio |  |  |  |
| 589 | 235.6 | CT6 aspects of LTE Relay Node Security | 3d? | 2011-03-16 A | 2011-03-18 A | 100% |  | 2011-03-16 | 2011-03-18 | 3d? |  | start no earlier than 2011-03-16 | C6 | 24h | 24h | LTE_Relay-Sec | PCG-26 | n/a | n/a | Rel-10 | CP-51 | Xavier |  |  |  |
| 590 | 235.7 | Core Network Impacts for Relay Nodes | 3d? | 2011-03-16 A | 2011-03-18 A | 100% |  | 2011-03-16 | 2011-03-18 | 3d? |  | finish no earlier than 2011-03-18 | C4 | 24h | 24h | LTE_Relay-CN | PCG-26 | Vodafone | David.Hutton@vodafone.com | Rel-10 | CP-51 | Kimmo |  |  |  |
| 591 | 236 | **Enhanced Inter-Cell Interference Control (ICIC) for non-Carrier Aggregation (CA) based deployments of heterogeneous networks for LTE** | 714d? | 2010-03-19 A | 2012-12-07 | 77% | 167.78d? | 2010-03-19 | 2012-12-07 | 714d? | 263d |  | R1,R2,R3,R4,R5 | 12032h | 6768.8h | eICIC_LTE | PCG-24 | China Mobile | Xiaodong XU (xuxiaodong@chinamobile.com) | Rel-10 | RP-47 | Patrick |  |  |  |
| 592 | 236.1 | Core part: Enhanced ICIC for non-CA based deployments of heterogeneous networks for LTE | 316d? | 2010-03-19 A | 2011-06-03 A | 100% |  | 2010-03-19 | 2011-06-03 | 316d? |  | finish no earlier than 2011-06-03 | R1,R2,R3,R4 | 2528h | 2528h | eICIC_LTE-Core | PCG-24 | China Mobile | Xiaodong XU (xuxiaodong@chinamobile.com) | Rel-10 | RP-47 | Patrick | RP-110543 |  |  |
| 593 | 236.2 | Perf. part: Enhanced ICIC for non-CA based deployments of heterogeneous networks for LTE | 589d? | 2010-03-19 A | 2012-06-15 | 90% | 58.9d? | 2010-03-19 | 2012-06-15 | 589d? | 388d | finish no earlier than 2012-06-15 | R4 | 4712h | 4240.8h | eICIC_LTE-Perf | PCG-24 | China Mobile | Xiaodong XU (xuxiaodong@chinamobile.com) | Rel-10 | RP-47 | Issam | RP-120351 |  |  |
| 594 | 236.3 | Test part: Enhanced ICIC for non-CA based deployments of heterogeneous networks for LTE | 201d? | 2012-03-02 | 2012-12-07 |  |  | 2012-03-02 | 2012-12-07 | 201d? | 263d | finish no earlier than 2012-12-07 | R5 | 1608h |  | eICIC_LTE-UEConTest | PCG-28 | Qualcomm | Anjali Mishra (ajha@qualcomm.com) | Rel-10 | RP-55 |  |  |  |  |
| 595 | 237 | **LTE TDD in 2600MHz for US** | 191d? | 2010-03-19 A | 2010-12-10 A | 100% |  | 2010-03-19 | 2010-12-10 | 191d? |  |  | R4,R2,R3,R5 | 4712h | 4712h | LTE_TDD_2600_US | PCG-24 | Clearwire | michael.hart@clearwire.com | Rel-10 | RP-47 | Issam |  |  |  |
| 596 | 237.1 | Core part: LTE TDD in 2600MHz for US | 131d? | 2010-03-19 A | 2010-09-17 A | 100% |  | 2010-03-19 | 2010-09-17 | 131d? |  | finish no earlier than 2010-09-17 | R4,R2,R3 | 1048h | 1048h | LTE_TDD_2600_US-Core | PCG-24 | Clearwire | michael.hart@clearwire.com | Rel-10 | RP-47 | Issam | RP-100782 |  |  |
| 597 | 237.2 | Perf. part: LTE TDD in 2600MHz for US | 131d? | 2010-03-19 A | 2010-09-17 A | 100% |  | 2010-03-19 | 2010-09-17 | 131d? |  | finish no earlier than 2010-09-17 | R4 | 1048h | 1048h | LTE_TDD_2600_US-Perf | PCG-24 | Clearwire | michael.hart@clearwire.com | Rel-10 | RP-47 | Issam | RP-100783 |  |  |
| 598 | 237.3 | UE conformance test part: LTE TDD in 2600MHz for US | 136d? | 2010-06-04 A | 2010-12-10 A | 100% |  | 2010-06-04 | 2010-12-10 | 136d? |  | finish no earlier than 2010-12-10 | R5 | 1088h | 1088h | LTE_TDD_2600_US-UEConTest | PCG-25 | Clearwire | michael.hart@clearwire.com | Rel-10 | RP-48 | Ingbert | RP-101071 |  |  |
| 599 | 238 | **Adding 2 GHz band LTE FDD (Band 23) for Ancillary Terrestrial Component (ATC) of Mobile Satellite Service (MSS) in North America** | 454d? | 2010-03-19 A | 2011-12-09 A | 100% |  | 2010-03-19 | 2011-12-09 | 454d? |  |  | R2,R4,R5 | 9776h | 9776h | S_Band_LTE_ATC_MSS | PCG-24 | DBSD | Mariam.Sorond@ico.com | Rel-10 | RP-47 | Joern |  |  |  |
| 600 | 238.1 | Core part: Adding 2 GHz band LTE FDD (Band 23) for ATC of MSS in North America | 316d? | 2010-03-19 A | 2011-06-03 A | 100% |  | 2010-03-19 | 2011-06-03 | 316d? |  | finish no earlier than 2011-06-03 | R4,R2 | 2528h | 2528h | S_Band_LTE_ATC_MSS-Core | PCG-24 | DBSD | Mariam.Sorond@ico.com | Rel-10 | RP-47 | Issam | RP-110545 |  |  |
| 601 | 238.2 | Perf. part: Adding 2 GHz band LTE FDD (Band 23) for ATC of MSS in North America | 316d? | 2010-03-19 A | 2011-06-03 A | 100% |  | 2010-03-19 | 2011-06-03 | 316d? |  | finish no earlier than 2011-06-03 | R4 | 2528h | 2528h | S_Band_LTE_ATC_MSS-Perf | PCG-24 | DBSD | Mariam.Sorond@ico.com | Rel-10 | RP-47 | Issam | RP-110546 |  |  |
| 602 | 238.3 | Test part: Adding 2 GHz band LTE FDD (Band 23) for ATC of MSS in North America | 137d? | 2011-06-07 A | 2011-12-09 A | 100% |  | 2011-06-07 | 2011-12-09 | 137d? |  | finish no earlier than 2011-12-09 | R5 | 1088h | 1088h | S_Band_LTE_ATC_MSS-UEConTest | PCG-27 | DBSD | Mariam.Sorond@ico.com | Rel-10 | RP-52 | Ingbert | RP-111444 |  |  |
| 603 | 239 | **Adding L-Band (Band 24) LTE for Ancillary Terrestrial Component (ATC) of Mobile Satellite Service (MSS) in North America** | 393d? | 2010-03-19 A | 2011-09-16 A | 100% |  | 2010-03-19 | 2011-09-16 | 393d? |  |  | R4,R2,R5 | 8808h | 8808h | L_Band_LTE_ATC_MSS | PCG-24 | LightSquared | Eric.Jacks@lightsquared.com, Maqbool.Aliani@lightsquared.com | Rel-10 | RP-47 | Issam |  |  |  |
| 604 | 239.1 | Core part: Adding L-Band (Band 24) LTE for ATC of MSS in North America | 261d? | 2010-03-19 A | 2011-03-18 A | 100% |  | 2010-03-19 | 2011-03-18 | 261d? |  | finish no earlier than 2010-12-10 | R4,R2 | 2088h | 2088h | L_Band_LTE_ATC_MSS-Core | PCG-24 | LightSquared | Eric.Jacks@lightsquared.com, Maqbool.Aliani@lightsquared.com | Rel-10 | RP-47 | Issam | RP-101117 |  |  |
| 605 | 239.2 | Perf. part: Adding L-Band (Band 24) LTE for ATC of MSS in North America | 316d? | 2010-03-19 A | 2011-06-03 A | 100% |  | 2010-03-19 | 2011-06-03 | 316d? |  | finish no earlier than 2011-06-03 | R4 | 2528h | 2528h | L_Band_LTE_ATC_MSS-Perf | PCG-24 | LightSquared | Eric.Jacks@lightsquared.com, Maqbool.Aliani@lightsquared.com | Rel-10 | RP-47 | Issam | RP-110548 |  |  |
| 606 | 239.3 | Test part: Adding L-Band (Band 24) LTE for ATC of MSS in North America | 131d? | 2011-03-18 A | 2011-09-16 A | 100% |  | 2011-03-18 | 2011-09-16 | 131d? |  | finish no earlier than 2011-09-16 | R5 | 1048h | 1048h | L_Band_LTE_ATC_MSS-UEConTest | PCG-26 | LightSquared | Masoud.olfat@LightSquared.com | Rel-10 | RP-51 | Ingbert | RP-110980 |  |  |

Notes:
- 583: RP#52 completed (open RAN4 Core & Perf parts moved to new Rel-11) / Text3: LTE
- 584: RP#52 completed. Updated WID RP-101417=>RP-101911 (contains only Core part completed in Rel-10). Open RAN4 Core & Perf parts moved to new Rel-11 / Text3: 36.133, 36.201, 36.211, 36.212, 36.213, 36.300, 36.321, 36.323, 36.331, new RAN1 TS 36.216, new RAN4 (36.116, 36.826)
- 585: RP#52 stopped at 30% (no CRs so far) . Transferred completely to Rel-11 together with remaining core part / Text3: 36.133, new TS 36.117 (E-UTRA Relay conformance testing)
- 586: SP#52 SP-110338 (S2-85/S2-112851) 23.401 Cat F CR#2128 Completion of Relay procedure overview / Text3: 23.401
- 587: SP#51 completed / Text3: 33.816
- 588: SP#51 completed (impacting Stage 3 in CT and RAN) / Text3: 33.401 (CR#0437,0438), CT1 24.301, CT4 (29.272, 29.274), CT6 31.102, RAN2 (36.331, 36.323), RAN3 36.413
- 589: CP#51 completed / Text3: 31.101, 31.102
- 590: CP#51 completed / Text3: 23.003, 23.008, 29.303, 29.230, 29.272
- 591: RP#52 Core completed / Text3: LTE
- 592: RP#52 completed / Text3: 36.101, 36.133, 36.201, 36.211, 36.212, 36.213, 36.214, 36.300, 36.321, 36.331, 36.413, 36.423
- 593: RP#55 completion 03/12=>06/12 / Text3: 36.101, 36.133
- 594: - / Text3: 36.508, 36.521-1, 36.521-2, 36.521-3, 36.523-1, 36.523-2, 36.523-3
- 595: RP#50 Testing completed. RP#49 Core+Perf completed / Text3: LTE
- 596: RP#49 completed / Text3: 25.461, 25.466, 36.101, 36.104, 36.113, 36.124, 36.133, 36.141, 36.307, 36.331, 37.104, 37.113, 37.141, new TR 36.812
- 597: RP#49 completed / Text3: 36.101, 36.104, 36.133, 36.141, 36.307, 37.104, 37.141, new TR 36.812
- 598: RP#50 completed / Text3: 36.508, 36.521-1, 36.521-2, 36.521-3, 36.523-1, 36.523-2, 36.523-3
- 599: RP#52 completed. Updated WID RP-101401=>RP-110775 (changed in Title "LTE" to "LTE FDD (Band 23)" / Text3: LTE
- 600: RP#52 completed / Text3: 25.101, 25.104, 25.141, 25.461, 25.466, 36.101, 36.104, 36.113, 36.124, 36.133, 36.307, 37.104, 37.141, new TR 36.811
- 601: RP#52 completed / Text3: 36.101, 36.104, 36.113, 36.124, 36.133, 36.141, 36.307, 36.811
- 602: RP#54 completed / Text3: 36.508, 36.521-1, 36.521-2, 36.521-3, 36.523-1, 36.523-2, 36.523-3
- 603: RP#53 completed / Text3: LTE
- 604: RP#51 completed / Text3: 25.101, 25.104, 25.141, 25.461, 25.466, 34.124, 36.101, 36.104, 36.113, 36.124, 36.133, 36.307, 37.104, 37.141, new RAN4 TR 36.813
- 605: RP#52 completed / Text3: 34.121-1, 36.101, 36.104, 36.113, 36.124, 36.133, 36.141, 36.307, 36.521-1, 36.813
- 606: RP#53 completed / Text3: 36.508, 36.521-1, 36.521-2, 36.521-3, 36.523-2

| ID | WBS | Task | Duration | Start | Finish | Complete | Remaining | Baseline start | Baseline finish | Baseline duration | Total slack | Constraint | Resources | Work | Actual work | Text1 | Text2 | Text4 | Text5 | Text6 | Text7 | Text8 | Text11 |
| --- | --- | --- | --- | --- | --- | --- | --- | --- | --- | --- | --- | --- | --- | --- | --- | --- | --- | --- | --- | --- | --- | --- | --- |
| 607 | 240 | **LTE Self Optimizing Networks (SON) enhancements** | 316d? | 2010-03-19 A | 2011-06-03 A | 100% |  | 2010-03-19 | 2011-06-03 | 316d? |  |  | R3,R2,R4 | 5056h | 5056h | SONenh_LTE | PCG-24 | Nokia Siemens Networks | krzysztof.kordybach@nsn.com | Rel-10 | RP-47 | Juha |  |
| 608 | 240.1 | Core part: LTE Self Optimizing Networks (SON) enhancements | 316d? | 2010-03-19 A | 2011-06-03 A | 100% |  | 2010-03-19 | 2011-06-03 | 316d? |  | finish no earlier than 2011-06-03 | R3,R2,R4 | 2528h | 2528h | SONenh_LTE-Core | PCG-24 | Nokia Siemens Networks | krzysztof.kordybach@nsn.com | Rel-10 | RP-47 | Juha | RP-110547 |
| 609 | 241 | **Further enhancements to MBMS for LTE** | 459d? | 2010-06-04 A | 2012-03-02 A | 100% |  | 2010-06-04 | 2012-03-02 | 459d? |  |  | R2,R3,R5 | 5848h | 5848h | MBMS_LTE_enh | PCG-25 | Huawei | Ms Zhao Junhui (zhaojh@huawei.com) | Rel-10 | RP-48 | Joern |  |
| 610 | 241.1 | Core part: Further enhancements to MBMS for LTE | 206d? | 2010-06-04 A | 2011-03-18 A | 100% |  | 2010-06-04 | 2011-03-18 | 206d? |  | finish no earlier than 2011-03-18 | R2,R3 | 1648h | 1648h | MBMS_LTE_enh-Core | PCG-25 | Huawei | Ms Zhao Junhui (zhaojh@huawei.com) | Rel-10 | RP-48 | Joern | RP-110083 |
| 611 | 241.2 | Test part: Further enhancements to MBMS for LTE | 66d? | 2011-12-02 A | 2012-03-02 A | 100% |  | 2011-12-02 | 2012-03-02 | 66d? |  | finish no earlier than 2012-03-02 | R5 | 528h | 528h | MBMS_LTE_enh-UEConTest | PCG-28 | Huawei | Zhang Xin (suzanna.zhang@huawei.com) | Rel-10 | RP-54 |  | RP-120049 |
| 612 | 242 | **UMTS/LTE 3500 MHz** | 1190d? | 2007-11-30 A | 2012-06-15 | 90% | 116.69d? | 2007-11-30 | 2012-06-15 | 1190d? | 388d |  | R4,R2,R3,R5 | 29226h | 26360.2h | RInImp8-UMTSLTE3500 | PCG-21 | Ericsson | johan.skold@ericsson.com | Rel-10 | RP-38 | Issam |  |
| 613 | 242.1 | Core part: UMTS/LTE 3500 MHz | 980d? | 2007-11-30 A | 2011-09-16 A | 100% |  | 2007-11-30 | 2011-09-16 | 980d? |  | finish no earlier than 2011-09-16 | R4,R2,R3 | 7840h | 7840h | RInImp8-UMTSLTE3500 | PCG-21 | Ericsson | johan.skold@ericsson.com | Rel-10 | RP-38 | Issam | RP-110987 |
| 614 | 242.2 | Conformance Test Aspects – LTE 3500 | 925d? | 2008-12-05 A | 2012-06-15 | 90% | 92.5d? | 2008-12-05 | 2012-06-15 | 925d? | 388d | finish no earlier than 2012-06-15 | R5 | 7400h | 6660h | LTE-UEConTest_LTE3500 | PCG-22 | Ericsson | fredrik.sundstrom@ericsson.com | Rel-10 | RP-42 | Ingbert | RP-120040 |
| 615 | 242.3 | Conformance Test Aspects – UMTS 3500 | 925d? | 2008-12-05 A | 2012-06-15 | 80% | 185d? | 2008-12-05 | 2012-06-15 | 925d? | 388d | finish no earlier than 2012-06-15 | R5 | 7400h | 5920h | RInImp-UEConTest_UMTS3500 | PCG-22 | Ericsson | fredrik.sundstrom@ericsson.com | Rel-10 | RP-42 | Ingbert | RP-120041 |
| 616 | 243 | **Minimization of Drive Tests for E-UTRAN and UTRAN** | 724d? | 2009-12-04 A | 2012-09-07 | 68% | 229.17d? | 2009-12-04 | 2012-09-07 | 724d? | 328d |  | R2,R4,R3,R5 | 10968h | 6665.6h | MDT_UMTSLTE | PCG-24 | Nokia Siemens Networks | malgorzata.tomala@nsn.com | Rel-10 | RP-46 | Joern |  |
| 617 | 243.1 | Core part: Minimization of Drive Tests for E-UTRAN and UTRAN | 391d? | 2009-12-04 A | 2011-06-03 A | 100% |  | 2009-12-04 | 2011-06-03 | 391d? |  | finish no earlier than 2011-06-03 | R2,R4,R3 | 3128h | 3128h | MDT_UMTSLTE-Core | PCG-24 | Nokia Siemens Networks | malgorzata.tomala@nsn.com | Rel-10 | RP-46 | Joern | RP-110528 |
| 618 | 243.2 | Test part: Minimization of Drive Tests for E-UTRAN and UTRAN | 256d? | 2011-09-19 A | 2012-09-07 | 20% | 204.8d? | 2011-09-19 | 2012-09-07 | 256d? | 328d | finish no earlier than 2012-09-07 | R5 | 2048h | 409.6h | MDT_UMTSLTE-UEConTest | PCG-27 | Ericsson | leif.mattisson@ericsson.com | Rel-10 | RP-53 |  | RP-120044 |
| 619 | 244 | **HNB and HeNB Mobility Enhancements** | 714d? | 2010-03-19 A | 2012-12-07 | 56% | 310.64d? | 2010-03-19 | 2012-12-07 | 714d? | 263d |  | R3,R2,R5 | 9408h | 2088h | HNB_HENB_mob_enh | PCG-24 | Alcatel-Lucent | Martin,Warner@alcatel-lucent.com | Rel-10 | RP-47 | Juha |  |
| 620 | 244.1 | Core part: HNB and HeNB Mobility Enhancements | 261d? | 2010-03-19 A | 2011-03-18 A | 100% |  | 2010-03-19 | 2011-03-18 | 261d? |  | start no earlier than 2010-03-19 | R3,R2 | 2088h | 2088h | HNB_HENB_mob_enh-Core | PCG-24 | Alcatel-Lucent | Martin.Warner@alcatel-lucent.com | Rel-10 | RP-47 | Juha | RP-110058 |
| 621 | 244.2 | Test part: HeNB Mobility Enhancements | 201d? | 2012-03-02 | 2012-12-07 |  |  | 2012-03-02 | 2012-12-07 | 201d? | 263d | finish no earlier than 2012-12-07 | R5 | 1608h |  | HNB_HENB_mob_enh-UEConTest_LTE | PCG-28 | Qualcomm | Anjali Mishra (ajha@qualcom.com) | Rel-10 | RP-55 |  |  |
| 622 | 245 | **Expanded 1900 MHz Band for UTRA and LTE** | 534d? | 2010-06-04 A | 2012-06-15 | 85% | 82.32d? | 2010-06-04 | 2012-06-15 | 534d? | 388d |  | R4,R2,R5 | 10616h | 7444.8h | E1900 | PCG-25 | Sprint | nick.j.baustert@sprint.com | Rel-10 | RP-48 | Issam |  |
| 623 | 245.1 | Core part: Expanded 1900 MHz Band for UTRA and LTE | 261d? | 2010-06-04 A | 2011-06-03 A | 100% |  | 2010-06-04 | 2011-06-03 | 261d? |  | finish no earlier than 2011-06-03 | R4,R2 | 2088h | 2088h | E1900-Core | PCG-25 | Sprint | nick.j.baustert@sprint.com | Rel-10 | RP-48 | Issam | RP-110529 |
| 624 | 245.2 | Perf. part: Expanded 1900 MHz Band for UTRA and LTE | 261d? | 2010-06-04 A | 2011-06-03 A | 100% |  | 2010-06-04 | 2011-06-03 | 261d? |  | finish no earlier than 2011-06-03 | R4,R2 | 2088h | 2088h | E1900-Perf | PCG-25 | Sprint | nick.j.baustert@sprint.com | Rel-10 | RP-48 | Issam | RP-110530 |
| 625 | 245.3 | Test part: Expanded 1900 MHz Band for UTRA and LTE | 272d? | 2011-06-07 A | 2012-06-15 | 55% | 122.4d? | 2011-06-07 | 2012-06-15 | 272d? | 388d | finish no earlier than 2012-06-15 | R5 | 2168h | 1188.8h | E1900-UEConTest | PCG-27 | Sprint | nick.j.baustert@sprint.com | Rel-10 | RP-52 | Ingbert | RP-120043 |
| 626 | 246 | **Multi-standard radio Base Station RF requirements for non-contiguous spectrum deployments** | 389d? | 2010-06-04 A | 2011-11-25 A | 100% |  | 2010-06-04 | 2011-11-25 | 389d? |  |  | R4,G1 | 10472h | 10472h | MSR_NC | PCG-25 | Ericsson | johan.skold@ericsson.com | Rel-10 | RP-48 | Issam |  |
| 627 | 246.1 | Core part: Multi-standard radio Base Station RF requirements for non-contiguous spectrum deployments | 261d? | 2010-06-04 A | 2011-06-03 A | 100% |  | 2010-06-04 | 2011-06-03 | 261d? |  | finish no earlier than 2011-06-03 | R4 | 2088h | 2088h | MSR_NC-Core | PCG-25 | Ericsson | johan.skold@ericsson.com | Rel-10 | RP-48 | Issam | RP-110531 |
| 628 | 246.2 | Perf. part: Multi-standard radio Base Station RF requirements for non-contiguous spectrum deployments | 336d? | 2010-06-04 A | 2011-09-16 A | 100% |  | 2010-06-04 | 2011-09-16 | 336d? |  | finish no earlier than 2011-09-16 | R4 | 2688h | 2688h | MSR_NC-Perf | PCG-25 | Ericsson | johan.skold@ericsson.com | Rel-10 | RP-48 | Issam | RP-110988 |
| 629 | 246.3 | GERAN Core part: Multi-standard radio Base Station RF requirements for non-contiguous spectrum deployments | 261d? | 2010-09-03 A | 2011-09-02 A | 100% |  | 2010-09-03 | 2011-09-02 | 261d? |  | finish no earlier than 2011-09-02 | G1 | 2088h | 2088h | MSR_NC-GERAN | PCG-25 | Ericsson | mats.y.samuelsson@ericsson.com | Rel-10 | GP-47 | Paolo |  |
| 630 | 246.4 | GERAN BS Test part: Multi-standard radio Base Station RF requirements for non-contiguous spectrum deployments | 62d? | 2011-09-02 A | 2011-11-25 A | 100% |  | 2011-09-02 | 2011-11-25 | 62d? |  | finish no earlier than 2011-11-25 | G1 | 496h | 496h | MSR_NC-GERAN | PCG-28 | Ericsson | mats.y.samuelsson@ericsson.com | Rel-10 | GP-52 |  |  |
| 631 | 247 | (Small) Technical Enhancements and Improvements for Rel-10 | 470d? | 2009-06-04 A | 2011-03-23 A | 100% |  | 2009-06-04 | 2011-03-23 | 470d? |  | finish no earlier than 2011-03-23 | All | 3760h | 3760h | TEI10 | PCG-23 |  |  | Rel-10 | SP-44 |  |  |
| 632 | 248 | (IETF) (Small) Technical Enhancements and Improvements for Rel-10 (draft-atarius) | 654d? | 2009-06-04 A | 2012-09-14 | 20% | 523.2d? | 2009-06-04 | 2012-09-14 | 654d? | 323d | finish no earlier than 2012-09-14 | C1-IETF | 5232h | 1046.4h | TEI10_IETF_draft-atarius-dispatch-meid-urn | PCG-27 | Andrew Allen |  | Rel-10 | CP-52 | Frederic |  |
| 633 | 249 | (IETF) (Small) Technical Enhancements and Improvements for Rel-10 (RFC6275) | 562d? | 2009-06-04 A | 2011-07-29 A | 100% |  | 2009-06-04 | 2011-07-29 | 562d? |  | finish no earlier than 2011-07-29 | C1-IETF | 4496h | 4496h | TEI10_IETF_RFC6275 | PCG-27 |  |  | Rel-10 | CP-53 |  |  |
| 634 | 250 | Test - (Small) Technical Enhancements and Improvements for Rel-10 | 267d? | 2011-12-01 A | 2012-12-07 | 30% | 186.9d? | 2011-12-01 | 2012-12-07 | 267d? | 263d | finish no earlier than 2012-12-07 | R5,G3new | 2136h | 640.8h | TEI10_Test | PCG-28 | n/a |  | Rel-10 | RP-54 |  |  |

Notes:
- 607: RP#52 completed / Text3: LTE
- 608: RP#52 completed (Stage 1,2,3) / Text3: 36.300, 36.331, 36.413, 36.423
- 609: RP#51 completed. SA2 decided not to support MBR>GBR in Rel-10 MBMS. For SA2, MBR=GBR in Rel-10 MBMS. Hence RAN removed enabling statistical multiplexing gains for variable bit rate services in Objectives / Text3: LTE
- 610: RP#51 completed / Text3: 25.446, 36.300, 36.321, 36.322, 36.323, 36.331, 36.440, 36.441, 36.442, 36.443, 36.444, 36.445
- 611: RP#55 completed / Text3: 36.508, 36.523-1, 36.523-2, 36.523-3
- 612: RP#53 completed (test ongoing) / Text3: UTRA, LTE
- 613: RP#53 completed. TR 37.801v200 for Approval / Text3: 25.101, 25.104, 25.113, 25.133, 25.141, 25.307, 25.307, 25.331, 25.461, 25.463, 34.124, 36.101, 36.104, 36.113, 36.141, 36.331, new 37.801
- 614: - / Text3: 36.508, 36.521-1, 36.521-2, 36.521-3
- 615: - / Text3: 34.108, 34.121-1, 34.121-2
- 616: RP#52 Core completed. Triggered by UID_430021 TR 36.805 (Study on Minimization of drive-tests in NGN) / Text3: UTRA, LTE
- 617: RP#52 completed / Text3: 25.133, 25.215, 25.304, 25.331, 25.423, 36.133, 36.214, 36.300, 36.304, 36.331, 36.413, 36.423, new 37.320 (Stage 2)
- 618: Testing for LTE only / Text3: LTE 34.108, 34.123-1, 34.123-2, 34.123-3, 36.508, 36.523-1, 36.523-2, 36.523-3
- 619: RP#51 completed. Common UTRA and E-UTRA Work Item to ensure that divergence between the systems is minimized / Text3: UTRA, LTE
- 620: RP#51 completed. WID updated RP-101426=>RP-110183 / Text3: 25.413, 25.467, 25.469, 36.300, 36.413, 36.423, new 25.471
- 621: - / Text3: 34.108, 34.123-1, 34.123-2, 34.123-3, 36.508, 36.523-1, 36.523-2, 36.523-3
- 622: RP#52 Core & Perf completed. Create a new band that expands UTRA and E-UTRA band 2 to include frequencies between 1910 1915 MHz and 1990-1995 MHz (US FCC allocation) / Text3: UTRA, LTE
- 623: RP#52 completed / Text3: 25.101, 25.104, 25.113, 25.133, 25.141, 25.461, 25.466, 36.101, 36.104, 36.113, 36.124, 36.133, 36.141, 36.307, 36.331, new TR 36.818
- 624: RP#52 completed / Text3: 25.101, 25.104, 25.113, 25.133, 25.141, 25.461, 25.466, 36.101, 36.104, 36.113, 36.124, 36.133, 36.141, 36.307, 36.331, new TR 36.818
- 625: RP#55 completion 03/12=>06/12 / Text3: 34.108, 34.121-1, 34.121-2, 34.123-1, 34.123-2, 34.123-3, 36.508, 36.521-1, 36.521-2, 36.521-3, 36.523-1, 36.523-2, 36.523-3
- 626: RP#53 completed / Text3: UTRA, LTE, GERAN
- 627: RP#52 completed. TR 37.802 v100 for Approval / Text3: 25.104, 36.104, 37.104, new TR 37.802
- 628: RP#53 completed / Text3: 25.141, 36.141, 37.141, 37.802
- 629: GP#51 completed. GP#47 approved WID / Text3: 45.005
- 630: GP#52 completed / Text3: 51.021
- 631: -
- 632: Not completed internet-draft / Text3: draft-atarius-dispatch-meid-urn
- 633: SP#53/IETF#81: RFC 6275 completed / Text3: RFC 6275 (was draft-ietf-mext-rfc3775bis)
- 634: -

| ID | WBS | Task | Type | Duration | Start | Finish | Complete | Baseline start | Baseline finish | Baseline duration | Constraint | Resources | Work | Actual work | Text1 | Text2 | Text4 | Text6 | Text7 | Text8 | Text9 | Text12 | Text3 | Text11 |
| --- | --- | --- | --- | --- | --- | --- | --- | --- | --- | --- | --- | --- | --- | --- | --- | --- | --- | --- | --- | --- | --- | --- | --- | --- |
| 635 | 251 | **Deleted - GTP-based S8 chaining** |  | 337d? | 2008-12-11 A | 2010-03-25 A | 100% | 2008-12-11 | 2010-03-25 | 337d? |  | S2 | 5392h | 5392h | GTPchaining | PCG-22 | Huawei | Rel-10 | SP-42 | Maurice | PCG-24 | SP-47 |  |  |
| 636 | 251.1 | Deleted - Stage 2 for GTPchaining |  | 337d? | 2008-12-11 A | 2010-03-25 A | 100% | 2008-12-11 | 2010-03-25 | 337d? | finish no earlier than 2010-03-25 | S2 | 2696h | 2696h | GTPchaining | PCG-22 | Huawei | Rel-10 | SP-42 | Maurice | PCG-24 | SP-47 | 23.402 |  |
| 637 | 252 | Deleted - UTRAN 2 ms TTI uplink range improvement |  | 272d? | 2009-03-06 A | 2010-03-19 A | 100% | 2009-03-06 | 2010-03-19 | 272d? | finish no earlier than 2010-03-19 | R1,R2,R3,R4 | 2176h | 2176h | RANimp-2mTTI_ULimp | PCG-22 | Nokia Siemens Networks | Rel-10 | RP-43 | Patrick | PCG-24 | RP-47 | 25.133, 25.212, 25.214, 25.321, 25.331 | RP-100040 |
| 638 | 253 | Deleted - Enhanced Home NodeB / eNodeB continuation of Rel-9 |  | 337d? | 2008-12-11 A | 2010-03-25 A | 100% | 2008-12-11 | 2010-03-25 | 337d? |  | S2 | 2696h | 2696h | eEHNB | PCG-23 | Alcatel-Lucent | Rel-10 | SP-44 | Maurice | PCG-24 | SP-47 |  |  |
| 639 | 254 | **Deleted - Fixed Wireless Customer-Premises Equipment (CPE) RF Requirements** |  | 391d? | 2009-12-04 A | 2011-06-03 A | 100% | 2009-12-04 | 2011-06-03 | 391d? |  | R4,R5 | 9384h | 9384h | FW_CPE_RF | PCG-24 | Verizon Wireless | Rel-10 | RP-46 | Issam | PCG-27 | RP-52 | LTE |  |
| 640 | 254.1 | Deleted - Core part: Fixed Wireless Customer-Premises Equipment (CPE) RF Requirements |  | 391d? | 2009-12-04 A | 2011-06-03 A | 100% | 2009-12-04 | 2011-06-03 | 391d? | finish no earlier than 2011-06-03 | R4 | 3128h | 3128h | FW_CPE_RF-Core | PCG-24 | Verizon Wireless | Rel-10 | RP-46 | Issam | PCG-27 | RP-52 | 36.101 | RP-110539 |
| 641 | 254.2 | Deleted - Test part: Fixed Wireless Customer-Premises Equipment (CPE) RF Requirements |  | 391d? | 2009-12-04 A | 2011-06-03 A | 100% | 2009-12-04 | 2011-06-03 | 391d? | finish no earlier than 2011-06-03 | R5 | 3128h | 3128h | FW_CPE_RF-UEConTest | PCG-24 | Verizon Wireless | Rel-10 | RP-46 | Ingbert | PCG-27 | RP-52 | 36.521-1 | RP-110504 |
| 642 | 255 | **Deleted - Latency reductions for LTE** |  | 266d? | 2009-12-04 A | 2010-12-10 A | 100% | 2009-12-04 | 2010-12-10 | 266d? |  | R2,R1 | 4256h | 4256h | LTE_LATRED | PCG-24 | Ericsson | Rel-10 | RP-46 | Joern | PCG-26 | RP-50 | LTE |  |
| 643 | 255.1 | Deleted - Core part: Latency reductions for LTE |  | 266d? | 2009-12-04 A | 2010-12-10 A | 100% | 2009-12-04 | 2010-12-10 | 266d? | finish no earlier than 2010-12-10 | R2,R1 | 2128h | 2128h | LTE_LATRED-Core | PCG-24 | Ericsson | Rel-10 | RP-46 | Joern | PCG-26 | RP-50 | 36.213, 36.300, 36.306, 36.321, 36.331 | RP-101112 |
| 644 | 256 | **Deleted - Enhanced Interference Management for Home NodeBs** |  | 131d? | 2010-03-19 A | 2010-09-17 A | 100% | 2010-03-19 | 2010-09-17 | 131d? |  | R3 | 2096h | 2096h | HNB_IM | PCG-24 | Qualcomm | Rel-10 | RP-47 | Juha | PCG-25 | RP-49 | UTRA | RP-100754 |
| 645 | 256.1 | Deleted - Core part: Enhanced Interference Management for Home NodeBs |  | 131d? | 2010-03-19 A | 2010-09-17 A | 100% | 2010-03-19 | 2010-09-17 | 131d? | finish no earlier than 2010-09-17 | R3 | 1048h | 1048h | HNB_IM-Core | PCG-24 | Qualcomm | Rel-10 | RP-47 | Juha | PCG-25 | RP-49 | 25.413, 25.467, 25.469 | RP-100754 |
| 646 | 257 | Release 10 Studies |  | 531d? | 2009-03-12 A | 2011-03-23 A | 100% | 2009-03-12 | 2011-03-23 | 531d? | finish no earlier than 2011-03-23 | CP,GP,RP,SP | 4248h | 4248h |  |  |  | Rel-10 |  |  |  |  |  |  |
| 647 | 258 | Study on System enhancements for the use of IMS services in Local BreakOut and Optimal Routing of Media |  | 575d? | 2007-10-01 A | 2009-12-10 A | 100% | 2007-10-01 | 2009-12-10 | 575d? | finish no earlier than 2009-12-10 | S2 | 4600h | 4600h | FS_IMS_LBO_ORM |  | Telecom Italia, BT | Rel-10 | SP-37 | Maurice |  |  | 23.894 |  |
| 648 | 259 | Study on Intra Domain Connection of RAN Nodes to Multiple CN Nodes |  | 533d? | 2008-03-12 A | 2010-03-25 A | 100% | 2008-03-12 | 2010-03-25 | 533d? | finish no earlier than 2010-03-25 | S2 | 4264h | 4264h | FS_IDC | PCG-21 | China Mobile | Rel-10 | SP-39 | Maurice |  |  | 23.924 (was 23.823) |  |
| 649 | 260 | Study on Single Radio Voice Call Continuity enhancements |  | 341d? | 2009-06-04 A | 2010-09-23 A | 100% | 2009-06-04 | 2010-09-23 | 341d? | finish no earlier than 2010-09-23 | S2 | 2728h | 2728h | FS_eSRVCC | PCG-23 | China Mobile | Rel-10 | SP-44 | Maurice |  |  | 23.856 |  |
| 650 | 261 | Study on Single Radio Video Call Continuity for 3G-CS |  | 131d? | 2010-03-25 A | 2010-09-23 A | 100% | 2010-03-25 | 2010-09-23 | 131d? | finish no earlier than 2010-09-23 | S2 | 1048h | 1048h | FS_vSRVCC | PCG-24 | Samsung | Rel-10 | SP-47 | Maurice |  |  | 23.886 |  |
| 651 | 262 | Study on S2b Mobility based on GTP |  | 56d? | 2010-03-25 A | 2010-06-10 A | 100% | 2010-03-25 | 2010-06-10 | 56d? | finish no earlier than 2010-06-07 | S2 | 448h | 448h | FS_SMOG | PCG-24 | Alcatel-Lucent | Rel-10 | SP-47 | Maurice |  |  | 23.834 |  |
| 652 | 263 | Study on Surround Sound codec extension for PSS and MBMS |  | 530d? | 2009-03-12 A | 2011-03-23 A | 100% | 2009-03-12 | 2011-03-23 | 530d? | finish no earlier than 2011-03-23 | S4 | 4240h | 4240h | FS_SS_PSS_MBMS | PCG-22 | Fraunhofer Gesellschaft | Rel-10 | SP-43 | Paolo |  |  | 26.950 |  |
| 653 | 264 | Study on Improved Video Coding Support |  | 205d? | 2010-06-10 A | 2011-03-23 A | 100% | 2010-06-10 | 2011-03-23 | 205d? | finish no earlier than 2011-03-23 | S4 | 1640h | 1640h | FS_IVCS | PCG-25 | Nokia, ETRI | Rel-10 | SP-48 | Paolo |  |  | 26.904 |  |
| 654 | 265 | Study on Rc Reference Point Functionalities and Message Flows |  | 397d? | 2008-09-18 A | 2010-03-25 A | 100% | 2008-09-18 | 2010-03-25 | 397d? | finish no earlier than 2010-03-23 | S5 | 3170.08h | 3170.08h | FS_OAM_Rc | PCG-21 | Huawei | Rel-10 | SP-41 | Dionisio |  |  | 32.825 |  |
| 655 | 266 | Study on Telecommunication Management; Energy Savings Management |  | 271d? | 2009-03-12 A | 2010-03-25 A | 100% | 2009-03-12 | 2010-03-25 | 271d? | finish no earlier than 2010-03-25 | S5 | 2168h | 2168h | FS_OAM_ESM | PCG-22 | Orange, Vodafone | Rel-10 | SP-43 | Dionisio |  |  | 32.826 |  |
| 656 | 267 | Study on Integration of Device Management Information with Itf-N |  | 211d? | 2009-06-04 A | 2010-03-25 A | 100% | 2009-06-04 | 2010-03-25 | 211d? | finish no earlier than 2010-03-25 | S5 | 1688h | 1688h | FS_IDMI_Itf-N | PCG-23 | Motorola | Rel-10 | SP-44 | Dionisio |  |  | 32.827 |  |
| 657 | 268 | Study on Alignment of 3GPP Generic NRM IRP and TMF Shared Information Data (SID) model |  | 335d? | 2009-12-10 A | 2011-03-23 A | 100% | 2009-12-10 | 2011-03-23 | 335d? | finish no earlier than 2011-03-23 | S5 | 2680h | 2680h | FS_3GNRM_TMFSID | PCG-24 | Nokia Siemens Networks | Rel-10 | SP-46 | Dionisio |  |  | 32.828 |  |
| 658 | 269 | Study on Harmonization of 3GPP Alarm IRP and TMF Interface Program (TIP) Fault Management |  | 335d? | 2009-12-10 A | 2011-03-23 A | 100% | 2009-12-10 | 2011-03-23 | 335d? | finish no earlier than 2011-03-23 | S5 | 2680h | 2680h | FS_3G_TMF_FM | PCG-24 | Nokia Siemens Networks, Alcatel-Lucent | Rel-10 | SP-46 | Dionisio |  |  | 32.829 |  |
| 659 | 270 | Study on Alarm Correlation and Alarm Root Cause Analysis |  | 205d? | 2010-06-10 A | 2011-03-23 A | 100% | 2010-06-10 | 2011-03-23 | 205d? | finish no earlier than 2011-03-23 | S5 | 1640h | 1640h | FS_AC_ARCA | PCG-25 | Ericsson | Rel-10 | SP-48 | Dionisio |  |  | 32.832 |  |
| 660 | 271 | Study on Alignment of 3GPP PM IRP and TMF Interface Program (TIP) PM |  | 205d? | 2010-06-10 A | 2011-03-23 A | 100% | 2010-06-10 | 2011-03-23 | 205d? | finish no earlier than 2011-03-23 | S5 | 1640h | 1640h | FS_3G_TMF_PM | PCG-25 | Alcatel-Lucent | Rel-10 | SP-48 | Dionisio |  |  | 32.831 |  |
| 661 | 272 | Study on Policy and Charging Rules Function (PCRF) failure and restoration |  | 261d? | 2009-08-18 A | 2010-09-17 A | 100% | 2009-08-18 | 2010-09-17 | 261d? | finish no earlier than 2010-09-17 | C3 | 2088h | 2088h | FS_PCRF-FR | PCG-23 | NEC | Rel-10 | CP-45 | Jiwan |  |  | 29.816 |  |
| 662 | 273 | Study on User Data Convergence (UDC) evolution |  | 206d? | 2010-06-04 A | 2011-03-18 A | 100% | 2010-06-04 | 2011-03-18 | 206d? | finish no earlier than 2011-03-18 | C4 | 1648h | 1648h | FS_UDCe | PCG-25 | Alcatel-Lucent | Rel-10 | CP-48 | Kimmo |  |  | 23.845 |  |
| 663 | 274 | Study on UICC access to IMS |  | 206d? | 2010-06-04 A | 2011-03-18 A | 100% | 2010-06-04 | 2011-03-18 | 206d? | finish no earlier than 2011-03-18 | C6 | 1648h | 1648h | FS_IMS-UICC | PCG-25 | Gemalto | Rel-10 | CP-48 | Xavier |  |  | 31.828 |  |
| 664 | 275 | Study on Uplink Tx Diversity for HSPA |  | 208.4d? | 2009-08-18 A | 2010-06-04 A | 100% | 2009-08-18 | 2010-06-04 | 208.4d? | finish no earlier than 2010-06-04 | R4 | 1667.2h | 1667.2h | FS_UL-TxDiv-HSPA | PCG-23 | Qualcomm | Rel-10 | RP-45 | Issam |  |  | UTRA 25.863 | RP-100499 |
| 665 | 276 | Study on Solutions for Energy Saving within UTRA Node B |  | 206d? | 2009-12-04 A | 2010-09-17 A | 100% | 2009-12-04 | 2010-09-17 | 206d? | finish no earlier than 2010-09-17 | R1,R3 | 1648h | 1648h | FS_Energy_UMTS | PCG-24 | Vodafone | Rel-10 | RP-46 | Patrick |  |  | UTRA 25.927 | RP-100796 |
| 666 | 277 | Study on Potential solutions for energy saving for E-UTRAN |  | 316d? | 2010-02-02 A | 2011-06-03 A | 100% | 2010-02-02 | 2011-06-03 | 316d? | finish no earlier than 2011-06-03 | R3,R2 | 2528h | 2528h | FS_Energy_LTE | PCG-24 | China Mobile | Rel-10 | RP-47 | Juha |  |  | LTE 36.927 | RP-110597 |
| 667 | 278 | Study on Improvements of distributed antenna for 1.28Mcps TDD |  | 191d? | 2010-03-05 A | 2010-12-10 A | 100% | 2010-03-05 | 2010-12-10 | 191d? | finish no earlier than 2010-12-10 | R1,R2,R3 | 1528h | 1528h | FS_distr_ant_LCR_TDD | PCG-24 | ZTE | Rel-10 | RP-47 | Patrick |  |  | UTRA 25.865 | RP-101287 |
| 668 | 279 | Deleted - Study on enhancements to IMS border functions for IMS Interconnection of services |  | 586d? | 2008-09-18 A | 2010-12-15 A | 100% | 2008-09-18 | 2010-12-15 | 586d? | finish no earlier than 2010-12-15 | S2 | 4688h | 4688h | FS_eIMS_IBCF | PCG-21 | Starent Networks | Rel-10 | SP-41 | Maurice | PCG-26 | SP-50 | 23.848 |  |
| 669 | 280 | Deleted - Study on EPC Charging enhancement |  | 211d? | 2009-06-04 A | 2010-03-25 A | 100% | 2009-06-04 | 2010-03-25 | 211d? | finish no earlier than 2010-03-25 | S5 | 1688h | 1688h | FS_EPCcharg | PCG-23 | Nokia Siemens Networks | Rel-10 | SP-44 | Dionisio | PCG-24 | SP-47 |  |  |
| 670 | 281 | Deleted - Study on Interworking Proxy between GTP based and PMIP based interfaces |  | 186d? | 2009-09-18 A | 2010-06-04 A | 100% | 2009-09-18 | 2010-06-04 | 186d? | finish no earlier than 2010-06-04 | C4 | 1488h | 1488h | FS_GTP-MIP-IW | PCG-23 | NTT DoCoMo | Rel-10 | CP-45 | Kimmo | PCG-25 | CP-48 | 29.875 |  |
| 671 | 282 | Release 9 Features | milestone | 0d? | 2008-06-05 A | 2008-06-05 A | 100% | 2008-06-05 | 2008-06-05 | 0d? |  | CP,GP,RP,SP |  |  |  |  |  | Rel-9 |  |  |  |  |  |  |

Notes:
- 635: SP#47 work stopped (depending on ongoing related CT4 work). Stage 1 in UID_320022 Rel-8 Requirements for evolution of the 3GPP system architecture (AIPN-SAE): 22.278, 22.011, 22.246 / Text5: Haining Wang (wanghaining@huawei.com)
- 636: SP#47 work stopped / Text5: Haining Wang (wanghaining@huawei.com)
- 637: RP#47 work stopped/abandoned (no CR approved). Cell sets the TTI (Transmission Time Interval) to 2 ms / Text5: Karri Ranta-aho (karri.ranta-aho@nsn.com)
- 638: SP#47 deleted (SA2 work moved under SA1 UID_450053). SP#44 Umbrella Feature created to host WIs moved out of Rel-9 (SA2 UID_420034 on IMS aspects of Architecture for Home NodeB) / Text5: Nicolas Drevon
- 639: RP#52 work stopped (lack of contributions). Add new power classes in E-UTRAN UL to allow CPE type applications to be operated at higher max output power / Text5: zheng.zhao@verizonwireless.com
- 640: RP#52 work stopped at 55% (lack of contributions) / Text5: zheng.zhao@verizonwireless.com
- 641: RP#52 work stopped (lack of contributions) / Text5: zheng.zhao@verizonwireless.com
- 642: RP#50 work stopped (RP-101266) / Text5: henrik.enbuske@ericsson.com
- 643: RP#50 work stopped (RP-101266) / Text5: henrik.enbuske@ericsson.com
- 644: RP#49 stopped (no further standardization needed). Ensure that Enhanced Interference Management methods identified in Rel-9 for HNBs do not fail in deployments with a large penetration of CSG-aware UEs / Text5: Andrei Radulescu (aradules@qualcomm.com)
- 645: RP#49 stopped (no further standardization needed) / Text5: Andrei Radulescu (aradules@qualcomm.com)
- 646: -
- 647: SP#46 completed. Spin-off Feature UID_460028 Optimal Media Routeing (OMR). Linked to Study on Multimedia Session Continuity UID_350051, Study on Centralized IMS Service Control UID_330012, IMS inter-operator service interconnection interface UID_360011 / Text5: mario.madella@telecomitalia.it, victor.kueh@bt.com
- 648: SP#47 completed. Concluded no further normative work expected. Linked to 23.236 / Text5: LIU HONG (liuhongyfw@chinamobile.com)
- 649: SP#49 completed (Conclusion: select the SIP anchoring based solution for normative work CR (TEI10) introducing and completing stage-2). Analyzed performance of Rel-8 SRVCC solution from E-UTRAN/HSPA to UTRAN/GERAN / Text5: Hou zhiqiang (houzhiqiang@chinamobile.com), Jiang Yi (jiangyi@chinamobile.com)
- 650: SP#49 completed. TR 23.886v100 for Approval. Related to Rel-8 UID_350030 Single Radio Voice Call Continuity for 3GPP (SAES-SRVCC). Study how to provide Video Call seamless service continuity for 3G/LTE terminal user / Text5: Haris Zisimopoulos (haris.z@samsung.com)
- 651: SP#48 completed. Triggered by Rel-8 UID_350027 SAE for support for non-3GPP accesses. Nature of relationship: S2b one of the interfaces defined for non-3GPP accesses support in EPS. Stage 1 in Rel-8 UID_320022 (AIPN-SAE) 22.278,22.101 / Text5: bruno.landais@alcatel-lucent.com
- 652: SP#51 completed. Extend Rel-8 UID_34043 (Extending PSS and MBMS User Services for optimized Mobile TV) / Text5: jan.plogsties@iis.franhofer.de
- 653: SP#51 completed. Extends Rel-9 Improved Video Support for PSS and MBMS (UID_430039) / Text5: imed.bouazizi@nokia.com, jaihyung@etri.re.kr
- 654: SP#47 completed / Text5: shan.mingjun@huawei.com
- 655: SP#47 completed. Study result might impact Feature UID_420011 Self Organising Networks (SON) / Text5: Jean-Michel Cornilly (Orange)
- 656: SP#47 completed. TR 32.827 v100 for Information + Approval. WID updated SP-090462=>SP-100088. Study the missing Itf-N part in the Framework. Study changes to Itf-N to utilize UE based measurements / Text5: Yizhi Yao (yzyao@motorola.com)
- 657: SP#51 completed / Text5: olaf.pollakowski@nsn.com
- 658: SP#51 completed / Text5: olaf.pollakowski@nsn.com, Padma.Sudarsan@alcatel-lucent.com
- 659: SP#51 completed / Text5: edwin.tse@ericsson.com
- 660: SP#51 completed / Text5: Padma.Sudarsan@alcatel-lucent.com
- 661: CP#49 completed / Text5: gottfried.punz@nw.neclab.eu
- 662: CP#51 completed. Study UDC evolution from Features in Rel-9 UID_400034 and Rel-10 UID_480011 UDC Data Model / Text5: jean-jacques.trottin@alcatel-lucent.com
- 663: CP#51 completed / Text5: Denis.Lheriteau@gemalto.com
- 664: RP#48 completed / Text5: Heechoon Lee (heechoon@qualcomm.com)
- 665: RP#49 completed. Based on ETSI EE TS 102 706. / Text5: Prakash.bhat@vodafone.com
- 666: RP#52 completed / Text5: Yang Ning (yangning@chinamobile.com)
- 667: RP#50 completed. TR 25.865 v101 for Approval / Text5: huang.he4@zte.com.cn
- 668: SP#50 work stopped. Additional work may be addressed as part of the Rel-11 Feature UID_470051 Advanced IP Interconnection of Services (IPXS) / Text5: Rajat Ghai (rghai@starentnetworks.com)
- 669: SP#47 work stopped. Issue covered by Rel-10 UID_460039 Charging for LIPA_SIPTO and UID_4700xy Charging for IFOM / Text5: Gerald.Goermer@nsn.com
- 670: CP#48 work stopped/abandoned / Text5: takaaki.matsuura.sp@s1.nttdocomo.com
- 671: -

| ID | WBS | Task | Duration | Start | Finish | Complete | Remaining | Baseline start | Baseline finish | Baseline duration | Total slack | Constraint | Resources | Work | Actual work | Text1 | Text2 | Text6 | Text7 | Text8 | Text4 | Text5 | Text11 |
| --- | --- | --- | --- | --- | --- | --- | --- | --- | --- | --- | --- | --- | --- | --- | --- | --- | --- | --- | --- | --- | --- | --- | --- |
| 672 | 283 | **LCS for LTE and EPS** | 981d? | 2008-06-05 A | 2012-03-02 A | 100% |  | 2008-06-05 | 2012-03-02 | 981d? |  |  | S2,C1,C4,R2,R1,R3,R4,R5 | 24304h | 24304h | LCS_LTE_EPS | PCG-22 | Rel-9 | SP-43 | Maurice |  |  |  |
| 673 | 283.1 | **LCS Control Plane Solution for EPS** | 468d? | 2008-06-05 A | 2010-03-19 A | 100% |  | 2008-06-05 | 2010-03-19 | 468d? |  |  | S2,C4,C1 | 9224h | 9224h | LCS_EPS-CPS | PCG-21 | Rel-9 | SP-40 | Maurice | Polaris Wireless | Robert Gross (rgross@polariswireless.com) |  |
| 674 | 283.1.1 | Stage 2 for LCS Control Plane Solution for EPS | 261d? | 2008-06-05 A | 2009-06-04 A | 100% |  | 2008-06-05 | 2009-06-04 | 261d? |  | finish no earlier than 2009-06-04 | S2 | 2088h | 2088h | LCS_EPS-CPS | PCG-21 | Rel-9 | SP-40 | Maurice | Polaris Wireless | Robert Gross (rgross@polariswireless.com) |  |
| 675 | 283.1.2 | CT4 aspects of Control Plane LCS in the EPC | 212d? | 2009-05-29 A | 2010-03-19 A | 100% |  | 2009-05-29 | 2010-03-19 | 212d? |  | finish no earlier than 2010-03-19 | C4 | 1696h | 1696h | LCS_EPS-CPS | PCG-23 | Rel-9 | CP-44 | Kimmo | Polaris Wireless | Robert Gross (rgross@polariswireless.com) |  |
| 676 | 283.1.3 | CT1 aspects of Control Plane LCS in the EPC | 212d? | 2009-05-29 A | 2010-03-19 A | 100% |  | 2009-05-29 | 2010-03-19 | 212d? |  | finish no earlier than 2010-03-19 | C1 | 1696h | 1696h | LCS_EPS-CPS | PCG-23 | Rel-9 | CP-44 | Frederic | Polaris Wireless | Robert Gross (rgross@polariswireless.com) |  |
| 677 | 283.2 | Positioning Support for LTE | 392d? | 2008-12-05 A | 2010-06-04 A | 100% |  | 2008-12-05 | 2010-06-04 | 392d? |  | finish no earlier than 2010-06-04 | R2,R1,R3,R4 | 3136h | 3136h | LCS_LTE | PCG-22 | Rel-9 | RP-42 | Joern | Qualcomm | Nathan Tenny (ntenny@qualcomm.com) | RP-100442 |
| 678 | 283.3 | Conformance Test Aspects – Positioning Support for LTE | 512d? | 2010-03-19 A | 2012-03-02 A | 100% |  | 2010-03-19 | 2012-03-02 | 512d? |  | finish no earlier than 2012-03-02 | R5 | 4096h | 4096h | LCS_LTE_UEConTest | PCG-24 | Rel-9 | RP-47 | Ingbert | Qualcomm | Shubhang Vora (svoral@qualcomm.com) | RP-120034 |
| 679 | 284 | **MBMS support in EPS** | 921d? | 2008-06-05 A | 2011-12-09 A | 100% |  | 2008-06-05 | 2011-12-09 | 921d? |  |  | S2,S3,S5,C3,C4,R2,R3,R4,R5 | 19592h | 19592h | MBMS_EPS | PCG-21 | Rel-9 | SP-40 | Maurice | China Mobile | Liu Hong (liuhongyfw@chinamobile.com) |  |
| 680 | 284.1 | Stage 2 for MBMS support in EPS | 261d? | 2008-06-05 A | 2009-06-04 A | 100% |  | 2008-06-05 | 2009-06-04 | 261d? |  | finish no earlier than 2009-06-04 | S2 | 2088h | 2088h | MBMS_EPS | PCG-21 | Rel-9 | SP-40 | Maurice | China Mobile | Liu Hong (liuhongyfw@chinamobile.com) |  |
| 681 | 284.2 | Security for MBMS support in EPS | 261d? | 2008-12-11 A | 2009-12-10 A | 100% |  | 2008-12-11 | 2009-12-10 | 261d? |  | finish no earlier than 2009-12-10 | S3 | 2088h | 2088h | MBMS_EPS | PCG-22 | Rel-9 | SP-42 | Dionisio | China Mobile | Liu Hong (liuhongyfw@chinamobile.com) |  |
| 682 | 284.3 | MBMS Charging in EPS | 201d? | 2009-03-06 A | 2009-12-10 A | 100% |  | 2009-03-06 | 2009-12-10 | 201d? |  | finish no earlier than 2009-12-10 | S5 | 1600h | 1600h | MBMS_EPS | PCG-22 | Rel-9 | SP-43 | Dionisio | ZTE | guo.wenjie1@zte.com.cn |  |
| 683 | 284.4 | CT4 aspects of MBMS support in EPS (Stage 3) | 137d? | 2009-05-29 A | 2009-12-04 A | 100% |  | 2009-05-29 | 2009-12-04 | 137d? |  | finish no earlier than 2009-12-04 | C4 | 1096h | 1096h | MBMS_EPS | PCG-23 | Rel-9 | CP-44 | Kimmo | China Mobile, ZTE | wangjingyf@chinamobile.com, lu.fei1@zte.com.cn |  |
| 684 | 284.5 | CT3 aspects of MBMS support in EPS (Stage 3) | 137d? | 2009-05-29 A | 2009-12-04 A | 100% |  | 2009-05-29 | 2009-12-04 | 137d? |  | start no earlier than 2009-05-29 | C3 | 1096h | 1096h | MBMS_EPS | PCG-23 | Rel-9 | CP-44 | Jiwan | ZTE, China Mobile | zhou.xiaoyun@zte.com.cn, wangjingyf@chinamobile.com |  |
| 685 | 284.6 | MBMS support in LTE | 271d? | 2009-03-06 A | 2010-03-19 A | 100% |  | 2009-03-06 | 2010-03-19 | 271d? |  | finish no earlier than 2010-03-19 | R2,R3,R4 | 2168h | 2168h | MBMS_LTE | PCG-22 | Rel-9 | RP-43 | Joern | Huawei | arnaud.meylan@huawei.com | RP-100033 |
| 686 | 284.7 | Conformance Test Aspects – MBMS support in LTE | 262d? | 2010-12-10 A | 2011-12-09 A | 100% |  | 2010-12-10 | 2011-12-09 | 262d? |  | finish no earlier than 2011-12-09 | R5 | 2088h | 2088h | MBMS_LTE-UEConTest | PCG-26 | Rel-9 | RP-50 | Ingbert | Huawei | Zhang Xin (zhangxin0208@huawei.com) | RP-111437 |
| 687 | 285 | **Access Network Discovery and Selection Function enhancements** | 333d? | 2008-12-11 A | 2010-03-19 A | 100% |  | 2008-12-11 | 2010-03-19 | 333d? |  |  | S2,C1 | 4720h | 4720h | eANDSF | PCG-22 | Rel-9 | SP-42 | Maurice | Motorola | Apostolis Salkintzis (salki@motorola.com) |  |
| 688 | 285.1 | Stage 2 for Access Network Discovery and Selection Function enhancements | 126d? | 2008-12-11 A | 2009-06-04 A | 100% |  | 2008-12-11 | 2009-06-04 | 126d? |  | finish no earlier than 2009-06-04 | S2 | 1008h | 1008h | eANDSF | PCG-22 | Rel-9 | SP-42 | Maurice | Motorola | Apostolis Salkintzis (salki@motorola.com) |  |
| 689 | 285.2 | CT1 aspects of Access Network Discovery and Selection Function enhancements | 131d? | 2009-09-18 A | 2010-03-19 A | 100% |  | 2009-09-18 | 2010-03-19 | 131d? |  | finish no earlier than 2010-03-19 | C1 | 1048h | 1048h | eANDSF | PCG-23 | Rel-9 | CP-45 | Frederic | Panasonic | benjamin.limck@sg.panasonic.com |  |
| 690 | 286 | **Multiple PDN Connection to the Same APN for PMIP-based Interfaces** | 267d? | 2009-03-13 A | 2010-03-19 A | 100% |  | 2009-03-13 | 2010-03-19 | 267d? |  |  | S2,C4,C1 | 4120h | 4120h | MUPSAP | PCG-22 | Rel-9 | SP-43 | Maurice | Samsung | erik.guttman@partner.samsung.com |  |
| 691 | 286.1 | Stage 2 for Multiple PDN Connection to the Same APN for PMIP-based Interfaces | 61d? | 2009-03-13 A | 2009-06-04 A | 100% |  | 2009-03-13 | 2009-06-04 | 61d? |  | finish no earlier than 2009-06-04 | S2 | 488h | 488h | MUPSAP | PCG-22 | Rel-9 | SP-43 | Maurice | Samsung | erik.guttman@partner.samsung.com |  |
| 692 | 286.2 | CT4 aspects of Multiple PDN Connection to the Same APN for PMIP-based Interfaces | 56d? | 2009-09-18 A | 2009-12-04 A | 100% |  | 2009-09-18 | 2009-12-04 | 56d? |  | finish no earlier than 2009-12-04 | C4 | 448h | 448h | MUPSAP | PCG-23 | Rel-9 | CP-45 | Kimmo | Samsung | Surjyakanta Mohapatra (surjya.kanta@samsung.com) |  |
| 693 | 286.3 | CT1 aspects of Multiple PDN Connection to the Same APN for PMIP-based Interfaces | 131d? | 2009-09-18 A | 2010-03-19 A | 100% |  | 2009-09-18 | 2010-03-19 | 131d? |  | finish no earlier than 2010-03-19 | C1 | 1048h | 1048h | MUPSAP | PCG-23 | Rel-9 | CP-45 | Frederic | Samsung | Surjyakanta Mohapatra (surjya.kanta@samsung.com) |  |
| 694 | 287 | **System aspects of vocoder rate adaptation for LTE** | 864d? | 2009-05-30 A | 2012-09-14 | 84% | 141.73d? | 2009-05-30 | 2012-09-14 | 864d? | 323d |  | S2,S4,C1,C3,R2,IETF | 19521.6h | 11082.9h | LTEimp-Vocoder | PCG-23 | Rel-9 | SP-45 | Maurice | Qualcomm | AC Mahendran (ac@qualcomm.com) |  |
| 695 | 287.1 | SA2 system aspects of vocoder rate adaptation for LTE | 81d? | 2009-06-04 A | 2009-09-24 A | 100% |  | 2009-06-04 | 2009-09-24 | 81d? |  | start no earlier than 2009-06-04 | S2 | 648h | 648h | LTEimp-Vocoder | PCG-23 | Rel-9 | SP-45 | Maurice | Qualcomm | AC Mahendran (ac@qualcomm.com) |  |
| 696 | 287.2 | SA4 system aspects of vocoder rate adaptation for LTE | 136d? | 2009-06-04 A | 2009-12-10 A | 100% |  | 2009-06-04 | 2009-12-10 | 136d? |  | finish no earlier than 2009-12-07 | S4 | 1088h | 1088h | LTEimp-Vocoder | PCG-23 | Rel-9 | SP-45 | Paolo | Qualcomm | Nikolai Leung |  |
| 697 | 287.3 | Vocoder rate adaptation for LTE | 81d? | 2009-05-30 A | 2009-09-18 A | 100% |  | 2009-05-30 | 2009-09-18 | 81d? |  | finish no earlier than 2009-09-18 | R2 | 648h | 648h | LTEimp-Vocoder | PCG-23 | Rel-9 | RP-44 | Joern | Alcatel-Lucent | Sudeep Palat (spalat@alcatel-lucent.com) | RP-090704 |
| 698 | 287.4 | (IETF) SA4 system aspects of vocoder rate adaptation for LTE | 679.6d? | 2009-06-04 A | 2012-09-14 | 80% | 135.92d? | 2009-06-04 | 2012-09-14 | 679.6d? | 323d | finish no earlier than 2012-09-14 | S4-IETF | 5436.8h | 4349.44h | LTEimp-Vocoder_IETF | PCG-27 | Rel-9 | SP-52 | Paolo | Mark Jones |  |  |
| 699 | 287.5 | (IETF) CT aspects of vocoder rate adaptation for LTE | 679.6d? | 2009-06-04 A | 2012-09-14 | 80% | 135.92d? | 2009-06-04 | 2012-09-14 | 679.6d? | 323d | finish no earlier than 2012-09-14 | C1-IETF, C3-IETF, C4-IETF | 5436.8h | 4349.44h | LTEimp-Vocoder_IETF | PCG-27 | Rel-9 | CP-52 | Frederic | Mark Jones |  |  |
| 700 | 288 | Access Security Enhancements | 505d? | 2007-07-02 A | 2009-06-04 A | 100% |  | 2007-07-02 | 2009-06-04 | 505d? |  | finish no earlier than 2009-06-03 | S3 | 4040h | 4040h | ACCSEC2 |  | Rel-9 | SP-26 | Dionisio | Ericsson | Bengt.Sahlin@ericsson.com |  |

Notes:
- 672: - / Text3: LTE
- 673: Triggered by abandoned Study UID_380068 (FS_LCS_EPS). Linked to Feature UID_380064 Support for IMS Emergency Calls over GPRS and EPS
- 674: SP#44 completed / Text3: 23.891, 23.271, 23.401, 23.402
- 675: CP#47 completed (IANA registrations outstanding). Stage 3 SLs and SLg interfaces & transport of positioning messages between E-SMLC and MME in the scope of UID_420006 (Positioning Support for LTE) / Text3: 24.080, 29.002, 29.272, 29.230, new 24.171, 29.171, 29.172, 29.173
- 676: CP#47 completed / Text3: 24.301
- 677: RP#48 completed. UID_400038 (LCS Control Plane Solution for EPS) depends on this WI / Text3: 34.213, 36.133, 36.211, 36.214, 36.300, 36.305, 36.331, 36.355, 36.410, 36.413, 36.455, new 36.171
- 678: RP#55 completed / Text3: 36.508, 36.509, new (36.571-1, 36.571-2, 36.571-3, 36.571-4, 37.571-1, 37.571-2, 37.571-3, 37.571-4, 37.571-5)
- 679: RP#47 completed. SP#46, CP#46 completed / Text3: LTE
- 680: SP#44 completed / Text3: 23.246
- 681: SP#46 completed / Text3: 33.246
- 682: SP#46 completed / Text3: 32.273, 32.251, 32.298, 32.299
- 683: CP#46 completed / Text3: 29.274, 29.281, 23.007, 23.008
- 684: CP#46 completed / Text3: 29.061
- 685: RP#47 completed / Text3: 25.446, 36.101, 36.104, 36.141, 36.300, 36.304, 36.321, 36.322, 36.323, 36.331, 36.440, 36.441, 36.442, 36.444, 36.445
- 686: RP#54 completed / Text3: 36.508, 36.521-1, 36.521-2, 36.523-1, 36.523-2, 36.523-3
- 687: CP#47 completed. No new Rel-9 use cases defined. Implement service requirements not covered in Rel-8 / Text3: 22.278, SA3 33.402 CR#0055
- 688: SP#44 completed / Text3: 23.402, 23.002
- 689: CP#47 completed / Text3: 24.302, 24.312
- 690: CP#47 completed. Continues Rel-8 SAES Stage 2 UID_320005. Stage 1 in 22.278 (EPS Service requirements)
- 691: SP#44 completed / Text3: 23.060, 23.203, 23.401, 23.402
- 692: CP#46 completed / Text3: 29.275, 23.008, 29.282
- 693: CP#47 completed / Text3: 24.302
- 694: SP#46 completed. Triggered by RAN2 UID_440013 Vocoder rate adaptation for LTE / Text3: LTE
- 695: SP#45 completed (CR adding support for Explicit Congestion Notification) / Text3: 23.401 CR#1103r3
- 696: SP#46 completed / Text3: 26.114
- 697: RP#45 completed / Text3: 36.300 CR#0114
- 698: Not completed internet-draft / Text3: draft-ietf-avtcore-ecn-for-rtp
- 699: Not completed internet-draft / Text3: draft-ietf-avtcore-ecn-for-rtp
- 700: SP#44 completed. Stopped TR 33.801. CRs 33.102,43.020 on A5/2 removal done long time ago. A5/4 introduction CRs will be done under UID_440057 128 bit encryption for GSM and GPRS. SP#26 approved WID (improved GERAN security) / Text3: 33.102, 43.020

| ID | WBS | Task | Duration | Start | Finish | Complete | Remaining | Baseline start | Baseline finish | Baseline duration | Total slack | Constraint | Resources | Work | Actual work | Text1 | Text2 | Text4 | Text5 | Text6 | Text7 | Text8 | Text3 | Text9 | Text12 |
| --- | --- | --- | --- | --- | --- | --- | --- | --- | --- | --- | --- | --- | --- | --- | --- | --- | --- | --- | --- | --- | --- | --- | --- | --- | --- |
| 701 | 289 | **IMS Media Plane Security** | 920d? | 2009-03-13 A | 2012-09-14 | 38% | 569.58d? | 2009-03-13 | 2012-09-14 | 920d? | 323d |  | S3,C1,C4,C3,IETF | 17763.2h | 5179.2h | MEDIASEC | PCG-22 | Vodafone | Peter.Howard@vodafone.com | Rel-9 | SP-43 | Dionisio |  |  |  |
| 702 | 289.1 | SA3 aspects of IMS Media Plane Security | 271d? | 2009-03-13 A | 2010-03-25 A | 100% |  | 2009-03-13 | 2010-03-25 | 271d? |  | finish no earlier than 2010-03-25 | S3 | 2168h | 2168h | MEDIASEC | PCG-22 | Vodafone | Peter.Howard@vodafone.com | Rel-9 | SP-43 | Dionisio | new 33.828, 33.328 |  |  |
| 703 | 289.2 | (IETF) SA3 aspects of IMS Media Plane Security | 920d? | 2009-03-13 | 2012-09-14 |  |  | 2009-03-13 | 2012-09-14 | 920d? | 323d | finish no earlier than 2012-09-14 | S3-IETF,C1-IETF | 7360h |  | MEDIASEC_IETF | PCG-27 | Peter Dawes |  | Rel-9 | SP-52 | Dionisio | draft-dawes-dispatch-mediasec-parameter |  |  |
| 704 | 289.3 | **CN aspects of IMS Media Plane Security** | 186d? | 2009-09-18 A | 2010-06-04 A | 100% |  | 2009-09-18 | 2010-06-04 | 186d? |  |  | C1,C4,C3 | 3011.2h | 3011.2h | MEDIASEC_CORE | PCG-23 | Vodafone | peter.dawes@vodafone.com | Rel-9 | CP-45 | Frederic |  |  |  |
| 705 | 289.3.1 | CT1 aspects of IMS Media Plane Security | 33d? | 2009-09-18 A | 2010-03-19 A | 100% |  | 2009-09-18 | 2010-03-19 | 33d? |  | finish no earlier than 2010-03-19 | C1 | 264h | 264h | MEDIASEC_CORE | PCG-23 | Vodafone | peter.dawes@vodafone.com | Rel-9 | CP-45 | Frederic | 23.218, 24.229 |  |  |
| 706 | 289.3.2 | CT4 aspects of IMS Media Plane Security | 131d? | 2009-09-18 A | 2010-03-19 A | 100% |  | 2009-09-18 | 2010-03-19 | 131d? |  | finish no earlier than 2010-03-19 | C4 | 1048h | 1048h | MEDIASEC_CORE | PCG-23 | Vodafone | peter.dawes@vodafone.com | Rel-9 | CP-45 | Kimmo | 29.238, 23.334, 29.334 |  |  |
| 707 | 289.3.3 | CT3 aspects of IMS Media Plane Security | 131d? | 2009-12-04 A | 2010-06-04 A | 100% |  | 2009-12-04 | 2010-06-04 | 131d? |  | finish no earlier than 2010-06-04 | C3 | 1048h | 1048h | MEDIASEC_CORE | PCG-24 | Vodafone | peter.dawes@vodafone.com | Rel-9 | CP-46 | Jiwan | 29.162 |  |  |
| 708 | 290 | **GBAPush enhancements (Generic push layer)** | 533d? | 2008-03-12 A | 2010-03-25 A | 100% |  | 2008-03-12 | 2010-03-25 | 533d? |  |  | S3 | 8528h | 8528h | eGBAPush | PCG-23 | Ericsson | Rolf Blom | Rel-9 | SP-44 | Dionisio | new 33.224 |  |  |
| 709 | 290.1 | SA3 part of eGBAPush (Generic push layer) | 533d? | 2008-03-12 A | 2010-03-25 A | 100% |  | 2008-03-12 | 2010-03-25 | 533d? |  | finish no earlier than 2010-03-25 | S3 | 4264h | 4264h | eGBAPush | PCG-21 | Ericsson | Rolf Blom | Rel-9 | SP-39 | Dionisio | new 33.224 |  |  |
| 710 | 291 | Extended Identity Management | 136d? | 2009-06-04 A | 2009-12-10 A | 100% |  | 2009-06-04 | 2009-12-10 | 136d? |  | finish no earlier than 2009-12-10 | S3 | 1088h | 1088h | GBA-IdM | PCG-23 | Nokia | Silke.Holtmanns@nokia.com | Rel-9 | SP-44 | Dionisio | new 33.924, CT4 29.109 (added service code) |  |  |
| 711 | 292 | **Network Domain Security (NDS) enhancements to support backhaul security** | 860d? | 2009-06-04 A | 2012-09-14 | 50% | 428.65d? | 2009-06-04 | 2012-09-14 | 860d? | 323d |  | S3,C4,IETF | 14004.8h | 4103.2h | NDS_Backhaul | PCG-23 | Vodafone | Peter.Howard@vodafone.com | Rel-9 | SP-44 | Dionisio |  |  |  |
| 712 | 292.1 | SA3 part of Network Domain Security (NDS) enhancements to support backhaul security | 211d? | 2009-06-04 A | 2010-03-25 A | 100% |  | 2009-06-04 | 2010-03-25 | 211d? |  | finish no earlier than 2010-03-25 | S3 | 1688h | 1688h | NDS_Backhaul | PCG-23 | Vodafone | Peter.Howard@vodafone.com | Rel-9 | SP-44 | Dionisio | 33.102, 33.210, 33.310, 33.401, 33.402 |  |  |
| 713 | 292.2 | (IETF) SA3 part of Network Domain Security (NDS) enhancements to support backhaul security | 679.6d? | 2009-06-04 A | 2012-09-14 | 25% | 509.7d? | 2009-06-04 | 2012-09-14 | 679.6d? | 323d | finish no earlier than 2012-09-14 | S3-IETF | 5436.8h | 1359.2h | NDS_Backhaul_IETF | PCG-27 | Bengt Sahlin |  | Rel-9 | SP-52 | Dionisio | draft-ietf-pkix-cmp-transport-protocols |  |  |
| 714 | 292.3 | CT4 part of Network Domain Security (NDS) enhancements to support backhaul security | 132d? | 2009-06-04 A | 2009-12-04 A | 100% |  | 2009-06-04 | 2009-12-04 | 132d? |  | finish no earlier than 2009-12-04 | C4 | 1056h | 1056h | NDS_Backhaul | PCG-23 | Vodafone | Peter.Howard@vodafone.com | Rel-9 | SP-44 | Kimmo |  |  |  |
| 715 | 293 | **128 bit encryption for GSM and GPRS** | 136d? | 2009-06-04 A | 2009-12-10 A | 100% |  | 2009-06-04 | 2009-12-10 | 136d? |  |  | S3,C1,C4,G2,G3new | 6040h | 6040h | A5/4-GEA4 | PCG-23 | Ericsson | Karl Norrman | Rel-9 | SP-44 | Dionisio |  |  |  |
| 716 | 293.1 | SA3 part of 128 bit encryption for GSM and GPRS | 136d? | 2009-06-04 A | 2009-12-10 A | 100% |  | 2009-06-04 | 2009-12-10 | 136d? |  | finish no earlier than 2010-01-06 | S3 | 1088h | 1088h | A5/4-GEA4 | PCG-23 | Ericsson | Karl Norrman | Rel-9 | SP-44 | Dionisio | 33.102,43.020, new 55.226 |  |  |
| 717 | 293.2 | CT1 part of 128 bit encryption for GSM and GPRS | 77d? | 2009-06-04 A | 2009-09-18 A | 100% |  | 2009-06-04 | 2009-09-18 | 77d? |  | start no earlier than 2009-06-04 | C1 | 616h | 616h | A5/4-GEA4 | PCG-23 | Ericsson | Karl Norrman | Rel-9 | SP-44 | Frederic | 24.008,44.064 |  |  |
| 718 | 293.3 | CT4 part of 128 bit encryption for GSM and GPRS | 136d? | 2009-06-04 A | 2009-12-10 A | 100% |  | 2009-06-04 | 2009-12-10 | 136d? |  | start no earlier than 2009-06-04 | C4 | 1088h | 1088h | A5/4-GEA4 | PCG-23 | Ericsson | Karl Norrman | Rel-9 | SP-44 | Kimmo |  |  |  |
| 719 | 293.4 | GERAN2 part of 128 bit encryption for GSM and GPRS | 67d? | 2009-06-04 A | 2009-09-04 A | 100% |  | 2009-06-04 | 2009-09-04 | 67d? |  | finish no earlier than 2009-09-04 | G2 | 536h | 536h | A5/4-GEA4 | PCG-23 | Ericsson | Karl Norrman | Rel-9 | SP-44 | Gert | 44.018,48.008,48.018,48.058 |  |  |
| 720 | 293.5 | GERAN3new (testing) part of 128 bit encryption for GSM and GPRS | 122d? | 2009-06-04 A | 2009-11-20 A | 100% |  | 2009-06-04 | 2009-11-20 | 122d? |  | finish no earlier than 2009-11-20 | G3new | 976h | 976h | A5/4-GEA4 | PCG-23 | Ericsson | Karl Norrman | Rel-9 | SP-44 | Ingbert | 51.010 |  |  |
| 721 | 293.6 | Deleted - SA2 part of 128 bit encryption for GSM and GPRS | 81d? | 2009-06-04 A | 2009-09-24 A | 100% |  | 2009-06-04 | 2009-09-24 | 81d? |  | finish no earlier than 2009-09-24 | S2 | 648h | 648h | A5/4-GEA4 | PCG-23 | Ericsson | Karl Norrman | Rel-9 | SP-44 | Maurice | 23.060 | PCG-23 | SP-45 |
| 722 | 294 | Timed Graphics | 337d? | 2008-12-11 A | 2010-03-25 A | 100% |  | 2008-12-11 | 2010-03-25 | 337d? |  | finish no earlier than 2010-03-25 | S4 | 2696h | 2696h | TG | PCG-22 | Ericsson | clinton.priddle@ericsson.com | Rel-9 | SP-42 | Paolo | 26.114, 26.140, 26.234, 26.244, 26.245, 26.346, new 26.430 |  |  |
| 723 | 295 | Managing MTSI Media Adaptation | 197d? | 2009-03-12 A | 2009-12-10 A | 100% |  | 2009-03-12 | 2009-12-10 | 197d? |  | finish no earlier than 2009-12-10 | S4 | 1568h | 1568h | M3A | PCG-22 | Samsung | kyunghun.jung@samsung.com | Rel-9 | SP-43 | Paolo | 26.114 |  |  |
| 724 | 296 | **PSS and MBMS Aspects** | 272d? | 2009-03-12 A | 2010-03-25 A | 100% |  | 2009-03-12 | 2010-03-25 | 272d? |  |  | S4 | 6512h | 6512h | PMA | PCG-23 | Ericsson, Nokia | Clinton.Priddle@ericsson.com, imed.bouazizi@nokia.com | Rel-9 | SP-44 | Paolo |  |  |  |
| 725 | 296.1 | PSS and MBMS extensions | 271d? | 2009-03-12 A | 2010-03-25 A | 100% |  | 2009-03-12 | 2010-03-25 | 271d? |  | finish no earlier than 2010-03-25 | S4 | 2168h | 2168h | PMA-MBS_Ext | PCG-22 | Ericsson | Clinton.Priddle@ericsson.com | Rel-9 | SP-43 | Paolo | 26.234, 26.346 |  |  |
| 726 | 296.2 | Improved Video Support for PSS and MBMS | 271d? | 2009-03-12 A | 2010-03-25 A | 100% |  | 2009-03-12 | 2010-03-25 | 271d? |  | finish no earlier than 2010-03-25 | S4 | 2168h | 2168h | PMA-IVS | PCG-22 | Nokia | imed.bouazizi@nokia.com | Rel-9 | SP-43 | Paolo | 26.234, 26.244, 26.346, new 26.903 |  |  |
| 727 | 297 | IMS based PSS and MBMS User Service extensions | 197d? | 2009-03-12 A | 2009-12-10 A | 100% |  | 2009-03-12 | 2009-12-10 | 197d? |  | finish no earlier than 2009-12-10 | S4 | 1576h | 1576h | IMS_PSS_MBMS_US_EXT | PCG-22 | Ericsson | Markus Kampmann | Rel-9 | SP-43 | Paolo | 26.237 |  |  |
| 728 | 298 | Syndicated Feed Reception within 3GPP environments | 136d? | 2009-06-04 A | 2009-12-10 A | 100% |  | 2009-06-04 | 2009-12-10 | 136d? |  | start no earlier than 2009-06-04 | S4 | 1088h | 1088h | SFR | PCG-23 | Ericsson | Thorsten.Lohmar@ericsson.com | Rel-9 | SP-44 | Paolo | new 26.150 |  |  |
| 729 | 299 | Distortion Measurement Test Methods and Requirements | 131d? | 2009-09-24 A | 2010-03-25 A | 100% |  | 2009-09-24 | 2010-03-25 | 131d? |  | finish no earlier than 2010-03-25 | S4 | 1048h | 1048h | DTMR | PCG-23 | Motorola | Stephen Kendall (wcsk01@motorola.com) | Rel-9 | SP-45 | Paolo | 26.131, 26.132 |  |  |

Notes:
- 701: CP#48 completed
- 702: SP#47 completed
- 703: Not completed internet-draft
- 704: CP#48 completed
- 705: CP#47 completed
- 706: CP#47 completed
- 707: CP#48 completed
- 708: SP#43 umbrella to host 33.224, moved from Rel-8 to Rel-9. SP#47 completed
- 709: SP#47 completed
- 710: SP#46 completed. Stage 1 not identified (GBA Liberty Interworking has been outlined and GBAOpenID interworking is analogous)
- 711: SP#47 completed. Continuation of Rel-8 UID_390044 SAE security architecture. Covers gaps in backhaul security in SAE (also applicable to UTRAN and GERAN backhaul)
- 712: SP#47 completed
- 713: AD evaluation
- 714: CP#46 completed. No impact on CT4 specs
- 715: Allow 128 as an alternative to 64 bit keys (Stage 2/3 + Test spec)
- 716: SP#46 completed
- 717: CP#45 completed
- 718: CP#46 completed. Kc128 enhancements are carried as UMTS keys => no impact on CT4 29.002, 29.060
- 719: GP#43 WID approved + completed
- 720: GP#44 completed. GP#43 WID approved
- 721: SP#45 work stopped/abandoned
- 722: SP#47 completed. Provide graphics in parallel to a video stream (without requiring an umbrella scene descriptor such as 3GPP DIMS in TS 26.142)
- 723: SP#46 completed. Work extending Rel-8 UID_34041 MTSI Video - Dynamic Rate Adaptation/Signalling of Image Size. Update speech/video adaptation algorithms used by network to control MTSI client terminal in congestion or poor transmission conditions.
- 724: Umbrella WI
- 725: SP#47 completed. Extends Rel-8 UID_34043 (PSS_MBMS_OMTV) & ensures compatibility with UID_34046 (IMS_PSS_MBMS_US)
- 726: SP#47 completed
- 727: SP#46 completed. Work extending Rel-8 UID_34046 (IMS_PSS_MBMS_US), SA2 UID_410034 IMSSCC-SPI (IMS Service Continuity Enhancements: Service, Policy and Interactions)
- 728: SP#46 completed. TS 26.150v100 for Approval. RSS optimized for mobile use. Reuse/reference OMA's enabler DCD.
- 729: SP#47 completed

| ID | WBS | Task | Duration | Start | Finish | Complete | Baseline start | Baseline finish | Baseline duration | Constraint | Resources | Work | Actual work | Text1 | Text2 | Text6 | Text7 | Text8 | Text4 | Text9 | Text12 |
| --- | --- | --- | --- | --- | --- | --- | --- | --- | --- | --- | --- | --- | --- | --- | --- | --- | --- | --- | --- | --- | --- |
| 730 | 300 | **Rel-9 Operations, Administration, Maintenance and Provisioning (OAM&P)** | 601d? | 2008-02-22 A | 2010-06-10 A | 100% | 2008-02-22 | 2010-06-10 | 601d? |  | S5 | 36890.4h | 36890.4h | OAM9 | PCG-22 | Rel-9 | SP-42 | Dionisio |  |  |  |
| 731 | 300.1 | **Rel-9 Network Infrastructure Management** | 337d? | 2008-12-11 A | 2010-03-25 A | 100% | 2008-12-11 | 2010-03-25 | 337d? |  | S5 | 8760h | 8760h | OAM9-NIM | PCG-22 | Rel-9 | SP-42 | Dionisio |  |  |  |
| 732 | 300.1.1 | Software Management for Network Elements | 336d? | 2008-12-11 A | 2010-03-25 A | 100% | 2008-12-11 | 2010-03-25 | 336d? | finish no earlier than 2010-03-25 | S5 | 2688h | 2688h | OAM9-NE_SWM | PCG-22 | Rel-9 | SP-42 | Dionisio | Huawei, Nokia Siemens Networks |  |  |
| 733 | 300.1.2 | Service Oriented Architecture (SOA) for IRP | 211d? | 2009-06-04 A | 2010-03-25 A | 100% | 2009-06-04 | 2010-03-25 | 211d? | finish no earlier than 2010-03-25 | S5 | 1688h | 1688h | OAM9 | PCG-23 | Rel-9 | SP-44 | Dionisio | Ericsson, Nokia Siemens Networks |  |  |
| 734 | 300.1.3 | IRP SOAP Solution Sets continuation from Rel-8 | 211d? | 2009-06-04 A | 2010-03-25 A | 100% | 2009-06-04 | 2010-03-25 | 211d? | finish no earlier than 2010-03-25 | S5 | 1688h | 1688h | OAM9 | PCG-23 | Rel-9 | SP-44 | Dionisio | Ericsson |  |  |
| 735 | 300.2 | **Rel-9 Performance Management** | 327d? | 2009-03-12 A | 2010-06-10 A | 100% | 2009-03-12 | 2010-06-10 | 327d? |  | S5 | 7890.41h | 7890.41h | OAM9-PM | PCG-22 | Rel-9 | SP-42 | Dionisio |  |  |  |
| 736 | 300.2.1 | Enhancement of UTRAN Performance Measurements | 136d? | 2009-06-04 A | 2009-12-10 A | 100% | 2009-06-04 | 2009-12-10 | 136d? | start no earlier than 2009-06-04 | S5 | 1088h | 1088h | OAM9 | PCG-23 | Rel-9 | SP-44 | Dionisio | China Mobile |  |  |
| 737 | 300.2.2 | Enhancement of E-UTRAN Performance Measurements | 327d? | 2009-03-12 A | 2010-06-10 A | 100% | 2009-03-12 | 2010-06-10 | 327d? | finish no earlier than 2010-06-10 | S5 | 2616h | 2616h | OAM9 | PCG-22 | Rel-9 | SP-43 | Dionisio | Motorola, Huawei |  |  |
| 738 | 300.2.3 | Enhancement of EPC Performance Measurements | 197d? | 2009-03-12 A | 2009-12-10 A | 100% | 2009-03-12 | 2009-12-10 | 197d? | finish no earlier than 2010-03-25 | S5 | 1570.41h | 1570.41h | OAM9 | PCG-22 | Rel-9 | SP-43 | Dionisio | China Mobile |  |  |
| 739 | 300.3 | **Rel-9 Self-Organizing Networks (SON) - OAM aspects** | 601d? | 2008-02-22 A | 2010-06-10 A | 100% | 2008-02-22 | 2010-06-10 | 601d? |  | S5 | 11736h | 11736h | OAM9-SON | PCG-22 | Rel-9 | SP-43 | Dionisio |  |  |  |
| 740 | 300.3.1 | SON self-optimization management | 600d? | 2008-02-22 A | 2010-06-10 A | 100% | 2008-02-22 | 2010-06-10 | 600d? | finish no earlier than 2010-06-10 | S5 | 4800h | 4800h | LTE_SON-OAM | PCG-21 | Rel-9 | SP-39 | Dionisio | Huawei |  |  |
| 741 | 300.3.2 | Automatic Radio Network Configuration Data Preparation | 266d? | 2009-06-04 A | 2010-06-10 A | 100% | 2009-06-04 | 2010-06-10 | 266d? | finish no earlier than 2010-06-10 | S5 | 2128h | 2128h | OAM9 | PCG-23 | Rel-9 | SP-44 | Dionisio | Nokia Siemens Networks |  |  |
| 742 | 300.4 | Rel-9 Subscription Management (SuM) evolution | 266d? | 2009-06-04 A | 2010-06-10 A | 100% | 2009-06-04 | 2010-06-10 | 266d? | finish no earlier than 2010-06-10 | S5 | 2128h | 2128h | OAM9-SuM | PCG-23 | Rel-9 | SP-44 | Dionisio | Ericsson |  |  |
| 743 | 300.5 | Deleted - Rel-9 Trace | 196d? | 2009-03-13 A | 2009-12-10 A | 100% | 2009-03-13 | 2009-12-10 | 196d? | finish no earlier than 2009-12-10 | S5 | 1568h | 1568h | OAM9-Trace | PCG-22 | Rel-9 | SP-42 | Dionisio |  | PCG-24 | SP-46 |
| 744 | 301 | Rel-9 Charging Management small Enhancements | 211d? | 2009-06-04 A | 2010-03-25 A | 100% | 2009-06-04 | 2010-03-25 | 211d? |  | S5 | 1688h | 1688h | CH9 | PCG-23 | Rel-9 | SP-44 | Dionisio |  |  |  |
| 745 | 302 | **CS-IBCF and CS-TrGW definition in 3GPP specifications** | 472d? | 2008-05-30 A | 2010-03-19 A | 100% | 2008-05-30 | 2010-03-19 | 472d? |  | C3,C4 | 10714.3h | 10714.3h | CS-IBCF | PCG-21 | Rel-9 | CP-40 | Jiwan | Telecom Italia |  |  |
| 746 | 302.1 | CT3 aspects of CS-IBCF and CS-TrGW definition in 3GPP specifications | 472d? | 2008-05-30 A | 2010-03-19 A | 100% | 2008-05-30 | 2010-03-19 | 472d? | finish no earlier than 2009-12-04 | C3 | 3770.34h | 3770.34h | CS-IBCF | PCG-21 | Rel-9 | CP-40 | Jiwan | Telecom Italia |  |  |
| 747 | 302.2 | CT4 aspects of CS-IBCF and CS-TrGW definition in 3GPP specifications | 396d? | 2008-05-30 A | 2009-12-04 A | 100% | 2008-05-30 | 2009-12-04 | 396d? | finish no earlier than 2009-12-04 | C4 | 3168h | 3168h | CS-IBCF | PCG-21 | Rel-9 | CP-40 | Kimmo | Telecom Italia |  |  |
| 748 | 303 | **IMS – Interconnection Border Control Function (IBCF) – Transition Gateway (TrGW); Ix Interface; Stage 3** | 322d? | 2008-09-12 A | 2009-12-04 A | 100% | 2008-09-12 | 2009-12-04 | 322d? |  | C4,C3 | 6858.4h | 6858.4h | IMS_IBCF | PCG-21 | Rel-9 | CP-41 | Kimmo | Alcatel-Lucent |  |  |
| 749 | 303.1 | CT4 part of IMS – Interconnection Border Control Function (IBCF) – Transition Gateway (TrGW); Ix Interface; Stage 3 | 321d? | 2008-09-12 A | 2009-12-04 A | 100% | 2008-09-12 | 2009-12-04 | 321d? | finish no earlier than 2009-12-04 | C4 | 2568h | 2568h | IMS_IBCF | PCG-21 | Rel-9 | CP-41 | Kimmo | Alcatel-Lucent |  |  |
| 750 | 303.2 | CT3 part of IMS – Interconnection Border Control Function (IBCF) – Transition Gateway (TrGW); Ix Interface; Stage 3 | 295.8d? | 2008-09-12 A | 2009-12-04 A | 100% | 2008-09-12 | 2009-12-04 | 295.8d? | finish no earlier than 2010-03-19 | C3 | 2366.4h | 2366.4h | IMS_IBCF | PCG-21 | Rel-9 | CP-41 | Jiwan | Alcatel-Lucent |  |  |
| 751 | 304 | IMS Application Level Gateway Control Function (ALGCF) – IMS Access Media Gateway (IMA-MGW); Iq Interface; Stage 2 and Stage 3 | 321d? | 2008-09-12 A | 2009-12-04 A | 100% | 2008-09-12 | 2009-12-04 | 321d? | finish no earlier than 2009-12-04 | C4 | 2568h | 2568h | IMS_AGCF | PCG-21 | Rel-9 | CP-41 | Kimmo | Alcatel-Lucent |  |  |
| 752 | 305 | **Enhancements of IMS Customized Alerting Tone (CAT) Service** | 392d? | 2008-12-05 A | 2010-06-04 A | 100% | 2008-12-05 | 2010-06-04 | 392d? |  | C1 | 5846.4h | 5846.4h | eCAT | PCG-22 | Rel-9 | CP-42 | Frederic | China Mobile |  |  |
| 753 | 305.1 | Stage 3 for Enhancements of IMS Customized Alerting Tone (CAT) Service | 391d? | 2008-12-05 A | 2010-06-04 A | 100% | 2008-12-05 | 2010-06-04 | 391d? | finish no earlier than 2010-06-04 | C1 | 3128h | 3128h | eCAT-SS | PCG-22 | Rel-9 | CP-42 | Frederic | China Mobile |  |  |

Notes:
- 730: SP#42 umbrella Feature created to host OAM WIs / Text3: TR 30.819
- 731: SP#42 umbrella BB created to host OAM WIs
- 732: SP#47 completed / Text3: 32.531, 32.532, 32.533, new 32.537 / Text5: Bidipta Das (bidipta@huawei.com), Clemens Suerbaum (clemens.suerbaum@nsn.com)
- 733: SP#47 completed (covering SOA Architecture & SOA-supporting Solution Set). Triggered by UID_400029 Study on Service Oriented Architecture (SOA) for IRP (TR 32.824) / Text3: 32.101, 32.102, 32.150 / Text5: edwin.tse@ericsson.com, Jörg Schmidt (joerg@cox.net)
- 734: SP#47 completed. Continuation of Rel-8 UID_400030 IRP SOAP Solution Sets / Text3: New (32.127/ 327/ 337/ 357/ 387/ 397/ 447/ 397/ 447/ 507/ 537), 32.121,32.122,32.123,32,32.321,32.322,32.323,32.325,32.331,32.332,32.333,32.335,32.351,32.352,32.353,32.381,32.382,32.383,32.385,32.391,32.392,32.393,32.395,32.441,32.442,32.443 / Text5: John Power
- 735: SP#42 umbrella BB created to host OAM WIs
- 736: SP#46 completed / Text3: 32.405 / Text5: Liang Shuangchun (liangshuangchun@cmdi.chinamobile.com), Li Jian (lijian@chinamobile.com), Bao Haitao
- 737: SP#48 completed / Text3: 32.425 / Text5: Yizhi Yao (yzyao@motorola.com),Lan Zou (zlan@huawei.com)
- 738: SP#46 completed / Text3: 32.426 / Text5: Li Jian (lijian@chinamobile.com), Liang Shuangchun (liangshuangchun@cmdi.chinamobile.com)
- 739: SP#43 umbrella BB created to host OAM WIs
- 740: SP#48 completed / Text3: 32.425, new (32.521, 32.522, 32.523, 32.525) / Text5: Lan Zou (zlan@huawei.com)
- 741: SP#48 completed / Text3: 32.501, 32.502, 32.503, 32.505, new 32.507 / Text5: clemens.suerbaum@nsn.com
- 742: SP#48 completed / Text3: 32.140, 32.141, 32.152, 32.172, 32.175 / Text5: frode.nergard@ericsson.com
- 743: SP#46 stopped (no work in Rel-9)
- 744: SP#47 completed / Text3: TR 30.819
- 745: CP#47 completed. Rel-8 UID_380061 (Ipinterc) covers Stage 1 in SA1 22.101, 22.228 / Text5: mauro.ficaccio@telecomitalia.it
- 746: CP#47 completed / Text3: 29.235 / Text5: mauro.ficaccio@telecomitalia.it
- 747: CP#46 completed / Text3: 23.231, 29.232, new 29.238 / Text5: mauro.ficaccio@telecomitalia.it
- 748: CP#46 completed / Text5: bruno.landais@alcatel-lucent.fr
- 749: CP#46 completed / Text3: new 29.238 / Text5: bruno.landais@alcatel-lucent.fr
- 750: CP#46 completed / Text3: 29.162, 29.235 / Text5: bruno.landais@alcatel-lucent.fr
- 751: CP#46 completed / Text3: new 23.334, 29.334 / Text5: bruno.landais@alcatel-lucent.fr
- 752: CP#48 completed. Stage 1 in 22.182 / Text5: Jiang Yi
- 753: CP#48 completed / Text3: 24.182 / Text5: Jiang Yi

| ID | WBS | Task | Duration | Start | Finish | Complete | Remaining | Baseline start | Baseline finish | Baseline duration | Total slack | Constraint | Resources | Work | Actual work | Text1 | Text2 | Text4 | Text5 | Text6 | Text7 | Text8 | Text11 |
| --- | --- | --- | --- | --- | --- | --- | --- | --- | --- | --- | --- | --- | --- | --- | --- | --- | --- | --- | --- | --- | --- | --- | --- |
| 754 | 306 | **Completion of IMS Restoration Procedures** | 212d? | 2009-05-29 A | 2010-03-19 A | 100% |  | 2009-05-29 | 2010-03-19 | 212d? |  |  | C3, C4,C1 | 6784h | 6784h | eIMS_RP | PCG-23 | Ericsson | Emiliano Merino (emiliano.merino@ericsson.com) | Rel-9 | CP-44 | Kimmo |  |
| 755 | 306.1 | CT4 aspects of Completion of IMS Restoration Procedures | 212d? | 2009-05-29 A | 2010-03-19 A | 100% |  | 2009-05-29 | 2010-03-19 | 212d? |  | finish no earlier than 2010-03-19 | C4 | 1696h | 1696h | eIMS_RP | PCG-23 | Ericsson | Emiliano Merino (emiliano.merino@ericsson.com) | Rel-9 | CP-44 | Kimmo |  |
| 756 | 306.2 | CT1 aspects of Completion of IMS Restoration Procedures | 212d? | 2009-05-29 A | 2010-03-19 A | 100% |  | 2009-05-29 | 2010-03-19 | 212d? |  | finish no earlier than 2010-03-19 | C1 | 1696h | 1696h | eIMS_RP | PCG-23 | Ericsson | Emiliano Merino (emiliano.merino@ericsson.com) | Rel-9 | CP-44 | Kimmo |  |
| 757 | 306.3 | CT3 aspects of Completion of IMS Restoration Procedures | 212d? | 2009-05-29 A | 2010-03-19 A | 100% |  | 2009-05-29 | 2010-03-19 | 212d? |  | finish no earlier than 2010-03-19 | C3 | 1696h | 1696h | eIMS_RP | PCG-24 | Ericsson | Emiliano Merino (emiliano.merino@ericsson.com) | Rel-9 | CP-46 | Kimmo |  |
| 758 | 307 | **IMS Stage 3 - IETF Protocol Alignment - phase 3** | 865d? | 2009-05-29 A | 2012-09-14 | 39% | 524.47d? | 2009-05-29 | 2012-09-14 | 865d? | 323d |  | C1,IETF | 14264h | 3554h | IMSProtoc3 | PCG-23 | Alcatel-Lucent | Keith Drage (drage@alcatel-lucent.com) | Rel-9 | CP-44 | Frederic |  |
| 759 | 307.1 | CT1 aspects of IMS Stage 3 - IETF Protocol Alignment - phase 3 | 212d? | 2009-05-29 A | 2010-03-19 A | 100% |  | 2009-05-29 | 2010-03-19 | 212d? |  | finish no earlier than 2010-03-19 | C1 | 1696h | 1696h | IMSProtoc3 | PCG-23 | Alcatel-Lucent | Keith Drage (drage@alcatel-lucent.com) | Rel-9 | CP-44 | Frederic |  |
| 760 | 307.2 | (IETF) CT1 IMS Stage 3 - IETF Protocol Alignment (draft-kaplan) | 654d? | 2009-05-29 A | 2012-09-14 | 15% | 555.9d? | 2009-05-29 | 2012-09-14 | 654d? | 323d | finish no earlier than 2012-09-14 | C1-IETF | 5232h | 784.8h | IMSProtoc3_IETF | PCG-27 | Christer Holmberg | christer.holmberg@ericsson.com | Rel-9 | CP-52 | Frederic |  |
| 761 | 307.3 | (IETF) CT1 IMS Stage 3 - IETF Protocol Alignment (rfc4244bis) | 265d? | 2011-09-13 A | 2012-09-14 | 51% | 129.85d? | 2011-09-13 | 2012-09-14 | 265d? | 323d | finish no earlier than 2012-09-14 | C1-IETF | 2112h | 1073.2h | IMSProtoc3_IETF | PCG-27 | Christer Holmberg | christer.holmberg@ericsson.com | Rel-9 | CP-53 |  |  |
| 762 | 308 | Operational description of the Inter-IMS Network to Network Interface (II-NNI) | 267d? | 2009-05-29 A | 2010-06-04 A | 100% |  | 2009-05-29 | 2010-06-04 | 267d? |  | finish no earlier than 2010-06-04 | C3 | 2136h | 2136h | II-NNI | PCG-23 | Orange | sebastien.daudet@orange-ftgroup.com | Rel-9 | CP-44 | Jiwan |  |
| 763 | 309 | Definition of Ml interface for Control Plane LCS (Stage 3) | 131d? | 2009-09-18 A | 2010-03-19 A | 100% |  | 2009-09-18 | 2010-03-19 | 131d? |  | finish no earlier than 2010-03-19 | C1 | 1048h | 1048h | EMC2 | PCG-23 | Alcatel-Lucent | Keith Drage (drage@alcatel-lucent.com) | Rel-9 | CP-45 | Frederic |  |
| 764 | 310 | PCC enhancements | 56d? | 2009-09-18 A | 2009-12-04 A | 100% |  | 2009-09-18 | 2009-12-04 | 56d? |  | finish no earlier than 2009-12-04 | C3 | 448h | 448h | PCC-Enh | PCG-23 | Huawei | Wei Weihua (weiwh@huawei.com) | Rel-9 | CP-45 | Jiwan |  |
| 765 | 311 | 3GPP IMS Conferencing Management Object (MO) | 2d? | 2009-12-03 A | 2009-12-04 A | 100% |  | 2009-12-03 | 2009-12-04 | 2d? |  | start no earlier than 2009-12-03 | C1 | 16h | 16h | IMS_ConfMO | PCG-24 |  |  | Rel-9 | CP-46 | Frederic |  |
| 766 | 312 | In Case of Emergency (ICE) Graphics | 3d? | 2010-03-17 A | 2010-03-19 A | 100% |  | 2010-03-17 | 2010-03-19 | 3d? |  | finish no earlier than 2010-03-19 | C6 | 24h | 24h | ICE_Graphics | PCG-24 | Sagem-Orga | heiko.kruse@sagem-orga.com | Rel-9 | CP-47 | Xavier |  |
| 767 | 313 | **Rel-9 Improvements of the Radio Interface** | 397d? | 2008-09-12 A | 2010-03-19 A | 100% |  | 2008-09-12 | 2010-03-19 | 397d? |  |  | RP,GP | 19147.6h | 19147.6h | RInImp9 | PCG-21 |  |  | Rel-9 | RP-41 | Issam |  |
| 768 | 313.1 | LCR TDD UE OTA Performance Requirements | 186d? | 2008-09-12 A | 2009-05-29 A | 100% |  | 2008-09-12 | 2009-05-29 | 186d? |  | finish no earlier than 2009-05-29 | R4 | 1488h | 1488h | RInImp9-RFLCROTA | PCG-21 | RITT | Wu Xiang (wuxiang@chinattl.com) | Rel-9 | RP-41 | Issam | RP-090389 |
| 769 | 313.2 | **RF requirements for Multicarrier and Multi-RAT BS** | 347d? | 2008-11-21 A | 2010-03-19 A | 100% |  | 2008-11-21 | 2010-03-19 | 347d? |  |  | R4,G1 | 7403.6h | 7403.6h | RInImp9-RFmulti | PCG-21 | Ericsson | Johan.skold@ericsson.com | Rel-9 | RP-41 | Issam |  |
| 770 | 313.2.1 | RAN4 part of RF requirements for Multicarrier and Multi RAT BS | 337d? | 2008-12-05 A | 2010-03-19 A | 100% |  | 2008-12-05 | 2010-03-19 | 337d? |  | finish no earlier than 2010-03-19 | R4 | 2696h | 2696h | RInImp9-Rfmulti | PCG-22 | Ericsson | johan.skold@ericsson.com | Rel-9 | RP-42 | Issam | RP-100027 |
| 771 | 313.2.2 | GERAN part of RF requirements for Multicarrier and Multi RAT BS | 261d? | 2008-11-21 A | 2009-11-20 A | 100% |  | 2008-11-21 | 2009-11-20 | 261d? |  | finish no earlier than 2009-11-20 | G1 | 2088h | 2088h | RInImp9-RFmulti-GERAN | PCG-22 | Ericsson | mats.y.samuelsson@ericsson.com | Rel-9 | GP-40 | Paolo |  |
| 772 | 313.3 | Extended UMTS/LTE 800 MHz | 207d? | 2008-12-05 A | 2009-09-18 A | 100% |  | 2008-12-05 | 2009-09-18 | 207d? |  |  | R4,R2,R3 | 1648h | 1648h | RInImp9-UMTSLTE800 | PCG-22 | NTT DoCoMo | Shingo Suwa (suwas@nttdocomo.co.jp) | Rel-9 | RP-42 | Issam | RP-090687 |
| 773 | 313.4 | UMTS/LTE 800 MHz for Europe | 272d? | 2009-03-06 A | 2010-03-19 A | 100% |  | 2009-03-06 | 2010-03-19 | 272d? |  | finish no earlier than 2010-03-19 | R4,R2,R3 | 2176h | 2176h | RInImp9-UMTSLTE800EU | PCG-22 | Ericsson | olav.queseth@ericsson.com | Rel-9 | RP-43 | Issam | RP-100028 |
| 774 | 313.5 | Performance requirement for LCR TDD with UE speeds up to 350 km/h | 196d? | 2009-03-06 A | 2009-12-04 A | 100% |  | 2009-03-06 | 2009-12-04 | 196d? |  | finish no earlier than 2009-12-04 | R4 | 1568h | 1568h | RInImp9-LCRTDD350 | PCG-22 | CATT | Yuexia Song (songyuexia@datangmobile.cn) | Rel-9 | RP-43 | Issam | RP-091035 |
| 775 | 313.6 | Extended UMTS/LTE 1500 MHz | 211d? | 2009-05-30 A | 2010-03-19 A | 100% |  | 2009-05-30 | 2010-03-19 | 211d? |  | finish no earlier than 2010-03-19 | R4,R2,R3 | 1688h | 1688h | UMTSLTE1500 | PCG-23 | NTT DoCoMo | Shingo Suwa (suwas@nttdocomo.co.jp) | Rel-9 | RP-44 | Issam | RP-100029 |
| 776 | 314 | **Rel-9 Improvements of the Radio Interface - UE Conformance Testing** | 350d? | 2009-05-19 A | 2010-09-17 A | 100% |  | 2009-05-19 | 2010-09-17 | 350d? |  |  | R5 | 8184h | 8184h | RInImp-UEConTest | PCG-23 |  |  | Rel-9 | RP-44 | Ingbert |  |
| 777 | 314.1 | Conformance Test Aspects – UMTS/LTE in 800 MHz for Europe | 350d? | 2009-05-19 A | 2010-09-17 A | 100% |  | 2009-05-19 | 2010-09-17 | 350d? |  | finish no earlier than 2010-09-17 | R5 | 2800h | 2800h | RInImp-UEConTest-UMTSLTE800EU | PCG-23 | Ericsson | fredrik.sundstrom@ericsson.com | Rel-9 | RP-44 | Ingbert | RP-100736 |
| 778 | 314.2 | Conformance Test Aspects – Extended UMTS/LTE 1500 MHz | 186d? | 2009-09-18 A | 2010-06-04 A | 100% |  | 2009-09-18 | 2010-06-04 | 186d? |  | finish no earlier than 2010-06-04 | R5 | 1488h | 1488h | UMTSLTE1500_UEConTest | PCG-23 | NTT DoCoMo | Nguyen Dung Dao (dao@nttdocomo.co.jp) | Rel-9 | RP-45 | Ingbert | RP-100487 |
| 779 | 314.3 | TDD UE Over The Air (Antenna) conformance testing methodology | 81d? | 2009-05-30 A | 2009-09-18 A | 100% |  | 2009-05-30 | 2009-09-18 | 81d? |  | finish no earlier than 2009-09-18 | R5 | 648h | 648h | UEAnt_TDDTest | PCG-23 | CATR | Qu Yan (quyan@emcite.com) | Rel-9 | RP-44 | Ingbert | RP-090727 |
| 780 | 314.4 | Conformance Test Aspects – Performance requirement for LCR TDD with UE speeds up to 350 km/h | 56d? | 2010-03-19 A | 2010-06-04 A | 100% |  | 2010-03-19 | 2010-06-04 | 56d? |  | finish no earlier than 2010-06-04 | R5 | 448h | 448h | RInImp9-LCRTDD350_UEConTest | PCG-24 | CATT | Xiaozhong Chen (chexiaozhong@datangmobile.cn) | Rel-9 | RP-47 | Ingbert | RP-100496 |
| 781 | 315 | Conformance Test Aspects – SMS over IMS in E-UTRAN | 131d? | 2009-09-18 A | 2010-03-19 A | 100% |  | 2009-09-18 | 2010-03-19 | 131d? |  | finish no earlier than 2010-06-18 | R5 | 1048h | 1048h | SMSoverIMS_UEConTest | PCG-23 | Alcatel-Lucent | Nidal Khrais (khrais@alcatel-lucent.com) | Rel-9 | RP-45 | Ingbert | RP-100072 |

Notes:
- 754: CP#47 completed. Continuation of Rel-8 Feature UID_400012 IMS Restoration Procedures
- 755: CP#47 completed / Text3: 23.380, 23.820
- 756: CP#47 completed / Text3: 24.229
- 757: CP#47 completed / Text3: 29.061, 29.212, 29.213, 29.214, 29.215
- 758: CP#47 completed / Text3: 23.218, 24.229, 24.930
- 759: CP#47 completed / Text3: 23.218, 24.229, 24.930
- 760: Expired / Text3: draft-kaplan-dispatch-session-id
- 761: Not completed internet-draft / Text3: draft-ietf-sipcore-rfc4244bis
- 762: CP#48 completed / Text3: 29.165
- 763: CP#47 completed [Stage 3 for Rel-7 Emergency Calls (EMC1)]. Related to Rel-9 UID_400038 LCS Control Plane Solution for EPS. Stage 2 in Rel-9 UID_400038 (23.271), UID_410037 (23.167) / Text3: 24.229
- 764: CP#46 completed / Text3: 29.212, 29.213, 29.215
- 765: CP#46 completed. Linked to Rel-6 UID_11051 (IMS Management objects) under the Feature UID_32021 (IMS Phase 2). MO compatible with OMA DM v1.2 & upwards and defined using OMA DM Device Description Framework (OMA-ERELD _DM-V1_2) / Text3: new 24.166
- 766: CP#47 approved WID and completed. Added capability to store ICE graphical information (picture). Linked to CT6 Rel-8 ICE Feature UID_380059 In Case of Emergency numbers storage and easy access on UICC / Text3: 31.102 CR#0433
- 767: RP#41 umbrella Feature created to host Rel-9 WIs / Text3: GERAN, UTRA, LTE
- 768: RP#44 completed technical work (RAN4 internal TR abandoned) / Text3: UTRA (no TR 25.8xy produced)
- 769: RP#47 completed. RF requirements specification applicable to Multi-Standard Radio (MSR) Base Station with multiple carriers and/or multiple 3GPP Radio Access Technologies (RAT) / Text3: GERAN, UTRA, LTE
- 770: RP#48 completed / Text3: UTRA, LTE 25.104, 25.105, 36.104, new 37.104, 37.113, 37.141, 37.900
- 771: GP#44 Core spec completed. GP#40 WID approved / Text3: GERAN 45.005, 51.021
- 772: RP#45 completed / Text3: UTRA, LTE 25.101, 25.104, 25.113, 25.133, 34.124, 36.101, 36.104, 36.113, 36.124, 36.133, 36.141, 25.306, 25.307, 25.331, 36.331, 25.461, 25.466, new 36.800
- 773: RP#47 completed / Text3: UTRA, LTE 25.101, 25.104, 25.113, 25.133, 25.141, 34.124, 36.101, 36.104, 36.113, 36.124, 36.133, 36.141, new 36.810, 25.306, 25.307, 25.331, 36.331, 25.461, 25.466
- 774: RP#46 completed / Text3: UTRA 25.102, 25.105, 25.142
- 775: RP#47 completed. For potential deployment in Japan / Text3: UTRA, LTE 25.101, 25.104, 25.113, 25.133, 25.141, 25.306, 25.307, 25.331, 25.461, 25.466, 34.124, 36.101, 36.104, 36.113, 36.124, 36.133, 36.141, 36.331, new (36.821, 36.307)
- 776: - / Text3: UTRA, LTE
- 777: RP#49 completed. Testing for UID_430009 UMTS/LTE 800 MHz for Europe / Text3: UTRA, LTE 34.108, 34.121-1, 34.121-2, 36.508, 36.521-1, 36.521-2, 36.521-3
- 778: RP#48 completed / Text3: UTRA, LTE 34.108, 34.121-1, 34.121-2, 34.123-1, 34.123-2, 36.508, 36.521-1, 36.521-2, 36.521-3, 36.523-1, 36.523-2, 36.523-3
- 779: RP#45 completed. Finalized TDD UE test methodology based on R4 TR 25.914 (UE and MS antenna performance evaluation method) and TS 25.144 Over the Air (Antenna) minimum performance requirements for the speech mode (terminal close to head) / Text3: UTRA 34.114
- 780: RP#48 completed. Testing for UID_430010 Performance requirement for LCR TDD with UE speeds up to 350 km/h / Text3: UTRA 34.122
- 781: RP#47 completed / Text3: LTE 34.229-1, 34.229-2, 34.229-3

| ID | WBS | Task | Duration | Start | Finish | Complete | Remaining | Baseline start | Baseline finish | Baseline duration | Total slack | Constraint | Resources | Work | Actual work | Text1 | Text2 | Text6 | Text7 | Text8 | Text4 | Text5 | Text11 |
| --- | --- | --- | --- | --- | --- | --- | --- | --- | --- | --- | --- | --- | --- | --- | --- | --- | --- | --- | --- | --- | --- | --- | --- |
| 782 | 316 | **Rel-9 RAN improvements** | 272d? | 2009-03-06 A | 2010-03-19 A | 100% |  | 2009-03-06 | 2010-03-19 | 272d? |  |  | RP | 9536h | 9536h | RANimp | PCG-22 | Rel-9 | RP-43 | Issam |  |  |  |
| 783 | 316.1 | Dual-Cell HSUPA | 272d? | 2009-03-06 A | 2010-03-19 A | 100% |  | 2009-03-06 | 2010-03-19 | 272d? |  | finish no earlier than 2010-03-19 | R1,R2,R3,R4 | 1568h | 1568h | RANimp-DC_HSUPA | PCG-22 | Rel-9 | RP-43 | Patrick | Nokia Siemens Networks | Karri Ranta-aho (karri.ranta-aho@nsn.com) | RP-100030 |
| 784 | 316.2 | Support for different bands for Dual-Cell HSDPA | 197d? | 2009-03-06 A | 2009-12-04 A | 100% |  | 2009-03-06 | 2009-12-04 | 197d? |  |  | R4,R2,R3 | 1568h | 1568h | RANimp-MultiBand_DC_HSDPA | PCG-22 | Rel-9 | RP-43 | Issam | Nokia Siemens Networks | Tuomo Säynäjäkangas (tuomo.saynajakangas@nsn.com) | RP-091038 |
| 785 | 316.3 | Combination of DC-HSDPA with MIMO | 197d? | 2009-03-06 A | 2009-12-04 A | 100% |  | 2009-03-06 | 2009-12-04 | 197d? |  |  | R1,R2,R3,R4 | 1568h | 1568h | RANimp-DC_MIMO | PCG-22 | Rel-9 | RP-43 | Patrick | Ericsson | johan.bergman@ericsson.com | RP-091039 |
| 786 | 316.4 | Transmit Antenna Array (TxAA) extension for non-MIMO UEs | 197d? | 2009-03-06 A | 2009-12-04 A | 100% |  | 2009-03-06 | 2009-12-04 | 197d? |  |  | R1,R2,R3,R4 | 1568h | 1568h | RANimp-TxAA_nonMIMO | PCG-22 | Rel-9 | RP-43 | Patrick | Nokia | Arto Lehti (arto.lehti@nokia.com) | RP-091040 |
| 787 | 316.5 | Cell Portion for 1.28 Mcps TDD | 136d? | 2009-05-30 A | 2009-12-04 A | 100% |  | 2009-05-30 | 2009-12-04 | 136d? |  |  | R3,R1,R4 | 1088h | 1088h | CP_LCRTDD | PCG-23 | Rel-9 | RP-44 | Juha | CATT | Ying Zhang (zhangying2@datangmobile.cn) | RP-091041 |
| 788 | 317 | **Rel-9 RAN improvements - UE Conformance Testing** | 459d? | 2010-09-17 A | 2012-06-15 | 91% | 39.14d? | 2010-09-17 | 2012-06-15 | 459d? | 388d |  | R5 | 9808h | 8971.7h |  | PCG-25 | Rel-9 | RP-49 | Ingbert |  |  |  |
| 789 | 317.1 | Conformance Test Aspects – Combination of DC-HSDPA with MIMO | 186d? | 2010-09-17 A | 2011-06-03 A | 100% |  | 2010-09-17 | 2011-06-03 | 186d? |  | finish no earlier than 2011-06-03 | R5 | 1488h | 1488h | RANimp-DC_MIMO_UEConTest | PCG-25 | Rel-9 | RP-49 | Ingbert | Ericsson | leif.mattisson@ericsson.com | RP-110510 |
| 790 | 317.2 | Conformance Test Aspects – Dual-Cell HSUPA | 327d? | 2011-03-18 A | 2012-06-15 | 80% | 65.4d? | 2011-03-18 | 2012-06-15 | 327d? | 388d | finish no earlier than 2012-06-15 | R5 | 2616h | 2092.8h | RANimp-DC_HSUPA_UEConTest | PCG-26 | Rel-9 | RP-51 | Ingbert | Ericsson | leif.mattisson@ericsson.com | RP-120037 |
| 791 | 317.3 | Conformance Test Aspects – Support for different bands for Dual-Cell HSDPA | 254d? | 2011-03-18 A | 2012-03-02 A | 100% |  | 2011-03-18 | 2012-03-02 | 254d? |  | finish no earlier than 2012-03-02 | R5 | 2032h | 2032h | RANimp-MultiBand_DC_HSDPA_UEConTest | PCG-26 | Rel-9 | RP-51 | Ingbert | Ericsson | leif.mattisson@ericsson.com | RP-120036 |
| 792 | 318 | **LTE improvements** | 587d? | 2009-03-06 A | 2011-06-03 A | 100% |  | 2009-03-06 | 2011-06-03 | 587d? |  |  | R1,R2,R4,R5 | 9928h | 9928h | LTEimp | PCG-22 | Rel-9 | RP-42 | Patrick |  |  |  |
| 793 | 318.1 | LTE Pico NodeB RF Requirements | 196d? | 2009-03-06 A | 2009-12-04 A | 100% |  | 2009-03-06 | 2009-12-04 | 196d? |  | finish no earlier than 2010-03-05 | R4 | 1568h | 1568h | LTEimp-Pico_eNB-RF | PCG-22 | Rel-9 | RP-43 | Issam | Huawei | Liyan Yin (yinliyan@huawei.com) | RP-091045 |
| 794 | 318.2 | Enhanced Dual-Layer transmission for LTE | 272d? | 2009-03-06 A | 2010-03-19 A | 100% |  | 2009-03-06 | 2010-03-19 | 272d? |  | finish no earlier than 2010-03-18 | R1,R2,R4 | 2176h | 2176h | LTEimp-eDL | PCG-22 | Rel-9 | RP-43 | Patrick | China Mobile | Xu Xiaodong (xuxiaodong@chinamobile.com) | RP-100034 |
| 795 | 318.3 | UE Conformance Test Aspects – Enhanced Dual-layer transmission for LTE TDD | 186d? | 2010-09-17 A | 2011-06-03 A | 100% |  | 2010-09-17 | 2011-06-03 | 186d? |  | finish no earlier than 2011-06-03 | R5 | 1488h | 1488h | LTEimp-eDL_UEConTest | PCG-25 | Rel-9 | RP-49 | Ingbert | China Mobile | Shanpeng Xiao (xiaoshanpeng@chinamobile.com) | RP-110509 |
| 796 | 319 | Rel-9 Self-Organizing Networks (SON) | 272d? | 2009-03-06 A | 2010-03-19 A | 100% |  | 2009-03-06 | 2010-03-19 | 272d? |  | finish no earlier than 2010-03-19 | R3,R2 | 2176h | 2176h | SON | PCG-22 | Rel-9 | SP-42 | Juha | Nokia Siemens Networks | krzysztof.kordybach@nsn.com | RP-100038 |
| 797 | 320 | **A-GNSS Performances and Testing Procedures** | 787d? | 2008-05-16 A | 2011-05-20 A | 100% |  | 2008-05-16 | 2011-05-20 | 787d? |  |  | GP | 16368h | 16368h | AGNSSPTP |  | Rel-9 |  | Paolo | Thales | Michel.monnerat@thalesaleniaspace.com |  |
| 798 | 320.1 | A-GNSS Minimum Performances | 472d? | 2008-05-16 A | 2010-03-05 A | 100% |  | 2008-05-16 | 2010-03-05 | 472d? |  | finish no earlier than 2010-03-05 | G1 | 3776h | 3776h | AGNSSPTP- Perfreq |  | Rel-9 |  | Paolo | Thales | Michel.monnerat@thalesaleniaspace.com |  |
| 799 | 320.2 | A-GNSS Testing Procedures | 787d? | 2008-05-16 A | 2011-05-20 A | 100% |  | 2008-05-16 | 2011-05-20 | 787d? |  | finish no earlier than 2011-05-20 | G3new | 6296h | 6296h | AGNSSPTP-MStest |  | Rel-9 |  | Ingbert | Thales | Michel.monnerat@thalesaleniaspace.com |  |
| 800 | 321 | **Voice services over Adaptive Multi-user channels on One Slot** | 860d? | 2008-11-21 A | 2012-03-02 A | 100% |  | 2008-11-21 | 2012-03-02 | 860d? |  |  | GP,G1,G2,G3new | 24728h | 24728h | VAMOS | PCG-22 | Rel-9 | SP-42 | Paolo | Nokia Siemens Networks, China Mobile | juergen.hofmann@nsn.com, liuxiaoyu@chinamobile.com |  |
| 801 | 321.1 | Stage 2 for Voice services over Adaptive Multi-user channels on One Slot | 392d? | 2008-11-21 A | 2010-05-21 A | 100% |  | 2008-11-21 | 2010-05-21 | 392d? |  | finish no earlier than 2010-05-21 | GP,G1,G2 | 3136h | 3136h | VAMOS | PCG-22 | Rel-9 | GP-40 | Paolo | Nokia Siemens Networks, China Mobile | juergen.hofmann@nsn.com, liuxiaoyu@chinamobile.com |  |
| 802 | 321.2 | Stage 3 for Voice services over Adaptive Multi-user channels on One Slot | 596d? | 2008-11-24 A | 2011-03-04 A | 100% |  | 2008-11-24 | 2011-03-04 | 596d? |  | finish no earlier than 2011-03-04 | GP,G1,G2 | 4768h | 4768h | VAMOS | PCG-22 | Rel-9 | GP-40 | Paolo | Nokia Siemens Networks, China Mobile | juergen.hofmann@nsn.com, liuxiaoyu@chinamobile.com |  |
| 803 | 321.3 | VAMOS Radio Performance Requirements | 651d? | 2008-11-24 A | 2011-05-20 A | 100% |  | 2008-11-24 | 2011-05-20 | 651d? |  | finish no earlier than 2011-05-20 | GP,G1,G2 | 5208h | 5208h | VAMOS | PCG-22 | Rel-9 | GP-40 | Paolo | Nokia Siemens Networks, China Mobile | juergen.hofmann@nsn.com, liuxiaoyu@chinamobile.com |  |
| 804 | 321.4 | VAMOS - MS conformance testing | 392d? | 2010-09-03 A | 2012-03-02 A | 100% |  | 2010-09-03 | 2012-03-02 | 392d? |  | finish no earlier than 2012-03-02 | G3new | 3128h | 3128h | VAMOS_MStest | PCG-25 | Rel-9 | GP-47 | Ingbert | Research In Motion | Raveendra Seetharam (rseetharam@rim.com) |  |
| 805 | 321.5 | VAMOS - BTS conformance testing | 201d? | 2010-11-26 A | 2011-09-02 A | 100% |  | 2010-11-26 | 2011-09-02 | 201d? |  | finish no earlier than 2011-09-02 | G1 | 1608h | 1608h | VAMOS_BTStest | PCG-26 | Rel-9 | GP-48 | Paolo | Nokia Siemens Networks | eddie.riddington@nsn.com |  |

Notes:
- 782: RP#47 completed / Text3: UTRA
- 783: RP#47 completed / Text3: 25.101, 25.104, 25.133, 25.211, 25.212, 25.213, 25.214, 25.215, 25.319, 25.306, 25.321, 25.331, 25.423, 25.433
- 784: RP#46 completed / Text3: 25.101, 25.104, 25.133, 25.306, 25.308, 25.331, 25.423, 25.433, new 25.317 (Requirements on Ues supporting a release-independent frequency band combination)
- 785: RP#46 completed / Text3: 25.101, 25.104, 25.133, 25.211, 25.212, 25.213, 25.214, 25.215, 25.308, 25.321, 25.331, 26.306, 25.423, 25.433
- 786: RP#46 completed / Text3: 25.101, 25.104, 25.211, 25.212, 25.213, 25.214, 25.215, 25.308, 25.306, 25.321, 25.331, 25.423, 25.433
- 787: RP#46 completed / Text3: 25.102, 25.105, 25.123, 25.225, 25.423, 25.433
- 788: -
- 789: UTRA. RP#52 completed. Testing for Rel-9 UID_430016 Combination of DC-HSDPA with MIMO / Text3: UTRA 34.108, 34.121-1, 34.121-2, 34.123-1, 34.123-2, 34.123-3
- 790: RP#55 completion 03/12=>06/12. Testing for Rel-9 UID_430014 Dual-Cell HSUPA / Text3: UTRA 34.108, 34.121-1, 34.121-2, 34.123-1, 34.123-2, 34.123-3
- 791: RP#55 completed. Testing for Rel-9 UID_430015 Support for different bands for Dual-Cell HSDPA / Text3: UTRA 34.108, 34.121-1, 34.121-2, 34.123-1, 34.123-2, 34.123-3
- 792: - / Text3: LTE
- 793: RP#46 completed / Text3: 36.104, 36.141, new 36.931
- 794: RP#47 completed / Text3: 36.101, 36.211, 36.212, 36.213, 36.331
- 795: RP#52 completed. Testing for UID_430029 (Enhanced Dual-Layer transmission for LTE) / Text3: 36.508, 36.521-1, 36.521-2
- 796: RP#47 completed / Text3: LTE 25.413, 36.300, 36.413, 36.423, 48.018, new 36.902
- 797: GP#46 still ongoing MS testing. Linked to Rel-10 RAN4 UID_450027 (A-GNSS Minimum Performance for UTRAN)
- 798: GP#45 completed (open performance requirements alignment GPS/Galileo) / Text3: 45.005
- 799: GP#50 completed / Text3: 51.010-1, new 51.010-7
- 800: GP#53 completed. Triggered by UID_50590 (MUROS) Study on Multi-User Reusing-One-Slot
- 801: GP#46 completed. GP#40 WID approved / Text3: 45.001
- 802: GP#49 completed. GP#40 WID approved / Text3: 24.008, 44.018, 45.002, 45.003, 45.004, 45.008, 48.008, 48.058
- 803: GP#50 completed. GP#40 WID approved / Text3: 45.005
- 804: GP#53 completed. GP#47 WID approved / Text3: 51.010-1, 51.010-2
- 805: GP#51 completed. GP#48 WID approved / Text3: 51.021

| ID | WBS | Task | Type | Duration | Start | Finish | Complete | Baseline start | Baseline finish | Baseline duration | Constraint | Resources | Work | Actual work | Text1 | Text2 | Text4 | Text5 | Text6 | Text7 | Text8 | Text9 | Text12 | Text11 |
| --- | --- | --- | --- | --- | --- | --- | --- | --- | --- | --- | --- | --- | --- | --- | --- | --- | --- | --- | --- | --- | --- | --- | --- | --- |
| 806 | 322 | **Cell Broadcast protocol Base Station Controller – Cell Broadcast Centre (BSC-CBC)** |  | 222d? | 2009-05-15 A | 2010-03-19 A | 100% | 2009-05-15 | 2010-03-19 | 222d? |  | GP,C1 | 5248h | 5248h | CEBRO | PCG-23 | Ericsson | claes-goran.persson@ericsson.com | Rel-9 | GP-42 | Paolo |  |  |  |
| 807 | 322.1 | GERAN part of Cell Broadcast protocol Base Station Controller – Cell Broadcast Centre |  | 212d? | 2009-05-15 A | 2010-03-05 A | 100% | 2009-05-15 | 2010-03-05 | 212d? | finish no earlier than 2010-03-05 | GP | 1696h | 1696h | CEBRO | PCG-23 | Ericsson | claes-goran.persson@ericsson.com | Rel-9 | GP-42 | Paolo |  |  |  |
| 808 | 322.2 | CT1 part of Cell Broadcast protocol Base Station Controller – Cell Broadcast Centre |  | 222d? | 2009-05-15 A | 2010-03-19 A | 100% | 2009-05-15 | 2010-03-19 | 222d? | finish no earlier than 2010-03-19 | C1 | 1776h | 1776h | CEBRO | PCG-23 | Ericsson | claes-goran.persson@ericsson.com | Rel-9 | GP-42 | Frederic |  |  |  |
| 809 | 323 | Hybrid Location |  | 136d? | 2009-05-18 A | 2009-11-20 A | 100% | 2009-05-18 | 2009-11-20 | 136d? | finish no earlier than 2009-11-20 | GP | 1088h | 1088h | HILT | PCG-23 | TruePosition | Matt Ward (mward@trueposition.com) | Rel-9 | GP-42 | Paolo |  |  |  |
| 810 | 324 | (Small) Technical Enhancements and Improvements for Rel-9 |  | 325d? | 2008-09-15 A | 2009-12-10 A | 100% | 2008-09-15 | 2009-12-10 | 325d? | finish no earlier than 2009-12-10 | All | 2600h | 2600h | TEI9 | PCG-22 |  |  | Rel-9 | SP-42 | All |  |  |  |
| 811 | 325 | Test - (Small) Technical Enhancements and Improvements for Rel-9 |  | 286d? | 2009-11-20 A | 2010-12-24 A | 100% | 2009-11-20 | 2010-12-24 | 286d? | finish no earlier than 2010-12-24 | R5,G3new | 2288h | 2288h | TEI9_Test | PCG-24 |  |  | Rel-9 | GP-44 | Ingbert |  |  |  |
| 812 | 326 | Deleted - Harmonization of Gq'/Rx for Common IMS |  | 304d? | 2008-01-14 A | 2009-03-12 A | 100% | 2008-01-14 | 2009-03-12 | 304d? | finish no earlier than 2009-03-12 | S2 | 2432h | 2432h | IMS_Comm_GqRx_Harm | PCG-21 | Alcatel-Lucent | geoffrey.cristallo@alcatel-lucent.be | Rel-9 | SP-38 | Maurice | PCG-22 | SP-43 |  |
| 813 | 327 | Deleted - Support of WiMAX - LTE Mobility |  | 407d? | 2008-06-06 A | 2009-12-25 A | 100% | 2008-06-06 | 2009-12-25 | 407d? | start no earlier than 2008-06-06 | R2 | 3248h | 3248h | WiMAX_LTE_Mobility | PCG-21 | Samsung |  | Rel-9 | RP-38 | Joern | PCG-21 | SP-39 |  |
| 814 | 328 | Deleted - Support of WiMAX - UMTS Mobility |  | 407d? | 2008-06-06 A | 2009-12-25 A | 100% | 2008-06-06 | 2009-12-25 | 407d? | start no earlier than 2008-06-06 | R2 | 3248h | 3248h | WiMAX_UMTS_Mobility | PCG-21 | Intel |  | Rel-9 | RP-38 | Joern | PCG-21 | SP-39 |  |
| 815 | 329 | Deleted - Definition of 3GPP UICC services over the new high-speed interface | milestone | 0d? | 2010-03-19 A | 2010-03-19 A | 100% | 2010-03-19 | 2010-03-19 | 0d? |  | C6 |  |  | UICCHS | PCG-21 | Gemalto | Denis.Lheriteau@gemalto.com | Rel-9 | CP-38 | Xavier | PCG-24 | CP-47 |  |
| 816 | 330 | **Deleted - SAES Enhancements (non RAN aspects)** |  | 381d? | 2007-06-25 A | 2008-12-08 A | 100% | 2007-06-25 | 2008-12-08 | 381d? |  | S2 | 11664h | 11664h | SAES_Ph2 | PCG-21 | Nokia Siemens Networks |  | Rel-9 | SP-39 | Maurice | PCG-21 | SP-39 |  |
| 817 | 330.1 | Deleted - Functions and procedures for SAE to support LTE MBMS |  | 381d? | 2007-06-25 A | 2008-12-08 A | 100% | 2007-06-25 | 2008-12-08 | 381d? | finish no earlier than 2008-12-08 | S2 | 3048h | 3048h | SAES_Ph2 |  |  |  | Rel-9 | SP-35 | Maurice | PCG-21 | SP-39 |  |
| 818 | 330.2 | Deleted - CS over EPS |  | 194d? | 2008-03-12 A | 2008-12-08 A | 100% | 2008-03-12 | 2008-12-08 | 194d? | finish no earlier than 2008-12-08 | S2 | 1552h | 1552h | SAES_Ph2 | PCG-21 |  |  | Rel-9 | SP-39 | Maurice | PCG-21 | SP-39 |  |
| 819 | 330.3 | **Deleted - SAE for generic support for non-3GPP accesses** |  | 251d? | 2007-06-25 A | 2008-06-09 A | 100% | 2007-06-25 | 2008-06-09 | 251d? |  | S2 | 4016h | 4016h | SAES_Ph2 | PCG-21 |  |  | Rel-9 | SP-39 | Maurice | PCG-21 | SP-39 |  |
| 820 | 330.3.1 | Deleted - Single Radio Aspects of SAE for Optimized Handover with WiMAX |  | 251d? | 2007-06-25 A | 2008-06-09 A | 100% | 2007-06-25 | 2008-06-09 | 251d? | finish no earlier than 2008-06-09 | S2 | 2008h | 2008h | SAES_Ph2 | PCG-21 |  |  | Rel-9 | SP-39 | Maurice | PCG-21 | SP-39 |  |
| 821 | 331 | Deleted - Lawful Interception in the 3GPP Rel-9 |  | 211d? | 2009-06-04 A | 2010-03-25 A | 100% | 2009-06-04 | 2010-03-25 | 211d? | finish no earlier than 2010-03-25 | S3 | 1688h | 1688h | LI9 | PCG-23 | PIDS, Nortel | Koen Jaspers, Ronald Ryan | Rel-9 | SP-44 | Dionisio | PCG-24 | SP-47 |  |
| 822 | 332 | Release 9 Studies |  | 468d? | 2008-06-05 A | 2010-03-19 A | 100% | 2008-06-05 | 2010-03-19 | 468d? |  | CP,RP,SP | 3744h | 3744h |  |  |  |  | Rel-9 |  |  |  |  |  |
| 823 | 333 | Study on CS Domain Services over EPS access |  | 492d? | 2007-04-25 A | 2009-03-12 A | 100% | 2007-04-25 | 2009-03-12 | 492d? | finish no earlier than 2009-03-12 | S2 | 3936h | 3936h | FS_CSoPS |  | T-Mobile | Karl-Heinz.Nenner@T-Mobile.net | Rel-9 | SP-35 | Maurice |  |  |  |
| 824 | 334 | Study on Extended Support of IMS Emergency Calls |  | 319d? | 2007-09-24 A | 2008-12-11 A | 100% | 2007-09-24 | 2008-12-11 | 319d? | finish no earlier than 2009-06-18 | S2 | 2552h | 2552h | FS_IMS-eCall |  | Qualcomm | Stephen Edge | Rel-9 | SP-37 | Maurice |  |  |  |
| 825 | 335 | Study on Service Continuity for Emergency Voice Calls |  | 721d? | 2006-06-08 A | 2009-03-12 A | 100% | 2006-06-08 | 2009-03-12 | 721d? | finish no earlier than 2009-03-12 | S2 | 5768h | 5768h | FS_VCCEm |  | Nortel | Ricky Kaura (rkaura@nortel.com) | Rel-9 | SP-32 | Maurice |  |  |  |
| 826 | 336 | Study on Security Aspects of Remote Provisioning and Change of Subscription for M2M Equipment |  | 582d? | 2004-04-06 A | 2009-12-10 A | 100% | 2004-04-06 | 2009-12-10 | 582d? | finish no earlier than 2009-12-10 | S3,C6 | 4656h | 4656h | FS_UM2M |  | Ericsson | vesa.lehtovirta@ericsson.com | Rel-9 | SP-37 | Dionisio |  |  |  |
| 827 | 337 | Study on System Maintenance over Itf-N |  | 602d? | 2007-06-07 A | 2009-09-24 A | 100% | 2007-06-07 | 2009-09-24 | 602d? | finish no earlier than 2009-09-24 | S5 | 4808h | 4808h | FS_OAM-Maint-Itf-N |  | ZTE | Shuqiang Huang (huangsq@zte.com.cn) | Rel-9 | SP-36 | Dionisio |  |  |  |
| 828 | 338 | Study on Self-Organizing Networks (SON) related OAM interfaces for Home NodeB |  | 522d? | 2007-06-07 A | 2009-06-04 A | 100% | 2007-06-07 | 2009-06-04 | 522d? | finish no earlier than 2009-12-10 | S5 | 4168h | 4168h | FS_OAM-SON-HNB |  | Huawei | Zou Lan (zlan@huawei.com) | Rel-9 | SP-36 | Dionisio |  |  |  |
| 829 | 339 | Study on Self-healing of Self-Organizing Networks (SON) |  | 416d? | 2008-02-22 A | 2009-09-24 A | 100% | 2008-02-22 | 2009-09-24 | 416d? | finish no earlier than 2009-09-24 | S5 | 3320.15h | 3320.15h | FS_OAM-SON-SH | PCG-21 | ZTE | zhu.weihong@zte.com.cn | Rel-9 | SP-39 | Dionisio |  |  |  |
| 830 | 340 | Study on Service Oriented Architecture (SOA) for IRP |  | 262d? | 2008-06-05 A | 2009-06-04 A | 100% | 2008-06-05 | 2009-06-04 | 262d? | finish no earlier than 2009-05-20 | S5 | 2088h | 2088h | FS_OAM_SOA_IRP | PCG-21 | Ericsson | edwin.tse@ericsson.com | Rel-9 | SP-40 | Dionisio |  |  |  |
| 831 | 341 | Study on Evaluation of the inclusion of Path Loss Based Technology in the UTRAN |  | 516d? | 2007-12-17 A | 2009-12-04 A | 100% | 2007-12-17 | 2009-12-04 | 516d? | finish no earlier than 2009-09-18 | R4 | 4120h | 4120h | FS_RAN-Pathloss | PCG-21 | Polaris Wireless | Norman Shaw (nshaw@polariswireless.com) | Rel-9 | RP-38 | Issam |  |  | RP-091080 |
| 832 | 342 | Study on LTE-Advanced |  | 461d? | 2007-03-23 A | 2010-03-19 A | 100% | 2007-03-23 | 2010-03-19 | 461d? | finish no earlier than 2010-03-19 | R1,R2,R3,R4 | 3688h | 3688h | FS_RAN_LTEA | PCG-21 | NTT DoCoMo | Tetsushi Abe | Rel-9 | RP-39 | Patrick |  |  | RP-100080 |
| 833 | 343 | Study on 1.28 Mcps TDD Home NodeB |  | 387d? | 2008-02-20 A | 2009-12-04 A | 100% | 2008-02-20 | 2009-12-04 | 387d? | finish no earlier than 2009-12-04 | R4 | 3096h | 3096h | FS_RAN-HNBLCRTDD | PCG-21 | TD Tech | Li Rong (lirong@td-tech.com) | Rel-9 | RP-41 | Issam |  |  | RP-091081 |
| 834 | 344 | Study on E-UTRAN Mobility Evaluation and Enhancement |  | 126d? | 2008-12-05 A | 2009-05-29 A | 100% | 2008-12-05 | 2009-05-29 | 126d? | finish no earlier than 2009-05-29 | R1 | 1008h | 1008h | FS_EUTRAN_mob | PCG-22 | Qualcomm | Rajat Prakash (rprakash@qualcomm.com) | Rel-9 | RP-42 | Patrick |  |  | RP-090426 |
| 835 | 345 | Study on Minimization of drive-tests in Next Generation Networks |  | 196d? | 2009-03-06 A | 2009-12-04 A | 100% | 2009-03-06 | 2009-12-04 | 196d? | finish no earlier than 2009-12-04 | R2 | 1568h | 1568h | FS_NGN_min_drive-tests | PCG-22 | Qualcomm | Masato Kitazoe (mkitazoe@qualcomm.com) | Rel-9 | RP-43 | Joern |  |  | RP-091084 |
| 836 | 346 | Study on Enhanced Interference Management for HNBs |  | 61d? | 2009-03-06 A | 2009-05-29 A | 100% | 2009-03-06 | 2009-05-29 | 61d? | start no earlier than 2009-03-06 | R4 | 488h | 488h | FS_eInterfMgmt_HNB | PCG-22 | Qualcomm | Farhad Meshkati (fmeshkat@qualcomm.com) | Rel-9 | RP-43 | Issam |  |  | RP-090429 |
| 837 | 347 | Study on Enhanced Interference Management Mechanisms for HNBs |  | 81d? | 2009-05-30 A | 2009-09-18 A | 100% | 2009-05-30 | 2009-09-18 | 81d? | finish no earlier than 2009-09-18 | R3 | 648h | 648h | FS_eInterfMgmtMchsm_HNB | PCG-23 | Qualcomm | Farhad Meshkati (fmeshkat@qualcomm.com) | Rel-9 | RP-44 | Juha |  |  | RP-090733 |
| 838 | 348 | Deleted - Study on Protection against SMS and MMS spam |  | 862d? | 2006-06-08 A | 2009-09-24 A | 100% | 2006-06-08 | 2009-09-24 | 862d? | finish no earlier than 2009-09-24 | S3 | 6896h | 6896h | FS_CPSMal |  | Orange | eric.gauthier@orange.ch | Rel-9 | SP-32 | Dionisio | PCG-23 | SP-45 |  |
| 839 | 349 | Release 8 Features |  | 914.3d? | 2006-09-19 A | 2010-03-19 A | 100% | 2006-09-19 | 2010-03-19 | 914.3d? | start no earlier than 2000-01-03 | CP,GP,RP,SP | 7314.4h | 7314.4h |  |  |  |  | Rel-8 |  |  |  |  |  |
| 840 | 350 | Conformance Test Aspects – Mobility management based on DSMIPv6 (Dual-Stack Mobile IPv6) |  | 261d? | 2009-09-18 A | 2010-09-17 A | 100% | 2009-09-18 | 2010-09-17 | 261d? | finish no earlier than 2010-09-17 | R5 | 2088h | 2088h | DSMIPv6_UEConTest | PCG-23 | Qualcomm | Lena Chaponniere (lchaponn@qualcomm.com) | Rel-8 | RP-45 | Ingbert |  |  | RP-100738 |

Notes:
- 806: CP#47 completed. GP#45 completed. GP#42 WID approved
- 807: GP#45 completed. GP#42 WID approved / Text3: new 48.049
- 808: CP#47 completed / Text3: 23.041
- 809: GP#44 completed. GP#42 WID approved (Hybrid Integrated Location Technology=HILT) / Text3: 43.059, 48.071
- 810: SP#46 completed
- 811: GP#44 created
- 812: SP#43 stopped. LS_out to TISPAN informs about stopping this activity / Text3: 23.822, 23.203
- 813: RP#39: No agreed WID / Text3: 36.306, 36.331, 36.413, 36.300, 36.214, 36.133, 36.304
- 814: RP#39: No agreed WID / Text3: 25.306, 25.331, 25.413
- 815: CP#47 work stopped/abandoned / Text3: 31.xyz
- 816: SP#39 created to host Rel-9 Wis. BUT no agreed WID
- 817: SP#39 SAE functionality moved to Rel-9. WID returned to SA2 for re-consideration & remove MBMS for EPS from Rel 8
- 818: SP#39 SAE functionality moved to Rel-9. BUT no agreed WID
- 819: SP#39 SAE functionality moved to Rel-9. BUT no agreed WID
- 820: SP#39 SAE functionality moved to Rel-9. BUT no agreed WID
- 821: SP#47 stopped. WI + new topics moved to Rel-10 / Text3: 33.106, 33.107, 33.108
- 822: -
- 823: SP#43 completed. Linked to Combinational Services UID_31064, Services Alignment and Migration (ServAl) UID_330017 and 3GPP System Architecture Evolution (SAES) UID_3208 / Text3: 23.879
- 824: SP#42 completed / Text3: 23.868
- 825: SP#43 completed / Text3: 23.826
- 826: SP#46 completed. Triggered by the SA1 Rel-8 Study on Facilitating Machine to Machine Communication in GSM and UMTS (FS_M2M) UID_7027 in TR 22.868. / Text3: 33.812
- 827: SP#45 completed / Text3: 32.822
- 828: SP#44 completed. Linked to SA5 TR 32.816 Study of Management for LTE and SAE (UID_340036) / Text3: 32.821
- 829: SP#45 completed. Linked to SA5 TR 32.816 Study of Management for LTE and SAE (UID_340036) / Text3: 32.823
- 830: SP#44 completed. Spin-off implementation WI UID_440064 Service Oriented Architecture (SOA) for IRP / Text3: 32.824
- 831: RP#46 completed / Text3: 25.907
- 832: RP#47 completed / Text3: 36.913 , new 36.814, 36.912, R2 36.806 (Relay architectures for E-UTRA), R4 36.815 (LTE-Advanced feasibility studies in RAN4)
- 833: RP#46 completed / Text3: 25.866
- 834: RP#44 closed (RP-090452 R1 LS to RAN on Conclusions for LTE Mobility Study Item - no further Rel-9 action / no TR needed) / Text3: none
- 835: RP#46 completed / Text3: 36.805
- 836: RP#44 completed. Linked to UID_420008 LTE FDD Home eNodeB RF Requirements. Spin-off RAN3 UID_440015 Study on Enhanced Interference Management Mechanisms for HNBs / Text3: 25.967
- 837: RP#45 completed. Triggered by RAN4 UID_430027 Study on Enhanced Interference Management for HNBs / Text3: 25.967
- 838: SP#45 work stopped/abandoned / Text3: 33.9xx
- 839: -
- 840: RP#49 completed. Testing for CT1's UID_360022 (24.303) under Rel-8 Feature SAES / Text3: 36.508, 36.523-1, 36.523-2, 36.523-3

| ID | WBS | Task | Type | Duration | Start | Finish | Complete | Remaining | Baseline start | Baseline finish | Baseline duration | Total slack | Constraint | Resources | Work | Actual work | Text1 | Text4 | Text5 | Text6 | Text8 | Text2 | Text7 |
| --- | --- | --- | --- | --- | --- | --- | --- | --- | --- | --- | --- | --- | --- | --- | --- | --- | --- | --- | --- | --- | --- | --- | --- |
| 841 | 351 | **IMS Enhancements for support of Packet Cable access** |  | 388d? | 2006-12-06 A | 2008-05-30 A | 100% |  | 2006-12-06 | 2008-05-30 | 388d? |  |  | S2,S3,C1,C3,C4 | 27448h | 27448h | PktCbl | Cablelabs | Bernie McKibben (b.mckibben@cablelabs.com) | Rel-8 | Maurice |  |  |
| 842 | 351.1 | **IMS Enhancements for Cable Client Types and Deployment Models** |  | 345d? | 2007-02-05 A | 2008-05-30 A | 100% |  | 2007-02-05 | 2008-05-30 | 345d? |  |  | S2,C1 | 6992h | 6992h | PktCbl-Deploy | Cablelabs | Bernie McKibben (b.mckibben@cablelabs.com) | Rel-8 | Maurice |  |  |
| 843 | 351.1.1 | Architecture aspects of PktCbl-Deploy |  | 219d? | 2007-02-05 A | 2007-12-06 A | 100% |  | 2007-02-05 | 2007-12-06 | 219d? |  | finish no earlier than 2007-12-03 | S2 | 1752h | 1752h | PktCbl-Deploy | Cablelabs | Bernie McKibben (b.mckibben@cablelabs.com) | Rel-8 | Maurice |  |  |
| 844 | 351.1.2 | CT1 aspects of PktCbl-Deploy |  | 310d? | 2007-03-26 A | 2008-05-30 A | 100% |  | 2007-03-26 | 2008-05-30 | 310d? |  | finish no earlier than 2008-06-15 | C1 | 2480h | 2480h | PktCbl-Deploy | Cablelabs | D.Hancock@CableLabs.com | Rel-8 | Frederic |  |  |
| 845 | 351.2 | **IMS Inter-working aspects in Support of Cable Regulatory requirements** |  | 290d? | 2007-02-05 A | 2008-03-14 A | 100% |  | 2007-02-05 | 2008-03-14 | 290d? |  |  | S2,C1,C3 | 5640h | 5640h | PktCbl-Intw | Cablelabs | B.McKibben@CableLabs.com | Rel-8 | Maurice |  |  |
| 846 | 351.2.1 | Architecture aspects of PktCbl-Interwork |  | 160d? | 2007-02-05 A | 2007-09-14 A | 100% |  | 2007-02-05 | 2007-09-14 | 160d? |  | start no earlier than 2007-02-05 | S2 | 1280h | 1280h | PktCbl-Intw | Cablelabs | B.McKibben@CableLabs.com | Rel-8 | Maurice |  |  |
| 847 | 351.2.2 | CT1,CT3 aspects of PktCbl-Interwork |  | 255d? | 2007-03-26 A | 2008-03-14 A | 100% |  | 2007-03-26 | 2008-03-14 | 255d? |  | finish no earlier than 2008-03-15 | C1,C3 | 2040h | 2040h | PktCbl-Intw | Cablelabs | D.Hancock@CableLabs.com | Rel-8 | Frederic |  |  |
| 848 | 351.3 | **IMS Enhancements for Security Requirements in Support of Cable Deployments** |  | 388d? | 2006-12-06 A | 2008-05-30 A | 100% |  | 2006-12-06 | 2008-05-30 | 388d? |  |  | S3,C1,C3,C4 | 11712h | 11712h | PktCbl-Sec | Cablelabs | s.dotson@cablelabs.com | Rel-8 | Dionisio |  |  |
| 849 | 351.3.1 | SA3 aspects of PktCbl-Sec |  | 331d? | 2006-12-06 A | 2008-03-12 A | 100% |  | 2006-12-06 | 2008-03-12 | 331d? |  | finish no earlier than 2007-12-20 | S3 | 2648h | 2648h | PktCbl-Sec | Cablelabs | s.dotson@cablelabs.com | Rel-8 | Dionisio |  |  |
| 850 | 351.3.2 | CT1 aspects of PktCbl-Sec |  | 310d? | 2007-03-26 A | 2008-05-30 A | 100% |  | 2007-03-26 | 2008-05-30 | 310d? |  | finish no earlier than 2008-06-06 | C1 | 2480h | 2480h | PktCbl-Sec | Cablelabs | D.Hancock@CableLabs.com | Rel-8 | Frederic |  |  |
| 851 | 351.3.3 | CT3 aspects of PktCbl-Sec |  | 180d? | 2007-03-26 A | 2007-11-30 A | 100% |  | 2007-03-26 | 2007-11-30 | 180d? |  | finish no earlier than 2008-03-15 | C3 | 1440h | 1440h | PktCbl-Intw | Cablelabs | D.Hancock@CableLabs.com | Rel-8 | Jiwan | PCG-21 | CP-38 |
| 852 | 351.3.4 | CT4 aspects of PktCbl-Sec |  | 255d? | 2007-03-26 A | 2008-03-14 A | 100% |  | 2007-03-26 | 2008-03-14 | 255d? |  | finish no earlier than 2008-03-14 | C4 | 2040h | 2040h | PktCbl-Sec | Cablelabs | D.Hancock@CableLabs.com | Rel-8 | Kimmo |  |  |
| 853 | 352 | **Maintenance of TISPAN documentation** |  | 1364d? | 2007-07-02 A | 2012-09-14 | 49% | 698.37d? | 2007-07-02 | 2012-09-14 | 1364d? | 323d |  | S2,C1,C3,C4,IETF | 17664h | 3740h | MAINTISP |  |  | Rel-8 | Maurice | PCG-21 | SP-38 |
| 854 | 352.1 | Maintenance of TISPAN R2 |  | 86d? | 2007-11-09 A | 2008-03-07 A | 100% |  | 2007-11-09 | 2008-03-07 | 86d? |  | start no earlier than 2007-11-09 | C1,C3,C4 | 688h | 688h | MAINT_R2 | Alcatel-Lucent | Keith Drage (drage@alcatel-lucent.com) | Rel-8 | Frederic | PCG-21 | CP-38 |
| 855 | 352.2 | (IETF) Maintenance of TISPAN R2 |  | 654d? | 2007-11-09 A | 2012-09-14 | 25% | 490.5d? | 2007-11-09 | 2012-09-14 | 654d? | 323d | finish no earlier than 2012-09-14 | C1-IETF | 5232h | 1308h | MAINT_R2_IETF | Andrew Allen |  | Rel-8 | Frederic | PCG-27 | CP-52 |
| 856 | 352.3 | Documentation of TISPAN NGN R1 and R2 in 3GPP SA2 |  | 104d? | 2008-01-14 A | 2008-06-05 A | 100% |  | 2008-01-14 | 2008-06-05 | 104d? |  | finish no earlier than 2008-06-20 | S2 | 832h | 832h | IMS_Comm_Doc | Nokia Siemens Networks | jozsef.varga@nsn.com | Rel-8 | Maurice | PCG-21 | SP-38 |
| 857 | 352.4 | Maintenance of TISPAN release 2 common IMS |  | 114d? | 2007-07-02 A | 2007-12-06 A | 100% |  | 2007-07-02 | 2007-12-06 | 114d? |  | finish no earlier than 2007-12-06 | S2 | 912h | 912h | IMS_Comm_Mtce8 | Telecom Italia | antonio.ascolese@telecomitalia.it | Rel-8 | Maurice | PCG-21 | SP-38 |
| 858 | 353 | **Security Enhancements for IMS** |  | 643.3d? | 2006-09-19 A | 2009-03-06 A | 100% |  | 2006-09-19 | 2009-03-06 | 643.3d? |  |  | S3,C1,C4 | 18624h | 18624h | IMS-Sec | Ericsson | Bengt.Sahlin@ericsson.com | Rel-8 | Dionisio |  | SP-37 |
| 859 | 353.1 | Stage 2 for IMS-Sec |  | 466d? | 2007-03-01 A | 2008-12-11 A | 100% |  | 2007-03-01 | 2008-12-11 | 466d? |  | finish no earlier than 2008-12-11 | S3 | 3728h | 3728h | IMS-Sec | Ericsson | Bengt.Sahlin@ericsson.com | Rel-8 | Dionisio |  |  |
| 860 | 353.2 | CT1 part of Stage 3 for IMS-Sec |  | 392d? | 2006-09-19 A | 2008-12-05 A | 100% |  | 2006-09-19 | 2008-12-05 | 392d? |  | finish no earlier than 2008-12-05 | C1 | 3136h | 3136h | IMS-Sec | Ericsson |  | Rel-8 | Frederic | PCG-21 | CP-39 |
| 861 | 353.3 | CT4 part of Stage 3 for IMS-Sec |  | 457d? | 2007-06-07 A | 2009-03-06 A | 100% |  | 2007-06-07 | 2009-03-06 | 457d? |  | finish no earlier than 2009-03-06 | C4 | 3656h | 3656h | IMS-Sec | Ericsson |  | Rel-8 | Kimmo | PCG-21 | CP-39 |
| 862 | 353.4 | CT1 part of Network Attachment Subsystem (NASS) Bundled Authentication |  | 343d? | 2007-11-14 A | 2009-03-06 A | 100% |  | 2007-11-14 | 2009-03-06 | 343d? |  | finish no earlier than 2009-03-06 | C1 | 2744h | 2744h | NBA | Alcatel-Lucent | Keith Drage (drage@alcatel-lucent.com) | Rel-8 | Frederic | PCG-21 | CP-39 |
| 863 | 353.5 | CT4 part of Network Attachment Subsystem (NASS) Bundled Authentication |  | 143d? | 2007-11-14 A | 2008-05-30 A | 100% |  | 2007-11-14 | 2008-05-30 | 143d? |  | start no earlier than 2007-11-14 | C4 | 1144h | 1144h | NBA-CT4 | Alcatel-Lucent |  | Rel-8 | Kimmo | PCG-21 | CP-39 |
| 864 | 354 | **IMS initiated and controlled PSS and MBMS User Service** |  | 924d? | 2008-03-12 A | 2011-09-21 A | 100% |  | 2008-03-12 | 2011-09-21 | 924d? |  |  | S4,S3,IETF | 13324.8h | 13324.8h | IMS_PSS_MBMS_US | FT, Ericsson | olle.franceschi@ericsson.com | Rel-8 | Paolo |  |  |
| 865 | 354.1 | SA4, SA3 part of IMS initiated and controlled PSS and MBMS User Service | milestone | 0d? | 2008-03-12 A | 2008-03-12 A | 100% |  | 2008-03-12 | 2008-03-12 | 0d? |  | finish no earlier than 2009-03-12 | S4,S3 |  |  | IMS_PSS_MBMS_US | FT, Ericsson | olle.franceschi@ericsson.com | Rel-8 | Paolo |  |  |
| 866 | 354.2 | (IETF) IMS initiated and controlled PSS and MBMS User Service |  | 743.6d? | 2008-03-12 A | 2011-09-21 A | 100% |  | 2008-03-12 | 2011-09-21 | 743.6d? |  | finish no earlier than 2011-09-21 | S4-IETF | 5932.8h | 5932.8h | IMS_PSS_MBMS_US_IETF_RFC6080 |  |  | Rel-8 | Paolo | PCG-27 | SP-52 |

Notes:
- 841: CP#40 completed
- 842: CP#40 completed
- 843: SP#38 completed / Text3: 23.228
- 844: CP#40 completed
- 845: CP#39 completed
- 846: SP#37 completed / Text3: 23.228
- 847: CP#39 completed / Text3: 24.229
- 848: CP#40 completed
- 849: SP#39 completed / Text3: 33.203, 33.210, 33.220
- 850: CP#40 completed / Text3: 24.229
- 851: CP#38 completed / Text3: 29.163
- 852: CP#39 completed / Text3: 29.228, 29.229, 23.008
- 853: SP#40 completed
- 854: CP#39 completed / Text3: 24.406, 24.407, 24.410, 24.411, 24.423, 24.430, 24.447, 24.451, 24.454, 24.503, 24.505, 24.508, 24.516, 24.528, 24.529, 29.412, 29.421, 29.433, 29.458, 29.527, 29.624
- 855: Not completed internet-draft / Text3: draft-avasarala-dispatch-comm-div-notification
- 856: SP#40 completed / Text3: 23.228, 23.204, 23.167
- 857: SP#38 completed / Text3: 23.506, 23.507,23.517, 23.521
- 858: CP#43 completed
- 859: SP#42 completed. SP#46 withdrawn draft 33.178-100 and 33.978 from Rel-8 onwards / Text3: 33.203, 33.141, 33.803
- 860: CP#42 completed
- 861: CP#43 completed
- 862: CP#43 completed / Text3: 24.229
- 863: CP#40 completed / Text3: 29.229, 29.228, 23.008
- 864: SP#39 WID approved
- 865: SP#43 completed / Text3: 26.234, 26.346, 33.246, new 26.237
- 866: SP#53/IETF#81: RFC 6080 included in 26.237 / Text3: draft-ietf-sipping-config-framework

| ID | WBS | Task | Duration | Start | Finish | Complete | Remaining | Baseline start | Baseline finish | Baseline duration | Total slack | Constraint | Resources | Work | Actual work | Text1 | Text4 | Text5 | Text6 | Text8 | Text3 | Text2 | Text7 |
| --- | --- | --- | --- | --- | --- | --- | --- | --- | --- | --- | --- | --- | --- | --- | --- | --- | --- | --- | --- | --- | --- | --- | --- |
| 867 | 355 | **Multimedia interworking between IMS and CS networks** | 836d? | 2005-09-23 A | 2008-12-05 A | 100% |  | 2005-09-23 | 2008-12-05 | 836d? |  |  | C3,C4 | 16112h | 16112h | MIW-IMS | Vodafone | nico.gabriele@vodafone.com | Rel-8 | Jiwan |  |  |  |
| 868 | 355.1 | Stage 1 and 2 defined in earlier Releases | 49d? | 2005-09-23 A | 2005-11-30 A | 100% |  | 2005-09-23 | 2005-11-30 | 49d? |  | start no earlier than 2005-09-23 | S2 | 392h | 392h | MIW-IMS | Vodafone | nico.gabriele@vodafone.com | Rel-8 | Maurice |  |  |  |
| 869 | 355.2 | Stage 3 of MW-IMS | 571d? | 2005-09-23 A | 2007-11-30 A | 100% |  | 2005-09-23 | 2007-11-30 | 571d? |  | finish no earlier than 2007-09-14 | C3 | 4568h | 4568h | MIW-IMS-St3 | Vodafone | nico.gabriele@vodafone.com | Rel-8 | Jiwan | 29.863, 29.163 |  |  |
| 870 | 355.3 | Stage 3 for MW-IMS, MONA extension | 285d? | 2007-11-05 A | 2008-12-05 A | 100% |  | 2007-11-05 | 2008-12-05 | 285d? |  | finish no earlier than 2008-12-05 | C3 | 2280h | 2280h | MIW-IMS | Vodafone | Christer.Holmberg@ericsson.com | Rel-8 | Jiwan | 29.863, 29.163 | PCG-21 | CP-38 |
| 871 | 355.4 | Mn interface (MGCF – IM MGW) | 273d? | 2007-11-21 A | 2008-12-05 A | 100% |  | 2007-11-21 | 2008-12-05 | 273d? |  | finish no earlier than 2008-12-19 | C4 | 2184h | 2184h | MIW-IMS | Vodafone | Christer.Holmberg@ericsson.com | Rel-8 | Kimmo | 29.332 | PCG-21 | CP-38 |
| 872 | 356 | **IMS Stage 3 IETF Protocol Alignment - phase 2** | 1370d? | 2007-06-22 A | 2012-09-14 | 63% | 502.77d? | 2007-06-22 | 2012-09-14 | 1370d? | 323d |  | C1,IETF | 26632h | 12179.2h | IMSProtoc2 | Alcatel-Lucent | Keith Drage (drage@alcatel-lucent.com) | Rel-8 | Frederic | 23.218, 24.229, 24.930 |  |  |
| 873 | 356.1 | CT1 aspects of IMS Stage 3 IETF Protocol Alignment - phase 2 | 446d? | 2007-06-22 A | 2009-03-06 A | 100% |  | 2007-06-22 | 2009-03-06 | 446d? |  | finish no earlier than 2009-03-06 | C1 | 3568h | 3568h | IMSProtoc2 | Alcatel-Lucent | Keith Drage (drage@alcatel-lucent.com) | Rel-8 | Frederic | 23.218, 24.229, 24.930 |  |  |
| 874 | 356.2 | (IETF) IMS Stage 3 IETF Protocol Alignment (draft-bakker-sipping-3gpp-ims-xml-body-handling) | 654d? | 2007-06-22 A | 2012-09-14 | 50% | 327d? | 2007-06-22 | 2012-09-14 | 654d? | 323d | finish no earlier than 2012-09-14 | C1-IETF | 5232h | 2616h | IMSProtoc2_IETF | Andrew Allen |  | Rel-8 | Frederic | draft-bakker-sipping-3gpp-ims-xml-body-handling | PCG-27 | CP-52 |
| 875 | 356.3 | (IETF) IMS Stage 3 IETF Protocol Alignment (draft-ietf-mmusic-ice-tcp) | 651d? | 2007-06-22 A | 2012-09-14 | 90% | 65.1d? | 2007-06-22 | 2012-09-14 | 651d? | 323d | finish no earlier than 2012-09-14 | C1-IETF | 5208h | 4687.2h | IMSProtoc2_IETF | Keith Drage |  | Rel-8 | Frederic | draft-ietf-mmusic-ice-tcp | PCG-27 | CP-52 |
| 876 | 356.4 | (IETF) IMS Stage 3 IETF Protocol Alignment (draft-ietf-salud-alert-info-urns) | 654d? | 2007-06-22 A | 2012-09-14 | 25% | 490.5d? | 2007-06-22 | 2012-09-14 | 654d? | 323d | finish no earlier than 2012-09-14 | C1-IETF | 5232h | 1308h | IMSProtoc2_IETF | Roland Jesske |  | Rel-8 | Frederic | draft-ietf-salud-alert-info-urns | PCG-27 | CP-52 |
| 877 | 357 | **Interworking between User-to-User Signalling (UUS) and SIP** | 1167.75d? | 2007-11-30 A | 2012-05-16 | 64% | 425.79d? | 2007-11-30 | 2012-05-16 | 1167.75d? | 410.25d |  | C1,C3,IETF | 24972h | 11283h | UUSIW | Huawei | Lili Yang (kadyyang@huawei.com) | Rel-8 | Kimmo |  | PCG-21 | CP-38 |
| 878 | 357.1 | CT1 part of Stage 3 MGCF UUSIW | 266d? | 2007-11-30 A | 2008-12-05 A | 100% |  | 2007-11-30 | 2008-12-05 | 266d? |  | finish no earlier than 2008-12-05 | C1 | 2128h | 2128h | UUSIW | Huawei | Lili Yang (kadyyang@huawei.com) | Rel-8 | Frederic | 24.279, 24.229 | PCG-21 | CP-38 |
| 879 | 357.2 | (IETF) Stage 3 MGCF UUSIW (sip-uui) | 451d? | 2007-11-30 A | 2012-05-16 | 50% | 225.5d? | 2007-11-30 | 2012-05-16 | 451d? | 410.25d | finish no earlier than 2011-12-09 | C1-IETF,C3-IETF | 3608h | 1804h | UUSIW_IETF | Roland Jesske |  | Rel-8 | Frederic | draft-ietf-cuss-sip-uui | PCG-27 | CP-52 |
| 880 | 357.3 | (IETF) Stage 3 MGCF UUSIW (sip-uui-isdn) | 1167.75d? | 2007-11-30 A | 2012-05-16 | 50% | 583.88d? | 2007-11-30 | 2012-05-16 | 1167.75d? | 410.25d | start no earlier than 2007-11-30 | C1-IETF,C3-IETF | 9342h | 4671h | UUSIW_IETF | Keith Drage |  | Rel-8 |  | draft-ietf-cuss-sip-uui-isdn | PCG-28 | CP-55 |
| 881 | 357.4 | CT3 part of Stage 3 MGCF UUSIW | 335d? | 2007-11-30 A | 2009-03-12 A | 100% |  | 2007-11-30 | 2009-03-12 | 335d? |  | finish no earlier than 2009-03-12 | C3 | 2680h | 2680h | UUSIW | Huawei | Lili Yang (kadyyang@huawei.com) | Rel-8 | Jiwan | 29.163 | PCG-21 | CP-38 |
| 882 | 358 | **Support of Overlap signalling** | 331d? | 2007-11-30 A | 2009-03-06 A | 100% |  | 2007-11-30 | 2009-03-06 | 331d? |  |  | C3,C1,C4 | 10008.2h | 10008.2h | Overlap | Deutsche Telekom | r.jesske@telekom.de | Rel-8 | Jiwan |  | PCG-21 | CP-38 |
| 883 | 358.1 | Stage 3 Overlap (CT1) | 331d? | 2007-11-30 A | 2009-03-06 A | 100% |  | 2007-11-30 | 2009-03-06 | 331d? |  | finish no earlier than 2009-03-06 | C1 | 2648h | 2648h | Overlap | Deutsche Telekom | r.jesske@telekom.de | Rel-8 | Frederic | 24.229 | PCG-21 | CP-38 |
| 884 | 358.2 | Stage 3 Overlap (CT3) | 331d? | 2007-11-30 A | 2009-03-06 A | 100% |  | 2007-11-30 | 2009-03-06 | 331d? |  | finish no earlier than 2009-03-06 | C3 | 2648h | 2648h | Overlap | Deutsche Telekom | r.jesske@telekom.de | Rel-8 | Jiwan | 29.163 | PCG-21 | CP-38 |
| 885 | 358.3 | Stage 3 Overlap (CT4) | 258.02d? | 2007-11-30 A | 2008-12-05 A | 100% |  | 2007-11-30 | 2008-12-05 | 258.02d? |  | start no earlier than 2007-11-30 | C4 | 2064.16h | 2064.16h | Overlap | Deutsche Telekom | r.jesske@telekom.de | Rel-8 | Kimmo | 29.228, 29.229 | PCG-21 | CP-38 |
| 886 | 359 | **AS/MRFC Stage 2 and 3** | 1067d? | 2007-11-14 A | 2011-12-09 | 96% | 47.65d? | 2007-11-14 | 2011-12-09 | 1067d? | 523d |  | C1,IETF | 14368h | 7695.2h | MRFC_TS | Hewlett-Packard | mark.syrett@hp.com | Rel-8 | Frederic |  | PCG-21 | CP-38 |
| 887 | 359.1 | AS/MRFC Stage 2 | 278d? | 2007-11-14 A | 2008-12-05 A | 100% |  | 2007-11-14 | 2008-12-05 | 278d? |  | finish no earlier than 2008-12-05 | C1 | 2224h | 2224h | MRFC_TS | Hewlett-Packard | mark.syrett@hp.com | Rel-8 | Frederic | 23.218 | PCG-21 | CP-38 |
| 888 | 359.2 | AS/MRFC Stage 3 | 278d? | 2007-11-14 A | 2008-12-05 A | 100% |  | 2007-11-14 | 2008-12-05 | 278d? |  | finish no earlier than 2008-12-05 | C1 | 2224h | 2224h | MRFC_TS | Hewlett-Packard | mark.syrett@hp.com | Rel-8 | Frederic | 24.229, 24.147, 24.247 | PCG-21 | CP-38 |
| 889 | 359.3 | (IETF) AS/MRFC Stage 2 and 3 | 454d? | 2007-11-14 A | 2011-12-09 | 90% | 45.1d? | 2007-11-14 | 2011-12-09 | 454d? | 523d | finish no earlier than 2011-12-09 | C1-IETF | 3608h | 3247.2h | MRFC_TS_IETF | Keith Drage |  | Rel-8 | Frederic | draft-ietf-mediactrl-mixer-control-package | PCG-27 | CP-52 |
| 890 | 360 | **IMS Restoration Procedures** | 201d? | 2008-05-30 A | 2009-03-06 A | 100% |  | 2008-05-30 | 2009-03-06 | 201d? |  |  | C4,C1 | 4824h | 4824h | IMS_RP | Ericsson | german.blanco@ericsson.com | Rel-8 | Kimmo |  | PCG-21 | SP-40 |
| 891 | 360.1 | IMS Restoration Procedures (CT4) | 201d? | 2008-05-30 A | 2009-03-06 A | 100% |  | 2008-05-30 | 2009-03-06 | 201d? |  | finish no earlier than 2009-03-06 | C4 | 1608h | 1608h | IMS_RP | Ericsson | german.blanco@ericsson.com | Rel-8 | Kimmo | 23.380, 29.228, 29.229, 29.230, 23.008 | PCG-21 | SP-40 |
| 892 | 360.2 | IMS Restoration Procedures (CT1) | 201d? | 2008-05-30 A | 2009-03-06 A | 100% |  | 2008-05-30 | 2009-03-06 | 201d? |  | finish no earlier than 2009-03-06 | C1 | 1608h | 1608h | IMS_RP | Ericsson | german.blanco@ericsson.com | Rel-8 | Frederic | 24.229 | PCG-21 | SP-40 |
| 893 | 361 | IMS Application Server Service Data Descriptions for AS interoperability | 125d? | 2008-09-12 A | 2009-03-06 A | 100% |  | 2008-09-12 | 2009-03-06 | 125d? |  | finish no earlier than 2009-03-06 | C4 | 1000h | 1000h | IMS_ASIO | Alcatel-Lucent | nhberry@alcatel-lucent.com | Rel-8 | Kimmo | 29.328, 29.329, 29.364 | PCG-21 | CP-41 |

Notes:
- 867: CP#42 completed
- 868: SP#31 Moved from FS section Feb 2006
- 869: Moved from Rel-7. Feature extended in Rel-8 by including Stage 3 covering MONA UID_380021
- 870: CP#42 completed
- 871: CP#42 completed
- 872: CP#43 completed
- 873: CP#43 completed
- 874: Not completed internet-draft
- 875: RFC editors queue
- 876: Not completed internet-draft
- 877: CP#43 completed
- 878: CP#42 completed
- 879: Not completed internet-draft
- 880: Not completed internet-draft
- 881: CP#43 completed
- 882: CP#43 completed
- 883: CP#43 completed
- 884: CP#43 completed
- 885: CP#42 completed
- 886: CP#42 completed. Triggered by Study UID_7048 (MRFC)
- 887: -
- 888: -
- 889: RFC editors queue - miss ref, AUTH48
- 890: CP#43 completed. Triggered by Study TR 23.820 (FS_IMS_RP) UID_350018
- 891: CP#43 completed
- 892: CP#43 completed
- 893: CP#43 completed. Triggered by UID_360030 (FS_IMS_ASIO)

| ID | WBS | Task | Duration | Start | Finish | Complete | Baseline start | Baseline finish | Baseline duration | Constraint | Resources | Work | Actual work | Text1 | Text4 | Text6 | Text7 | Text8 | Text2 | Text11 | Text12 |
| --- | --- | --- | --- | --- | --- | --- | --- | --- | --- | --- | --- | --- | --- | --- | --- | --- | --- | --- | --- | --- | --- |
| 894 | 362 | **Mobility between 3GPP-WLAN Interworking and 3GPP Systems** | 386d? | 2007-09-14 A | 2009-03-06 A | 100% | 2007-09-14 | 2009-03-06 | 386d? |  | S2,C1 | 6216h | 6216h | IWLAN_Mob | Orange | Rel-8 | SP-37 | Maurice |  |  |  |
| 895 | 362.1 | Stage 2 for Mobility between 3GPP-WLAN Interworking and 3GPP Systems | 190d? | 2007-09-14 A | 2008-06-05 A | 100% | 2007-09-14 | 2008-06-05 | 190d? | finish no earlier than 2008-09-08 | S2 | 1520h | 1520h | IWLAN_Mob | Orange | Rel-8 | SP-38 | Maurice | PCG-21 |  |  |
| 896 | 362.2 | CT1 aspects of Mobility between 3GPP-WLAN Interworking and 3GPP Systems | 201d? | 2008-05-30 A | 2009-03-06 A | 100% | 2008-05-30 | 2009-03-06 | 201d? | finish no earlier than 2009-03-06 | C1 | 1608h | 1608h | IWLAN_Mob | Orange | Rel-8 | CP-40 | Frederic | PCG-21 |  |  |
| 897 | 363 | Conformance Test Aspects – Mobility between 3GPP WLAN Interworking and 3GPP Systems | 206d? | 2009-12-04 A | 2010-09-17 A | 100% | 2009-12-04 | 2010-09-17 | 206d? | finish no earlier than 2010-09-17 | R5 | 1648h | 1648h | IWLAN_Mob_UEConTest | Qualcomm | Rel-8 | RP-46 | Ingbert | PCG-24 | RP-100740 |  |
| 898 | 364 | eCall data transfer Phase 2: Comparison of alternative in-band modem solutions and standardization of one in-band modem solution | 472d? | 2007-12-06 A | 2009-09-24 A | 100% | 2007-12-06 | 2009-09-24 | 472d? | finish no earlier than 2009-09-24 | S4 | 3768.09h | 3768.09h | eCall_Phase2 | Airbiquity | Rel-8 |  | Paolo |  |  |  |
| 899 | 365 | eCall Conformance Testing | 261d? | 2009-09-04 A | 2010-09-03 A | 100% | 2009-09-04 | 2010-09-03 | 261d? | finish no earlier than 2010-09-03 | G3new | 2088h | 2088h | eCall_MSTest | Ericsson, Qualcomm | Rel-8 | GP-45 | Ingbert | PCG-23 |  |  |
| 900 | 366 | Conformance Test Aspects – non-modem procedures of eCall sessions in UTRA | 186d? | 2009-09-18 A | 2010-06-04 A | 100% | 2009-09-18 | 2010-06-04 | 186d? | finish no earlier than 2010-06-04 | R5 | 1488h | 1488h | UMTS_eCall_UEConTest | Ericsson, Qualcomm | Rel-8 | RP-45 | Ingbert | PCG-23 | RP-100489 |  |
| 901 | 367 | Conformance Test Aspects – UMTS Earthquake and Tsunami Warning System (ETWS) FDD | 207d? | 2009-05-29 A | 2010-03-12 A | 100% | 2009-05-29 | 2010-03-12 | 207d? | finish no earlier than 2010-03-12 | R5 | 1656h | 1656h | ETWS_UMTS_UEConTestFDD | NTT DoCoMo | Rel-8 | RP-44 | Ingbert | PCG-23 | RP-100068 |  |
| 902 | 368 | Conformance Test Aspects – Paging Permission with Access Control (PPAC) | 61d? | 2010-09-17 A | 2010-12-10 A | 100% | 2010-09-17 | 2010-12-10 | 61d? | finish no earlier than 2010-12-10 | R5 | 488h | 488h | PPAC_UEConTest | NTT DoCoMo | Rel-8 | RP-49 | Ingbert | PCG-25 | RP-101074 |  |
| 903 | 369 | **UTRA HNB** | 326d? | 2008-03-07 A | 2009-06-04 A | 100% | 2008-03-07 | 2009-06-04 | 326d? |  | RP,S5 | 6832h | 6832h | HNB |  | Rel-8 | SP-39 | Issam | PCG-21 |  |  |
| 904 | 369.1 | Support of UTRA HNB | 201d? | 2008-05-30 A | 2009-03-06 A | 100% | 2008-05-30 | 2009-03-06 | 201d? | finish no earlier than 2009-03-06 | R2 | 1608h | 1608h | HNB-supp | Huawei | Rel-8 | SP-40 | Joern | PCG-21 | RP-090040 |  |
| 905 | 369.2 | UTRAN Architecture for 3G HNB | 136d? | 2008-05-30 A | 2008-12-05 A | 100% | 2008-05-30 | 2008-12-05 | 136d? | finish no earlier than 2008-12-05 | R3 | 1088h | 1088h | HNB-arch | Alcatel-Lucent | Rel-8 | SP-40 | Juha | PCG-21 | RP-090042 |  |
| 906 | 369.3 | FDD Home NodeB RF requirements | 261d? | 2008-03-07 A | 2009-03-06 A | 100% | 2008-03-07 | 2009-03-06 | 261d? | finish no earlier than 2009-03-06 | R4 | 2088h | 2088h | HNB-RF | Motorola | Rel-8 | SP-39 | Issam | PCG-21 | RP-090041 |  |
| 907 | 369.4 | 3G Home NodeB OAM&P Type 1 Management Interface | 127d? | 2008-12-11 A | 2009-06-04 A | 100% | 2008-12-11 | 2009-06-04 | 127d? | finish no earlier than 2009-06-04 | S5 | 1008h | 1008h | HNB-3G_OAM | Huawei | Rel-8 | SP-42 | Dionisio | PCG-22 |  |  |
| 908 | 370 | **UTRA HNB – UE Conformance Testing** | 327d? | 2009-03-06 A | 2010-06-04 A | 100% | 2009-03-06 | 2010-06-04 | 327d? |  | R5 | 5224h | 5224h | HNB-UEConTest |  | Rel-8 | RP-43 | Ingbert | PCG-22 |  |  |
| 909 | 370.1 | Conformance Test Aspects – UTRA HNB (FDD) | 326d? | 2009-03-06 A | 2010-06-04 A | 100% | 2009-03-06 | 2010-06-04 | 326d? | finish no earlier than 2010-06-04 | R5 | 2608h | 2608h | HNB-UEConTestFDD | Huawei | Rel-8 | RP-43 | Ingbert | PCG-22 | RP-100482 |  |
| 910 | 371 | Lawful Interception in the 3GPP Rel-8 | 524d? | 2007-03-12 A | 2009-03-12 A | 100% | 2007-03-12 | 2009-03-12 | 524d? | finish no earlier than 2009-03-12 | S3 | 4192h | 4192h | LI8 | BMWI, Verizon | Rel-8 |  | Dionisio |  |  |  |
| 911 | 372 | **Generic Bootstrapping Architecture Push Function** | 258d? | 2008-03-12 A | 2009-03-06 A | 100% | 2008-03-12 | 2009-03-06 | 258d? |  | S3,C1,C4 | 6468.8h | 6468.8h | GBAPush | Ericsson | Rel-8 | SP-39 | Dionisio | PCG-21 |  |  |
| 912 | 372.1 | SA3 part of GBAPush (33.223) | 193d? | 2008-03-12 A | 2008-12-05 A | 100% | 2008-03-12 | 2008-12-05 | 193d? | finish no earlier than 2008-12-05 | S3 | 1544h | 1544h | GBAPush | Ericsson | Rel-8 | SP-39 | Dionisio | PCG-21 |  |  |
| 913 | 372.2 | CT1 part of GBAPush | 178.8d? | 2008-03-12 A | 2009-03-06 A | 100% | 2008-03-12 | 2009-03-06 | 178.8d? | finish no earlier than 2009-03-06 | C1 | 1430.4h | 1430.4h | GBAPush | Ericsson | Rel-8 | SP-39 | Frederic | PCG-21 |  |  |
| 914 | 372.3 | CT4 part of GBAPush | 178.8d? | 2008-03-12 A | 2009-03-06 A | 100% | 2008-03-12 | 2009-03-06 | 178.8d? | finish no earlier than 2009-03-06 | C4 | 1430.4h | 1430.4h | GBAPush | Ericsson | Rel-8 | SP-39 | Kimmo | PCG-21 |  |  |
| 915 | 373 | Requirements and Test methods for Wideband Terminals | 197d? | 2008-03-12 A | 2008-12-11 A | 100% | 2008-03-12 | 2008-12-11 | 197d? | start no earlier than 2008-03-12 | S4 | 1576h | 1576h | RETEM_WB_T | FT, Ericsson | Rel-8 |  | Paolo |  |  |  |
| 916 | 374 | Extending PSS and MBMS User Services for optimized Mobile TV | 266d? | 2007-12-06 A | 2008-12-11 A | 100% | 2007-12-06 | 2008-12-11 | 266d? | finish no earlier than 2008-12-11 | S4 | 2128h | 2128h | PSS_MBMS_OMTV | Ericsson | Rel-8 |  | Paolo |  |  |  |
| 917 | 375 | **Encoding formats, transport formats and media description signalling for interworking, QoE, and other enhancements to MTSI-MHI** | 331d? | 2007-12-06 A | 2009-03-12 A | 100% | 2007-12-06 | 2009-03-12 | 331d? |  | S4,C3,C4 | 9640h | 9640h | MTSI_eMHI | Ericsson, Qualcomm | Rel-8 | SP-40 | Paolo | PCG-21 |  |  |
| 918 | 375.1 | MTSI Video - Dynamic Rate Adaptation/Signalling of Image Size | 331d? | 2007-12-06 A | 2009-03-12 A | 100% | 2007-12-06 | 2009-03-12 | 331d? | finish no earlier than 2009-03-12 | S4 | 2648h | 2648h | MTSI_eMHI-DRASIS | Qualcomm, Samsung | Rel-8 |  | Paolo |  |  |  |
| 919 | 375.2 | CT3 part of Enhancement of interworking between MTSI and CS networks | 201d? | 2008-05-30 A | 2009-03-06 A | 100% | 2008-05-30 | 2009-03-06 | 201d? | finish no earlier than 2009-03-06 | C3 | 1608h | 1608h | MTSI_eMHI | Huawei | Rel-8 | CP-40 | Jiwan | PCG-21 |  |  |
| 920 | 375.3 | CT4 part of Enhancement of interworking between MTSI and CS networks | 201d? | 2008-05-30 A | 2009-03-06 A | 100% | 2008-05-30 | 2009-03-06 | 201d? | finish no earlier than 2009-03-06 | C4 | 1608h | 1608h | MTSI_eMHI | Huawei | Rel-8 | CP-40 | Kimmo | PCG-21 |  |  |
| 921 | 375.4 | Deleted - CT1 part of Enhancement of interworking between MTSI and CS networks | 141d? | 2008-05-30 A | 2008-12-12 A | 100% | 2008-05-30 | 2008-12-12 | 141d? | start no earlier than 2008-05-30 | C1 | 1128h | 1128h | MTSI_eMHI | Huawei | Rel-8 | CP-40 | Frederic | PCG-21 |  | CP-42 |

Notes:
- 894: CP#43 completed / Text5: xiaobao.chen@orange-ftgroup.com
- 895: SP#40 completed / Text3: new 23.327 / Text5: xiaobao.chen@orange-ftgroup.com
- 896: CP#43 completed / Text3: 24.303, new 24.327 / Text5: reina.nader@orange-ftgroup.com
- 897: RP#49 completed. Testing for Rel-8 UID_400013 CT1 aspects of mobility between 3GPP WLAN Interworking and 3GPP Systems (24.327) / Text3: 34.108, 34.123-1, 34.123-2, 34.123-3 / Text5: Patrick Stupar (pstupar@qualcomm.com)
- 898: SP#45 completed. Triggered by Study UID_360015 (eCALLIBMS). Linked to SA1 Feature UID_330005 (EData) / Text3: 26.267, 26.268, 26.269, 26.967, 26.969 / Text5: lhong@airbiquity.com & rrobinson@airbiquity.com
- 899: GP#47 completed. GP#43 WID approved. Testing for Rel-8 eCall_Phase2 (UID_34042) and EData (UID_330005) / Text3: 51.010-1, 51.010-2 / Text5: Vikrant Jain (vikrantj@qualcomm.com)
- 900: RP#48 completed. Testing for Rel-8 eCall_Phase2 (UID_34042) and Edata (UID_330005) / Text3: 34.108, 34.123-1, 34.123-2, 34.123-3 / Text5: Shubhang Vora (svora@qualcomm.com)
- 901: RP#47 completed. Testing for Rel-8 ETWS UID_370051 / Text3: 34.108, 34.123-1, 34.123-2 / Text5: Makoto Ito (itohm@nttdocomo.co.jp)
- 902: RP#50 completed / Text3: UTRA 34.108, 34.123-1, 34.123-2, 34.123-3 / Text5: Takao.Shimizu.rp@nttdocomo.com
- 903: SP#44 completed
- 904: RP#43 completed / Text3: 25.304, 25.306, 25.331, new 25.367 / Text5: Yang Xudong (yangxudong@huawei.com)
- 905: RP#42 completed / Text3: 25.401, 25.410, 25.412, 25.413, 25.414, 25.415, new (25.467, 25.468, 25.469) / Text5: Martin Warner (mw15@alcatel-lucent.com)
- 906: RP#43 completed / Text3: 25.104, 25.141, new 25.967 / Text5: Ying Cai (yingcai@motorola.com)
- 907: SP#44 completed. Complements work in BroadBand Forum / Text3: new (32.581, 32.582, 32.583, 32.584) / Text5: Zou Lan (zlan@huawei.com)
- 908: RP#48 FDD completed. Testing for Feature UID_390033 UTRA HNB
- 909: RP#48 completed / Text3: 34.108, 34.123-1, 34.123-2, 34.123-3 / Text5: Trica Li (trica_li@huawei.com)
- 910: SP#43 completed / Text3: 33.106, 33.107, 33.108 / Text5: berthold.wilhelm@bnetza.de, ron_ryan@verizon.net
- 911: CP#43 completed / Text5: Rolf Blom
- 912: SP#42 completed 33.223 as Rel-8. TS 33.224 moved to Rel-9 under new UID_420039 / Text3: 33.223 / Text5: Rolf Blom
- 913: CP#43 completed / Text3: 24.109 / Text5: Rolf Blom
- 914: CP#43 completed / Text3: 29.109 / Text5: Rolf Blom
- 915: SP#42 completed. SP#39 WID approved. / Text3: 26.131, 26.132 / Text5: stephane.ragot@orange-ftgroup.com, wanqing.shi@sonyericsson.com
- 916: SP#42 completed. SP#38 WID approved. / Text3: 26.234, 26.346, 26.946 / Text5: thorsten.lohmar@ericsson.com
- 917: TSG#43 completed / Text5: olle.franceschi@ericsson.com, nleung@qualcomm.com
- 918: SP#43 completed / Text3: 26.114 / Text5: nleung@qualcomm.com & kyunghun.jung@samsung.com
- 919: CP#43 completed / Text3: 29.163 / Text5: Tingfang Tang (tagna_online@huawei.com)
- 920: CP#43 completed / Text3: 29.332 / Text5: Tingfang Tang (tagna_online@huawei.com)
- 921: CP#42 stopped (No CT1-impact). WID updated CP-080422=>CP-080774 / Text5: Tingfang Tang (tagna_online@huawei.com)

| ID | WBS | Task | Duration | Start | Finish | Complete | Remaining | Baseline start | Baseline finish | Baseline duration | Total slack | Constraint | Resources | Work | Actual work | Text1 | Text6 | Text8 | Text4 | Text2 | Text7 | Text9 | Text12 |
| --- | --- | --- | --- | --- | --- | --- | --- | --- | --- | --- | --- | --- | --- | --- | --- | --- | --- | --- | --- | --- | --- | --- | --- |
| 922 | 376 | **Rel-8 Operations, Administration, Maintenance and Provisioning (OAM&P)** | 1381d? | 2007-06-07 A | 2012-09-14 | 89% | 156.37d? | 2007-06-07 | 2012-09-14 | 1381d? | 323d |  | S5,C1,C4,IETF | 60382.4h | 39626.4h | OAM8 | Rel-8 | Dionisio |  |  |  |  |  |
| 923 | 376.1 | **Rel-8 Network Infrastructure Management** | 653d? | 2007-06-07 A | 2009-12-04 A | 100% |  | 2007-06-07 | 2009-12-04 | 653d? |  |  | S5 | 19464h | 19464h | OAM8-NIM | Rel-8 | Dionisio |  |  |  |  |  |
| 924 | 376.1.1 | Telecom Management Methodology | 461d? | 2007-06-07 A | 2009-03-12 A | 100% |  | 2007-06-07 | 2009-03-12 | 461d? |  | finish no earlier than 2009-03-12 | S5 | 3688h | 3688h | OAM8 | Rel-8 | Dionisio | Ericsson |  |  |  |  |
| 925 | 376.1.2 | Advanced Alarming on Itf-N | 266d? | 2007-06-07 A | 2008-06-12 A | 100% |  | 2007-06-07 | 2008-06-12 | 266d? |  | finish no earlier than 2008-12-11 | S5 | 2128h | 2128h | OAM8 | Rel-8 | Dionisio | Nokia Siemens Networks |  |  |  |  |
| 926 | 376.1.3 | CN CS Bearer Transport Network (BTN) relative NRM | 266d? | 2007-06-07 A | 2008-06-12 A | 100% |  | 2007-06-07 | 2008-06-12 | 266d? |  | finish no earlier than 2008-12-11 | S5 | 2128h | 2128h | OAM8 | Rel-8 | Dionisio | China Mobile |  |  |  |  |
| 927 | 376.1.4 | Alignment with eTOM and M.3060 architectural concepts | 210d? | 2008-02-22 A | 2008-12-11 A | 100% |  | 2008-02-22 | 2008-12-11 | 210d? |  | start no earlier than 2008-02-22 | S5 | 1680h | 1680h | OAM8 | Rel-8 | Dionisio | TeliaSonera | PCG-21 | SP-39 |  |  |
| 928 | 376.1.5 | IRP SOAP Solution Sets | 201d? | 2008-06-05 A | 2009-03-12 A | 100% |  | 2008-06-05 | 2009-03-12 | 201d? |  | finish no earlier than 2009-03-12 | S5 | 1608h | 1608h | OAM8 | Rel-8 | Dionisio | Ericsson | PCG-21 | SP-40 |  |  |
| 929 | 376.1.6 | Create missing specifications for IRP XML definitions | 52d? | 2009-09-24 A | 2009-12-04 A | 100% |  | 2009-09-24 | 2009-12-04 | 52d? |  | finish no earlier than 2010-03-12 | S5 | 416h | 416h | OAM8 | Rel-8 | Dionisio | ZTE | PCG-23 | SP-45 |  |  |
| 930 | 376.1.7 | Deleted - End point modelling for reference point | 324d? | 2007-09-17 A | 2008-12-11 A | 100% |  | 2007-09-17 | 2008-12-11 | 324d? |  | finish no earlier than 2008-12-11 | S5 | 2592h | 2592h | OAM8 | Rel-8 | Dionisio | Motorola |  | SP-37 | PCG-21 | SP-41 |
| 931 | 376.2 | **Rel-8 Performance Management** | 461d? | 2007-06-07 A | 2009-03-12 A | 100% |  | 2007-06-07 | 2009-03-12 | 461d? |  |  | S5 | 13712h | 13712h | OAM8-PM | Rel-8 | Dionisio |  |  |  |  |  |
| 932 | 376.2.1 | IP bearer network Performance measurement definitions | 396d? | 2007-06-07 A | 2008-12-11 A | 100% |  | 2007-06-07 | 2008-12-11 | 396d? |  | finish no earlier than 2008-12-11 | S5 | 3168h | 3168h | OAM8 | Rel-8 | Dionisio | China Mobile |  |  |  |  |
| 933 | 376.2.2 | HSUPA performance measurements | 396d? | 2007-06-07 A | 2008-12-11 A | 100% |  | 2007-06-07 | 2008-12-11 | 396d? |  | finish no earlier than 2008-12-11 | S5 | 3168h | 3168h | OAM8 | Rel-8 | Dionisio | China Mobile |  |  |  |  |
| 934 | 376.2.3 | Key Performance Indicators (KPIs) for UMTS and GSM | 461d? | 2007-06-07 A | 2009-03-12 A | 100% |  | 2007-06-07 | 2009-03-12 | 461d? |  | finish no earlier than 2009-03-12 | S5 | 3688h | 3688h | OAM8 | Rel-8 | Dionisio | China Mobile |  |  |  |  |
| 935 | 376.3 | **Rel-8 Trace Management** | 1185d? | 2008-03-07 A | 2012-09-14 | 62% | 447.52d? | 2008-03-07 | 2012-09-14 | 1185d? | 323d |  | S5,C1,C3,C4,IETF | 18286.4h | 6450.44h | OAM8-Trace | Rel-8 | Dionisio |  |  |  |  |  |
| 936 | 376.3.1 | CT1 part of Service Level Tracing in IMS | 196d? | 2008-03-07 A | 2008-12-05 A | 100% |  | 2008-03-07 | 2008-12-05 | 196d? |  | finish no earlier than 2008-12-05 | C1 | 1568h | 1568h | OAM8-Trace | Rel-8 | Frederic | Vodafone |  |  |  |  |
| 937 | 376.3.2 | (IETF) Service Level Tracing in IMS (draft-dawes-sipping-debug) | 654d? | 2008-03-07 A | 2012-09-14 | 25% | 490.5d? | 2008-03-07 | 2012-09-14 | 654d? | 323d | finish no earlier than 2012-09-14 | C1-IETF | 5232h | 1308h | OAM8-Trace_IETF | Rel-8 | Frederic | Peter Dawes | PCG-27 | CP-52 |  |  |
| 938 | 376.3.3 | (IETF) Service Level Tracing in IMS (draft-dawes-sipping-debug-event) | 98d? | 2008-03-07 A | 2011-12-09 A | 100% |  | 2008-03-07 | 2011-12-09 | 98d? |  | finish no earlier than 2011-12-09 | C1-IETF | 768.04h | 768.04h | OAM8-Trace_IETF | Rel-8 |  | Peter Dawes | PCG-27 | CP-53 |  |  |
| 939 | 376.3.4 | CT4 part of Service Level Tracing in IMS | 175.4d? | 2008-03-07 A | 2008-12-05 A | 100% |  | 2008-03-07 | 2008-12-05 | 175.4d? |  | finish no earlier than 2008-12-05 | C4 | 1403.2h | 1403.2h | OAM8-Trace | Rel-8 | Frederic | Vodafone | PCG-21 | CP-40 |  |  |
| 940 | 376.3.5 | Deleted - CT3 part of Service Level Tracing in IMS | 175.4d? | 2008-03-07 A | 2008-12-05 A | 100% |  | 2008-03-07 | 2008-12-05 | 175.4d? |  | finish no earlier than 2008-12-05 | C3 | 1403.2h | 1403.2h | OAM8-Trace | Rel-8 | Jiwan | Vodafone | PCG-21 | CP-40 |  | CP-42 |
| 941 | 377 | **Rel-8 Charging Management small Enhancements** | 716d? | 2006-03-16 A | 2008-12-11 A | 100% |  | 2006-03-16 | 2008-12-11 | 716d? |  |  | S5 | 12544h | 12544h | CH8 | Rel-8 | Dionisio |  |  |  |  |  |
| 942 | 377.1 | Online charging correlation | 457d? | 2006-03-16 A | 2007-12-14 A | 100% |  | 2006-03-16 | 2007-12-14 | 457d? |  | start no earlier than 2006-03-16 | S5 | 3656h | 3656h | CH8 | Rel-8 | Dionisio | Orange |  |  |  |  |
| 943 | 377.2 | SMS online charging | 137d? | 2007-06-07 A | 2007-12-14 A | 100% |  | 2007-06-07 | 2007-12-14 | 137d? |  | finish no earlier than 2007-12-14 | S5 | 1096h | 1096h | CH8 | Rel-8 | Dionisio | Vodafone |  |  |  |  |
| 944 | 377.3 | Introduce Online Charging from SMS-SC into the SMS Charging Specifications | 61d? | 2008-09-18 A | 2008-12-11 A | 100% |  | 2008-09-18 | 2008-12-11 | 61d? |  | finish no earlier than 2008-12-11 | S5 | 488h | 488h | CH8 | Rel-8 | Dionisio | Acision | PCG-21 | SP-41 |  |  |
| 945 | 377.4 | Deleted - WLAN Offline Charging | 244d? | 2008-01-07 A | 2008-12-11 A | 100% |  | 2008-01-07 | 2008-12-11 | 244d? |  | finish no earlier than 2008-12-11 | S5 | 1952h | 1952h | CH8 | Rel-8 | Dionisio | Alcatel-Lucent | PCG-21 | SP-38 | PCG-22 | SP-42 |

Notes:
- 922: - / Text3: TR 30.818
- 923: -
- 924: SP#43 completed / Text3: 32.155, 32.153 / Text5: thomas.tovinger@ericsson.com
- 925: SP#40 completed / Text3: 32.121, 32.122, 32.123 / Text5: SUERBAUM, Clemens
- 926: SP#40 completed / Text3: 32.632, 32.633, 32.635 / Text5: Li Jian (lijian@chinamobile.com)
- 927: SP#42 completed / Text3: 32.101/2, 32-series / Text5: tommy.berggren@teliasonera.com
- 928: SP#43 completed / Text3: 32.111-7, 32.617, 32.417, 32.367, 32.347, 32.111-1, 32.111-2, 32.111-3, 32.111-5, 32.307, 32.317, 32.341, 32.342, 32.343, 32.345, 32.361, 32.362, 32.363, 32.365, 32.411, 32.412, 32.413, 32.415, 32.611, 32.612, 32.613, 32.615, 32.625 / Text5: edwin.tse@ericsson.com
- 929: SP#46 completed. Create missing XML definitions specs for IRPs (Advanced Alarm Management, Communication Surveillance, Self-Configuration of Network Elements, Software Management) needed for implementation of Rel-8 Notification Log IRP (TS 32.33x) / Text3: new (32.125, 32.355, 32.505, 32.535), 32.150, 32.153, 32.335 / Text5: Shuqiang Huang (huangsq@zte.com.cn)
- 930: SP#41 Work stopped. Contributions related to E-UTRAN/EPC to be submitted to UID_380036 E-UTRAN NRM IRP/ UID_380037 EPC NRM IRP / Text3: 32.152, 32.62/3/4x, 32.73x / Text5: Yizhi Yao (yzyao@motorola.com)
- 931: - / Text5: Li Jian (lijian@chinamobile.com)
- 932: SP#42 completed / Text3: 32.321, 32.322, 32.323, 32.325 / Text5: lilianyuan@chinamobile.com
- 933: SP#42 completed / Text3: 32.405 / Text5: Li Jian (lijian@chinamobile.com)
- 934: SP#43 completed / Text3: 32.410 / Text5: Li Jian (lijian@chinamobile.com), Liang Shuangchun (liangshuangchun@cmdi.chinamobile.com)
- 935: -
- 936: CP#42 completed / Text3: 24.323, 24.229 / Text5: peter.dawes@vodafone.com
- 937: Not completed internet-draft / Text3: draft-dawes-dispatch-debug / Text5: peter.dawes@vodafone.com
- 938: CP#54 Draft removed from 3GPP documentation, covered by draft-dawes-sipping-debug / Text3: draft-dawes-sipping-debug-event / Text5: peter.dawes@vodafone.com
- 939: CP#42 completed / Text3: 29.228, 29.229 / Text5: peter.dawes@vodafone.com
- 940: CP#42 stopped (No CT3-impact) / Text5: peter.dawes@vodafone.com
- 941: SP#42 completed / Text3: TR 30.818
- 942: SP#38 completed / Text3: 32.296 / Text5: Chahine, Rony
- 943: SP#38 completed / Text3: 32.240, 32.299, new 32.274 / Text5: Gavin.Wong@vodafone.com
- 944: SP#42 completed. Linked to SA2 UID 32081 (Support of SMS over IP networks) and CT4 UID 340016 (Routeing of MT-SMS via the HPLMN). / Text3: 32.274, 32.299 / Text5: erik.gebler@acision.com
- 945: SP#42 stopped / Text3: 32.252, 32.298, 32.299 / Text5: Maryse.Gardella@alcatel.fr

| ID | WBS | Task | Type | Duration | Start | Finish | Complete | Baseline start | Baseline finish | Baseline duration | Constraint | Resources | Work | Actual work | Text1 | Text2 | Text4 | Text5 | Text6 | Text8 | Text7 | Text12 | Text11 |
| --- | --- | --- | --- | --- | --- | --- | --- | --- | --- | --- | --- | --- | --- | --- | --- | --- | --- | --- | --- | --- | --- | --- | --- |
| 946 | 378 | **Conferencing enhancements for Mp interface** |  | 266d? | 2007-11-30 A | 2008-12-05 A | 100% | 2007-11-30 | 2008-12-05 | 266d? |  | C4 | 6384h | 6384h | eMp | PCG-21 | Huawei | Chencheng@huawei.com | Rel-8 | Kimmo |  |  |  |
| 947 | 378.1 | Stage 2 for eMp |  | 266d? | 2007-11-30 A | 2008-12-05 A | 100% | 2007-11-30 | 2008-12-05 | 266d? | finish no earlier than 2008-12-11 | C4 | 2128h | 2128h | eMp | PCG-21 | Huawei | Chencheng@huawei.com | Rel-8 | Kimmo | CP-38 |  |  |
| 948 | 378.2 | Stage 3 for eMp |  | 266d? | 2007-11-30 A | 2008-12-05 A | 100% | 2007-11-30 | 2008-12-05 | 266d? | finish no earlier than 2008-12-05 | C4 | 2128h | 2128h | eMp | PCG-21 | Huawei | Chencheng@huawei.com | Rel-8 | Kimmo | CP-38 |  |  |
| 949 | 379 | **Contact Manager for 3GPP UICC applications** |  | 642d? | 2006-06-22 A | 2008-12-05 A | 100% | 2006-06-22 | 2008-12-05 | 642d? |  | C6 | 13352h | 13352h | eUPHBOOK |  | Gemalto | Jacques.seif@gemalto.com | Rel-8 | Xavier |  |  |  |
| 950 | 379.1 | Requirements for Contact Manager |  | 392d? | 2006-06-22 A | 2007-12-21 A | 100% | 2006-06-22 | 2007-12-21 | 392d? | finish no earlier than 2007-12-21 | C6 | 3136h | 3136h | eUPHBOOK-St1 |  | Gemalto | Jacques.seif@gemalto.com | Rel-8 | Xavier |  |  |  |
| 951 | 379.2 | External interface for eUPHBOOK |  | 220d? | 2007-05-07 A | 2008-03-07 A | 100% | 2007-05-07 | 2008-03-07 | 220d? | finish no earlier than 2008-03-07 | C6 | 1760h | 1760h | eUPHBOOK-Ext_Spec |  | Gemalto | Jacques.seif@gemalto.com | Rel-8 | Xavier |  |  |  |
| 952 | 379.3 | Internal interface for eUPHBOOK |  | 415d? | 2007-05-07 A | 2008-12-05 A | 100% | 2007-05-07 | 2008-12-05 | 415d? | finish no earlier than 2008-12-05 | C6 | 3320h | 3320h | eUPHBOOK-Int_Spec |  | Gemalto | Jacques.seif@gemalto.com | Rel-8 | Xavier | CP-37 |  |  |
| 953 | 379.4 | Deleted - Implementation of eUPHBOOK | milestone | 0d? | 2007-06-21 A | 2007-06-21 A | 100% | 2007-06-21 | 2007-06-21 | 0d? | start no earlier than 2007-06-21 | C6 |  |  | eUPHBOOK-St23 |  | Giesecke & Devrient | Claus Dietze | Rel-8 | Xavier |  | SP-33 |  |
| 954 | 380 | **Rel-8 LTE – 3G Long Term Evolution - Evolved Packet System RAN part** |  | 644d? | 2006-09-25 A | 2009-03-12 A | 100% | 2006-09-25 | 2009-03-12 | 644d? |  | RP,S5 | 44896h | 44896h | LTE |  | NTT DoCoMo | Takehiro Nakamura (nakamurata@nttdocomo.co.jp) | Rel-8 |  |  |  | RP-080741 |
| 955 | 380.1 | LTE – Physical Layer |  | 380d? | 2006-09-25 A | 2008-03-07 A | 100% | 2006-09-25 | 2008-03-07 | 380d? | finish no earlier than 2007-09-14 | R1 | 3040h | 3040h | LTE-Phys |  | NTT DoCoMo | Sadayuki Abeta | Rel-8 | Patrick |  |  | RP-080741 |
| 956 | 380.2 | LTE – Radio Interface Layer 2 and 3 Protocol Aspect |  | 575d? | 2006-09-25 A | 2008-12-05 A | 100% | 2006-09-25 | 2008-12-05 | 575d? | finish no earlier than 2008-12-11 | R2 | 4600h | 4600h | LTE-L23 |  | Nokia Siemens Networks | benoist.sebire@nokia.com | Rel-8 | Joern |  |  | RP-080741 |
| 957 | 380.3 | LTE – eUTRAN Interfaces |  | 575d? | 2006-09-25 A | 2008-12-05 A | 100% | 2006-09-25 | 2008-12-05 | 575d? | finish no earlier than 2008-12-11 | R3 | 4600h | 4600h | LTE-interfaces |  | Ericsson | Martin Israelsson | Rel-8 | Juha |  |  | RP-080741 |
| 958 | 380.4 | LTE – Evolved UTRA and UTRAN RF Radio Transmission/Reception, System Performance Requirements and Conformance Testing |  | 575d? | 2006-09-25 A | 2008-12-05 A | 100% | 2006-09-25 | 2008-12-05 | 575d? | finish no earlier than 2008-12-11 | R4 | 4600h | 4600h | LTE-RF |  | Nokia Siemens Networks | Tuomo Saynajakangas | Rel-8 | Issam |  |  | RP-080741 |
| 959 | 380.5 | LTE – FDD repeaters |  | 386d? | 2007-09-14 A | 2009-03-06 A | 100% | 2007-09-14 | 2009-03-06 | 386d? | finish no earlier than 2009-03-06 | R4 | 3088h | 3088h | LTE-Repeaters |  | Powerwave Technologies, Andrew Wireless | ralf.michanikl@andrew.com, Alf.Ahlstrom@pwav.com | Rel-8 | Issam | RP-37 |  | RP-090037 |
| 960 | 380.6 | **E-UTRAN Data Definitions** |  | 389d? | 2007-09-17 A | 2009-03-12 A | 100% | 2007-09-17 | 2009-03-12 | 389d? |  | S5 | 13096h | 13096h | E-UTRAN-OAM | PCG-21 |  |  | Rel-8 | Dionisio | SP-39 |  |  |
| 961 | 380.6.1 | Subscriber and Equipment Trace for E-UTRAN and EPC |  | 389d? | 2007-09-17 A | 2009-03-12 A | 100% | 2007-09-17 | 2009-03-12 | 389d? | finish no earlier than 2009-03-12 | S5 | 3112h | 3112h | E-UTRAN-OAM |  | Ericsson | robert.petersen@ericsson.com | Rel-8 | Dionisio | SP-37 |  |  |
| 962 | 380.6.2 | E-UTRAN Network Resource Model (NRM) Integration Reference Point (IRP) |  | 309d? | 2008-01-07 A | 2009-03-12 A | 100% | 2008-01-07 | 2009-03-12 | 309d? | finish no earlier than 2009-03-12 | S5 | 2472h | 2472h | E-UTRAN-OAM | PCG-21 | Ericsson | ELMDAHL, Per | Rel-8 | Dionisio | SP-38 |  |  |
| 963 | 380.6.3 | Performance measurements for E-UTRAN |  | 275d? | 2008-02-22 A | 2009-03-12 A | 100% | 2008-02-22 | 2009-03-12 | 275d? | finish no earlier than 2009-03-12 | S5 | 2200h | 2200h | E-UTRAN-OAM | PCG-21 | Motorola, Huawei | Yizhi Yao (yzyao@motorola.com) | Rel-8 | Dionisio | SP-39 |  |  |
| 964 | 380.6.4 | Key Performance Indicators (KPIs) for E-UTRAN |  | 275d? | 2008-02-22 A | 2009-03-12 A | 100% | 2008-02-22 | 2009-03-12 | 275d? | finish no earlier than 2009-03-12 | S5 | 2200h | 2200h | E-UTRAN-OAM | PCG-21 | Ericsson | ulf.hubinette@ericsson.com | Rel-8 | Dionisio | SP-39 |  |  |
| 965 | 380.7 | **Self-Organizing Networks (SON)** |  | 210d? | 2008-02-22 A | 2008-12-11 A | 100% | 2008-02-22 | 2008-12-11 | 210d? |  | S5 | 6720h | 6720h | LTE_SON-OAM | PCG-21 | Vodafone | GOMPAKIS, Panagiotis | Rel-8 | Dionisio | SP-39 |  |  |
| 966 | 380.7.1 | SON Concepts and requirements |  | 210d? | 2008-02-22 A | 2008-12-11 A | 100% | 2008-02-22 | 2008-12-11 | 210d? |  | S5 | 1680h | 1680h | LTE_SON-OAM | PCG-21 | Vodafone | GOMPAKIS, Panagiotis | Rel-8 | Dionisio | SP-39 |  |  |
| 967 | 380.7.2 | Self-Establishment of eNBs, including automated Software Management |  | 210d? | 2008-02-22 A | 2008-12-11 A | 100% | 2008-02-22 | 2008-12-11 | 210d? | start no earlier than 2008-02-22 | S5 | 1680h | 1680h | LTE_SON-OAM | PCG-21 | Nokia Siemens Networks | SUERBAUM, Clemens | Rel-8 | Dionisio | SP-39 |  |  |
| 968 | 380.7.3 | SON Automatic Neighbour Relations (ANR) List Management |  | 210d? | 2008-02-22 A | 2008-12-11 A | 100% | 2008-02-22 | 2008-12-11 | 210d? | finish no earlier than 2008-12-11 | S5 | 1680h | 1680h | LTE_SON-OAM | PCG-21 | Ericsson | edwin.tse@ericsson.com | Rel-8 | Dionisio | SP-39 |  |  |
| 969 | 381 | **Rel-8 LTE – Terminal Conformance Test Specification** |  | 657d? | 2007-06-01 A | 2009-12-04 A | 100% | 2007-06-01 | 2009-12-04 | 657d? |  | R5 | 17544h | 17544h | LTE-UEConTest |  |  |  | Rel-8 | Ingbert |  |  |  |
| 970 | 381.1 | 3G LTE – Terminal Protocol Conformance Test Specifications |  | 657d? | 2007-06-01 A | 2009-12-04 A | 100% | 2007-06-01 | 2009-12-04 | 657d? | finish no earlier than 2009-12-04 | R5 | 5256h | 5256h | LTE-UEConTest_SIG |  | NEC, Motorola | david.lecompte@nectech.fr, Jacob.John@motorola.com | Rel-8 | Ingbert |  |  | RP-091060 |
| 971 | 381.2 | LTE – Terminal Radio Transmission and Reception Conformance Test Specifications |  | 657d? | 2007-06-01 A | 2009-12-04 A | 100% | 2007-06-01 | 2009-12-04 | 657d? |  | R5 | 5256h | 5256h | LTE-UEConTest_RF |  | Agilent | andrea_leonardi@agilent.com | Rel-8 | Ingbert |  |  | RP-091059 |
| 972 | 381.3 | Deleted - LTE – Terminal Radio Transmission and Reception Conformance Test Specifications |  | 401d? | 2007-06-01 A | 2008-12-12 A | 100% | 2007-06-01 | 2008-12-12 | 401d? |  | R5 | 3208h | 3208h | LTE-UEConTest_RF |  | Agilent | andrea_leonardi@agilent.com | Rel-8 | Ingbert |  | RP-41 | RP-091059 |

Notes:
- 946: CP#42 completed
- 947: CP#42 completed / Text3: 23.333
- 948: CP#42 completed / Text3: 29.333
- 949: CP#42 completed. CP#40: WID updated CP-070622=>CP-080382. aka Enhanced USIM phonebook
- 950: CP#38 completed / Text3: 21.111
- 951: CP#39 completed / Text3: new 31.220
- 952: CP#42 completed / Text3: new 31.221
- 953: SP#33 stopped / Text3: 31.102
- 954: RP#43 completed. Role model for SAE/LTE system wide project management by SA2 in SP-060166 / Text3: LTE 36.300, 36.938
- 955: RP#39 completed / Text3: 36.201, 36.211, 36.212, 36.213, 36.214, 25.215, 25.225
- 956: RP#42 completed / Text3: 36.302, 36.304, 36.306, 36.314, 36.321, 36.322, 36.323, 36.331, 25.302, 25.304, 25.331
- 957: RP#42 completed / Text3: 36.401, 36.410, 36.411, 36.412, 36.413, 36.414, 36.420, 36.421, 36.422, 36.423, 36.424, 25.413
- 958: RP#42 completed. RP#47 abandoned draft 36.801, 36.803, 36.804 / Text3: 36.101, 36.104, 36.113, 36.124, 36.133, 36.141, 36.942, 25.123, 25.133
- 959: RP#43 completed. RP#47 create Rel-9 TR 36.956 (see R4-100386, RP-100320_RAN4 Report) / Text3: 36.106, 36.143, 25.113
- 960: SP#43 completed
- 961: SP#43 completed / Text3: 32.421, 2.422, 32.423, 2.441, 32.442, 32.443, 32.445
- 962: SP#43 completed / Text3: new (32.761, 32.762, 32.763, 32.765)
- 963: SP#43 completed / Text3: new 32.425
- 964: SP#43 completed / Text3: new (32.450, 32.451)
- 965: SP#42 completed (WT UID_390007 moved to Rel-9)
- 966: SP#42 completed / Text3: new 32.500
- 967: SP#42 completed / Text3: new (32.501, 32.502, 32.503, 32.531, 32.532, 32.533)
- 968: SP#42 completed / Text3: 32.761, 32.762, 32.763, 32.765, new 32.511
- 969: Testing for Feature UID_20068 (LTE)
- 970: RP#46 completed / Text3: 36.521-1, 36.521-2, 36.508, 36.509, 36.523-1, 36.523-2, 36.523-3
- 971: RP#46 completed. RP#50 TR 36.903 v100 for Approval / Text3: 36.521-1, 36.521-2, 36.521-3, new TR 36.903
- 972: RP#41 stopped / Text3: 36.521-1, 36.521-2, 36.521-3

| ID | WBS | Task | Duration | Start | Finish | Complete | Baseline start | Baseline finish | Baseline duration | Constraint | Resources | Work | Actual work | Text1 | Text6 | Text8 | Text4 | Text5 | Text11 | Text2 | Text7 | Text9 | Text12 |
| --- | --- | --- | --- | --- | --- | --- | --- | --- | --- | --- | --- | --- | --- | --- | --- | --- | --- | --- | --- | --- | --- | --- | --- |
| 973 | 382 | **Rel-8 Improvements of the Radio Interface** | 525d? | 2007-03-05 A | 2009-03-06 A | 100% | 2007-03-05 | 2009-03-06 | 525d? |  | RP | 18152h | 18152h | RInImp8 | Rel-8 | Issam |  |  |  |  |  |  |  |
| 974 | 382.1 | UMTS 1500 MHz | 140d? | 2007-03-05 A | 2007-09-14 A | 100% | 2007-03-05 | 2007-09-14 | 140d? | finish no earlier than 2007-09-14 | R4 | 1120h | 1120h | RInImp8-UMTS1500 | Rel-8 | Issam | NTT DoCoMo | Takehiro Nakamura (nakamurata@nttdocomo.co.jp) | RP-070526 |  |  |  |  |
| 975 | 382.2 | UMTS 700 MHz FDD | 325d? | 2007-03-05 A | 2008-05-30 A | 100% | 2007-03-05 | 2008-05-30 | 325d? | finish no earlier than 2008-06-12 | R4 | 2600h | 2600h | RInImp8-UMTS700 | Rel-8 | Issam | Nokia | Tuomo Saynajakangas | RP-080260 |  |  |  |  |
| 976 | 382.3 | UMTS 1880 MHz TDD | 126d? | 2008-09-12 A | 2009-03-06 A | 100% | 2008-09-12 | 2009-03-06 | 126d? | finish no earlier than 2009-03-09 | R4 | 1008h | 1008h | RInImp9-UMTS1880TDD | Rel-8 | Issam | CATT | Yuexia Song (songyuexia@datangmobile.cn) | RP-090044 | PCG-21 | RP-41 |  |  |
| 977 | 382.4 | UMTS 2300 MHz TDD LCR | 195d? | 2007-12-17 A | 2008-09-12 A | 100% | 2007-12-17 | 2008-09-12 | 195d? | finish no earlier than 2008-09-12 | R4 | 1560h | 1560h | RInImp8-UMTS2300TDD | Rel-8 | Issam | CATT | songyuexia@datangmobile.cn | RP-080517 | PCG-21 | RP-38 |  |  |
| 978 | 382.5 | Further Improved Minimum Performance Requirements for HSDPA UE (FDD) - Two-Branch Interference Cancellation | 265d? | 2007-03-05 A | 2008-03-07 A | 100% | 2007-03-05 | 2008-03-07 | 265d? | finish no earlier than 2008-03-12 | R4 | 2120h | 2120h | RInImp8-2BIC | Rel-8 | Issam | AT&T | Marc Grant | RP-080041 |  |  |  |  |
| 979 | 382.6 | CS Voice Service over HSPA | 167d? | 2007-07-19 A | 2008-03-07 A | 100% | 2007-07-19 | 2008-03-07 | 167d? |  | R2 | 1336h | 1336h | RInImp8-CsHspa | Rel-8 | Joern | Nokia Siemens Networks | woonhee.hwang@nsn.com | RP-080042 |  | RP-37 |  |  |
| 980 | 382.7 | Performance requirements for 15 code reception with 16QAM/QPSK (FDD) | 126d? | 2007-06-11 A | 2008-03-07 A | 100% | 2007-06-11 | 2008-03-07 | 126d? | finish no earlier than 2008-06-12 | R4 | 1008h | 1008h | RInImp8-Hsdpa15codes | Rel-8 | Issam | Vodafone | tim.frost@vodafone.com | RP-080043 |  | RP-37 |  |  |
| 981 | 382.8 | Deleted - UMTS 2300 MHz FDD/TDD | 400d? | 2007-03-05 A | 2008-09-12 A | 100% | 2007-03-05 | 2008-09-12 | 400d? | finish no earlier than 2008-12-11 | R4 | 3200h | 3200h | RInImp8-UMTS2300 | Rel-8 | Issam | AT&T | Marc Grant | RP-080515 |  |  | PCG-21 | RP-41 |
| 982 | 383 | **Rel-8 Improvements of the Radio Interface - UE Conformance Testing** | 396d? | 2007-06-01 A | 2008-12-05 A | 100% | 2007-06-01 | 2008-12-05 | 396d? |  | R5 | 6256h | 6256h | RInImp-UEConTest | Rel-8 | Ingbert |  |  |  |  |  |  |  |
| 983 | 383.1 | Conformance Test Aspects – CS Voice Service over HSPA | 336d? | 2007-06-01 A | 2008-09-12 A | 100% | 2007-06-01 | 2008-09-12 | 336d? | finish no earlier than 2008-09-12 | R5 | 2688h | 2688h | RInImp8-CsHspa_UEConTest | Rel-8 | Ingbert | Huawei | baoyi@huawei.com | RP-080542 |  |  |  |  |
| 984 | 383.2 | Conformance Test Aspects – Performance requirements for 15 code reception with 16QAM/QPSK (FDD) | 195d? | 2008-03-07 A | 2008-12-05 A | 100% | 2008-03-07 | 2008-12-05 | 195d? | finish no earlier than 2008-12-05 | R5 | 1560h | 1560h | RInImp8-UEConTest_ Hsdpa15codes | Rel-8 | Ingbert | Ericsson | Mikael.Ziren@Ericsson.com | RP-080818 | PCG-21 | RP-40 |  |  |
| 985 | 384 | **Rel-8 RAN improvements** | 520d? | 2007-06-04 A | 2009-05-29 A | 100% | 2007-06-04 | 2009-05-29 | 520d? |  | RP | 29776h | 29776h | RANimp | Rel-8 |  |  |  |  |  |  |  |  |
| 986 | 384.1 | Combination of 64QAM and MIMO for HSDPA (FDD) | 205d? | 2007-06-04 A | 2008-09-12 A | 100% | 2007-06-04 | 2008-09-12 | 205d? | finish no earlier than 2008-09-12 | R1 | 1640h | 1640h | RANimp-64QamMimoHsdpa | Rel-8 | Patrick | Ericsson | Johan.Bergman@ericsson.com | RP-080518 |  |  |  |  |
| 987 | 384.2 | Improved L2 for uplink | 186d? | 2007-09-14 A | 2008-05-30 A | 100% | 2007-09-14 | 2008-05-30 | 186d? | finish no earlier than 2008-05-30 | R2 | 1488h | 1488h | RANimp-UplinkL2dataRates | Rel-8 | Joern | Ericsson | Janne.Peisa@ericsson.com | RP-080265 |  | RP-37 |  |  |
| 988 | 384.3 | Enhanced Uplink for CELL_FACH State in FDD | 321d? | 2007-09-14 A | 2008-12-05 A | 100% | 2007-09-14 | 2008-12-05 | 321d? | finish no earlier than 2008-12-12 | R2 | 2568h | 2568h | RANimp-UplinkEnhState | Rel-8 | Joern | Nokia Siemens Networks | markus.wimmer@nsn.com | RP-080804 |  | RP-37 |  |  |
| 989 | 384.4 | Enhanced UE Discontinuous Reception (DRX) for FDD | 261d? | 2007-09-14 A | 2008-09-12 A | 100% | 2007-09-14 | 2008-09-12 | 261d? | finish no earlier than 2008-09-12 | R2 | 2088h | 2088h | RANimp-DRX | Rel-8 | Joern | Nokia | luis.barreto@nokia.com | RP-080520 |  | RP-37 |  |  |
| 990 | 384.5 | Enhancements for Serving Radio Network Subsystem (SRNS) Relocation Procedure | 261d? | 2007-09-14 A | 2008-09-12 A | 100% | 2007-09-14 | 2008-09-12 | 261d? | finish no earlier than 2008-09-12 | R3 | 2088h | 2088h | RANimp-SrnsReloc | Rel-8 | Juha | Nokia Siemens Networks | masatoshi.nakamata@nsn.com | RP-080521 |  | RP-37 |  |  |
| 991 | 384.6 | Enhancements for FDD HSPA Evolution | 321d? | 2007-09-14 A | 2008-12-05 A | 100% | 2007-09-14 | 2008-12-05 | 321d? | finish no earlier than 2008-12-05 | R3,R2 | 2568h | 2568h | RANimp-HSPAEvo | Rel-8 | Juha | Nokia Siemens Networks | masatoshi.nakamata@nsn.com | RP-080805 |  | RP-37 |  |  |
| 992 | 384.7 | 64QAM for 1.28 Mcps TDD HSDPA | 264d? | 2007-12-04 A | 2008-12-05 A | 100% | 2007-12-04 | 2008-12-05 | 264d? | finish no earlier than 2008-12-05 | R1 | 2112h | 2112h | RANimp-64Qam1.28TDD | Rel-8 | Patrick | ZTE | zfmail@zte.com.cn | RP-080806 | PCG-21 | RP-38 |  |  |
| 993 | 384.8 | Enhanced CELL_FACH state in 1.28 Mcps TDD | 264d? | 2007-12-04 A | 2008-12-05 A | 100% | 2007-12-04 | 2008-12-05 | 264d? | finish no earlier than 2008-12-12 | R2 | 2112h | 2112h | RANimp-EnhState1.28TDD | Rel-8 | Joern | ZTE | zhang.yincheng@zte.com.cn | RP-080807 | PCG-21 | RP-38 |  |  |
| 994 | 384.9 | Continuous Connectivity for packet data users for 1.28 Mcps TDD | 321d? | 2008-03-07 A | 2009-05-29 A | 100% | 2008-03-07 | 2009-05-29 | 321d? | finish no earlier than 2009-05-29 | R1 | 2568h | 2568h | RANimp-LCRCPC | Rel-8 | Patrick | TD Tech | chenying@td-tech.com | RP-090394 | PCG-21 | RP-39 |  |  |
| 995 | 384.10 | HSPA VoIP to WCDMA/GSM CS continuity | 261d? | 2008-03-07 A | 2009-03-06 A | 100% | 2008-03-07 | 2009-03-06 | 261d? | finish no earlier than 2009-03-06 | R2 | 2088h | 2088h | RANimp-HSPAVoIP | Rel-8 | Joern | Nokia | Simone.Provvedi@nokia.com | RP-090050 | PCG-21 | RP-39 |  |  |
| 996 | 384.11 | HS-DSCH Serving Cell Change Enhancements | 196d? | 2008-03-07 A | 2008-12-05 A | 100% | 2008-03-07 | 2008-12-05 | 196d? | finish no earlier than 2008-12-12 | R2 | 1568h | 1568h | RANimp-HSDSCH | Rel-8 | Joern | Ericsson | henrik.enbuske@ericsson.com | RP-080811 | PCG-21 | RP-39 |  |  |
| 997 | 384.12 | MIMO for 1.28 Mcps TDD. Linked to Rel-8 Study on Scope of future HSPA Evolution for 1.28 Mcps TDD (UID_370041) TR 25.824 | 201d? | 2007-11-01 A | 2009-03-06 A | 100% | 2007-11-01 | 2009-03-06 | 201d? | finish no earlier than 2009-05-29 | R1,R4 | 1608h | 1608h | RANimp-MIMOLCR | Rel-8 | Patrick | CATT | wangke@datangmobile.cn | RP-090313 | PCG-21 | RP-40 |  |  |
| 998 | 384.13 | Dual-Cell HSDPA operation on adjacent carriers | 140d? | 2008-05-30 A | 2008-12-11 A | 100% | 2008-05-30 | 2008-12-11 | 140d? | finish no earlier than 2009-05-29 | R1,R4 | 1120h | 1120h | RANimp-DCHSDPA | Rel-8 | Patrick | Ericsson | johan.bergman@ericsson.com | RP-080814 | PCG-21 | RP-40 |  |  |

Notes:
- 973: -
- 974: RP#37 completed / Text3: 25.101, 25.104, 25.133, 25.141, 25.331, 25.942, 25.306, 25.307, 34.121
- 975: RP#40 completed / Text3: 25.101, 25.104, 25.133, 25.141, 25.331, 25.942, 25.306, 25.307, 34.121
- 976: RP#43 completed / Text3: 25.102, 25.105, 25.113, 25.123, 25.142, 34.124, 25.307
- 977: RP#41 completed. RP#47 abandoned draft 25.828 / Text3: 25.102, 25.105, 25.113, 25.123, 25.142, 34.124, 25.306, 25.331, 34.122
- 978: RP#39 completed / Text3: 25.101
- 979: RP#39 completed / Text3: 25.323, 25.331, 25.322
- 980: RP#39 completed / Text3: 25.101
- 981: RP#41 stopped / Text3: 25.101, 25.104, 25.133, 25.141, 25.331, 25.942, 25.306, 25.307, 34.121
- 982: 05/08: Linked to Feature UID_20028 (RInImp)
- 983: RP#41 completed / Text3: 34.108, 34.123-1, 34.123-2, 34.123-3
- 984: RP#42 completed / Text3: 34.121-1, 34.121-2
- 985: -
- 986: RP#41 completed / Text3: 25.308, 25.211, 25.212, 25.213, 25.306, 25.331, 25.433, 25.435, 25.423, 25.425, 25.101, 25.104, 25.141
- 987: RP#40 completed. Linked to UID_370037 Enhanced Uplink for CELL_FACH State in FDD / Text3: 25.319, 25.301, 25.306, 25.321, 25.331, 25.433, 25.435, 25.423, 25.425, 25.427
- 988: RP#42 completed. Linked to UID_370036 Improved L2 for uplink / Text3: 25.309, 25.211, 25.214, 25.321, 25.331, 25.423, 25.433
- 989: RP#41 completed. Continuation of Rel-7 work item "Continuous connectivity for packet data users" UID_20046. / Text3: 25.306, 25.308, 25.321, 25.331, 25.423
- 990: RP#41 completed. Linked to UID_370040 Enhancements for FDD HSPA Evolution / Text3: 25.306, 25.308, 25.321, 25.331, 25.423, 25.433, 25.214, 25.133
- 991: RP#42 completed. Triggered by Rel-7 Study on Scope of future FDD HSPA Evolution (UID_20065) TR 25.999 / Text3: 25.401, 25.413, 25.420, 25.423, 25.427, 25.433, 25.446, 25.301, 25.346
- 992: RP#42 completed. Linked to Rel-8 Study on Scope of future HSPA Evolution for 1.28 Mcps TDD (UID_370041) TR 25.824 / Text3: 25.102, 25.105, 25.123, 25.142, 25.201, 25.221, 25.222, 25.223, 25.224, 25.306, 25.308, 25.321, 25.331, 25.423, 25.433
- 993: RP#42 completed. Linked to Rel-8 Study on Scope of future HSPA Evolution for 1.28 Mcps TDD (UID_370041) TR 25.824 / Text3: 25.123, 25.221, 25.222, 25.224, 25.301, 25.302, 25.304, 25.306, 25.308, 25.319, 25.321, 25.331, 25.401, 25.423, 25.425, 25.433, 25.435
- 994: RP#44 completed. Linked to Rel-8 Study on Scope of future HSPA Evolution for 1.28 Mcps TDD (UID_370041) TR 25.824 / Text3: 25.929, 25.308, 25.319
- 995: RP#43 completed / Text3: 25.331, 25.413
- 996: RP#42 completed / Text3: 25.101, 25.104, 25.133, 25.212, 25.214, 25.308, 25.321, 25.331, 25.423, 25.433
- 997: RP#43 completed / Text3: 25.201, 25.221, 25.222, 25.223, 25.224, 25.306, 25.308, 25.321, 25.331, 25.423, 25.433, 25.102, 25.105, 25.142
- 998: RP#42 completed. Triggered by UID_390032 Study on Dual-Cell HSDPA (withdrawn TR 25.825 v100). / Text3: 25.101, 25.104, 25.133, 25.141, 25.211, 25.212, 25.213, 25.214, 25.215, 25.306, 25.308, 25.321, 25.331, 25.423, 25.433

| ID | WBS | Task | Duration | Start | Finish | Complete | Baseline start | Baseline finish | Baseline duration | Constraint | Resources | Work | Actual work | Text1 | Text6 | Text8 | Text2 | Text4 | Text7 | Text11 |
| --- | --- | --- | --- | --- | --- | --- | --- | --- | --- | --- | --- | --- | --- | --- | --- | --- | --- | --- | --- | --- |
| 999 | 385 | **Rel-8 RAN improvements - UE Conformance Testing** | 602d? | 2008-05-30 A | 2010-09-17 A | 100% | 2008-05-30 | 2010-09-17 | 602d? |  | R5 | 29391.2h | 29391.2h | RANimp-UEConTest | Rel-8 | Ingbert |  |  |  |  |
| 1000 | 385.1 | Conformance Test Aspects – Combination of 64QAM and MIMO for HSDPA (FDD) | 322d? | 2008-09-12 A | 2009-12-04 A | 100% | 2008-09-12 | 2009-12-04 | 322d? | finish no earlier than 2009-12-04 | R5 | 2576h | 2576h | RANimp-UEConTest_64QamMimoHsdpa | Rel-8 | Ingbert | PCG-21 | Ericsson | RP-41 | RP-091058 |
| 1001 | 385.2 | Conformance Test Aspects – Improved L2 for uplink | 341d? | 2008-05-30 A | 2009-09-18 A | 100% | 2008-05-30 | 2009-09-18 | 341d? | finish no earlier than 2009-09-18 | R5 | 2728h | 2728h | RANimp-UEConTest_UplinkL2dataRates | Rel-8 | Ingbert | PCG-21 | Ericsson | RP-40 | RP-090712 |
| 1002 | 385.3 | Conformance Test Aspects – 1.28 Mcps TDD Improved L2 support for high data rates | 342d? | 2009-05-29 A | 2010-09-17 A | 100% | 2009-05-29 | 2010-09-17 | 342d? | finish no earlier than 2010-09-17 | R5 | 2736h | 2736h | RANimp-UEConTest_ImprovedL2LCRTDD | Rel-8 | Ingbert | PCG-23 | CATT | RP-44 | RP-100737 |
| 1003 | 385.4 | Conformance Test Aspects – 64QAM for 1.28 Mcps TDD HSDPA | 261d? | 2008-05-30 A | 2009-05-29 A | 100% | 2008-05-30 | 2009-05-29 | 261d? | finish no earlier than 2009-05-29 | R5 | 2088h | 2088h | RANimp-UEConTest_64Qam1.28TDD | Rel-8 | Ingbert | PCG-21 | ZTE | RP-40 | RP-090415 |
| 1004 | 385.5 | Conformance Test Aspects – Dual-Cell HSDPA operation on adjacent carriers | 391d? | 2008-12-05 A | 2010-06-04 A | 100% | 2008-12-05 | 2010-06-04 | 391d? | finish no earlier than 2010-06-04 | R5 | 3128h | 3128h | RANimp-UEConTest_DCHSDPA | Rel-8 | Ingbert | PCG-22 | Qualcomm | RP-42 | RP-100479 |
| 1005 | 385.6 | Conformance Test Aspects – Enhanced Uplink for CELL_FACH State in FDD | 326d? | 2009-03-06 A | 2010-06-04 A | 100% | 2009-03-06 | 2010-06-04 | 326d? | finish no earlier than 2010-06-04 | R5 | 2608h | 2608h | RANimp-UEConTest_EnhancedRACHCellFACHState | Rel-8 | Ingbert | PCG-22 | Nokia | RP-43 | RP-100483 |
| 1006 | 385.7 | Conformance Test Aspects – Receiver Type3i | 196d? | 2009-03-06 A | 2009-12-04 A | 100% | 2009-03-06 | 2009-12-04 | 196d? | finish no earlier than 2009-12-04 | R5 | 1568h | 1568h | RANimp-UEConTest_ReceiverType3i | Rel-8 | Ingbert | PCG-22 | Qualcomm | RP-43 | RP-091066 |
| 1007 | 385.8 | Conformance Test Aspects – Enhanced CELL_FACH State in LCR TDD | 341d? | 2009-05-30 A | 2010-09-17 A | 100% | 2009-05-30 | 2010-09-17 | 341d? | finish no earlier than 2010-09-17 | R5 | 2728h | 2728h | RANimp-UEConTest_EnhancedCellFACHStateLCRTDD | Rel-8 | Ingbert | PCG-23 | CATT | RP-44 | RP-100735 |
| 1008 | 385.9 | Conformance Test Aspects – Continuous Connectivity for packet data users for 1.28 Mcps TDD | 261d? | 2009-09-18 A | 2010-09-17 A | 100% | 2009-09-18 | 2010-09-17 | 261d? | finish no earlier than 2010-09-17 | R5 | 2088h | 2088h | RANimp-UEConTest_CPCLCRTDD | Rel-8 | Ingbert | PCG-23 | ZTE | RP-45 | RP-100739 |
| 1009 | 385.10 | Conformance Test Aspects – MIMO for 1.28 Mcps TDD | 186d? | 2009-09-18 A | 2010-06-04 A | 100% | 2009-09-18 | 2010-06-04 | 186d? | finish no earlier than 2010-06-04 | R5 | 1488h | 1488h | RANimp-UEConTest_MIMOLCRTDD | Rel-8 | Ingbert | PCG-23 | ZTE | RP-45 | RP-100660 |
| 1010 | 385.11 | Conformance Test Aspects – HS-DSCH Serving Cell Change Enhancements | 131d? | 2009-09-18 A | 2010-03-19 A | 100% | 2009-09-18 | 2010-03-19 | 131d? | finish no earlier than 2010-03-12 | R5 | 1048h | 1048h | HSDSCH_UEConTest | Rel-8 | Ingbert | PCG-23 | Qualcomm | RP-45 | RP-100077 |
| 1011 | 386 | 3.84 Mcps TDD MBSFN Integrated Mobile Broadcast | 395d? | 2007-06-04 A | 2008-12-05 A | 100% | 2007-06-04 | 2008-12-05 | 395d? |  | R1 | 3160h | 3160h | MBSFN-DOB | Rel-8 | Patrick |  | Ericsson |  | RP-080218 |
| 1012 | 387 | Conformance Test Aspects – 3.84 Mcps TDD MBSFN Integrated Mobile Broadcast | 211d? | 2009-05-30 A | 2010-03-19 A | 100% | 2009-05-30 | 2010-03-19 | 211d? | finish no earlier than 2010-03-19 | R5 | 1688h | 1688h | MBSFN_IMB_UEConTest | Rel-8 | Ingbert | PCG-23 | IPwireless | RP-44 | RP-100070 |
| 1013 | 388 | **GERAN support for GERAN - 3G Long Term Evolution interworking** | 1365d? | 2006-09-08 A | 2011-11-25 A | 100% | 2006-09-08 | 2011-11-25 | 1365d? |  | GP,G1,C1,G3new | 37200h | 37200h | GELTE | Rel-8 | Paolo |  | Nokia, Nokia Siemens Networks |  |  |
| 1014 | 388.1 | G1 part of GERAN support for GERAN - 3G Long Term Evolution interworking | 641d? | 2006-09-08 A | 2009-02-20 A | 100% | 2006-09-08 | 2009-02-20 | 641d? | finish no earlier than 2009-02-20 | G1 | 5128h | 5128h | GELTE | Rel-8 | Paolo |  | Nokia, Nokia Siemens Networks |  |  |
| 1015 | 388.2 | G2 part of GERAN support for GERAN - 3G Long Term Evolution interworking | 641d? | 2006-09-08 A | 2009-02-20 A | 100% | 2006-09-08 | 2009-02-20 | 641d? | finish no earlier than 2009-02-20 | G2 | 5128h | 5128h | GELTE | Rel-8 | Paolo |  | Nokia, Nokia Siemens Networks |  |  |
| 1016 | 388.3 | CT1 part of GERAN support for GERAN - 3G Long Term Evolution interworking | 641d? | 2006-09-08 A | 2009-02-20 A | 100% | 2006-09-08 | 2009-02-20 | 641d? | finish no earlier than 2009-02-20 | C1 | 5128h | 5128h | GELTE | Rel-8 | Paolo |  | Nokia, Nokia Siemens Networks |  |  |
| 1017 | 388.4 | Testing for GERAN support for GERAN - 3G Long Term Evolution interworking | 1363d? | 2006-09-08 A | 2011-11-25 A | 100% | 2006-09-08 | 2011-11-25 | 1363d? | finish no earlier than 2011-11-25 | G3new | 10896h | 10896h | GELTE | Rel-8 | Ingbert |  | Renesas Mobile |  |  |
| 1018 | 389 | U-TDOA Enhancement | 131d? | 2007-05-18 A | 2007-11-16 A | 100% | 2007-05-18 | 2007-11-16 | 131d? | finish no earlier than 2007-05-18 | GP | 1048h | 1048h | GUTEN | Rel-8 | Paolo |  | TruePosition |  |  |
| 1019 | 390 | **GAN Enhancements** | 604.2d? | 2007-05-15 A | 2009-09-04 A | 100% | 2007-05-15 | 2009-09-04 | 604.2d? |  | GP | 9432h | 9432h | GANENH | Rel-8 | Paolo |  | T-Mobile |  |  |
| 1020 | 390.1 | Update to GAN specifications | 126d? | 2007-08-31 A | 2008-02-22 A | 100% | 2007-08-31 | 2008-02-22 | 126d? | finish no earlier than 2008-02-22 | GP | 1008h | 1008h | GANENH-SPEC | Rel-8 | Paolo |  | T-Mobile |  |  |
| 1021 | 390.2 | Update TS 51.010 Mobile Station (MS) Conformance Specification for GAN Enhancements | 526d? | 2007-05-15 A | 2009-09-04 A | 100% | 2007-05-15 | 2009-09-04 | 526d? | finish no earlier than 2009-09-04 | G3new | 4208h | 4208h | GANENH-MStest | Rel-8 | Ingbert |  | T-Mobile |  |  |
| 1022 | 391 | **AoIP (A-interface over IP)** | 2335d? | 2000-01-03 A | 2008-12-11 A | 100% | 2000-01-03 | 2008-12-11 | 2335d? |  | GP,S4,C4,C1,C3 | 42500.1h | 42500.1h | AoIP | Rel-8 | Paolo | PCG-21 | China Mobile, Ericsson |  |  |
| 1023 | 391.1 | GERAN aspects of AoIP | 2321d? | 2000-01-03 A | 2008-11-21 A | 100% | 2000-01-03 | 2008-11-21 | 2321d? | finish no earlier than 2008-11-21 | GP | 18560h | 18560h | AoIP | Rel-8 | Paolo | PCG-21 | China Mobile, Ericsson | SP-40 |  |
| 1024 | 391.2 | Media Requirements for CS over IP based User Plane | 267d? | 2007-12-05 A | 2008-12-11 A | 100% | 2007-12-05 | 2008-12-11 | 267d? | finish no earlier than 2008-12-11 | S4 | 1996.09h | 1996.09h | AoIP-CSoIP | Rel-8 | Paolo | PCG-21 | China Mobile, Ericsson | SP-40 |  |

Notes:
- 999: Linked to Feature UID_20029 (RANimp)
- 1000: RP#46 completed. Testing for UID_360013 / Text3: 34.108, 34.121-1, 34.121-2, 34.123-1, 34.123-2 / Text5: leif.mattisson@ericsson.com
- 1001: RP#45 completed. Testing for UID_370036 / Text3: 34.108, 34.123-1, 34.123-2, 34.123-3 / Text5: leif.mattisson@ericsson.com
- 1002: RP#49 completed. Testing for Rel-7 UID_340039 Improved L2 support for high data rates and Rel-8 UID_370036 Improved L2 for uplink / Text3: 34.108, 34.123-1, 34.123-2, 34.123-3 / Text5: Xiaozhong Chen (chenxiaozhong@datangmobile.cn)
- 1003: RP#44 completed. Testing for UID_380075 / Text3: 34.108, 34.122, 34.123-1, 34.123-2, 34.123-3 / Text5: ma.zijiang@zte.com.cn
- 1004: RP#48 completed. Testing for UID_400052 / Text3: 34.108, 34.121-1, 34.121-2, 34.123-1, 34.123-2, 34.123-3 / Text5: Shubhang Vora (svora@qualcomm.com)
- 1005: RP#48 completed. Testing for UID_370037 / Text3: 34.108, 34.121-1, 34.121-2, 34.123-1, 34.123-2, 34.123-3 / Text5: jarkko.hellsten@nokia.com
- 1006: RP#46 completed. Testing for Receiver Type3i in 25.101 UE radio Tx and Rx FDD / Text3: 34.108, 34.121-1, 34.121-2 / Text5: Ashok Kumar Narayanaswamy (anarayan@qualcomm.com)
- 1007: RP#49 completed. Testing for UID_380076 / Text3: 34.108, 34.123-1, 34.123-2, 34.123-3 / Text5: Xiaozhong Chen (chenxiaozhong@datangmobile.cn)
- 1008: RP#49 completed. Testing for UID_390028 / Text3: 34.108, 34.123-1, 34.123-2, 34.123-3 / Text5: huang.he4@zte.com.cn
- 1009: PR#48 completed. Testing for UID_400050 / Text3: 34.108, 34.122, 34.123-1, 34.123-2, 34.123-3 / Text5: huang.chun2@zte.com.cn
- 1010: RP#47 completed. Testing for UID_390030 / Text3: 34.108, 34.121-1, 34.121-2, 34.123-1, 34.123-2, 34.123-3 / Text5: Shubhang Vora (svora@qualcomm.com)
- 1011: RP#42 completed. WID updated RP-070493=>RP-081124 (changed WI title "MBSFN Downlink Optimized Broadcast (DOB) 3.84 Mcps TDD" => "3.84Mcps TDD MBSFN Integrated Mobile Broadcast"). / Text3: 25.102, 25.105, 25.123, 25.201, 25.221, 25.222, 25.223, 25.224, 25.304, 25.306, 25.331, 25.346, 25.402, 25.433 / Text5: Lars.Lindbom@ericsson.com
- 1012: RP#47 completed. Testing for Rel-8 MBSFN-DOB UID_360008 / Text3: 34.108, 34.122, 34.123-1, 34.123-2, 34.123-3 / Text5: Phil Young (pyoung@ipwireless.com)
- 1013: GP#41 completed. GP#52 completed MS conformance testing / Text3: 44.018, 44.060, 45.002, 45.008, 45.010, 48.008, 48.018, 51.010 / Text5: sergio.parolari@nsn.com, vlora.rexhepi@nokia.com
- 1014: GP#41 completed / Text3: 43.055, 43.129, 43.246, 45.002, 45.008, 45.010 / Text5: sergio.parolari@nsn.com, vlora.rexhepi@nokia.com
- 1015: GP#41 completed / Text3: 44.018, 44.060, 48.008, 48.018 / Text5: sergio.parolari@nsn.com, vlora.rexhepi@nokia.com
- 1016: - / Text3: 24.008 / Text5: sergio.parolari@nsn.com, vlora.rexhepi@nokia.com
- 1017: GP#52 completed / Text3: 51.010 / Text5: deepa.kamath@renesasmobile.com
- 1018: GP#36 completed U-TDOA (Uplink Time Difference of Arrival) / Text3: 43.059, 45.008, 48.071 / Text5: Terry Brooks (terri.brooks@trueposition.com)
- 1019: GP#37 completed. GP#43 completed Testing / Text5: mohammed.versi@t-mobile.com
- 1020: GP#37 completed / Text3: 43.318, 44.318 / Text5: mohammed.versi@t-mobile.com
- 1021: GP#43 completed / Text3: 51.010 / Text5: mohammed.versi@t-mobile.com
- 1022: GP#40/TSG#42 completed . Triggered by TR 43.903 Study on A-interface over IP (AINTIP) UID_50589. / Text5: wangshuaiyu@chinamobile.com, paul.schliwa-bertling@ericsson.com
- 1023: GP#40 completed. GP#39 updated WID GP-080901=>GP-081362. / Text3: 48.001, 48.002, 48.008, 48.020, 49.008, 48.103 / Text5: wangshuaiyu@chinamobile.com, paul.schliwa-bertling@ericsson.com
- 1024: SP#42 completed / Text3: 26.102, 26.103, 26.202 / Text5: Karl.Hellwig@Ericsson.com

| ID | WBS | Task | Type | Duration | Start | Finish | Complete | Remaining | Baseline start | Baseline finish | Baseline duration | Total slack | Constraint | Resources | Work | Actual work | Text1 | Text2 | Text4 | Text6 | Text7 | Text8 | Text3 | Text12 | Text9 | Text11 |
| --- | --- | --- | --- | --- | --- | --- | --- | --- | --- | --- | --- | --- | --- | --- | --- | --- | --- | --- | --- | --- | --- | --- | --- | --- | --- | --- |
| 1025 | 391.3 | **Core Network Impacts for A-Interface User Plane over IP** |  | 136d? | 2008-05-30 A | 2008-12-05 A | 100% |  | 2008-05-30 | 2008-12-05 | 136d? |  |  | C4,C1,C3 | 3264h | 3264h | AoIP-CN | PCG-21 | Ericsson | Rel-8 | CP-40 | Kimmo |  |  |  |  |
| 1026 | 391.3.1 | CT4 part of Core Network Impacts for A-Interface User Plane over IP |  | 136d? | 2008-05-30 A | 2008-12-05 A | 100% |  | 2008-05-30 | 2008-12-05 | 136d? |  | start no earlier than 2008-05-30 | C4 | 1088h | 1088h | AoIP-CN | PCG-21 | Ericsson | Rel-8 | CP-40 | Kimmo | 23.205, 23.153, 23.231, 29.232 |  |  |  |
| 1027 | 391.3.2 | CT1 part of Core Network Impacts for A-Interface User Plane over IP |  | 68d? | 2008-05-30 A | 2008-12-05 A | 100% |  | 2008-05-30 | 2008-12-05 | 68d? |  | finish no earlier than 2008-12-05 | C1 | 544h | 544h | AoIP-CN | PCG-21 | Ericsson | Rel-8 | CP-40 | Frederic | 23.009 |  |  |  |
| 1028 | 391.3.3 | CT3 part of Core Network Impacts for A-Interface User Plane over IP |  | 68d? | 2008-05-30 A | 2008-12-05 A | 100% |  | 2008-05-30 | 2008-12-05 | 68d? |  | finish no earlier than 2008-12-05 | C3 | 544h | 544h | AoIP-CN | PCG-21 | Ericsson | Rel-8 | CP-40 | Jiwan | 29.007 |  |  |  |
| 1029 | 392 | New multicarrier BTS class |  | 261d? | 2007-08-31 A | 2008-08-29 A | 100% |  | 2007-08-31 | 2008-08-29 | 261d? |  | finish no earlier than 2008-08-29 | G1 | 2088h | 2088h | MCBTS |  | Alcatel-Lucent | Rel-8 |  | Paolo | 45.005, 45.050, 51.021 |  |  |  |
| 1030 | 393 | **Conformance testing for the Latency Reductions feature** |  | 532d? | 2008-02-22 A | 2010-03-05 A | 100% |  | 2008-02-22 | 2010-03-05 | 532d? |  |  | G1, G3new | 10592h | 10592h | CTLATRED | PCG-21 | Ericsson | Rel-8 |  | Paolo |  |  |  |  |
| 1031 | 393.1 | MS conformance testing for the Latency Reductions feature |  | 532d? | 2008-02-22 A | 2010-03-05 A | 100% |  | 2008-02-22 | 2010-03-05 | 532d? |  | finish no earlier than 2010-03-05 | G3new | 4248h | 4248h | CTLATRED-MStest | PCG-21 | Ericsson | Rel-8 |  | Ingbert | 51.010 |  |  |  |
| 1032 | 393.2 | BTS conformance testing for the Latency Reductions feature |  | 261d? | 2008-02-22 A | 2009-02-20 A | 100% |  | 2008-02-22 | 2009-02-20 | 261d? |  | finish no earlier than 2009-02-20 | G1 | 2088h | 2088h | CTLATRED-BTStest | PCG-21 | Ericsson | Rel-8 |  | Paolo | 51.021 |  |  |  |
| 1033 | 394 | MS conformance testing of changes introduced by WI "Support of Packet-switched Handover for GERAN A/Gb mode" |  | 196d? | 2008-02-22 A | 2008-11-21 A | 100% |  | 2008-02-22 | 2008-11-21 | 196d? |  | finish no earlier than 2008-11-21 | G3new | 1568h | 1568h | PSHCT-MStest | PCG-21 | Rohde & Schwarz | Rel-8 |  | Ingbert | 51.010 |  |  |  |
| 1034 | 395 | (Small) Technical Enhancements and Improvements for Rel-8 |  | 509d? | 2007-01-01 A | 2008-12-11 A | 100% |  | 2007-01-01 | 2008-12-11 | 509d? |  | finish no earlier than 2008-12-11 | All | 4072h | 4072h | TEI8 |  |  | Rel-8 |  | All |  |  |  |  |
| 1035 | 396 | (IETF) (Small) Technical Enhancements and Improvements for Rel-8 |  | 654d? | 2007-01-01 A | 2012-09-14 | 50% | 327d? | 2007-01-01 | 2012-09-14 | 654d? | 323d | finish no earlier than 2012-09-14 | C1-IETF | 5232h | 2616h | TEI8_IETF_draft-ietf-simple-msrp-cema | PCG-27 | Christer Holmberg | Rel-8 | CP-52 | Frederic | draft-ietf-simple-msrp-cema |  |  |  |
| 1036 | 397 | Test - (Small) Technical Enhancements and Improvements for Rel-8 |  | 672d? | 2007-03-07 A | 2010-12-24 A | 100% |  | 2007-03-07 | 2010-12-24 | 672d? |  | finish no earlier than 2010-12-24 | R5,G3new | 5376h | 5376h | TEI8_Test | PCG-21 |  | Rel-8 | RP-40 | Ingbert |  |  |  |  |
| 1037 | 398 | Deleted - was Rel7 - LCS for 3GPP Interworking WLAN | milestone | 0d? | 2007-09-28 A | 2007-09-28 A | 100% |  | 2007-09-28 | 2007-09-28 | 0d? |  | start no earlier than 2007-09-28 | S2 |  |  | LCS4_IWLAN |  | LG Electronics | Rel-8 |  | Maurice | 23.234, 23.271, 23.167 | SP-35 |  |  |
| 1038 | 399 | Deleted - never approved- FBI Phase 2 | milestone | 0d | 2007-09-28 A | 2007-09-28 A | 100% |  | 2007-09-28 | 2007-09-28 | 0d |  | start no earlier than 2007-09-28 | S2 |  |  | FBI2 |  | Nokia Siemens Networks | Rel-8 |  | Maurice |  | SP-38 |  |  |
| 1039 | 400 | **Deleted - Contact Manager Conformance Test specifications** |  | 471d? | 2008-06-02 A | 2010-03-19 A | 100% |  | 2008-06-02 | 2010-03-19 | 471d? |  |  | C6 | 11304h | 11304h | eUPHBOOK-Test | PCG-21 | Comprion, Gemalto | Rel-8 | CP-40 | Xavier |  | CP-47 | PCG-24 |  |
| 1040 | 400.1 | Deleted - Contact Manager for 3GPP UICC applications test specifications |  | 471d? | 2008-06-02 A | 2010-03-19 A | 100% |  | 2008-06-02 | 2010-03-19 | 471d? |  | finish no earlier than 2010-03-19 | C6 | 3768h | 3768h | eUPHBOOK-Test | PCG-21 | Comprion | Rel-8 | CP-40 | Xavier | 31.320 (external interface for communication with the ME) | CP-47 | PCG-24 |  |
| 1041 | 400.2 | Deleted - Contact Manager API for Java™ Card test specification |  | 471d? | 2008-06-02 A | 2010-03-19 A | 100% |  | 2008-06-02 | 2010-03-19 | 471d? |  | finish no earlier than 2010-03-19 | C6 | 3768h | 3768h | eUPHBOOK-Test | PCG-21 | Gemalto | Rel-8 | CP-40 | Xavier | 31.321 (internal interface (API)) | CP-47 | PCG-24 |  |
| 1042 | 401 | Deleted - MS conformance testing of Support of Conversational Services in A/Gb mode via the PS domain |  | 401d? | 2008-02-25 A | 2009-09-04 A | 100% |  | 2008-02-25 | 2009-09-04 | 401d? |  | finish no earlier than 2009-09-04 | G3new | 3208h | 3208h | SCSAGBCT-MStest | PCG-21 | Nokia | Rel-8 |  | Ingbert | 51.010 | GP-43 | PCG-23 |  |
| 1043 | 402 | Release 8 Studies |  | 1332d? | 2005-10-07 A | 2010-11-12 A | 100% |  | 2005-10-07 | 2010-11-12 | 1332d? |  | start no earlier than 2000-01-03 | CP,GP,RP,SP | 10656h | 10656h |  |  |  | Rel-8 |  | All |  |  |  |  |
| 1044 | 403 | **Study on 3GPP System Architecture Evolution** |  | 1115d? | 2004-12-03 A | 2009-03-12 A | 100% |  | 2004-12-03 | 2009-03-12 | 1115d? |  |  | S2,S3 | 23456h | 23456h | FS_SAE |  | Vodafone | Rel-8 |  | Maurice |  |  |  |  |
| 1045 | 403.1 | Stage 2 Interim conclusion for RAN Work to start |  | 990d? | 2004-12-03 A | 2008-09-18 A | 100% |  | 2004-12-03 | 2008-09-18 | 990d? |  | finish no earlier than 2005-09-23 | S2 | 7920h | 7920h | FS_SAE |  | Vodafone | Rel-8 |  | Maurice | 23.882 |  |  |  |
| 1046 | 403.2 | Stage 2 study on 3GPP architectural development |  | 704d? | 2006-01-09 A | 2008-09-18 A | 100% |  | 2006-01-09 | 2008-09-18 | 704d? |  | finish no earlier than 2007-09-28 | S2 | 5632h | 5632h | FS_SAE |  | Vodafone | Rel-8 |  | Maurice | 23.882 |  |  |  |
| 1047 | 403.3 | Security study for Inter-access mobility between non-3GPP and 3GPP system |  | 334d? | 2007-09-03 A | 2009-03-12 A | 100% |  | 2007-09-03 | 2009-03-12 | 334d? |  | finish no earlier than 2009-03-12 | S3 | 2672h | 2672h | FS_SAE |  | Nokia | Rel-8 |  | Dionisio | 33.821, 33.822 |  |  |  |
| 1048 | 404 | Study on Stage 2 aspects of IMS Service Brokering |  | 589d? | 2006-06-19 A | 2008-09-18 A | 100% |  | 2006-06-19 | 2008-09-18 | 589d? |  | finish no earlier than 2008-09-18 | S2 | 4712h | 4712h | FS_ISB_ST2 |  | Telcordia | Rel-8 |  | Maurice | 23.810 |  |  |  |
| 1049 | 405 | Study on IMS utilizing multicast bearer services |  | 447d? | 2006-03-22 A | 2007-12-06 A | 100% |  | 2006-03-22 | 2007-12-06 | 447d? |  | finish no earlier than 2007-12-03 | S2 | 3576h | 3576h | FS_MLTICAST-IMS |  | Nokia Siemens Networks | Rel-8 |  | Maurice | 23.847 |  |  |  |
| 1050 | 406 | Study on Multimedia Session Continuity |  | 291d? | 2007-04-26 A | 2008-06-05 A | 100% |  | 2007-04-26 | 2008-06-05 | 291d? |  | finish no earlier than 2008-06-05 | S2 | 2328h | 2328h | FS_MMSC |  | LG Electronics | Rel-8 |  | Maurice | 23.893 |  |  |  |
| 1051 | 407 | Study on Architecture of IMS based Customized Alerting Tone (CAT) |  | 208d? | 2007-12-04 A | 2008-09-18 A | 100% |  | 2007-12-04 | 2008-09-18 | 208d? |  | finish no earlier than 2008-09-08 | S2 | 1664h | 1664h | FS_CAT-St2 | PCG-21 | China Mobile | Rel-8 | SP-38 | Maurice | 23.872 |  |  |  |
| 1052 | 408 | Study on Home (e)NodeB Security |  | 321d? | 2007-12-20 A | 2009-03-12 A | 100% |  | 2007-12-20 | 2009-03-12 | 321d? |  | finish no earlier than 2009-03-10 | S3 | 2568h | 2568h | FS_HNB_Sec | PCG-21 | Huawei | Rel-8 | SP-38 | Dionisio | 33.820 |  |  |  |
| 1053 | 409 | Study on Transferring of emergency call data – in-band modem solution |  | 265d? | 2006-12-07 A | 2007-12-12 A | 100% |  | 2006-12-07 | 2007-12-12 | 265d? |  | finish no earlier than 2008-09-18 | S4 | 2120h | 2120h | eCALLIBMS |  | Airbiquity | Rel-8 |  | Paolo | 26.967 |  |  |  |
| 1054 | 410 | Study on Element Operations Systems Function (EOSF) definition |  | 266d? | 2007-06-07 A | 2008-06-12 A | 100% |  | 2007-06-07 | 2008-06-12 | 266d? |  | finish no earlier than 2008-12-11 | S5 | 2128h | 2128h | OAM7-NIM- EOSF |  | China Mobile | Rel-8 |  | Dionisio | 32.819 |  |  |  |
| 1055 | 411 | Study on SA5 MTOSI XML Harmonization |  | 351d? | 2006-05-10 A | 2007-09-12 A | 100% |  | 2006-05-10 | 2007-09-12 | 351d? |  | finish no earlier than 2007-12-14 | S5 | 2808h | 2808h | OAM8-NIM-XML |  | Nortel | Rel-8 |  | Dionisio | 32.818 |  |  |  |
| 1056 | 412 | Study on Common Profile Storage (CPS) Framework of User Data for network services and management |  | 244d? | 2006-07-03 A | 2007-06-07 A | 100% |  | 2006-07-03 | 2007-06-07 | 244d? |  | finish no earlier than 2007-06-07 | S5 | 1952h | 1952h | OAM7-CPS |  | T-Mobile | Rel-8 |  | Dionisio | 32.808 |  |  |  |
| 1057 | 413 | Study on Management for LTE and SAE |  | 526d? | 2006-12-07 A | 2008-12-11 A | 100% |  | 2006-12-07 | 2008-12-11 | 526d? |  | finish no earlier than 2008-12-11 | S5 | 4208h | 4208h | FS_OAM_LTE_SAE |  | Ericsson | Rel-8 |  | Dionisio | 32.816 |  |  |  |
| 1058 | 414 | Study on Charging Aspects of 3GPP System Evolution |  | 179d? | 2007-04-02 A | 2007-12-06 A | 100% |  | 2007-04-02 | 2007-12-06 | 179d? |  | finish no earlier than 2007-12-06 | S5 | 1432h | 1432h | FS_SAEcharg |  | Nokia Siemens Networks | Rel-8 |  | Dionisio | 32.820 |  |  |  |
| 1059 | 415 | Study on AS-MRFC media server control protocol |  | 583d? | 2006-03-22 A | 2008-06-13 A | 100% |  | 2006-03-22 | 2008-06-13 | 583d? |  | finish no earlier than 2008-06-13 | C1 | 4664h | 4664h | MRFC |  | Hewlett-Packard | Rel-8 |  | Frederic | 24.880 |  |  |  |
| 1060 | 416 | Study on IMS Restoration Procedures |  | 310d? | 2007-03-26 A | 2008-05-30 A | 100% |  | 2007-03-26 | 2008-05-30 | 310d? |  | finish no earlier than 2008-05-30 | C4 | 2480h | 2480h | FS_IMS_RP |  | Ericsson | Rel-8 |  | Kimmo | 23.820 |  |  |  |
| 1061 | 417 | Study on IMS Application Server Service Data Descriptions for AS interoperability |  | 261d? | 2007-09-14 A | 2008-09-12 A | 100% |  | 2007-09-14 | 2008-09-12 | 261d? |  | finish no earlier than 2008-09-12 | C4 | 2088h | 2088h | FS_IMS_ASIO |  | Alcatel-Lucent | Rel-8 |  | Kimmo | 29.864 |  |  |  |
| 1062 | 418 | Study on Customized Alerting Tone (CAT) solution for voice and video call in CS domain |  | 261d? | 2007-09-14 A | 2008-09-12 A | 100% |  | 2007-09-14 | 2008-09-12 | 261d? |  |  | C4 | 626.4h | 626.4h | FS_CAT_VVC_CS |  | China Mobile | Rel-8 |  | Kimmo | 29.882 |  |  |  |
| 1063 | 419 | Study on InterWorking Function between MAP based and Diameter based interfaces |  | 266d? | 2007-11-30 A | 2008-12-05 A | 100% |  | 2007-11-30 | 2008-12-05 | 266d? |  | finish no earlier than 2008-12-05 | C4 | 2128h | 2128h | FS_MAP2Diam | PCG-21 | Huawei | Rel-8 | CP-38 | Kimmo | 29.805 |  |  |  |
| 1064 | 420 | Study on Scope of future HSPA Evolution for 1.28 Mcps TDD |  | 186d? | 2007-09-14 A | 2008-05-30 A | 100% |  | 2007-09-14 | 2008-05-30 | 186d? |  | finish no earlier than 2008-05-30 | R1 | 1488h | 1488h | FS_RAN-LCRTDDHSPAEvo |  | RITT | Rel-8 | RP-37 | Patrick | 25.824 |  |  | RP-080290 |
| 1065 | 421 | Study on Synchronized E-DCH for UTRA FDD |  | 126d? | 2007-09-14 A | 2008-03-07 A | 100% |  | 2007-09-14 | 2008-03-07 | 126d? |  | finish no earlier than 2008-03-14 | R1 | 1008h | 1008h | FS_RAN-UplinkSync |  | Nokia Siemens Networks | Rel-8 | RP-37 | Patrick | 25.823 |  |  | RP-080068 |
| 1066 | 422 | Study on Improved network controlled mobility between LTE and 3GPP2/mobile WiMAX radio technologies |  | 131d? | 2007-06-04 A | 2007-12-03 A | 100% |  | 2007-06-04 | 2007-12-03 | 131d? |  | finish no earlier than 2007-12-03 | R4 | 1048h | 1048h | FS_RAN-LTEmob |  | Motorola | Rel-8 |  | Issam | 36.938 |  |  | RP-070827 |
| 1067 | 423 | Study on 3G Home NodeB/eNodeB |  | 325d? | 2007-03-05 A | 2008-05-30 A | 100% |  | 2007-03-05 | 2008-05-30 | 325d? |  | finish no earlier than 2008-05-30 | R4 | 2600h | 2600h | FS_RAN-HNBeNB |  | Motorola | Rel-8 |  | Issam | 25.820 |  |  | RP-080289 |
| 1068 | 424 | Study on A-interface over IP |  | 126d? | 2007-08-31 A | 2008-02-22 A | 100% |  | 2007-08-31 | 2008-02-22 | 126d? |  | finish no earlier than 2008-02-22 | GP | 1008h | 1008h | AINTIP |  | China Mobile, Ericsson | Rel-8 |  | Paolo | 43.903 |  |  |  |
| 1069 | 425 | Study on Multi-User Reusing-One-Slot |  | 782d? | 2007-11-16 A | 2010-11-12 A | 100% |  | 2007-11-16 | 2010-11-12 | 782d? |  | finish no earlier than 2010-11-12 | GP | 6248h | 6248h | MUROS |  | Nokia Siemens Networks | Rel-8 |  | Paolo | 45.914 |  |  |  |
| 1070 | 426 | Study on Optimized Transmit Pulse Shape for Downlink EGPRS2-B |  | 657d? | 2007-11-16 A | 2010-05-21 A | 100% |  | 2007-11-16 | 2010-05-21 | 657d? |  | finish no earlier than 2010-05-27 | G1 | 5248.44h | 5248.44h | WIDER |  | Research In Motion, Nokia Siemens Networks | Rel-8 |  | Paolo | 45.913 |  |  |  |
| 1071 | 427 | Deleted - Study on Mobility between 3GPP-WLAN Interworking and 3GPP Systems |  | 393d? | 2007-03-20 A | 2008-09-18 A | 100% |  | 2007-03-20 | 2008-09-18 | 393d? |  | finish no earlier than 2008-09-18 | S2 | 3144h | 3144h | FS_SM3GWLAN |  | Orange | Rel-8 |  | Maurice | withdrawn 23.827 | SP-41 | PCG-21 |  |
| 1072 | 428 | Deleted - Study on Evaluation of LCS Control Plane Solution for EPS |  | 100d? | 2008-01-14 A | 2008-05-30 A | 100% |  | 2008-01-14 | 2008-05-30 | 100d? |  | finish no earlier than 2009-03-20 | S2 | 800h | 800h | FS_LCS_EPS |  | SiRF | Rel-8 | SP-38 | Maurice | 23.891 | SP-40 | PCG-21 |  |
| 1073 | 429 | Deleted - Study on HS-PDSCH serving cell change enhancements |  | 60d? | 2007-12-17 A | 2008-03-07 A | 100% |  | 2007-12-17 | 2008-03-07 | 60d? |  | finish no earlier than 2008-06-12 | R4 | 480h | 480h | FS_RAN-HSPDSCH | PCG-21 | Qualcomm | Rel-8 | RP-38 | Issam | none | RP-39 | PCG-21 | RP-080070 |
| 1074 | 430 | Deleted - Study on Dual-Cell HSDPA operation |  | 261d? | 2007-08-15 A | 2009-03-06 A | 100% |  | 2007-08-15 | 2009-03-06 | 261d? |  | finish no earlier than 2009-03-06 | R1 | 2088h | 2088h | FS_RAN-DCHS | PCG-21 | Qualcomm | Rel-8 | RP-39 | Patrick | withdrawn 25.825 v100 | RP-43 | PCG-22 | RP-090066 |
| 1075 | 431 | Release 7 Features |  | 679d? | 2005-05-02 A | 2007-12-06 A | 100% |  | 2005-05-02 | 2007-12-06 | 679d? |  | start no earlier than 2000-01-01 | CP,GP,RP,SP | 5432h | 5432h |  |  |  | Rel-7 |  | All |  |  |  |  |

Notes:
- 1025: CP#42 completed. Updated WID CP-080278=>CP-080722 / Text5: philip.hodges@ericsson.com
- 1026: CP#42 completed. Updated WID CP-080278=>CP-080722 / Text5: philip.hodges@ericsson.com
- 1027: CP#42 completed. Updated WID CP-080278=>CP-080722 / Text5: philip.hodges@ericsson.com
- 1028: CP#42 completed. Updated WID CP-080278=>CP-080722 / Text5: philip.hodges@ericsson.com
- 1029: GP#39 completed / Text5: thomas.bitzer@alcatel-lucent.de
- 1030: GP#45 completed / Text5: mats.y.samuelsson@ericsson.com, hakan.e.grunditz@ericsson.com
- 1031: GP#45 completed / Text5: hakan.e.grunditz@ericsson.com
- 1032: GP#41 completed / Text5: mats.y.samuelsson@ericsson.com
- 1033: GP#40 completed / Text5: Franz.Segerer@ROHDE-SCHWARZ.COM
- 1034: SP#42 completed
- 1035: IESG evaluation / Text5: christer.holmberg@ericsson.com
- 1036: -
- 1037: SP#35 stopped / Text5: dhshim@lge.com
- 1038: SP#38 stopped
- 1039: CP#47 work stopped/abandoned / Text5: Udo Willenbrink, Jacques Seif
- 1040: CP#47 work stopped/abandoned / Text5: Udo Willenbrink (uwillenbrink@comprion.com )
- 1041: CP#47 work stopped/abandoned / Text5: jacques.seif@gemalto.com
- 1042: GP#43 work stopped/abandoned (completion 0%) / Text5: arsi.heino@nokia.com
- 1043: -
- 1044: SP#43 completed / Text5: Chris Pudney
- 1045: SP#41 completed / Text5: Chris Pudney
- 1046: SP#41 completed / Text5: Chris Pudney
- 1047: SP#43 completed / Text5: dajiang.zhang@nokia.com
- 1048: SP#41 completed. No spin-off activity proposed. [Note: IMS Service Brokering enhancements UID_31088 moved back from R8 to R7 to give a home to 22228CR0036_(Rel-7)_S1-051232. Hence, Rel-7 ISB has Stage 1 only (and is misaligned with Rel-7 Stages 2/3.] / Text5: raquel@research.telcordia.com
- 1049: SP#38 completed
- 1050: SP#40 completed
- 1051: SP#41 completed as Rel-8 / Text5: WANG, Jing (wangjing@chinamobilecom)
- 1052: SP#43 completed. Linked to RAN4 Study on 3G Home NodeB/eNodeB (UID_350039) and to SA5 Study on Self-Organizing Networks (SON) related OAM interfaces for Home NodeB (UID_360007) / Text5: yangyanmei@huawei.com
- 1053: SP#38 completed. Spin-off WID UID_34042 (eCall_Phase2) / Text5: lhong@airbiquity.com
- 1054: SP#40 completed. WID updated SP-050608=>SP-070307 / Text5: Li Jian (lijian@chinamobile.com)
- 1055: SP#37 completed. WID updated SP-050295=>SP-070305 / Text5: jduguay@nortel.com
- 1056: SP#36 completed. Spin-off New Feature UID_400034 User Data Convergence (UDC) / Text5: istvan.aba@t-mobile.at
- 1057: SP#42 completed / Text5: robert.petersen@ericsson.com
- 1058: SP#38 completed / Text5: Gerald.Goermer@nsn.com
- 1059: CP#40 completed. Spin-off New Feature UID_380035 (MRFC_TS) / Text5: mark.syrett@hp.com
- 1060: CP#40 completed. Spin-off WID UID_400012 (IMS_RP) / Text5: german.blanco@ericsson.com
- 1061: CP#41 completed. Linked to SA5 Study on Common Profile Storage framework UID_320006. Spin-off WID UID_410003 (IMS_ASIO) / Text5: Jean-Jacques Trottin
- 1062: CP#41 completed. Spin-off WID under Feature CAT UID_340029 / Text5: zhanghao@chinamobile.com
- 1063: CP#42 completed. Spin-off implementation Building Block UID_410007 (MAP2Diam) under the SAES Feature UID_320005 / Text5: liming49985@huawei.com
- 1064: RP#40 completed / Text5: Xu Fei
- 1065: RP#39 completed / Text5: Karri.Ranta-aho@nsn.com
- 1066: RP#38 completed / Text5: hao.bi@Motorola.com
- 1067: RP#40 completed / Text5: howard.thomas@motorola.com
- 1068: GP#37 completed. Spin-off implementation Feature AoIP (A-interface over IP) UID_50591 / Text5: paul.schliwa-bertling@ericsson.com
- 1069: GP#48 completed as Rel-8. Spin-off implementation WI UID_420002 VAMOS (Voice services over Adaptive Multi-user channels on One Slot) / Text5: juergen.hofmann@nsn.com
- 1070: GP#46 completed / Text5: jdwyer@RIM.COM and eddie.riddington@nsn.com
- 1071: SP#41 stopped. Draft TR 23.827 content implemented in TS 23.327.
- 1072: SP#40 spin-off Feature UID_400038 (LCS_CPS_EPS). SP#40 FS stopped
- 1073: RP#39 stopped (no TR produced). Spin-off HS-DSCH Serving Cell Change Enhancements (UID_39003)
- 1074: RP#43 stopped (draft TR 25.825 v100 withdrawn). Conclusions in RP-090318 (RAN1 findings of the UTRA Multi-Carrier Evolution study). RP#42 New WI approved on Dual-Cell HSDPA operation on adjacent carriers (UID_400052) / Text5: Josef Blanz
- 1075: -

| ID | WBS | Task | Duration | Start | Finish | Complete | Baseline start | Baseline finish | Baseline duration | Constraint | Resources | Work | Actual work | Text1 | Text4 | Text5 | Text6 | Text8 | Text12 | Text11 | Text2 | Text7 |
| --- | --- | --- | --- | --- | --- | --- | --- | --- | --- | --- | --- | --- | --- | --- | --- | --- | --- | --- | --- | --- | --- | --- |
| 1076 | 432 | **Identification of Communication Services in IMS** | 620d? | 2005-05-02 A | 2007-09-14 A | 100% | 2005-05-02 | 2007-09-14 | 620d? |  | S2,S1,C1,S5 | 13016h | 13016h | ServID | Ericsson | stephen.terrill@ericsson.com | Rel-7 | Maurice |  |  |  |  |
| 1077 | 432.1 | TR on ServID | 232d? | 2005-05-02 A | 2006-03-21 A | 100% | 2005-05-02 | 2006-03-21 | 232d? | finish no earlier than 2006-03-20 | S2 | 1856h | 1856h | ServID | Ericsson | stephen.terrill@ericsson.com | Rel-7 | Maurice |  |  |  |  |
| 1078 | 432.2 | Stage 1,2 of ServID | 144d? | 2005-11-11 A | 2006-05-31 A | 100% | 2005-11-11 | 2006-05-31 | 144d? | start no earlier than 2005-11-11 | S1,S2 | 1152h | 1152h | ServID | Ericsson | stephen.terrill@ericsson.com | Rel-7 | Maurice |  |  |  |  |
| 1079 | 432.3 | Stage 3 of ServID | 250d? | 2006-03-31 A | 2007-03-15 A | 100% | 2006-03-31 | 2007-03-15 | 250d? | finish no earlier than 2007-03-15 | C1 | 2000h | 2000h | ServID | Ericsson | christer.holmberg@ericsson.com | Rel-7 | Frederic |  |  |  |  |
| 1080 | 432.4 | Charging of ServID | 381d? | 2006-03-31 A | 2007-09-14 A | 100% | 2006-03-31 | 2007-09-14 | 381d? | finish no earlier than 2007-09-14 | S5 | 3048h | 3048h | ServID | Orange | alain.bibas@orange-ft.com | Rel-7 | Dionisio |  |  |  |  |
| 1081 | 433 | **Supporting Globally Routable User Agent URIs in IMS** | 415d? | 2005-11-14 A | 2007-06-15 A | 100% | 2005-11-14 | 2007-06-15 | 415d? |  | S2,S1,C1 | 7760h | 7760h | GRUU | Research In Motion | Adrian Buckley (abuckley@rim.com) | Rel-7 | Maurice |  |  |  |  |
| 1082 | 433.1 | Deleted - TR on GRUU | 219d? | 2005-11-14 A | 2006-09-14 A | 100% | 2005-11-14 | 2006-09-14 | 219d? | finish no earlier than 2006-09-14 | S2 | 1752h | 1752h | GRUU | Research In Motion | Adrian Buckley (abuckley@rim.com) | Rel-7 | Maurice | SP-32 |  |  |  |
| 1083 | 433.2 | Stage 1,2 of GRUU | 65d? | 2006-07-03 A | 2006-09-29 A | 100% | 2006-07-03 | 2006-09-29 | 65d? | start no earlier than 2006-07-03 | S1,S2 | 520h | 520h | GRUU | Research In Motion | Adrian Buckley (abuckley@rim.com) | Rel-7 | Maurice |  |  |  |  |
| 1084 | 433.3 | Stage 3 of GRUU | 271d? | 2006-06-02 A | 2007-06-15 A | 100% | 2006-06-02 | 2007-06-15 | 271d? | finish no earlier than 2007-06-15 | C1 | 2168h | 2168h | GRUU | CableLabs | Bernie McKibben (b.mckibben@cablelabs.com) | Rel-7 | Frederic |  |  |  |  |
| 1085 | 434 | Multimedia Telephony Service for IMS (MTSI) - UE Conformance Testing | 387d | 2007-09-19 A | 2009-03-12 A | 100% | 2007-09-19 | 2009-03-12 | 387d | finish no earlier than 2009-03-13 | R5 | 1664h | 1664h | MTSI-UEConTest | Ericsson, Motorola | Leif.Mattisson@ericsson.com, Jacob.John@motorola.com | Rel-7 | Ingbert |  | RP-090056 |  |  |
| 1086 | 435 | IMS Support of Conferencing | 355d? | 2005-11-04 A | 2007-03-15 A | 100% | 2005-11-04 | 2007-03-15 | 355d? | finish no earlier than 2007-03-15 | C1 | 2840h | 2840h | IMSconf | Alcatel-Lucent | Keith Drage (drage@alcatel-lucent.com) | Rel-7 | Frederic |  |  |  |  |
| 1087 | 436 | Performance Characterization of VoIMS over HSDPA\EUL channels | 713d? | 2005-03-15 A | 2007-12-06 A | 100% | 2005-03-15 | 2007-12-06 | 713d? | finish no earlier than 2007-12-06 | S4 | 5704h | 5704h | VoIMS-PCVoIMS | Alcatel-Lucent | mcgowan@alcatel-lucent.com | Rel-7 | Paolo |  |  |  |  |
| 1088 | 437 | **WLAN Interworking – Private Network access from WLAN 3GPP IP Access** | 252d? | 2005-10-10 A | 2006-09-26 A | 100% | 2005-10-10 | 2006-09-26 | 252d? |  | S2,C1,C3,C4 | 8936h | 8936h | WLANPNA | NEC | Toshiyuki Tamura (tamurato@aj.jp.nec.com) | Rel-7 | Maurice |  |  |  |  |
| 1089 | 437.1 | WLAN-PNA - Stage 2 | 185d? | 2005-10-10 A | 2006-06-23 A | 100% | 2005-10-10 | 2006-06-23 | 185d? | start no earlier than 2005-10-10 | S2 | 1480h | 1480h | WLANPNA-st2 | NEC | Toshiyuki Tamura (tamurato@aj.jp.nec.com) | Rel-7 | Maurice |  |  |  |  |
| 1090 | 437.2 | **WLAN-PNA - Stage 3** | 170d? | 2006-02-01 A | 2006-09-26 A | 100% | 2006-02-01 | 2006-09-26 | 170d? |  | C1,C3,C4 | 5440h | 5440h | WLANPNA-st3 | NEC |  | Rel-7 | Frederic |  |  |  |  |
| 1091 | 437.2.1 | CT1 aspets for WLAN-PNA | 170d? | 2006-02-01 A | 2006-09-26 A | 100% | 2006-02-01 | 2006-09-26 | 170d? | start no earlier than 2006-02-01 | C1 | 1360h | 1360h | WLANPNA-st3 | NEC |  | Rel-7 | Frederic |  |  |  |  |
| 1092 | 437.2.2 | CT3 aspets for WLAN-PNA | 170d? | 2006-02-01 A | 2006-09-26 A | 100% | 2006-02-01 | 2006-09-26 | 170d? | start no earlier than 2006-02-01 | C3 | 1360h | 1360h | WLANPNA-st3 | NEC |  | Rel-7 | Jiwan |  |  |  |  |
| 1093 | 437.2.3 | Deleted - CT4 aspets for WLAN-PNA | 170d? | 2006-02-01 A | 2006-09-26 A | 100% | 2006-02-01 | 2006-09-26 | 170d? | start no earlier than 2006-02-01 | C4 | 1360h | 1360h | WLANPNA-st3 | NEC |  | Rel-7 | Kimmo | CP-32 |  |  |  |
| 1094 | 438 | **Enhancements to support QoS provisioning over 3GPP/WLAN Interworking** | 520d? | 2005-03-14 A | 2007-03-09 A | 100% | 2005-03-14 | 2007-03-09 | 520d? |  | S2,C4,C1 | 8360h | 8360h | WLANQOS | Samsung |  | Rel-7 | Maurice |  |  |  |  |
| 1095 | 438.1 | Deleted - TR on support of QoS on WLAN | 232d? | 2005-03-14 A | 2006-01-31 A | 100% | 2005-03-14 | 2006-01-31 | 232d? | start no earlier than 2005-03-14 | S2 | 1856h | 1856h | WLANQOS | Samsung |  | Rel-7 | Maurice | SP-32 |  |  |  |
| 1096 | 438.2 | Stage 2 on support of QoS over 3GPP/WLAN interworking | 108d? | 2006-02-01 A | 2006-06-30 A | 100% | 2006-02-01 | 2006-06-30 | 108d? | start no earlier than 2006-02-01 | S2 | 864h | 864h | WLANQOS | Samsung |  | Rel-7 | Maurice |  |  |  |  |
| 1097 | 438.3 | Stage 3 CT4 on support of QoS over 3GPP/WLAN Interworking | 121d? | 2006-09-22 A | 2007-03-09 A | 100% | 2006-09-22 | 2007-03-09 | 121d? | finish no earlier than 2007-03-09 | C4 | 968h | 968h | WLANQOS | Huawei | zhang.peng@huawei.com | Rel-7 | Kimmo |  |  |  |  |
| 1098 | 438.4 | Stage 3 CT1 on support of QoS over 3GPP/WLAN Interworking | 64d? | 2006-09-04 A | 2006-11-30 A | 100% | 2006-09-04 | 2006-11-30 | 64d? | finish no earlier than 2006-11-30 | C1 | 512h | 512h | WLANQOS | Huawei | zhang.peng@huawei.com | Rel-7 | Frederic |  |  |  |  |
| 1099 | 439 | **MBMS - UE Conformance Testing** | 657d? | 2007-06-01 A | 2009-12-04 A | 100% | 2007-06-01 | 2009-12-04 | 657d? |  | R5 | 13848h | 13848h | MBMSE_UEConTest |  |  | Rel-7 | Ingbert |  |  | PCG-21 | SP-40 |
| 1100 | 439.1 | Conformance Test Aspects – MBMS TDD Physical layer Enhancements – MBSFN for HCR and VHCR TDD | 336d? | 2007-06-01 A | 2008-09-12 A | 100% | 2007-06-01 | 2008-09-12 | 336d? | start no earlier than 2007-06-01 | R5 | 2688h | 2688h | MBMSE-RANPhysTDD_UEConTest | IPWireless | tspeight@ipwireless.com | Rel-7 | Ingbert |  | RP-080541 |  |  |
| 1101 | 439.2 | Conformance Test Aspects – MBMS LCR TDD Physical Layer Enhancement | 342d? | 2008-05-30 A | 2009-09-18 A | 100% | 2008-05-30 | 2009-09-18 | 342d? | finish no earlier than 2009-09-18 | R5 | 2728h | 2728h | MBMSE-RANPhysLCRTDD_UEConTest | CATT | chenxiaozhong@datangmobile.cn | Rel-7 | Ingbert |  | RP-090715 | PCG-21 | RP-40 |
| 1102 | 439.3 | Conformance Test Aspects – MBSFN for FDD | 397d? | 2008-05-30 A | 2009-12-04 A | 100% | 2008-05-30 | 2009-12-04 | 397d? | finish no earlier than 2009-12-04 | R5 | 3176h | 3176h | MBMSE-UEConTest_RANPhysFDD | Huawei | Xiang Li (trica_li@huawei.com) | Rel-7 | Ingbert |  | RP-091214 | PCG-21 | RP-40 |
| 1103 | 440 | MBMS User Service Extensions | 392d? | 2005-12-07 A | 2007-06-07 A | 100% | 2005-12-07 | 2007-06-07 | 392d? | finish no earlier than 2007-06-07 | S4 | 3136h | 3136h | MBMSUSE | Ericsson | Thorsten.Lohmar@ericsson.com | Rel-7 | Paolo |  |  |  |  |
| 1104 | 441 | A-GPS Minimum Performance | 351d? | 2006-04-28 A | 2007-08-31 A | 100% | 2006-04-28 | 2007-08-31 | 351d? | finish no earlier than 2007-08-31 | GP | 2808h | 2808h | GAGR | Spirent | richard.catmur@spirentcom.com | Rel-7 | Paolo |  |  |  |  |
| 1105 | 442 | Network selection enhancements (NSP) - UE Conformance Testing | 396d? | 2007-06-01 A | 2008-12-05 A | 100% | 2007-06-01 | 2008-12-05 | 396d? | finish no earlier than 2008-12-05 | R5 | 3168h | 3168h | NSP-CR_UEConTest | Nokia | jarkko.hellsten@nokia.com | Rel-7 | Ingbert |  | RP-080819 |  |  |

Notes:
- 1076: WID approved SP#28. WID updated SP#32
- 1077: - / Text3: 23.816
- 1078: - / Text3: 22.228, 23.228, 23.203
- 1079: CP#32 approved WID / Text3: 23.218, 24.229
- 1080: - / Text3: 32.260, 32.298, 32.299
- 1081: SP#29 approved WID
- 1082: Abandoned
- 1083: SP#29 approved WID / Text3: 22.228, 23.228, 23.218, 24.229
- 1084: CP#32 approved WID / Text3: 24.229
- 1085: RP#43 completed. Linked UID_7038 (MTSI) / Text3: 34.123-1, 34.123-2, 34.123-3, 34.229-1, 34.229-2
- 1086: CP#35 revised WID / Text3: 24.147, 24.229
- 1087: - / Text3: 26.935
- 1088: -
- 1089: Approved at SP#29 / Text3: 23.234, 33.234
- 1090: Approved at CP#29
- 1091: Approved at CP#29 / Text3: 24.234
- 1092: Approved at CP#29 / Text3: 29.161
- 1093: CT4#31; no impacts identified, therefore completed. CP-32 stopped / Text3: 29.234
- 1094: Moved from FS section Feb 06. SP-30 updated WID
- 1095: SP#32 stopped / Text3: 23.836
- 1096: SP#30 updated WID / Text3: 23.234
- 1097: CP#33 approved WID / Text3: 29.234, 23.008
- 1098: CP#33 approved WID / Text3: 24.234
- 1099: Linked to Rel-7 Feature UID_31084 (MBMSE)
- 1100: RP#41 completed / Text3: 34.108, 34.122, 34.123-1/2/3
- 1101: RP#45 completed / Text3: 34.108, 34.123-1
- 1102: RP#46 completed / Text3: 34.108, 34.109, 34.121-1, 34.121-2, 34.123-1, 34.123-2, 34.123-3
- 1103: - / Text3: 26.346, 26.946
- 1104: - / Text3: 45.005, 51.010
- 1105: RP#42 completed. Testing for Feature UID_7041 (NSP-CR) / Text3: 34.108, 34.123-1, 34.123-2, 34.123-3

| ID | WBS | Task | Type | Duration | Start | Finish | Complete | Baseline start | Baseline finish | Baseline duration | Constraint | Resources | Work | Actual work | Text1 | Text4 | Text5 | Text6 | Text8 | Text12 | Text2 | Text7 |
| --- | --- | --- | --- | --- | --- | --- | --- | --- | --- | --- | --- | --- | --- | --- | --- | --- | --- | --- | --- | --- | --- | --- |
| 1106 | 443 | **Access Class Barring and Overload Protection** |  | 650d? | 2004-03-15 A | 2006-09-08 A | 100% | 2004-03-15 | 2006-09-08 | 650d? |  | S2,C1 | 3568h | 3568h | ACBOP | Vodafone | Chris Pudney | Rel-7 | Maurice |  |  |  |
| 1107 | 443.1 | TR on Stage 2 |  | 274d? | 2004-03-15 A | 2005-03-31 A | 100% | 2004-03-15 | 2005-03-31 | 274d? | finish no earlier than 2005-03-31 | S2 | 2192h | 2192h | ACBOP | NTT DoCoMo | Jean-Jacques Davidian (davidian@docomo.fr) | Rel-7 | Maurice |  |  |  |
| 1108 | 443.2 | Stage 3 CN aspects of ACBOP |  | 172d? | 2005-06-06 A | 2006-01-31 A | 100% | 2005-06-06 | 2006-01-31 | 172d? | start no earlier than 2005-06-06 | C1 | 1376h | 1376h | ACBOP |  |  | Rel-7 | Frederic |  |  |  |
| 1109 | 443.3 | Deleted - Potential impact on Iu interface Overload functionality | milestone | 0d? | 2004-03-15 A | 2004-03-15 A | 100% | 2004-03-15 | 2004-03-15 | 0d? | finish no earlier than 2004-03-15 | RP |  |  | ACBOP |  |  | Rel-7 | Issam | RP-25 |  |  |
| 1110 | 443.4 | Deleted - Extra ACBOP information in RAN | milestone | 0d? | 2004-03-15 A | 2004-03-15 A | 100% | 2004-03-15 | 2004-03-15 | 0d? | finish no earlier than 2004-03-15 | RP |  |  | ACBOP |  |  | Rel-7 | Issam | RP-25 |  |  |
| 1111 | 443.5 | Deleted - Extra ACBOP information in GERAN | milestone | 0d? | 2006-09-08 A | 2006-09-08 A | 100% | 2006-09-08 | 2006-09-08 | 0d? | start no earlier than 2006-09-08 | GP |  |  | ACBOP |  |  | Rel-7 | Paolo | RP-33 |  |  |
| 1112 | 444 | **System enhancements for Fixed Broadband access to IMS** |  | 2117d? | 2003-11-05 A | 2011-12-09 A | 100% | 2003-11-05 | 2011-12-09 | 2117d? |  | S2,S3,S5,C1,C3,C4,IETF | 75372.8h | 75372.8h | FBI |  |  | Rel-7 | Maurice |  |  |  |
| 1113 | 444.1 | **TISPAN Rel 1 related aspects** |  | 2117d? | 2003-11-05 A | 2011-12-09 A | 100% | 2003-11-05 | 2011-12-09 | 2117d? |  | S2,S3,C1,C3,C4,IETF | 57724.8h | 57724.8h | FBI-TIS1 |  |  | Rel-7 | Maurice |  |  |  |
| 1114 | 444.1.1 | Stage 2 of FBI for TISPAN R1 |  | 365d? | 2004-10-14 A | 2006-03-08 A | 100% | 2004-10-14 | 2006-03-08 | 365d? | start no earlier than 2004-10-14 | S2 | 2920h | 2920h | FBI-TIS1 |  |  | Rel-7 | Maurice |  |  |  |
| 1115 | 444.1.2 | **Protocol impact of FBI for TISPAN R1** |  | 2117d? | 2003-11-05 A | 2011-12-09 A | 100% | 2003-11-05 | 2011-12-09 | 2117d? |  | S3,C1,C3,C4,IETF | 41300.8h | 41300.8h | FBI-TIS1 | Siemens | peter.leis@nsn.com | Rel-7 | Frederic |  |  |  |
| 1116 | 444.1.2.1 | (IETF) CT aspects of FBI for TISPAN R1 |  | 1936.6d? | 2003-11-05 A | 2011-12-09 A | 100% | 2003-11-05 | 2011-12-09 | 1936.6d? | start no earlier than 2003-11-05 | C1-IETF, C3-IETF | 15492.8h | 15492.8h | FBI-TIS1_IETF | Roland Jesske |  | Rel-7 | Frederic |  | PCG-27 | CP-52 |
| 1117 | 444.1.2.2 | CT1 aspects of FBI for TISPAN R1 |  | 802d? | 2003-11-05 A | 2006-11-30 A | 100% | 2003-11-05 | 2006-11-30 | 802d? | finish no earlier than 2006-11-30 | C1 | 6416h | 6416h | FBI-TIS1 | Siemens | peter.leis@nsn.com | Rel-7 | Frederic |  |  |  |
| 1118 | 444.1.2.3 | CT3 aspects of FBI for TISPAN R1 |  | 808d? | 2003-11-05 A | 2006-12-08 A | 100% | 2003-11-05 | 2006-12-08 | 808d? | finish no earlier than 2006-12-08 | C3 | 6464h | 6464h | FBI-TIS1 | Siemens | peter.leis@nsn.com | Rel-7 | Jiwan |  |  |  |
| 1119 | 444.1.2.4 | CT4 aspects of FBI for TISPAN R1 |  | 301d? | 2006-01-13 A | 2007-03-09 A | 100% | 2006-01-13 | 2007-03-09 | 301d? | finish no earlier than 2007-03-09 | C4 | 2408h | 2408h | FBI-TIS1-st3-c4 | Siemens | peter.leis@nsn.com | Rel-7 | Kimmo |  |  |  |
| 1120 | 444.1.3 | Security Enhancements for FBI |  | 118d? | 2005-06-28 A | 2005-12-08 A | 100% | 2005-06-28 | 2005-12-08 | 118d? | start no earlier than 2005-06-28 | S3 | 944h | 944h | FBI-ISE | Ericsson | Bengt.Sahlin@ericsson.com | Rel-7 | Dionisio |  |  |  |
| 1121 | 444.2 | **PacketCable Related aspects** |  | 291d? | 2006-02-01 A | 2007-03-14 A | 100% | 2006-02-01 | 2007-03-14 | 291d? |  | S2,S5,C1 | 5088h | 5088h | FBI-PCBL | CableLabs | Bernie McKibben (b.mckibben@cablelabs.com) | Rel-7 | Maurice |  |  |  |
| 1122 | 444.2.1 | Stage 1,2 of FBI for PacketCable |  | 228d? | 2006-02-01 A | 2006-12-15 A | 100% | 2006-02-01 | 2006-12-15 | 228d? | finish no earlier than 2006-12-15 | S2 | 1824h | 1824h | FBI-PCBL | CableLabs | Bernie McKibben (b.mckibben@cablelabs.com) | Rel-7 | Maurice |  |  |  |
| 1123 | 444.2.2 | Protocol impact of FBI for PacketCable |  | 228d? | 2006-05-01 A | 2007-03-14 A | 100% | 2006-05-01 | 2007-03-14 | 228d? | finish no earlier than 2007-03-15 | C1 | 1824h | 1824h | FBI-PCBL |  |  | Rel-7 | Frederic |  |  |  |
| 1124 | 444.2.3 | SA5 Charging aspects of FBI for PacketCable |  | 180d? | 2006-03-31 A | 2006-12-07 A | 100% | 2006-03-31 | 2006-12-07 | 180d? | finish no earlier than 2006-12-07 | S5 | 1440h | 1440h | FBI-PCBL-CH | CableLabs | Bernie McKibben (b.mckibben@cablelabs.com) | Rel-7 | Dionisio |  |  |  |
| 1125 | 445 | **Support of SMS over generic 3GPP IP access** |  | 696d? | 2004-10-14 A | 2007-06-14 A | 100% | 2004-10-14 | 2007-06-14 | 696d? |  | S2,C4,C1 | 12408h | 12408h | SMSIP | Huawei | zhangwenlin@huawei.com | Rel-7 | Maurice |  |  |  |
| 1126 | 445.1 | FS on SMSIP |  | 173d? | 2004-10-14 A | 2005-06-13 A | 100% | 2004-10-14 | 2005-06-13 | 173d? | start no earlier than 2004-10-14 | S2 | 1384h | 1384h | SMSIP | Huawei | zhangwenlin@huawei.com | Rel-7 | Maurice |  |  |  |
| 1127 | 445.2 | Stage 2 for SMSIP |  | 333d? | 2005-06-08 A | 2006-09-15 A | 100% | 2005-06-08 | 2006-09-15 | 333d? | finish no earlier than 2006-09-15 | S2 | 2664h | 2664h | SMSIP | Huawei | zhangwenlin@huawei.com | Rel-7 | Maurice |  |  |  |
| 1128 | 445.3 | **Stage 3 for SMSIP** |  | 527d? | 2005-06-08 A | 2007-06-14 A | 100% | 2005-06-08 | 2007-06-14 | 527d? |  | C4,C1 | 8360h | 8360h | SMSIP-St3 | Nokia | jari.jansson@nokia.com | Rel-7 | Kimmo |  |  |  |
| 1129 | 445.3.1 | CT1 aspects for SMSIP |  | 527d? | 2005-06-08 A | 2007-06-14 A | 100% | 2005-06-08 | 2007-06-14 | 527d? | finish no earlier than 2007-06-15 | C1 | 4216h | 4216h | SMSIP | Nokia | jari.jansson@nokia.com | Rel-7 | Frederic |  |  |  |
| 1130 | 445.3.2 | CT4 aspects for SMSIP |  | 518d? | 2005-06-08 A | 2007-06-01 A | 100% | 2005-06-08 | 2007-06-01 | 518d? | finish no earlier than 2007-06-01 | C4 | 4144h | 4144h | SMSIP-St3-c4 | Nokia | jari.jansson@nokia.com | Rel-7 | Kimmo |  |  |  |

Notes:
- 1106: - / Text3: 23.898
- 1107: - / Text3: 23.898
- 1108: - / Text3: 24.008
- 1109: - / Text3: 25.413
- 1110: - / Text3: 25.331
- 1111: - / Text3: 44.018
- 1112: -
- 1113: -
- 1114: -
- 1115: -
- 1116: CP#54 completed / Text3: RFC 6432 (was draft-jesske-dispatch-update3326-reason-responses)
- 1117: - / Text3: 24.819, 24.229
- 1118: - / Text3: 29.163, 29.209
- 1119: CT4#32: a set of CRs on FBI for cable labs / Text3: 29.229
- 1120: Duplicated entry ("ACCSEC2", "Access Security Enhancements", SP-040865) deleted by A.Sultan / Text3: 33.203
- 1121: -
- 1122: - / Text3: 22.228, 23.228
- 1123: -
- 1124: 03/2006 SP#31 WID approved / Text3: 32.240, 32.260, 32.298, 32.299
- 1125: SP#33 updated WID (removed MMS)
- 1126: SP#33 updated WID / Text3: 23.804
- 1127: SP#33 updated WID / Text3: 23.204
- 1128: CP#34 updated WID
- 1129: CP#34 updated WID / Text3: 23.040, 24.229
- 1130: CP#34 updated WID / Text3: 23.008, 29.002

| ID | WBS | Task | Type | Duration | Start | Finish | Complete | Baseline start | Baseline finish | Baseline duration | Constraint | Resources | Work | Actual work | Text1 | Text4 | Text5 | Text6 | Text8 | Text3 | Text12 |
| --- | --- | --- | --- | --- | --- | --- | --- | --- | --- | --- | --- | --- | --- | --- | --- | --- | --- | --- | --- | --- | --- |
| 1131 | 446 | **Evolution of Policy Control and Charging** |  | 817d? | 2004-10-14 A | 2007-11-30 A | 100% | 2004-10-14 | 2007-11-30 | 817d? |  | S2,S5,C3,C1 | 30336h | 30336h | PCC | Nokia | balazs.bertenyi@nsn.com | Rel-7 | Maurice |  |  |
| 1132 | 446.1 | Deleted - TR for PCC |  | 315d? | 2004-10-14 A | 2005-12-29 A | 100% | 2004-10-14 | 2005-12-29 | 315d? | finish no earlier than 2005-12-28 | S2 | 2520h | 2520h | PCC | Nokia | balazs.bertenyi@nsn.com | Rel-7 | Maurice | 23.803 | SP-33 |
| 1133 | 446.2 | Stage 2 for PCC |  | 315d? | 2005-07-04 A | 2006-09-15 A | 100% | 2005-07-04 | 2006-09-15 | 315d? | finish no earlier than 2006-09-15 | S2 | 2520h | 2520h | PCC | Nokia | balazs.bertenyi@nsn.com | Rel-7 | Maurice | 23.203 |  |
| 1134 | 446.3 | Evolution of policy control and flow based bearer level charging |  | 109d? | 2006-08-01 A | 2006-12-29 A | 100% | 2006-08-01 | 2006-12-29 | 109d? | start no earlier than 2006-08-01 | S2 | 872h | 872h | PCC | Nokia | balazs.bertenyi@nsn.com | Rel-7 | Maurice | 23.207, 23.002, 23.228 |  |
| 1135 | 446.4 | SA5 Charging aspects of PCC |  | 316d? | 2006-03-31 A | 2007-06-15 A | 100% | 2006-03-31 | 2007-06-15 | 316d? | finish no earlier than 2007-06-15 | S5 | 2528h | 2528h | PCC-CH | Orange | alain.bibas@orange-ft.com | Rel-7 | Dionisio | 32.250, 32.251, 32.298, 32.299 |  |
| 1136 | 446.5 | Gx reference point for Policy and Charging Control |  | 521d? | 2005-12-02 A | 2007-11-30 A | 100% | 2005-12-02 | 2007-11-30 | 521d? | finish no earlier than 2007-09-14 | C3 | 4168h | 4168h | PCC-Gx | Siemens | Thomas.Belling@nsn.com | Rel-7 | Jiwan | 29.212 (not progressed to Rel-7: 29.210, 29.207, 29.208) |  |
| 1137 | 446.6 | **Rx reference point for PCC CT3 aspects** |  | 521d? | 2005-12-02 A | 2007-11-30 A | 100% | 2005-12-02 | 2007-11-30 | 521d? |  | C3,C1 | 11192h | 11192h | PCC-Rx | Ericsson | j.javier.pastor@ericsson.com | Rel-7 | Jiwan |  |  |
| 1138 | 446.6.1 | PCC-Rx CT3 aspects |  | 521d? | 2005-12-02 A | 2007-11-30 A | 100% | 2005-12-02 | 2007-11-30 | 521d? | finish no earlier than 2007-09-14 | C3 | 4168h | 4168h | PCC-Rx-c3 | Ericsson | j.javier.pastor@ericsson.com | Rel-7 | Jiwan | 29.213, 29.214 (not progressed to Rel-7: 29.209, 29.211) |  |
| 1139 | 446.6.2 | PCC-Rx CT1 aspects |  | 357d? | 2005-12-02 A | 2007-06-15 A | 100% | 2005-12-02 | 2007-06-15 | 357d? | finish no earlier than 2007-06-15 | C1 | 2856h | 2856h | PCC-Rx-Gx-c1 | Ericsson | j.javier.pastor@ericsson.com | Rel-7 | Frederic | 24.229 |  |
| 1140 | 447 | **One Tunnel solution for optimization of Packet Data Traffic** |  | 418d? | 2006-03-27 A | 2007-10-31 A | 100% | 2006-03-27 | 2007-10-31 | 418d? |  | S2 | 7048h | 7048h | OPTUNEL | Nokia | antti.j.pasanen@nokia.com | Rel-7 | Maurice |  |  |
| 1141 | 447.1 | Deleted - Study on Stage 2 for One Tunnel solution |  | 125d? | 2006-03-27 A | 2006-09-15 A | 100% | 2006-03-27 | 2006-09-15 | 125d? | finish no earlier than 2005-09-12 | S2 | 1000h | 1000h | OPTUNEL-Study | Nokia | antti.j.pasanen@nokia.com | Rel-7 | Maurice | 23.809 | SP-34 |
| 1142 | 447.2 | One Tunnel Deployment Guideline |  | 268d? | 2006-10-23 A | 2007-10-31 A | 100% | 2006-10-23 | 2007-10-31 | 268d? | finish no earlier than 2007-10-31 | S2 | 2144h | 2144h | OPTUNEL-Guide | Huawei | lan.liu@huawei.com | Rel-7 | Maurice | 23.919 |  |
| 1143 | 447.3 | Stage 2 specification for One Tunnel solution |  | 70d? | 2006-09-11 A | 2006-12-15 A | 100% | 2006-09-11 | 2006-12-15 | 70d? | finish no earlier than 2006-12-15 | S2 | 560h | 560h | OPTUNEL-Stage2 | Nokia | antti.j.pasanen@nokia.com | Rel-7 | Maurice | 23.060 |  |
| 1144 | 448 | **CSI Terminating Session handling** |  | 267d? | 2006-06-08 A | 2007-06-15 A | 100% | 2006-06-08 | 2007-06-15 | 267d? |  | S2,C1 | 4728h | 4728h | CSItermS | Samsung | Osok Song | Rel-7 | Maurice |  |  |
| 1145 | 448.1 | Stage 2 of CStermS |  | 192d? | 2006-06-08 A | 2007-03-02 A | 100% | 2006-06-08 | 2007-03-02 | 192d? | start no earlier than 2006-06-08 | S2 | 1536h | 1536h | CSItermS | Samsung | Osok Song | Rel-7 | Maurice | 23.279 |  |
| 1146 | 448.2 | Stage 3 of CStermS |  | 132d? | 2006-12-14 A | 2007-06-15 A | 100% | 2006-12-14 | 2007-06-15 | 132d? | finish no earlier than 2007-06-15 | C1 | 1056h | 1056h | CSItermS | Samsung | chenho.chin@samsung.com | Rel-7 | Frederic | 24.229, 24.279 |  |
| 1147 | 448.3 | Deleted - duplicated with UID 340015 -Stage 3 CSI Terminating Session handling | milestone | 0d? | 2007-03-09 A | 2007-03-09 A | 100% | 2007-03-09 | 2007-03-09 | 0d? | start no earlier than 2007-03-09 | C1 |  |  | CSItermS | Samsung | chenho.chin@samsung.com | Rel-7 | Frederic | 24.229, 24.179, 24.279 | CP-34 |
| 1148 | 449 | Liberty Alliance and 3GPP Security Interworking |  | 451d? | 2005-03-10 A | 2006-11-30 A | 100% | 2005-03-10 | 2006-11-30 | 451d? | finish no earlier than 2006-11-30 | S3 | 3608h | 3608h | LibSec | Nokia | Silke.Holtmanns@nokia.com | Rel-7 | Dionisio | 33.980 |  |
| 1149 | 450 | Trust Requirements for Open Platforms in 3GPP |  | 499d? | 2005-01-03 A | 2006-11-30 A | 100% | 2005-01-03 | 2006-11-30 | 499d? | finish no earlier than 2006-11-30 | S3 | 3992h | 3992h | TrustOP | Nokia | Silke.Holtmanns@nokia.com | Rel-7 | Dionisio | 33.905 |  |
| 1150 | 451 | Development of UEA2 and UIA2 |  | 268d? | 2004-12-01 A | 2005-12-09 A | 100% | 2004-12-01 | 2005-12-09 | 268d? | finish no earlier than 2005-12-09 | S3 | 2144h | 2144h | AlgUEA2 | TeliaSonera | per.christoffersson@teliasonera.com | Rel-7 | Dionisio | 35.919, 35.215, 35.216, 35.217, 35.218 |  |
| 1151 | 452 | Lawful Interception in the 3GPP Rel-7 architecture |  | 118d? | 2005-06-28 A | 2005-12-08 A | 100% | 2005-06-28 | 2005-12-08 | 118d? | start no earlier than 2005-06-28 | S3 | 944h | 944h | LI-7A | BMWI | berthold.wilhelm@regtp.de | Rel-7 | Dionisio | 33.106, 33.107, 33.108 |  |
| 1152 | 453 | Key establishment between a UICC and a terminal |  | 201.45d? | 2005-12-07 A | 2006-09-28 A | 100% | 2005-12-07 | 2006-09-28 | 201.45d? | finish no earlier than 2006-09-28 | S3 | 1611.6h | 1611.6h | KeyEstUTerm | Gemalto | mireille.pauliac@gemplus.com | Rel-7 | Dionisio | 33.110 |  |
| 1153 | 454 | NDS Authentication Framework Extension for Transport Layer Security |  | 50d? | 2006-09-28 A | 2006-12-06 A | 100% | 2006-09-28 | 2006-12-06 | 50d? | finish no earlier than 2006-09-28 | S3 | 400h | 400h | NDSAFTLS | Nokia | tiina.s.koskinen@nokia.com | Rel-7 | Dionisio | 33.310 |  |
| 1154 | 455 | **Security enhancements** |  | 319d? | 2005-09-12 A | 2006-11-30 A | 100% | 2005-09-12 | 2006-11-30 | 319d? |  | S3,C1,C4 | 4856h | 4856h | SEC7 |  |  | Rel-7 | Dionisio |  |  |
| 1155 | 455.1 | HTTPS connection between a UICC and a NAF |  | 1d? | 2005-09-12 A | 2005-09-12 A | 100% | 2005-09-12 | 2005-09-12 | 1d? | start no earlier than 2005-09-12 | S3,C1 | 8h | 8h | SEC7-HSUN | Gemalto | JSeif@axalto.com, mireille.pauliac@gemplus.com | Rel-7 | Dionisio | 33.918, 33.222, 24.109 |  |
| 1156 | 455.2 | 2G GBA: 2G SIM usage in 3GPP GAA framework |  | 61d? | 2005-09-12 A | 2005-12-05 A | 100% | 2005-09-12 | 2005-12-05 | 61d? | finish no earlier than 2005-12-05 | S3 | 488h | 488h | SEC7-2GGBA | Nokia | Silke.Holtmanns@nokia.com | Rel-7 | Dionisio | 33.920, 33.220 |  |
| 1157 | 455.3 | Generic Authentication Architecture usage extensions and optimizations |  | 319d? | 2005-09-12 A | 2006-11-30 A | 100% | 2005-09-12 | 2006-11-30 | 319d? | finish no earlier than 2006-11-30 | S3 | 2552h | 2552h | SEC7-GAA2 | Nokia | Silke.Holtmanns@nokia.com | Rel-7 | Dionisio | 33.220, 29.109, 24.109, (33.223 goes to R8) |  |

Notes:
- 1131: SP-29 approved WID. SP-31 updated WID adding SA5 charging. 23.125 will be discontinued from Rel-7.
- 1132: SP-30: S2 has no intention for TR completion
- 1133: SP-29 approved WID. SP-31 updated WID. 23.125 will be discontinued from Rel-7.
- 1134: SP-29 approved WID. SP-31 updated WID. 23.125 will be discontinued from Rel-7.
- 1135: SP-31 updated WID with SA5 charging.
- 1136: -
- 1137: WID approved at CP#30, Revised at CP#31, Revised at CP#33
- 1138: -
- 1139: -
- 1140: -
- 1141: TR for Info SP-33. SP-34: S2 Report intention to discontinue TR
- 1142: -
- 1143: -
- 1144: Triggered by the abandoned Study UID_32117
- 1145: -
- 1146: CP-34 approved WID. CP-35 updated WID
- 1147: CP-34 approved WID
- 1148: WID approved SP#27.
- 1149: WID approved SP#26.
- 1150: WID approved SP#26, Dependant on Funding Availability.
- 1151: -
- 1152: -
- 1153: TLS profile is moved to Rel-8
- 1154: -
- 1155: -
- 1156: -
- 1157: 33.223 goes to R8

| ID | WBS | Task | Duration | Start | Finish | Complete | Baseline start | Baseline finish | Baseline duration | Constraint | Resources | Work | Actual work | Text1 | Text4 | Text5 | Text6 | Text8 | Text3 | Text12 | Text2 | Text7 |
| --- | --- | --- | --- | --- | --- | --- | --- | --- | --- | --- | --- | --- | --- | --- | --- | --- | --- | --- | --- | --- | --- | --- |
| 1158 | 455.4 | **SS7 TCAP security Gateway** | 241d? | 2005-09-12 A | 2006-08-14 A | 100% | 2005-09-12 | 2006-08-14 | 241d? |  | S3,C4 | 1808h | 1808h | SEC7-NDS-TCAPsec | Siemens | marc.blommaert.ext@nsn.com | Rel-7 | Dionisio |  |  |  |  |
| 1159 | 455.4.1 | SA3 aspects of SEC7-NDS-TCAPsec | 130d? | 2005-09-12 A | 2006-03-10 A | 100% | 2005-09-12 | 2006-03-10 | 130d? | finish no earlier than 2006-03-10 | S3 | 1040h | 1040h | SEC7-NDS-TCAPsec-SA3 | Siemens | marc.blommaert.ext@nsn.com | Rel-7 | Dionisio | 33.204 |  |  |  |
| 1160 | 455.4.2 | TCAPsec Gateway | 96d? | 2006-04-03 A | 2006-08-14 A | 100% | 2006-04-03 | 2006-08-14 | 96d? | start no earlier than 2006-04-01 | C4 | 768h | 768h | SEC7-TCAP | Siemens | Ulrich.wiehe@gksag.de | Rel-7 | Kimmo | 29.204, 29.002 |  |  |  |
| 1161 | 456 | IMS Stage 3 IETF Protocol alignment | 589d? | 2004-12-10 A | 2007-03-14 A | 100% | 2004-12-10 | 2007-03-14 | 589d? | finish no earlier than 2007-03-15 | C1 | 4712h | 4712h | IMSProtoc |  |  | Rel-7 | Frederic | 24.930 |  |  |  |
| 1162 | 457 | **Interoperability between VGCS/VBS and A/Gb flexibility** | 253d? | 2006-03-22 A | 2007-03-09 A | 100% | 2006-03-22 | 2007-03-09 | 253d? |  | C1,C4 | 3296h | 3296h | VGCSFlex | Siemens | robert.zaus@nsn.com | Rel-7 | Frederic |  |  |  |  |
| 1163 | 457.1 | CT1 aspects of VGCSFlex | 159d? | 2006-03-22 A | 2006-10-30 A | 100% | 2006-03-22 | 2006-10-30 | 159d? | finish no earlier than 2006-10-30 | C1 | 1272h | 1272h | VGCSFlex | Siemens | robert.zaus@nsn.com | Rel-7 | Frederic | 43.068, 43.069 |  |  |  |
| 1164 | 457.2 | CT4 aspects of VGCSFlex | 253d? | 2006-03-22 A | 2007-03-09 A | 100% | 2006-03-22 | 2007-03-09 | 253d? | finish no earlier than 2007-03-09 | C4 | 2024h | 2024h | VGCSFlex-c4 | Siemens | robert.zaus@nsn.com | Rel-7 | Kimmo | 29.002 |  |  |  |
| 1165 | 458 | DIAMETER on the GGSN Gi interface | 586d? | 2004-09-10 A | 2006-12-08 A | 100% | 2004-09-10 | 2006-12-08 | 586d? | finish no earlier than 2006-12-08 | C3 | 4688h | 4688h | DIAMGi | Vodafone | Nico.Gabriele@vodafone.com | Rel-7 | Jiwan | 29.061 |  |  |  |
| 1166 | 459 | DIAMETER on the PDG Wi interface | 586d? | 2004-09-10 A | 2006-12-08 A | 100% | 2004-09-10 | 2006-12-08 | 586d? | finish no earlier than 2006-12-08 | C3 | 4688h | 4688h | DIAMWi | Vodafone | Nico.Gabriele@vodafone.com | Rel-7 | Jiwan | 29.161 |  |  |  |
| 1167 | 460 | Interworking between the 3GPP CS domain with BICC or ISUP as signalling protocol and external SIP-I networks | 478d? | 2006-09-22 A | 2008-07-22 A | 100% | 2006-09-22 | 2008-07-22 | 478d? | finish no earlier than 2007-09-14 | C3 | 3824h | 3824h | ExtSIPI | Siemens | Thomas.Belling@nsn.com | Rel-7 | Jiwan | 29.164 |  |  |  |
| 1168 | 461 | PDU multiplexing at Nb Interface with IP transport | 427d? | 2006-12-04 A | 2008-07-22 A | 100% | 2006-12-04 | 2008-07-22 | 427d? | start no earlier than 2006-12-04 | C3 | 3416h | 3416h | NbIPMux | Alcatel-Lucent | Jean.Rzeznik@alcatel-lucent.fr | Rel-7 | Jiwan | 29.414 |  |  |  |
| 1169 | 462 | **Mp (MRFC - MRFP) interface** | 345d? | 2006-02-13 A | 2007-06-08 A | 100% | 2006-02-13 | 2007-06-08 | 345d? |  | C4,C1 | 4384h | 4384h | Mp | Ericsson | philip.hodges@ericsson.com | Rel-7 | Kimmo |  |  |  |  |
| 1170 | 462.1 | CT1 aspects of Mp | 1d | 2006-02-13 A | 2006-02-13 A | 100% | 2006-02-13 | 2006-02-13 | 1d | finish no earlier than 2006-02-13 | C1 | 8h | 8h | Mp | Ericsson | philip.hodges@ericsson.com | Rel-7 | Frederic | 24.229 |  |  |  |
| 1171 | 462.2 | Deleted - CT3 aspects of Mp | 1d | 2006-09-22 A | 2006-09-22 A | 100% | 2006-09-22 | 2006-09-22 | 1d | start no earlier than 2006-09-22 | C3 | 8h | 8h | Mp | Ericsson | philip.hodges@ericsson.com | Rel-7 | Jiwan | 29.162 | CP-33 |  |  |
| 1172 | 462.3 | Procedures description | 201d? | 2006-06-02 A | 2007-03-09 A | 100% | 2006-06-02 | 2007-03-09 | 201d? | finish no earlier than 2007-03-09 | C4 | 1608h | 1608h | Mp-PROCc4 | Huawei | Chencheng@huawei.com | Rel-7 | Kimmo | 23.333 |  |  |  |
| 1173 | 462.4 | Stage 3 for Mp (MRFC - MRFP) interface | 345d | 2006-02-13 A | 2007-06-08 A | 100% | 2006-02-13 | 2007-06-08 | 345d | finish no earlier than 2007-06-08 | C4 | 2760h | 2760h | Mp-St3c4 | Ericsson | philip.hodges@ericsson.com | Rel-7 | Kimmo | 29.333 |  |  |  |
| 1174 | 463 | Routeing of MT-SMS via the HPLMN | 71d? | 2006-12-01 A | 2007-03-09 A | 100% | 2006-12-01 | 2007-03-09 | 71d? | finish no earlier than 2007-03-09 | C4,C1 | 568h | 568h | SMSviaH | Vodafone | Nick.Russell@vodafone.com | Rel-7 | Kimmo | 23.040, 29.002 |  |  |  |
| 1175 | 464 | Mobile Termination whilst the MS is moving to another MSC | 60d? | 2007-03-09 A | 2007-05-31 A | 100% | 2007-03-09 | 2007-05-31 | 60d? | start no earlier than 2007-03-09 | C4 | 480h | 480h | MTmovMS | Alcatel-Lucent | bruno.landais@alcatel-lucent.fr | Rel-7 | Kimmo | 23.008, 23.012, 23.018, 23.078, 23.079, 29.002 |  |  |  |
| 1176 | 465 | ISIM API for Java Card | 620d? | 2005-03-14 A | 2007-07-27 A | 100% | 2005-03-14 | 2007-07-27 | 620d? | finish no earlier than 2007-07-27 | C6 | 4960h | 4960h | APIJAVA | Sun | Sebastian Hans | Rel-7 | Xavier | 31.103, 102 241 |  |  |  |
| 1177 | 466 | Rel-7 (U)SIM API Testing (TS 31.213) | 211d? | 2009-05-30 A | 2010-03-19 A | 100% | 2009-05-30 | 2010-03-19 | 211d? | finish no earlier than 2010-03-12 | C6 | 1688h | 1688h | USIM_API_Test | Sagem Orga | gerrit.hartbrod@sagem-orga.com | Rel-7 | Xavier | 31.213 |  | PCG-23 | CP-44 |
| 1178 | 467 | High speed interface between the UICC and the ME | 311d? | 2006-09-22 A | 2007-11-30 A | 100% | 2006-09-22 | 2007-11-30 | 311d? | finish no earlier than 2007-11-30 | C6 | 2488h | 2488h | HSI | Gemalto | jacques.seif@GEMALTO.COM | Rel-7 | Xavier | 31.101 |  |  |  |
| 1179 | 468 | Video Codec Performance Requirements | 634d? | 2005-01-03 A | 2007-06-07 A | 100% | 2005-01-03 | 2007-06-07 | 634d? | finish no earlier than 2007-06-07 | S4 | 5072h | 5072h | VICPer | Siemens | juergen.pandel@siemens.com | Rel-7 | Paolo | 26.234, 26.235, 26.346, 26.140, 26.902 |  |  |  |
| 1180 | 469 | Dynamic and Interactive Multimedia Scenes | 583d? | 2005-03-15 A | 2007-06-07 A | 100% | 2005-03-15 | 2007-06-07 | 583d? | finish no earlier than 2007-06-07 | S4 | 4664h | 4664h | DIMS | Streamezzo | gaelle.martin-cocher@streamezzo.com | Rel-7 | Paolo | 26.140, 26.142, 26.234, 26.244, 23.346 |  |  |  |
| 1181 | 470 | 3G-324M Video Telephony Call Setup Times Improvements | 341d? | 2005-06-08 A | 2006-09-27 A | 100% | 2005-06-08 | 2006-09-27 | 341d? | finish no earlier than 2006-09-27 | S4 | 2728h | 2728h | VTCSTI | Vodafone | edward.hall@vodafone.co.uk | Rel-7 | Paolo | 26.911 |  |  |  |

Notes:
- 1158: -
- 1159: -
- 1160: -
- 1161: TR 24.930: Signalling flows for the session setup in the IM CN subsystem based on Session Initiation Protocol (SIP)
- 1162: Voice Group Call Service
- 1163: -
- 1164: -
- 1165: -
- 1166: -
- 1167: -
- 1168: -
- 1169: -
- 1170: -
- 1171: CP#34: CT3 not involved in Mp interface definition
- 1172: -
- 1173: -
- 1174: WID approved in CP#34
- 1175: -
- 1176: -
- 1177: CP#47 completed. Update of Rel-6 (U)SIM API for Java Card Testing UID_43007 under Rel-6 UICC/USIM enhancements and interworking UID_1800
- 1178: Following ETSI publication of TS 102 600, expected to be completed at CT6 meeting 45
- 1179: -
- 1180: -
- 1181: -

| ID | WBS | Task | Type | Duration | Start | Finish | Complete | Baseline start | Baseline finish | Baseline duration | Constraint | Resources | Work | Actual work | Text1 | Text4 | Text5 | Text6 | Text8 | Text12 |
| --- | --- | --- | --- | --- | --- | --- | --- | --- | --- | --- | --- | --- | --- | --- | --- | --- | --- | --- | --- | --- |
| 1182 | 471 | **Optimizations for Multimedia Telephony over IMS** |  | 0d? | 2005-09-28 A | 2005-09-28 A | 100% | 2005-09-28 | 2005-09-28 | 0d? |  | S4 |  |  | OMTIMS | Ericsson | olle.franceschi@ericsson.com | Rel-7 | Paolo |  |
| 1183 | 471.1 | Deleted - Characterisation of Adaptive Jitter Management Performance for VoIP Services | milestone | 0d? | 2005-09-28 A | 2005-09-28 A | 100% | 2005-09-28 | 2005-09-28 | 0d? | start no earlier than 2007-03-15 | S4 |  |  | OMTIMS-CAJMP | Lucent | dhuo@lucent.com | Rel-7 | Paolo | SP-35 |
| 1184 | 472 | End-to-End Multimedia Services Performance Metrics |  | 382d? | 2005-09-28 A | 2007-03-15 A | 100% | 2005-09-28 | 2007-03-15 | 382d? | finish no earlier than 2007-03-15 | S4 | 3056h | 3056h | E2EMSPM | China Mobile | zhangyanyf@chinamobile.com | Rel-7 | Paolo |  |
| 1185 | 473 | Packet Switched Streaming Enhancements |  | 261d? | 2006-06-08 A | 2007-06-07 A | 100% | 2006-06-08 | 2007-06-07 | 261d? | finish no earlier than 2007-06-07 | S4 | 2088h | 2088h | PSSe | Ericsson | olle.franceschi@ericsson.com | Rel-7 | Paolo |  |
| 1186 | 474 | **Rel-7 Operations, Administration, Maintenance and Provisioning (OAM&P)** |  | 472.86d? | 2005-09-02 A | 2007-06-26 A | 100% | 2005-09-02 | 2007-06-26 | 472.86d? |  | S5 | 82725.8h | 82725.8h | OAM7 | Huawei | Christian.Toche@huawei.com | Rel-7 | Dionisio |  |
| 1187 | 474.1 | **Rel-7 Network Infrastructure Management** |  | 465d? | 2005-09-02 A | 2007-06-14 A | 100% | 2005-09-02 | 2007-06-14 | 465d? |  | S5 | 41800h | 41800h | OAM7-NIM |  |  | Rel-7 | Dionisio |  |
| 1188 | 474.1.1 | Enhance NRM to accommodate NGN (IMS as basis of the Next Generation Network) |  | 465d? | 2005-09-02 A | 2007-06-14 A | 100% | 2005-09-02 | 2007-06-14 | 465d? | finish no earlier than 2007-06-14 | S5 | 3720h | 3720h | OAM7-NIM | Motorola |  | Rel-7 | Dionisio |  |
| 1189 | 474.1.2 | Co-operative Element Management interface (CO-OP) (Study + Implementation) |  | 400d? | 2005-09-02 A | 2007-03-15 A | 100% | 2005-09-02 | 2007-03-15 | 400d? | finish no earlier than 2007-03-15 | S5 | 3200h | 3200h | OAM7-NIM | Motorola |  | Rel-7 | Dionisio |  |
| 1190 | 474.1.3 | Network Management (NM) Itf-N performance criteria |  | 465d? | 2005-09-02 A | 2007-06-14 A | 100% | 2005-09-02 | 2007-06-14 | 465d? | finish no earlier than 2007-06-14 | S5 | 3720h | 3720h | OAM7-NIM | China Mobile |  | Rel-7 | Dionisio |  |
| 1191 | 474.1.4 | Delta synchronization between IRP Manager and IRP Agent (Study + Implementation) |  | 465d? | 2005-09-02 A | 2007-06-14 A | 100% | 2005-09-02 | 2007-06-14 | 465d? | finish no earlier than 2007-06-14 | S5 | 3720h | 3720h | OAM7-NIM | Siemens |  | Rel-7 | Dionisio |  |
| 1192 | 474.1.5 | Subscription Management (SuM) IRP Solution Sets |  | 330d? | 2005-09-02 A | 2006-12-07 A | 100% | 2005-09-02 | 2006-12-07 | 330d? | finish no earlier than 2006-12-07 | S5 | 2640h | 2640h | OAM7-NIM | Ericsson |  | Rel-7 | Dionisio |  |
| 1193 | 474.1.6 | Integration Reference Point (IRP) Security Management |  | 400d? | 2005-09-02 A | 2007-03-15 A | 100% | 2005-09-02 | 2007-03-15 | 400d? | finish no earlier than 2007-03-15 | S5 | 3200h | 3200h | OAM7-NIM | Huawei | Christian.Toche@huawei.com | Rel-7 | Dionisio |  |
| 1194 | 474.1.7 | Partial suspension of Itf-N during maintenance/testing (Study + Implementation) |  | 465d? | 2005-09-02 A | 2007-06-14 A | 100% | 2005-09-02 | 2007-06-14 | 465d? | finish no earlier than 2007-06-14 | S5 | 3720h | 3720h | OAM7-NIM | Siemens |  | Rel-7 | Dionisio |  |
| 1195 | 474.1.8 | Deleted - Management of Legacy Equipment |  | 336d? | 2005-09-02 A | 2006-12-15 A | 100% | 2005-09-02 | 2006-12-15 | 336d? | finish no earlier than 2006-12-15 | S5 | 2688h | 2688h | OAM7-NIM | Siemens |  | Rel-7 | Dionisio | SP-35 |
| 1196 | 474.1.9 | Deleted - Rules for Vendor Specific Extensions |  | 400d? | 2005-09-02 A | 2007-03-15 A | 100% | 2005-09-02 | 2007-03-15 | 400d? | finish no earlier than 2007-03-15 | S5 | 3200h | 3200h | OAM7-NIM | Siemens |  | Rel-7 | Dionisio | SP-35 |
| 1197 | 474.1.10 | Backward and Forward Compatibility of IRP systems |  | 465d? | 2005-09-02 A | 2007-06-14 A | 100% | 2005-09-02 | 2007-06-14 | 465d? | finish no earlier than 2007-06-14 | S5 | 3720h | 3720h | OAM7-NIM | Ericsson |  | Rel-7 | Dionisio |  |
| 1198 | 474.1.11 | Repeater Network Resource Model (NRM) definition |  | 214d? | 2006-02-13 A | 2006-12-07 A | 100% | 2006-02-13 | 2006-12-07 | 214d? | finish no earlier than 2006-12-07 | S5 | 1712h | 1712h | OAM7-NIM | China Mobile |  | Rel-7 | Dionisio |  |
| 1199 | 474.1.12 | UTRAN radio channel power monitoring |  | 284d? | 2006-02-13 A | 2007-03-15 A | 100% | 2006-02-13 | 2007-03-15 | 284d? | finish no earlier than 2007-03-15 | S5 | 2272h | 2272h | OAM7-NIM | China Mobile |  | Rel-7 | Dionisio |  |
| 1200 | 474.1.13 | Notification XML Schema |  | 71d? | 2006-12-07 A | 2007-03-15 A | 100% | 2006-12-07 | 2007-03-15 | 71d? | finish no earlier than 2007-03-15 | S5 | 568h | 568h | OAM7-NIM | Huawei | Christian.Toche@huawei.com | Rel-7 | Dionisio |  |
| 1201 | 474.2 | **Rel-7 Performance Management** |  | 465d? | 2005-09-02 A | 2007-06-14 A | 100% | 2005-09-02 | 2007-06-14 | 465d? |  | S5 | 22992h | 22992h | OAM7-PM |  |  | Rel-7 | Dionisio |  |
| 1202 | 474.2.1 | Performance measurements definition for CN CS |  | 400d? | 2005-09-02 A | 2007-03-15 A | 100% | 2005-09-02 | 2007-03-15 | 400d? | finish no earlier than 2007-03-15 | S5 | 3200h | 3200h | OAM7-PM | China Mobile |  | Rel-7 | Dionisio |  |
| 1203 | 474.2.2 | Enhancement UTRAN performance measurements definition |  | 465d? | 2005-09-02 A | 2007-06-14 A | 100% | 2005-09-02 | 2007-06-14 | 465d? | finish no earlier than 2007-06-14 | S5 | 3720h | 3720h | OAM7-PM | China Mobile |  | Rel-7 | Dionisio |  |
| 1204 | 474.2.3 | Add TDD specific counters in Performance measurement |  | 330d? | 2005-09-02 A | 2006-12-07 A | 100% | 2005-09-02 | 2006-12-07 | 330d? | finish no earlier than 2006-12-15 | S5 | 2640h | 2640h | OAM7-PM | CATT |  | Rel-7 | Dionisio |  |
| 1205 | 474.2.4 | ATM bearer network Performance measurements |  | 400d? | 2005-09-02 A | 2007-03-15 A | 100% | 2005-09-02 | 2007-03-15 | 400d? | finish no earlier than 2007-03-15 | S5 | 3200h | 3200h | OAM7-PM | ZTE |  | Rel-7 | Dionisio |  |
| 1206 | 474.2.5 | Performance measurements definition for IMS |  | 465d? | 2005-09-02 A | 2007-06-14 A | 100% | 2005-09-02 | 2007-06-14 | 465d? | finish no earlier than 2007-06-14 | S5 | 3720h | 3720h | OAM7-PM | China Mobile |  | Rel-7 | Dionisio |  |
| 1207 | 474.2.6 | HSDPA performance measurements |  | 349d? | 2006-02-13 A | 2007-06-14 A | 100% | 2006-02-13 | 2007-06-14 | 349d? | finish no earlier than 2007-06-14 | S5 | 2792h | 2792h | OAM7-PM | China Mobile |  | Rel-7 | Dionisio |  |

Notes:
- 1182: - / Text3: 26.235, 26.236
- 1183: SP-35 stopped
- 1184: - / Text3: 26.944
- 1185: - / Text3: 26.234, 26.244
- 1186: - / Text3: TR 30.817
- 1187: -
- 1188: - / Text3: 32.731/2/3/5, 32.631/2/3/5
- 1189: - / Text3: 32.806, 32.814, 32.101
- 1190: - / Text3: 32.811
- 1191: - / Text3: 32.391/2/3/5
- 1192: - / Text3: 32.307/317/607/667/665, 32.101, 32.175
- 1193: - / Text3: 32.372/3/5, 32.111,32.30x,32.32x,32.33x,32.34x,32.35x,32.36x,32.41x,32.60x,32.61x,32.66x
- 1194: - / Text3: 32.381/2/3/5
- 1195: Request to TSG#35 to STOP the WI / Text3: new 32.xxx
- 1196: Request to TSG#35 to STOP the WI / Text3: 32.62n; For n = 1 to 5
- 1197: - / Text3: 32.154
- 1198: - / Text3: 32.721/2/3/5
- 1199: - / Text3: 32.405, 32.64n; For n = 1 to 5
- 1200: 12/2006 SP#34 WID approved / Text3: New 32.325/345/365/415, CR to 32.335/615/665
- 1201: -
- 1202: - / Text3: 32.407, 32.408
- 1203: - / Text3: 32.405
- 1204: - / Text3: 32.405
- 1205: - / Text3: No impact on 32.404, 32.405, 32.406, 32.407
- 1206: - / Text3: 32.404,32.409,32.437, 32.632/3/4/5
- 1207: - / Text3: 32.405

| ID | WBS | Task | Type | Duration | Start | Finish | Complete | Baseline start | Baseline finish | Baseline duration | Constraint | Resources | Work | Actual work | Text1 | Text4 | Text6 | Text8 | Text12 | Text5 | Text11 |
| --- | --- | --- | --- | --- | --- | --- | --- | --- | --- | --- | --- | --- | --- | --- | --- | --- | --- | --- | --- | --- | --- |
| 1208 | 44.5 | **Rel-7 Trace Management** |  | 472.86d? | 2005-09-02 A | 2007-06-26 A | 100% | 2005-09-02 | 2007-06-26 | 472.86d? |  | S5 | 14150.9h | 14150.9h | OAM7-Trace | Vodafone | Rel-7 | Dionisio |  |  |  |
| 1209 | 474.3.1 | End-to-end Service Level tracing for IMS |  | 350d? | 2005-11-11 A | 2007-03-15 A | 100% | 2005-11-11 | 2007-03-15 | 350d? | finish no earlier than 2007-03-15 | S5 | 2800h | 2800h | OAM7-Trace | Vodafone | Rel-7 | Dionisio | SP-31 |  |  |
| 1210 | 474.3.2 | Trace record content for UTRAN TDD |  | 330d? | 2005-09-02 A | 2006-12-07 A | 100% | 2005-09-02 | 2006-12-07 | 330d? | finish no earlier than 2006-12-07 | S5 | 2640h | 2640h | OAM7-Trace | Nokia | Rel-7 | Dionisio |  |  |  |
| 1211 | 474.3.3 | IRP for Subscriber and Equipment Trace Management |  | 465d? | 2005-09-02 A | 2007-06-14 A | 100% | 2005-09-02 | 2007-06-14 | 465d? | finish no earlier than 2007-06-14 | S5 | 3720h | 3720h | OAM7-Trace | Nokia | Rel-7 | Dionisio |  |  |  |
| 1212 | 474.3.4 | Deleted - SIP enhancements for trace | milestone | 0d? | 2007-06-15 A | 2007-06-26 A | 100% | 2007-06-15 | 2007-06-26 | 0d? | start no earlier than 2007-06-15 | C1 |  |  | OAM7-Trace |  | Rel-7 | Frederic | CP-32 |  |  |
| 1213 | 474.3.5 | Deleted - duplicated with UID 35063 - IRP for Subscriber and Equipment Trace Management |  | 336d? | 2005-09-02 A | 2006-12-15 A | 100% | 2005-09-02 | 2006-12-15 | 336d? | finish no earlier than 2006-12-15 | S5 | 2688h | 2688h | OAM7-Trace | Nokia | Rel-7 | Dionisio | SP-33 |  |  |
| 1214 | 475 | **Rel-7 Charging Management small Enhancements** |  | 279d? | 2006-05-22 A | 2007-06-14 A | 100% | 2006-05-22 | 2007-06-14 | 279d? |  | S5 | 5952h | 5952h | CH7 | Orange | Rel-7 | Dionisio |  | alain.bibas@orange-ft.com |  |
| 1215 | 475.1 | Alternate Charged Party (ACP) for IMS |  | 279d? | 2006-05-22 A | 2007-06-14 A | 100% | 2006-05-22 | 2007-06-14 | 279d? | finish no earlier than 2007-06-14 | S5 | 2232h | 2232h | CH7-IMS-ACP | Lucent | Rel-7 | Dionisio |  | njmazzarella@alcatel-lucent.com |  |
| 1216 | 475.2 | Align 3GPP Charging with OMA PoC Enabler Release 2.0 |  | 186d? | 2006-09-28 A | 2007-06-14 A | 100% | 2006-09-28 | 2007-06-14 | 186d? | finish no earlier than 2007-06-14 | S5 | 1488h | 1488h | CH7-PoC | Siemens | Rel-7 | Dionisio |  | Gerald.Goermer@nsn.com |  |
| 1217 | 8.5 | **Multiple-Input Multiple-Output (MIMO) antennas** |  | 1301d? | 2003-03-14 A | 2008-03-07 A | 100% | 2003-03-14 | 2008-03-07 | 1301d? |  | R1,R5 | 45440h | 45440h | MIMO | Alcatel-Lucent | Rel-7 | Patrick |  | hchuang@Alcatel-Lucent.com | RP-070037, RP-070531 |
| 1218 | 476.1 | MIMO - Physical layer |  | 915d? | 2003-09-12 A | 2007-03-15 A | 100% | 2003-09-12 | 2007-03-15 | 915d? | finish no earlier than 2007-03-15 | R1 | 7320h | 7320h | MIMO-Phys | Alcatel-Lucent | Rel-7 | Patrick |  | hchuang@Alcatel-Lucent.com | RP-070037 |
| 1219 | 476.2 | MIMO - Layer 2,3 aspects |  | 915d? | 2003-09-12 A | 2007-03-15 A | 100% | 2003-09-12 | 2007-03-15 | 915d? | finish no earlier than 2007-03-15 | R2 | 7320h | 7320h | MIMO-L23 | Alcatel-Lucent | Rel-7 | Joern |  | hchuang@Alcatel-Lucent.com | RP-070037 |
| 1220 | 476.3 | MIMO - Iub/Iur Protocol Aspects |  | 1045d? | 2003-03-14 A | 2007-03-15 A | 100% | 2003-03-14 | 2007-03-15 | 1045d? | finish no earlier than 2007-03-15 | R3 | 8360h | 8360h | MIMO-IurIub | Alcatel-Lucent | Rel-7 | Juha |  | hchuang@Alcatel-Lucent.com | RP-070037 |
| 1221 | 476.4 | MIMO - RF Radio Transmission/Reception, System Performance Requirements and Conformance Testing |  | 982d? | 2003-12-12 A | 2007-09-17 A | 100% | 2003-12-12 | 2007-09-17 | 982d? | finish no earlier than 2007-09-17 | R4 | 7856h | 7856h | MIMO-RF | Alcatel-Lucent | Rel-7 | Issam |  | ngm@Alcatel-Lucent.com | RP-070531 |
| 1222 | 476.5 | **UE Conformance Testing for Multiple Input Multiple Output antennas (MIMO)** |  | 261d? | 2007-03-09 A | 2008-03-07 A | 100% | 2007-03-09 | 2008-03-07 | 261d? |  | R5 | 4176h | 4176h | MIMO-UEConTest | Qualcomm | Rel-7 | Ingbert |  | svora@qualcomm.com |  |
| 1223 | 476.5.1 | Conformance Test Aspects – Multiple Input Multiple Output Antennas (MIMO) for FDD |  | 261d? | 2007-03-09 A | 2008-03-07 A | 100% | 2007-03-09 | 2008-03-07 | 261d? | finish no earlier than 2008-03-07 | R5 | 2088h | 2088h | MIMO-UEConTest_FDD | Qualcomm | Rel-7 | Ingbert |  | svora@qualcomm.com |  |
| 1224 | 477 | **Rel-7 Improvements of the Radio Interface** |  | 709d? | 2004-09-15 A | 2007-06-04 A | 100% | 2004-09-15 | 2007-06-04 | 709d? |  | RP | 29696h | 29696h | RInImp |  | Rel-7 | Issam |  |  |  |
| 1225 | 477.1 | Extended UMTS 1.7/2.1 GHz |  | 198d? | 2006-03-15 A | 2006-12-15 A | 100% | 2006-03-15 | 2006-12-15 | 198d? | finish no earlier than 2006-12-15 | R4 | 1584h | 1584h | RInImp-UMTS1721Ext | Ericsson | Rel-7 | Issam |  | johan.skold@ericsson.com | RP-060681 |
| 1226 | 477.2 | UMTS 2.6 GHz 7.68 Mcps TDD |  | 67d? | 2006-06-15 A | 2006-09-15 A | 100% | 2006-06-15 | 2006-09-15 | 67d? | finish no earlier than 2006-09-15 | R4 | 536h | 536h | RInImp-UMTS26VHCRTDD | IPWireless | Rel-7 | Issam |  | Shin Horng Wong (shwong@ipwireless.com) | RP-060451 |
| 1227 | 477.3 | UMTS 2.6 GHz |  | 195d? | 2004-09-15 A | 2005-06-14 A | 100% | 2004-09-15 | 2005-06-14 | 195d? | finish no earlier than 2005-06-14 | R4 | 1560h | 1560h | RInImp-UMTS2600 | Nokia | Rel-7 | Issam |  | jussi.numminen@nokia.com | RP-050184 |
| 1228 | 477.4 | UMTS 2.6 GHz TDD |  | 261d? | 2004-12-15 A | 2005-12-14 A | 100% | 2004-12-15 | 2005-12-14 | 261d? | finish no earlier than 2005-12-15 | R4 | 2088h | 2088h | RInImp-UMTS2600TDD | IPWireless | Rel-7 | Issam |  | Shin Horng Wong (shwong@ipwireless.com) | RP-050661 |
| 1229 | 477.5 | UMTS 900 MHz |  | 261d? | 2004-12-15 A | 2005-12-14 A | 100% | 2004-12-15 | 2005-12-14 | 261d? | finish no earlier than 2005-12-15 | R4 | 2088h | 2088h | RInImp-UMTS900 | Nortel | Rel-7 | Issam |  | Yannick Li (yli@nortelnetworks.com) | RP-050662 |
| 1230 | 477.6 | UMTS 1700 MHz |  | 197d? | 2005-03-15 A | 2005-12-14 A | 100% | 2005-03-15 | 2005-12-14 | 197d? | finish no earlier than 2005-12-15 | R4 | 1576h | 1576h | RInImp-UMTS1700 | NTT DoCoMo | Rel-7 | Issam |  | Takehiro Nakamura (nakamurata@nttdocomo.co.jp) | RP-050824 |
| 1231 | 477.7 | UE Antenna Performance Evaluation Method and Requirements |  | 644d? | 2004-12-15 A | 2007-06-04 A | 100% | 2004-12-15 | 2007-06-04 | 644d? | finish no earlier than 2007-06-04 | R4 | 5152h | 5152h | RInImp-UEAnt | TeliaSonera | Rel-7 | Issam |  | Christian.Bergljung@TeliaSonera.com | RP-070281 |
| 1232 | 477.8 | Improved Performance Requirements for HSDPA UE based on Rx Diversity (type 1) & LMMSE equalizer (type 2) | milestone | 0d? | 2005-03-15 A | 2005-03-15 A | 100% | 2005-03-15 | 2005-03-15 | 0d? | finish no earlier than 2005-03-15 | R4 |  |  | RInImp-HSPerf-Type3 | Cingular | Rel-7 | Issam |  | Marc Grant | RP-060015 |

Notes:
- 1208: -
- 1209: 07/2005: OMA (Stage 1), Stage 2/3 SA5, CT1/3/4 / Text3: CR 32.101, 32.421/2/3.
- 1210: - / Text3: CR 32.421/2/3.
- 1211: - / Text3: 32.441/2/3/5, CRs 32.632/3/5
- 1212: combined with UID 11067
- 1213: - / Text3: 32.421,32.422,32.423. 3 new 32.4x1,2,3
- 1214: - / Text3: TR 30.817
- 1215: - / Text3: 32.240, 32.260, 32.298, 32.299
- 1216: 09/2006 SP#33 WID approved / Text3: 32.240, 32.272, 32.299, 32.298
- 1217: Completed Sep 2007; SR in RP-070037and RP-070531 / Text3: 25.876, 25.996
- 1218: Completed Sep 2007; SR in RP-070037 / Text3: 25.211, 25.212, 25.213, 25.214, 25.215, 25.221
- 1219: Completed Sep 2007; SR in RP-070037 / Text3: 25.876
- 1220: Completed Sep 2007; SR in RP-070037
- 1221: Completed Sep 2007; SR in RP-070531
- 1222: BB place holder for a number of RAN5 Tasks
- 1223: - / Text3: TS 34.108, TS 34.109, TS 34.121-1, TS 34.121-2, TS 34.123-1, TS 34.123-2, TS 34.123-3
- 1224: Generic feature
- 1225: RP#34 completed. Introduction of Band X (Extended UMTS 1.7/2.1 GHz) in 25.307 / Text3: 25.806, 25.101, 25.104, 25.133, 24.141, 25.331, 25.306, 25.307, 25.423, 25.461, 25.463, 34.121
- 1226: RP#33 completed / Text3: 25.102, 25.105, 25.123, 25.113, 25.142, 34.124
- 1227: RP#28 completed / Text3: 25.101, 25.104, 25.133, 25.141, 25.331, 25.942, 25.306, 25.307, 34.121
- 1228: RP#30 completed / Text3: 25.102, 25.105, 25.113, 25.123, 25.142, 25.331, 25.942, 25.306, 25.307, 34.122, 34.124
- 1229: RP#30 completed / Text3: 25.101, 25.104, 25.113, 25.133, 25.141, 25.331, 25.942, 25.306, 25.307, 34.121
- 1230: RP#30 completed / Text3: 25.101, 25.104, 25.113, 25.133, 25.141, 25.306, 25.307, 25.331, 34.121
- 1231: RP#36 completed / Text3: 25.101, new TR 25.963
- 1232: RP#27 completed / Text3: 25.101

| ID | WBS | Task | Type | Duration | Start | Finish | Complete | Baseline start | Baseline finish | Baseline duration | Constraint | Deadline | Resources | Work | Actual work | Text1 | Text4 | Text5 | Text6 | Text8 | Text11 | Text12 | Text9 | Text10 |
| --- | --- | --- | --- | --- | --- | --- | --- | --- | --- | --- | --- | --- | --- | --- | --- | --- | --- | --- | --- | --- | --- | --- | --- | --- |
| 1233 | 477.9 | **Additional minimum UE performance requirement for non-HSDPA channels based on type 1 enhanced receiver (Rx Diversity)** |  | 327d? | 2005-09-15 A | 2006-12-15 A | 100% | 2005-09-15 | 2006-12-15 | 327d? |  |  | R4 | 7344h | 7344h | RInImp-RxDiv | Qualcomm | Serge Willenegger (sergew@qualcomm.com) | Rel-7 | Issam |  |  |  |  |
| 1234 | 477.9.1 | Additional minimum UE performance requirement for DL physical channels in support of DCH/HS-DSCH operation based on type 1 enhanced receiver (RX-Diversity) |  | 195d? | 2005-09-15 A | 2006-06-14 A | 100% | 2005-09-15 | 2006-06-14 | 195d? | finish no earlier than 2006-06-15 |  | R4 | 1560h | 1560h | RInImp-RxDiv-DCH | Cingular | Marc Grant | Rel-7 | Issam | RP-060235 |  |  |  |
| 1235 | 477.9.2 | Additional minimum UE performance requirement for downlink physical channels in support of MTCH and MCCH operation based on type 1 enhanced receiver (Rx-Diversity) |  | 198d? | 2006-03-15 A | 2006-12-15 A | 100% | 2006-03-15 | 2006-12-15 | 198d? | finish no earlier than 2006-12-15 |  | R4 | 1584h | 1584h | RInImp-RxDiv-MBMS | Qualcomm | Serge Willenegger (sergew@qualcomm.com) | Rel-7 | Issam | RP-060678 |  |  |  |
| 1236 | 477.9.3 | Additional minimum UE performance requirement for downlink physical channels in support of E-DCH operation based on type 1 enhanced receiver (Rx-Diversity) |  | 198d? | 2006-03-15 A | 2006-12-15 A | 100% | 2006-03-15 | 2006-12-15 | 198d? | finish no earlier than 2006-12-15 |  | R4 | 1584h | 1584h | RInImp-RxDiv-EDCH | Qualcomm | Serge Willenegger (sergew@qualcomm.com) | Rel-7 | Issam | RP-060679 |  |  |  |
| 1237 | 477.10 | Deleted Improved support of gaming over HSDPA/EDCH |  | 262d? | 2005-12-15 A | 2006-12-15 A | 100% | 2005-12-15 | 2006-12-15 | 262d? | finish no earlier than 2006-12-15 |  | R2 | 2096h | 2096h | RInImp-Gaming | Cingular | Don Zelmer (dz1069@att.com) | Rel-7 | Joern | RP-060680 | RP-34 |  |  |
| 1238 | 477.11 | Deleted (not approved at PCG) - UMTS 2.6 GHz FDD DL External | milestone | 0d? | 2005-09-15 A | 2005-09-15 A | 100% | 2005-09-15 | 2005-09-15 | 0d? | finish no earlier than 2005-09-15 |  | R4 |  |  | RInImp-UMTS2600Ext | T-mobile | han.van.bussel@t-mobile.de | Rel-7 | Issam |  | RP-31 | PCG-16 |  |
| 1239 | 478 | **Rel-7 Improvements of the Radio Interface - UE Conformance Testing** |  | 741d? | 2005-11-11 A | 2008-09-12 A | 100% | 2005-11-11 | 2008-09-12 | 741d? |  |  | R5 | 17568h | 17568h | RInImp-UEConTest |  |  | Rel-7 | Ingbert |  |  |  |  |
| 1240 | 16.5.1 | UE Conformance Test for UMTS 2600 MHz |  | 146d | 2005-11-11 A | 2006-06-02 A | 100% | 2005-11-11 | 2006-06-02 | 146d | finish no earlier than 2006-06-02 | 2006-06-02 | R5 | 1168h | 1168h | RInImp-UMTS2600_Test | Nokia | Aleksi.Heino@nokia.com | Rel-7 | Ingbert |  |  |  | Fri 7/11/05 |
| 1241 | 16.5.1 | UE Conformance Test for UMTS 900 MHz (band VIII) |  | 146d | 2005-11-11 A | 2006-06-02 A | 100% | 2005-11-11 | 2006-06-02 | 146d | finish no earlier than 2006-06-02 | 2006-06-02 | R5 | 1168h | 1168h | RInImp-UMTS900_Test | Qualcomm | hanye@qualcomm.com | Rel-7 | Ingbert |  |  |  | Fri 11/03/05 |
| 1242 | 478.3 | Conformance Test Aspects – Improved Performance of HSDPA Receiver type 3 |  | 191d? | 2006-03-10 A | 2006-12-01 A | 100% | 2006-03-10 | 2006-12-01 | 191d? | finish no earlier than 2006-12-01 |  | R5 | 1528h | 1528h | RInImp-HSPerf-Type3_Test | Motorola | carolyn.taylor@motorola.com | Rel-7 | Ingbert |  |  |  |  |
| 1243 | 478.4 | UE antenna Over The Air (OTA) conformance testing |  | 518d? | 2006-09-20 A | 2008-09-12 A | 100% | 2006-09-20 | 2008-09-12 | 518d? | finish no earlier than 2008-09-12 |  | R5 | 4144h | 4144h | RInImp-UEAnt_Test | Nokia | Aleksi.Heino@nokia.com | Rel-7 | Ingbert | RP-080535 |  |  |  |
| 1244 | 478.5 | UE conformance testing for FDD Inter-Band Operation |  | 131d? | 2006-06-02 A | 2006-12-01 A | 100% | 2006-06-02 | 2006-12-01 | 131d? | finish no earlier than 2006-12-01 |  | R5 | 1048h | 1048h | RInImp-InterBand_Test | NEC, Motorola | Jacob.John@motorola.com | Rel-7 | Ingbert |  |  |  |  |
| 1245 | 478.6 | Conformance Test Aspects – Extended UMTS 1.7/2.1 GHz |  | 131d? | 2006-12-01 A | 2007-06-01 A | 100% | 2006-12-01 | 2007-06-01 | 131d? | finish no earlier than 2007-06-01 |  | R5 | 1048h | 1048h | RInImp-UEConTest_UMTS1721Ext | Motorola | carolyn.taylor@motorola.com | Rel-7 | Ingbert | RP-070312 |  |  |  |
| 1246 | 478.7 | Conformance Test Aspects – Minimum UE performance requirement for downlink physical channels in support of E-DCH operation based on type 1 enhanced receiver (Rx-Diversity) |  | 136d? | 2007-06-01 A | 2007-12-07 A | 100% | 2007-06-01 | 2007-12-07 | 136d? | finish no earlier than 2007-12-07 |  | R5 | 1088h | 1088h | RInImp-UEConTest_RxDivEDCH | Motorola | carolyn.taylor@motorola.com | Rel-7 | Ingbert | RP-070810 |  |  |  |
| 1247 | 478.8 | Conformance Test Aspects – Minimum UE performance requirement for downlink physical channels in support of MTCGH and MCCH operation based on type 1 enhanced receiver (Rx-Diversity) |  | 201d? | 2007-06-01 A | 2008-03-07 A | 100% | 2007-06-01 | 2008-03-07 | 201d? | finish no earlier than 2008-03-07 |  | R5 | 1608h | 1608h | RInImp-UEConTest_RxDivMBMS | Ericsson | leif.mattisson@ericsson.com | Rel-7 | Ingbert | RP-080056 |  |  |  |
| 1248 | 479 | **Rel-7 RAN improvements** |  | 653d? | 2004-12-15 A | 2007-06-15 A | 100% | 2004-12-15 | 2007-06-15 | 653d? |  |  | RP,S5 | 24728h | 24728h | RANimp |  |  | Rel-7 |  |  |  |  |  |
| 1249 | 479.1 | Optimization of channelisation code utilisation for 1.28 Mcps TDD |  | 523d? | 2004-12-15 A | 2006-12-15 A | 100% | 2004-12-15 | 2006-12-15 | 523d? | finish no earlier than 2006-12-15 |  | R1 | 4184h | 4184h | RANimp-RABSE-CodOptLCRTDD | UTStarcom | Ka Leong Lo (kaleong.lo@UTSTAR.COM) | Rel-7 | Patrick | RP-060682 |  |  |  |
| 1250 | 479.2 | Delay optimization for procedures applicable to CS and PS Connections |  | 394d? | 2005-03-15 A | 2006-09-15 A | 100% | 2005-03-15 | 2006-09-15 | 394d? | finish no earlier than 2006-09-15 |  | R2 | 3152h | 3152h | RANimp-DelayOpt | Nokia | juho.pirskanen@nokia.com | Rel-7 | Joern | RP-060453 |  |  |  |
| 1251 | 479.3 | Improved support of IMS Realtime Services using HSDPA/HSUPA |  | 197d? | 2005-03-15 A | 2005-12-14 A | 100% | 2005-03-15 | 2005-12-14 | 197d? | start no earlier than 2005-03-15 |  | R2 | 1576h | 1576h | RANimp-IMSRealTime | Cingular | Don Zelmer (dz1069@att.com) | Rel-7 | Joern | RP-050667 |  |  |  |
| 1252 | 479.4 | UE Performance Requirements for MBMS (TDD) |  | 328d? | 2005-03-15 A | 2006-06-15 A | 100% | 2005-03-15 | 2006-06-15 | 328d? | finish no earlier than 2006-06-15 |  | R4 | 2624h | 2624h | MBMS-RAN-RF-TDD | IPwireless | shwong@ipwireless.com | Rel-7 | Issam | RP-060477 |  |  |  |
| 1253 | 479.5 | Continuous connectivity for packet data users |  | 524d? | 2005-03-14 A | 2007-03-15 A | 100% | 2005-03-14 | 2007-03-15 | 524d? | finish no earlier than 2007-03-15 |  | R1 | 4192h | 4192h | RANimp-CPC | Siemens | Joern.Krause@siemens.com | Rel-7 | Patrick | RP-070033 |  |  |  |
| 1254 | 479.6 | Extended WCDMA Cell Range |  | 198d? | 2006-03-15 A | 2006-12-15 A | 100% | 2006-03-15 | 2006-12-15 | 198d? | finish no earlier than 2006-12-15 |  | R3 | 1584h | 1584h | RANimp-ExtCell | Ericsson | Muhammad Kazmi | Rel-7 | Juha | RP-060685 |  |  |  |
| 1255 | 479.7 | 7.68 Mcps TDD Enhanced Uplink |  | 198d? | 2006-03-15 A | 2006-12-15 A | 100% | 2006-03-15 | 2006-12-15 | 198d? | finish no earlier than 2006-12-15 |  | R1 | 1584h | 1584h | RANimp-VHCRTDD-EDCH | IPwireless | nanderson@ipwireless.com | Rel-7 | Patrick | RP-060684 |  |  |  |
| 1256 | 479.8 | Enhanced CELL_FACH State in FDD |  | 181d? | 2006-09-25 A | 2007-06-04 A | 100% | 2006-09-25 | 2007-06-04 | 181d? | finish no earlier than 2007-06-04 |  | R2 | 1448h | 1448h | RANimp-EnhState | Nokia | juho.pirskanen@nokia.com | Rel-7 | Joern | RP-070286 |  |  |  |
| 1257 | 479.9 | 64QAM for HSDPA (FDD) |  | 110d? | 2006-12-15 A | 2007-06-04 A | 100% | 2006-12-15 | 2007-06-04 | 110d? | finish no earlier than 2007-06-04 |  | R1 | 880h | 880h | RANimp-64QamDownlink | Ericsson | Johan.Bergman@ericsson.com | Rel-7 | Patrick | RP-070287 |  |  |  |
| 1258 | 479.10 | Improved L2 support for high data rates |  | 122d? | 2006-12-15 A | 2007-06-04 A | 100% | 2006-12-15 | 2007-06-04 | 122d? | finish no earlier than 2007-06-04 |  | R2 | 976h | 976h | RANimp-L2DataRates | Ericsson | Janne.Peisa@ericsson.com | Rel-7 | Joern | RP-070289 |  |  |  |
| 1259 | 479.11 | Introduction of 16QAM in HSUPA (FDD) |  | 110d? | 2006-12-15 A | 2007-06-04 A | 100% | 2006-12-15 | 2007-06-04 | 110d? | finish no earlier than 2007-06-04 |  | R1 | 880h | 880h | RANimp-16QamUplink | Nokia | Karri.Ranta-aho@nsn.com | Rel-7 | Patrick | RP-070288 |  |  |  |

Notes:
- 1233: - / Text3: 25.101
- 1234: RP#32 completed / Text3: 25.101
- 1235: RP#34 completed / Text3: 25.101
- 1236: RP#34 completed / Text3: 25.101
- 1237: RP#34 stopped. SR in RP-060680
- 1238: This item was conditionnaly approved pending decision of PCG#16 who decided not to approve it / Text3: 25.101, 25.104, 25.133, 25.141, 25.331, 25.942, 25.306, 25.307, 34.121
- 1239: Linked to Feature UID_20028 (RInImp)
- 1240: RP#32 completed / Text3: 34.108, 34.121
- 1241: RP#32 completed / Text3: 34.108, 34.121
- 1242: RP#34 completed / Text3: 34.121, 34.108
- 1243: RP#41 completed (GERAN aspects might need to be included later) / Text3: 34.114
- 1244: RP#34 completed / Text3: 34.108, 34.123-1, 34.123-2, 34.123-3
- 1245: RP#36 completed / Text3: 34.108, 34.121-1, 34.121-2
- 1246: RP#38 completed
- 1247: RP#39 completed
- 1248: Generic feature
- 1249: RP#34 completed
- 1250: RP#33 completed / Text3: 25.815, 25.321, 25.322, 25.331
- 1251: RP#30 completed
- 1252: RP#32 completed / Text3: 25.102, 25.123
- 1253: RP#35 completed / Text3: 25.903, 25.201, 25.211, 25.212, 25.214, 25.308, 25.321, 25.331, 25.423, 25.433, 25.101, 25.133
- 1254: RP#34 completed / Text3: 25.133, 25.423, 25.425, 25.433, 25.435, 25.453, 25.331
- 1255: RP#34 completed / Text3: 25.201, 25.202, 25.221, 25.222, 25.223, 25.224, 25.225, 25.331, 23.321, 25.306, 25.302, 25.401, 25.420, 25.423, 25.427, 25.433, 25.102, 25.105, 25.142
- 1256: RP#36 completed / Text3: 25.308, 25.304, 25.306, 25.321, 25.331, 25.433, 25.435, 25.423, 25.425,
- 1257: RP#36 completed / Text3: 25.308, 25.211, 25.212, 25.213, 25.306, 25.331, 25.433, 25.435, 25.423, 25.425, 25.101, 25.104, 25.141
- 1258: RP#36 completed / Text3: 25.301, 25.308,25.306, 25.321, 25.322, 25.331, 25.433, 25.435, 25.423, 25.425, 25.999
- 1259: RP#36 completed / Text3: 25.319, 25.101, 25.104, 25.133, 25.141, 25.211, 25.212, 25.213, 25.214, 25.306, 25.321, 25.331, 25.423, 25.433

| ID | WBS | Task | Duration | Start | Finish | Complete | Baseline start | Baseline finish | Baseline duration | Constraint | Resources | Work | Actual work | Text1 | Text4 | Text5 | Text6 | Text8 | Text11 | Text2 | Text7 |
| --- | --- | --- | --- | --- | --- | --- | --- | --- | --- | --- | --- | --- | --- | --- | --- | --- | --- | --- | --- | --- | --- |
| 1260 | 479.12 | **Interface to control Tower Mounted Amplifiers (TMAs)** | 271d? | 2006-06-02 A | 2007-06-15 A | 100% | 2006-06-02 | 2007-06-15 | 271d? |  | R3,S5 | 1648h | 1648h | RANImp-TMA | Vodafone | alexej.kulakov@vodafone.com | Rel-7 | Juha | RP-070140 |  |  |
| 1261 | 479.12.1 | RAN3 part of Interface to control Tower Mounted Amplifiers (TMAs) | 206d? | 2006-06-02 A | 2007-03-16 A | 100% | 2006-06-02 | 2007-03-16 | 206d? |  | R3 | 840h | 840h | RANImp-TMA | Vodafone | alexej.kulakov@vodafone.com | Rel-7 | Juha | RP-070140 |  |  |
| 1262 | 479.12.2 | OAM aspects to Interface to control TMAs | 101d? | 2007-01-26 A | 2007-06-15 A | 100% | 2007-01-26 | 2007-06-15 | 101d? | finish no earlier than 2007-06-15 | S5 | 808h | 808h | RANImp-TMA-OAM | Vodafone | Adrian.Neal@vodafone.com | Rel-7 | Dionisio |  |  |  |
| 1263 | 480 | **Rel-7 RAN improvements - UE Conformance Testing** | 784d? | 2006-09-20 A | 2009-09-18 A | 100% | 2006-09-20 | 2009-09-18 | 784d? |  | R5 | 25472h | 25472h | RANimp-UEConTest |  |  | Rel-7 | Ingbert |  |  |  |
| 1264 | 480.1 | Conformance Test Aspects - 3.84 Mcps and 7.68 Mcps TDD Enhanced Uplink | 518d? | 2006-09-20 A | 2008-09-12 A | 100% | 2006-09-20 | 2008-09-12 | 518d? | finish no earlier than 2008-09-12 | R5 | 4144h | 4144h | RANimp-UEConTest_EDCHTDH | IPWireless | tspeight@ipwireless.com | Rel-7 | Ingbert | RP-080536 |  |  |
| 1265 | 480.2 | Conformance Test Aspects – 64QAM for HSDPA (FDD) | 257d? | 2007-03-09 A | 2008-03-03 A | 100% | 2007-03-09 | 2008-03-03 | 257d? | finish no earlier than 2008-03-03 | R5 | 2056h | 2056h | RANimp-UEConTest_64QamDownlink | Ericsson | leif.mattisson@ericsson.com | Rel-7 | Ingbert | RP-080059 |  |  |
| 1266 | 480.3 | Conformance Test Aspects – 16QAM for HSUPA (FDD) | 321d? | 2007-03-09 A | 2008-05-30 A | 100% | 2007-03-09 | 2008-05-30 | 321d? | finish no earlier than 2008-05-30 | R5 | 2568h | 2568h | RANimp-UEConTest_16QamUplink | Motorola | carolyn.taylor@motorola.com | Rel-7 | Ingbert | RP-080281 |  |  |
| 1267 | 480.4 | Conformance Test Aspects – Improved L2 support for high data rates | 321d? | 2007-03-09 A | 2008-05-30 A | 100% | 2007-03-09 | 2008-05-30 | 321d? | finish no earlier than 2008-05-30 | R5 | 2568h | 2568h | RANimp-UEConTest_L2DataRates | Ericsson | leif.mattisson@ericsson.com | Rel-7 | Ingbert | RP-080256 |  |  |
| 1268 | 480.5 | Conformance Test Aspects – Continuous connectivity for packet data users | 321d? | 2007-03-09 A | 2008-05-30 A | 100% | 2007-03-09 | 2008-05-30 | 321d? | finish no earlier than 2008-05-30 | R5 | 2568h | 2568h | RANimp-UEConTest_CPC | Nokia | jarkko.hellsten@nokia.com | Rel-7 | Ingbert | RP-080282 |  |  |
| 1269 | 480.6 | Conformance Test Aspects – Enhanced CELL_FACH state in FDD | 662d? | 2007-03-09 A | 2009-09-18 A | 100% | 2007-03-09 | 2009-09-18 | 662d? | finish no earlier than 2009-09-18 | R5 | 5296h | 5296h | RANimp-UEConTest_EnhancedCellFACHState | Nokia | jarkko.hellsten@nokia.com | Rel-7 | Ingbert | RP-090711 |  |  |
| 1270 | 481 | **7.68 Mcps TDD option** | 783d? | 2004-09-15 A | 2007-09-14 A | 100% | 2004-09-15 | 2007-09-14 | 783d? |  | R1,R2,R3,R4,R5 | 24496h | 24496h | VHCRTDD | IPwireless | Martin Beale (mbeale@ipwireless.com) | Rel-7 |  | RP-060684 |  |  |
| 1271 | 481.1 | VHCRTDD: Stage 2 | 391d? | 2004-09-15 A | 2006-03-15 A | 100% | 2004-09-15 | 2006-03-15 | 391d? | finish no earlier than 2006-03-15 | R1 | 3128h | 3128h | VHCRTDD-Stage2 | IPwireless | Martin Beale (mbeale@ipwireless.com) | Rel-7 | Patrick | RP-060684 |  |  |
| 1272 | 481.2 | VHCRTDD: Physical Layer | 391d? | 2004-09-15 A | 2006-03-15 A | 100% | 2004-09-15 | 2006-03-15 | 391d? | finish no earlier than 2006-03-15 | R1 | 3128h | 3128h | VHCRTDD-Phys | IPwireless | Martin Beale (mbeale@ipwireless.com) | Rel-7 | Patrick | RP-060684 |  |  |
| 1273 | 481.3 | VHCRTDD: Layer 2 and layer 3 protocol aspects | 391d? | 2004-09-15 A | 2006-03-15 A | 100% | 2004-09-15 | 2006-03-15 | 391d? | finish no earlier than 2006-03-15 | R2 | 3128h | 3128h | VHCRTDD-L23 | IPwireless | drichards@ipwireless.com | Rel-7 | Joern | RP-060684 |  |  |
| 1274 | 481.4 | VHCRTDD: UTRAN Iub/Iur Protocol Aspects | 391d? | 2004-09-15 A | 2006-03-15 A | 100% | 2004-09-15 | 2006-03-15 | 391d? | finish no earlier than 2006-03-15 | R3 | 3128h | 3128h | VHCRTDD-IurIub | IPwireless | Peter Legg (plegg@ipwireless.com) | Rel-7 | Juha | RP-060684 |  |  |
| 1275 | 481.5 | VHCRTDD: RF Radio Transmission/ Reception, System Performance Requirements and Conformance Testing | 457d? | 2004-09-15 A | 2006-06-15 A | 100% | 2004-09-15 | 2006-06-15 | 457d? | finish no earlier than 2006-06-15 | R4 | 3656h | 3656h | VHCRTDD-RF | IPwireless | Shin Horng Wong (shwong@ipwireless.com) | Rel-7 | Issam | RP-060684 |  |  |
| 1276 | 481.6 | Conformance Test Aspects - 7.68 Mcps TDD | 258d? | 2006-09-20 A | 2007-09-14 A | 100% | 2006-09-20 | 2007-09-14 | 258d? | finish no earlier than 2007-09-10 | R5 | 2064h | 2064h | VHCRTDD-UEConTest | IPWireless | tspeight@ipwireless.com | Rel-7 | Ingbert | RP-070307 |  |  |
| 1277 | 482 | **3.84 Mcps TDD Enhanced Uplink** | 394d? | 2005-03-15 A | 2006-09-15 A | 100% | 2005-03-15 | 2006-09-15 | 394d? |  | RP | 18384h | 18384h | EDCHTDD | IPwireless | nanderson@ipwireless.com | Rel-7 |  | RP-060462 |  |  |
| 1278 | 482.1 | EDCHTDD: Stage 2 | 328d? | 2005-03-15 A | 2006-06-15 A | 100% | 2005-03-15 | 2006-06-15 | 328d? | finish no earlier than 2006-06-15 | R2 | 2624h | 2624h | EDCHTDD-Stage2 | IPwireless | nanderson@ipwireless.com | Rel-7 | Joern | RP-060462 |  |  |
| 1279 | 482.2 | EDCHTDD: Physical Layer | 394d? | 2005-03-15 A | 2006-09-15 A | 100% | 2005-03-15 | 2006-09-15 | 394d? | finish no earlier than 2006-09-15 | R1 | 3152h | 3152h | EDCHTDD-Phys | IPwireless | nanderson@ipwireless.com | Rel-7 | Patrick | RP-060462 |  |  |
| 1280 | 482.3 | EDCHTDD: Layer 2 and 3 Protocol Aspects | 394d? | 2005-03-15 A | 2006-09-15 A | 100% | 2005-03-15 | 2006-09-15 | 394d? | finish no earlier than 2006-09-15 | R2 | 3152h | 3152h | EDCHTDD-L23 | IPwireless | drichards@ipwireless.com | Rel-7 | Joern | RP-060462 |  |  |
| 1281 | 482.4 | EDCHTDD: UTRAN Iub/Iur Protocol Aspects | 394d? | 2005-03-15 A | 2006-09-15 A | 100% | 2005-03-15 | 2006-09-15 | 394d? | finish no earlier than 2006-09-15 | R3 | 3152h | 3152h | EDCHTDD-IurIub | Interdigital | jim.miller@interdigital.com | Rel-7 | Juha | RP-060462 |  |  |
| 1282 | 482.5 | EDCHTDD: RF Radio Transmission/ Reception, System Performance Requirements and Conformance Testing | 394d? | 2005-03-15 A | 2006-09-15 A | 100% | 2005-03-15 | 2006-09-15 | 394d? | finish no earlier than 2006-09-15 | R4 | 3152h | 3152h | EDCHTDD-RF | IPwireless | Shin Horng Wong (shwong@ipwireless.com) | Rel-7 | Issam | RP-060462 |  |  |
| 1283 | 483 | **1.28 Mcps TDD Enhanced Uplink** | 653d? | 2006-03-15 A | 2008-09-12 A | 100% | 2006-03-15 | 2008-09-12 | 653d? |  | R1,R2,R3,R4,R5 | 14760h | 14760h | LCRTDD-EDCH | CATT | Haijing Hu | Rel-7 |  | RP-070296 |  |  |
| 1284 | 483.1 | 1.28 Mcps TDD Enhanced Uplink: Physical Layer | 262d? | 2006-03-15 A | 2007-03-15 A | 100% | 2006-03-15 | 2007-03-15 | 262d? | finish no earlier than 2007-03-15 | R1 | 2096h | 2096h | LCRTDD-EDCH-Phys | CATT | Ke Wang | Rel-7 | Patrick | RP-070038 |  |  |
| 1285 | 483.2 | 1.28 Mcps TDD Enhanced Uplink: Layer 2 and 3 Protocol Aspects | 262d? | 2006-03-15 A | 2007-03-15 A | 100% | 2006-03-15 | 2007-03-15 | 262d? | finish no earlier than 2007-03-15 | R2 | 2096h | 2096h | LCRTDD-EDCH-L23 | CATT | Haiyang Quan | Rel-7 | Joern | RP-070038 |  |  |
| 1286 | 483.3 | 1.28 Mcps TDD Enhanced Uplink: UTRAN Iub/Iur Protocol Aspects | 262d? | 2006-03-15 A | 2007-03-15 A | 100% | 2006-03-15 | 2007-03-15 | 262d? | finish no earlier than 2007-03-15 | R3 | 2096h | 2096h | LCRTDD-EDCH-IubIur | CATT | Yincheng Zhang | Rel-7 | Juha | RP-070038 |  |  |
| 1287 | 483.4 | 1.28 Mcps TDD Enhanced Uplink: RF Radio Transmission/ Reception, System Performance Requirements and Conformance Testing | 328d? | 2006-03-15 A | 2007-06-15 A | 100% | 2006-03-15 | 2007-06-15 | 328d? | finish no earlier than 2007-06-15 | R4 | 2624h | 2624h | LCRTDD-EDCH-RF | CATT | Yuexia Song | Rel-7 | Issam | RP-070296 |  |  |
| 1288 | 483.5 | 1.28 Mcps TDD Enhanced Uplink - UE Conformance Testing | 257d? | 2007-09-20 A | 2008-09-12 A | 100% | 2007-09-20 | 2008-09-12 | 257d? | finish no earlier than 2008-09-11 | R5 | 624h | 624h | LCRTDD-EDCH-UEConTest | CATT | chenxiaozhong@datangmobile.cn | Rel-7 | Ingbert | RP-080539 |  |  |
| 1289 | 484 | Conformance Test Aspects – Multiple Band and Multiple Frequency operation for LCR TDD | 263d? | 2010-09-17 A | 2011-09-16 A | 100% | 2010-09-17 | 2011-09-16 | 263d? | finish no earlier than 2011-12-09 | R5 | 2091.37h | 2091.37h | LCRTDD_MB_MF_UEConTest | CATR | Ms Jun Chen (chenjun@catr.cn) | Rel-7 | Ingbert | RP-110968 | PCG-25 | RP-49 |
| 1290 | 485 | MS Antenna Performance Evaluation Method and Requirements | 731d? | 2005-01-28 A | 2007-11-16 A | 100% | 2005-01-28 | 2007-11-16 | 731d? | finish no earlier than 2007-11-16 | GP | 5848h | 5848h | APEMR | TeliaSonera | Ulf.Tegth@teliasonera.com | Rel-7 | Paolo |  |  |  |

Notes:
- 1260: RP#35 completed
- 1261: RP#35 completed
- 1262: SP#36 completed / Text3: 32.642, 32.643, 32.645 – Align with RAN 25.466
- 1263: Linked to Feature UID_20029 (RANimp)
- 1264: RP#41 completed / Text3: 34.108, 34.122, 34.123-1, 34.123-2, 34.123-3
- 1265: RP#39 completed / Text3: 34.108, 34.121-1, 34.121-2, 34.123-1, 34.123-2, 34.123-3
- 1266: RP#40 completed / Text3: 34.108, 34.121-1, 34.121-2, 34.123-1, 34.123-2, 34.123-3
- 1267: RP#40 completed / Text3: 34.108, 34.123-1, 34.123-2, 34.123-3
- 1268: RP#40 completed / Text3: 34.108, 34.121-1, 34.121-2, 34.123-1, 34.123-2, 34.123-3
- 1269: RP#45 completed / Text3: 34.108, 34.123-1, 34.123-2, 34.123-3
- 1270: RP#31 completed
- 1271: RP#31 completed / Text3: 25.202
- 1272: RP#31 completed / Text3: 25.221, 25.222, 25.223, 25.224,25.225
- 1273: RP#31 completed / Text3: 25.301, 25.302, 25.305, 25.306, 25.321, 25.331
- 1274: RP#31 completed / Text3: 25.401, 25.420, 25.423, 25.425, 25.427, 25.430, 25.433, 25.435
- 1275: RP#32 completed / Text3: 25.102, 25.105, 25.123, 25.133, 25.142
- 1276: RP#37 completed / Text3: 34.108, 34.122, 34.123-1, 34.123-2, 34.123-3
- 1277: RP#33 completed
- 1278: RP#33 completed
- 1279: RP#33 completed / Text3: 25.201, 25.221,25.222, 25.223, 25.224, 25.225
- 1280: RP#33 completed / Text3: 25.301, 25.302, 25.306, 25.321, 25.331
- 1281: RP#33 completed / Text3: 25.401, 25.420, 25.423, 25.427, 25.430, 25.433, 25.435
- 1282: RP#33 completed / Text3: 25.102, 25.105, 25.123, 25.142
- 1283: RP#35 completed
- 1284: RP#35 completed / Text3: 25.201, 25.221, 25.222, 25.223, 25.224, 25.225
- 1285: RP#35 completed / Text3: 25.301, 25.302, 25.306, 25.321, 25.331
- 1286: RP#35 completed / Text3: 25.401, 25.420, 25.423, 25.425, 25.427, 25.430, 25.433, 25.435
- 1287: RP#36 completed / Text3: 25.102, 25.105, 25.123, 25.142
- 1288: RP#41 completed / Text3: 34.108, 34.122, 34.123-1/2/3
- 1289: RP#53 completed. Core specification was introduced via Rel-7 CR under TEI7 (RP#37 RP-070650) and via 2 Rel-8 work items: RInImp9-UMTS1880TDD and RInImp8-UMTS2300TDD. / Text3: UTRA 34.108, 34.123-1, 34.123-2, 34.123-3
- 1290: GP#36 completed for R7 / Text3: 25.914, 25.144, 45.005

| ID | WBS | Task | Type | Duration | Start | Finish | Complete | Baseline start | Baseline finish | Baseline duration | Constraint | Resources | Work | Actual work | Text1 | Text4 | Text5 | Text6 | Text8 | Text12 |
| --- | --- | --- | --- | --- | --- | --- | --- | --- | --- | --- | --- | --- | --- | --- | --- | --- | --- | --- | --- | --- |
| 1291 | 486 | **Lower 700 MHz Inclusion in the GERAN Specifications** |  | 390d? | 2005-01-03 A | 2006-06-30 A | 100% | 2005-01-03 | 2006-06-30 | 390d? |  | GP | 7632h | 7632h | GSM710 | UTC | dcotton@mtview.union-tel.com | Rel-7 | Paolo |  |
| 1292 | 486.1 | Inclusion of the 698 – 746 MHz band into GERAN core specifications |  | 129d? | 2005-01-03 A | 2005-06-30 A | 100% | 2005-01-03 | 2005-06-30 | 129d? | finish no earlier than 2005-06-30 | G1 | 1032h | 1032h | GSM710-core |  |  | Rel-7 | Paolo |  |
| 1293 | 486.2 | G1 aspects of GSM710 |  | 217.5d? | 2005-08-31 A | 2006-06-30 A | 100% | 2005-08-31 | 2006-06-30 | 217.5d? | finish no earlier than 2006-06-30 | G1 | 1740h | 1740h | GSM-710-test |  |  | Rel-7 | Paolo |  |
| 1294 | 486.3 | G3 aspects of GSM710 |  | 217.5d? | 2005-08-31 A | 2006-06-30 A | 100% | 2005-08-31 | 2006-06-30 | 217.5d? | finish no earlier than 2006-06-30 | G3new | 1740h | 1740h | GSM-710-test |  |  | Rel-7 | Ingbert |  |
| 1295 | 487 | **Support of Conversational Services in A/Gb mode via the PS domain** |  | 626d? | 2005-04-08 A | 2007-08-31 A | 100% | 2005-04-08 | 2007-08-31 | 626d? |  | GP | 15442.8h | 15442.8h | SCSAGB | Ericsson | gunnar.hedby@ericsson.com | Rel-7 | Paolo |  |
| 1296 | 487.1 | Minimise the transfer delay between the SGSN and the MS |  | 604.95d? | 2005-04-08 A | 2007-08-31 A | 100% | 2005-04-08 | 2007-08-31 | 604.95d? | finish no earlier than 2007-08-31 | GP | 4839.6h | 4839.6h | SCSAGB-MTD | Ericsson | gunnar.hedby@ericsson.com | Rel-7 | Paolo |  |
| 1297 | 487.2 | Definition of radio resource management functionality for Support of Conversational Services in A/Gb mode via the PS domain |  | 626d? | 2005-04-08 A | 2007-08-31 A | 100% | 2005-04-08 | 2007-08-31 | 626d? | finish no earlier than 2007-08-31 | G1 | 5008h | 5008h | SCSAGB-RRM | Ericsson | gunnar.hedby@ericsson.com | Rel-7 | Paolo |  |
| 1298 | 487.3 | Support of Conversational Services in A/Gb mode via the PS domain – RLC Non-Persistent mode |  | 101d? | 2006-06-30 A | 2006-11-17 A | 100% | 2006-06-30 | 2006-11-17 | 101d? | finish no earlier than 2006-11-17 | G2 | 808h | 808h | SCSAGB-RLCNP | Ericsson | gunnar.hedby@ericsson.com | Rel-7 | Gert |  |
| 1299 | 487.4 | Deleted- Radio Channel Support | milestone | 0d? | 2006-07-17 A | 2006-07-17 A | 100% | 2006-07-17 | 2006-07-17 | 0d? | start no earlier than 2006-07-17 | G2 |  |  | SCSAGB-RCHS | Ericsson | gunnar.hedby@ericsson.com | Rel-7 | Gert | SP-32 |
| 1300 | 487.5 | Deleted- Modifications to FLO | milestone | 0d? | 2006-07-17 A | 2006-07-17 A | 100% | 2006-07-17 | 2006-07-17 | 0d? | start no earlier than 2006-07-17 | G2 |  |  | SCSAGB-FLO | Ericsson | gunnar.hedby@ericsson.com | Rel-7 | Gert | SP-32 |
| 1301 | 488 | **Addition of new frequency band to GSM (T-GSM810)** |  | 626d? | 2005-04-08 A | 2007-08-31 A | 100% | 2005-04-08 | 2007-08-31 | 626d? |  | GP | 12112h | 12112h | TGSM810 | Huawei | chende@huawei.com | Rel-7 | Paolo |  |
| 1302 | 488.1 | Changes to core specification |  | 106d? | 2005-04-08 A | 2005-09-02 A | 100% | 2005-04-08 | 2005-09-02 | 106d? | finish no earlier than 2005-09-02 | GP | 848h | 848h | TGSM810-Core | Huawei | chende@huawei.com | Rel-7 | Paolo |  |
| 1303 | 488.2 | Changes to MS testing specification |  | 626d? | 2005-04-08 A | 2007-08-31 A | 100% | 2005-04-08 | 2007-08-31 | 626d? | finish no earlier than 2007-08-31 | G3new | 5008h | 5008h | TGSM810-MStest | Huawei | chende@huawei.com | Rel-7 | Ingbert |  |
| 1304 | 488.3 | Changes to BTS testing specification |  | 156d? | 2005-04-08 A | 2005-11-11 A | 100% | 2005-04-08 | 2005-11-11 | 156d? | finish no earlier than 2005-11-11 | G1 | 1248h | 1248h | TGSM810-BTStest | Huawei | chende@huawei.com | Rel-7 | Paolo |  |
| 1305 | 489 | **Handover of dedicated and shared resources while in Dual Transfer Mode** |  | 421d? | 2005-04-08 A | 2006-11-17 A | 100% | 2005-04-08 | 2006-11-17 | 421d? |  | GP | 12672h | 12672h | HODSRDTM | Nokia | rami.vaittinen@nokia.com | Rel-7 | Paolo |  |
| 1306 | 489.1 | GERAN2 part of Handover of dedicated and shared resources while in Dual Transfer Mode |  | 321d? | 2005-04-08 A | 2006-06-30 A | 100% | 2005-04-08 | 2006-06-30 | 321d? | finish no earlier than 2006-06-30 | G2 | 2568h | 2568h | HODSRDTM-G2 | Nokia | rami.vaittinen@nokia.com | Rel-7 | Gert |  |
| 1307 | 489.2 | Deleted - MS Conformance Testing |  | 421d? | 2005-04-08 A | 2006-11-17 A | 100% | 2005-04-08 | 2006-11-17 | 421d? | finish no earlier than 2006-11-17 | G3new | 3368h | 3368h | HODSRDTM-Mstest | Nokia | rami.vaittinen@nokia.com | Rel-7 | Ingbert | GP-32 |
| 1308 | 489.3 | Deleted - BTS conformance testing |  | 421d? | 2005-04-08 A | 2006-11-17 A | 100% | 2005-04-08 | 2006-11-17 | 421d? | finish no earlier than 2006-11-17 | G1 | 3368h | 3368h | HODSRDTM-BTStest | Nokia | rami.vaittinen@nokia.com | Rel-7 | Paolo | GP-32 |
| 1309 | 490 | **Mobile Station Receive Diversity (DARP Phase II)** |  | 526d? | 2005-11-11 A | 2007-11-16 A | 100% | 2005-11-11 | 2007-11-16 | 526d? |  | GP | 16360h | 16360h | MSRD2 | Nokia | kent.pedersen@nokia.com | Rel-7 | Paolo |  |
| 1310 | 490.1 | Performance Requirements for Mobile Station Receive Diversity, DARP Phase II |  | 331d? | 2005-11-11 A | 2007-02-16 A | 100% | 2005-11-11 | 2007-02-16 | 331d? | finish no earlier than 2007-02-16 | GP | 2648h | 2648h | MSRD2-PerfReq | Nokia | kent.pedersen@nokia.com | Rel-7 | Paolo |  |
| 1311 | 490.2 | Capability signalling of Mobile Station Receive Diversity, DARP Phase II |  | 331d? | 2005-11-11 A | 2007-02-16 A | 100% | 2005-11-11 | 2007-02-16 | 331d? | finish no earlier than 2007-02-16 | GP | 2648h | 2648h | MSRD2-CapSig | Nokia | kent.pedersen@nokia.com | Rel-7 | Paolo |  |
| 1312 | 490.3 | Test Scenarios for Mobile Station Receive Diversity, DARP Phase II |  | 331d? | 2005-11-11 A | 2007-02-16 A | 100% | 2005-11-11 | 2007-02-16 | 331d? | finish no earlier than 2007-02-16 | GP | 2648h | 2648h | MSRD2-TestSc | Nokia | kent.pedersen@nokia.com | Rel-7 | Paolo |  |
| 1313 | 490.4 | MS conformance test of DARP Phase II (MSRD) |  | 526d? | 2005-11-11 A | 2007-11-16 A | 100% | 2005-11-11 | 2007-11-16 | 526d? | finish no earlier than 2007-11-16 | GP | 4208h | 4208h | MSRD2-Msconf | Nokia | kent.pedersen@nokia.com | Rel-7 | Ingbert |  |
| 1314 | 491 | **Downlink Dual Carrier** |  | 947d? | 2006-01-20 A | 2009-09-04 A | 100% | 2006-01-20 | 2009-09-04 | 947d? |  | GP | 15446.6h | 15446.6h | GDCDL | Nokia Siemens Networks | leonardo.provvedi@roke.co.uk | Rel-7 | Paolo |  |
| 1315 | 491.1 | Downlink Dual Carrier Stage 2 |  | 116d? | 2006-01-20 A | 2006-06-30 A | 100% | 2006-01-20 | 2006-06-30 | 116d? | finish no earlier than 2006-06-30 | G1 | 928h | 928h | GDCDL-Stage2 | Nokia Siemens Networks | leonardo.provvedi@roke.co.uk | Rel-7 | Paolo |  |
| 1316 | 491.2 | Downlink Dual Carrier Stage 3 |  | 421d? | 2006-01-20 A | 2007-08-31 A | 100% | 2006-01-20 | 2007-08-31 | 421d? | finish no earlier than 2007-08-31 | G1 | 3368h | 3368h | GDCDL-Stage2 | Nokia Siemens Networks | leonardo.provvedi@roke.co.uk | Rel-7 | Paolo |  |
| 1317 | 491.3 | Downlink Dual Carrier – MS Conformance Test |  | 446.82d? | 2006-01-20 A | 2009-09-04 A | 100% | 2006-01-20 | 2009-09-04 | 446.82d? | finish no earlier than 2009-09-04 | G3new | 3574.6h | 3574.6h | GDCDL-MStest | Nokia Siemens Networks | leonardo.provvedi@roke.co.uk | Rel-7 | Ingbert |  |
| 1318 | 492 | Support of SIGTRAN in GERAN |  | 116d? | 2006-01-20 A | 2006-06-30 A | 100% | 2006-01-20 | 2006-06-30 | 116d? | finish no earlier than 2006-06-30 | GP | 928h | 928h | GSIGT | Ericsson | peter.ostrup@ericsson.com | Rel-7 | Ingbert |  |

Notes:
- 1291: - / Text3: 24.008, 43.022, 44.018, 44.118, 45, 001, 45.005, 51.010, 51.021
- 1292: Completed / Text3: 24.008, 43.022, 44.018, 44.118, 45, 001, 45.005,
- 1293: - / Text3: 51.021
- 1294: - / Text3: 51.010
- 1295: Originally started Nov. 2003 as GP-030443
- 1296: -
- 1297: -
- 1298: - / Text3: 43.955, 43.064, 44.060, 45.001, 45.002, 45.003, 45.005, 45.010, 51.010, 51.021
- 1299: -
- 1300: -
- 1301: - / Text3: 45.005, 45.050, 24.008, 45.008, 45.001, 43.022, 43.030, 44.018, 44.060, 51.010-1, 51.021
- 1302: - / Text3: 45.005, 45.050, 24.008, 45.008, 45.001, 43.022, 43.030, 44.018, 44.060
- 1303: - / Text3: 51010-1
- 1304: - / Text3: 51021
- 1305: GP#30 completed. Started at GP#24
- 1306: GP#30 completed / Text3: 43.055, 44.018, 44.060
- 1307: Stopped, no work done. 12/2008 Marked as stopped ("deleted") / Text3: 51-010
- 1308: Stopped, no work done. 12/2008 Marked as stopped ("deleted") / Text3: 51.026
- 1309: GP#36 completed
- 1310: GP#33 completed / Text3: 45.005
- 1311: GP#33 completed / Text3: 24.008
- 1312: GP#33 completed / Text3: 45.005
- 1313: GP#36 completed / Text3: 51.010
- 1314: GP#35 completed
- 1315: GP#30 completed / Text3: 43.055, 43.064
- 1316: GP#35 completed / Text3: 24.008, 44.018, 44.060, 45.001, 45.002, 45.005, 45.008
- 1317: GP#43 completed / Text3: 51.010
- 1318: GP#30 completed / Text3: 48.001, 48.006, 43.059, 49.031

| ID | WBS | Task | Type | Duration | Start | Finish | Complete | Baseline start | Baseline finish | Baseline duration | Constraint | Resources | Work | Actual work | Text1 | Text4 | Text5 | Text6 | Text8 | Text12 |
| --- | --- | --- | --- | --- | --- | --- | --- | --- | --- | --- | --- | --- | --- | --- | --- | --- | --- | --- | --- | --- |
| 1319 | 493 | **Latency Reductions** |  | 306d? | 2006-06-30 A | 2007-08-31 A | 100% | 2006-06-30 | 2007-08-31 | 306d? |  | GP | 7344h | 7344h | LATRED | Ericsson | Hakan.Persson@Ericsson.com | Rel-7 | Paolo |  |
| 1320 | 493.1 | Improved Ack/Nack reporting |  | 306d? | 2006-06-30 A | 2007-08-31 A | 100% | 2006-06-30 | 2007-08-31 | 306d? | finish no earlier than 2007-08-31 | G2 | 2448h | 2448h | LATRED-ACKNAR | Ericsson | Hakan.Persson@Ericsson.com | Rel-7 | Gert |  |
| 1321 | 493.2 | Reduced TTI |  | 306d? | 2006-06-30 A | 2007-08-31 A | 100% | 2006-06-30 | 2007-08-31 | 306d? | finish no earlier than 2007-08-31 | G2 | 2448h | 2448h | LATRED-REDTTI | Ericsson | Hakan.Persson@Ericsson.com | Rel-7 | Gert |  |
| 1322 | 494 | PS Handover between GERAN/UTRAN mode and GAN Mode |  | 166d? | 2006-06-30 A | 2007-02-16 A | 100% | 2006-06-30 | 2007-02-16 | 166d? | finish no earlier than 2007-02-16 | G2 | 1328h | 1328h | GUGAN | Ericsson | John.Diachina@Ericsson.com | Rel-7 | Gert |  |
| 1323 | 495 | **Higher Uplink performance for GERAN Evolution** |  | 1227d? | 2006-09-08 A | 2011-05-20 A | 100% | 2006-09-08 | 2011-05-20 | 1227d? |  | GP | 37184h | 37184h | HUGE | Nokia Siemens Networks, Ericsson | eddie.riddington@nokia.com, stefan.g.eriksson@ericsson.com | Rel-7 | Paolo |  |
| 1324 | 495.1 | Stage 2 for HUGE |  | 261d? | 2006-09-08 A | 2007-09-07 A | 100% | 2006-09-08 | 2007-09-07 | 261d? | finish no earlier than 2007-09-07 | G1 | 2088h | 2088h | HUGE-Stage2 | Nokia Siemens Networks, Ericsson | eddie.riddington@nokia.com, stefan.g.eriksson@ericsson.com | Rel-7 | Paolo |  |
| 1325 | 495.2 | Layer 1 Support for HUGE |  | 381d? | 2006-09-08 A | 2008-02-22 A | 100% | 2006-09-08 | 2008-02-22 | 381d? | finish no earlier than 2008-02-22 | G1 | 3048h | 3048h | HUGE-Layer1 | Nokia Siemens Networks, Ericsson | eddie.riddington@nokia.com, stefan.g.eriksson@ericsson.com | Rel-7 | Paolo |  |
| 1326 | 495.3 | Layer 2/3 Support for HUGE |  | 256d? | 2006-09-08 A | 2007-08-31 A | 100% | 2006-09-08 | 2007-08-31 | 256d? | finish no earlier than 2007-08-31 | G2 | 2048h | 2048h | HUGE-Layer23 | Nokia Siemens Networks, Ericsson | eddie.riddington@nokia.com, stefan.g.eriksson@ericsson.com | Rel-7 | Gert |  |
| 1327 | 495.4 | Performance requirements for HUGE |  | 516d? | 2006-09-08 A | 2008-08-29 A | 100% | 2006-09-08 | 2008-08-29 | 516d? | finish no earlier than 2008-08-29 | G1 | 4128h | 4128h | HUGE-Perfreq | Nokia Siemens Networks, Ericsson | eddie.riddington@nokia.com, stefan.g.eriksson@ericsson.com | Rel-7 | Paolo |  |
| 1328 | 495.5 | BTS Conformance Test for HUGE |  | 782d? | 2006-09-08 A | 2009-09-04 A | 100% | 2006-09-08 | 2009-09-04 | 782d? | finish no earlier than 2009-09-04 | G1 | 6248h | 6248h | HUGE-BTStest | Nokia Siemens Networks, Ericsson | eddie.riddington@nokia.com, stefan.g.eriksson@ericsson.com | Rel-7 | Paolo |  |
| 1329 | 495.6 | MS Conformance Test for HUGE |  | 1226d? | 2006-09-08 A | 2011-05-20 A | 100% | 2006-09-08 | 2011-05-20 | 1226d? | finish no earlier than 2011-05-20 | G3new | 9808h | 9808h | HUGE-Mstest | Nokia Siemens Networks, Ericsson | eddie.riddington@nokia.com, stefan.g.eriksson@ericsson.com | Rel-7 | Ingbert |  |
| 1330 | 496 | **REduced symbol Duration, Higher Order modulation and Turbo coding (RED HOT) for downlink** |  | 1177d? | 2006-11-17 A | 2011-05-20 A | 100% | 2006-11-17 | 2011-05-20 | 1177d? |  | GP | 28808h | 28808h | REDHOT | Ericsson, Nokia Siemens Networks, Marvell | stefan.g.eriksson@ericsson.com | Rel-7 | Paolo |  |
| 1331 | 496.1 | Stage 2 for REDHOT |  | 206d? | 2006-11-17 A | 2007-08-31 A | 100% | 2006-11-17 | 2007-08-31 | 206d? | finish no earlier than 2007-08-31 | G1 | 1648h | 1648h | REDHOT-Stage2 | Ericsson, Nokia Siemens Networks, Marvell | stefan.g.eriksson@ericsson.com | Rel-7 | Paolo |  |
| 1332 | 496.2 | Stage 3 for REDHOT |  | 391d? | 2006-11-17 A | 2008-05-16 A | 100% | 2006-11-17 | 2008-05-16 | 391d? | finish no earlier than 2008-05-16 | G1 | 3128h | 3128h | REDHOT-Stage3 | Ericsson, Nokia Siemens Networks, Marvell | stefan.g.eriksson@ericsson.com | Rel-7 | Paolo |  |
| 1333 | 496.3 | BTS Conformance Tests for REDHOT |  | 651d? | 2006-11-17 A | 2009-05-15 A | 100% | 2006-11-17 | 2009-05-15 | 651d? | finish no earlier than 2009-05-15 | G1 | 5208h | 5208h | REDHOT-BTStest | Ericsson, Nokia Siemens Networks, Marvell | stefan.g.eriksson@ericsson.com | Rel-7 | Paolo |  |
| 1334 | 496.4 | MS Conformance Tests for REDHOT |  | 1176d? | 2006-11-17 A | 2011-05-20 A | 100% | 2006-11-17 | 2011-05-20 | 1176d? | finish no earlier than 2011-05-20 | G3new | 9408h | 9408h | REDHOT-Mstest | Ericsson, Nokia Siemens Networks, Marvell | stefan.g.eriksson@ericsson.com | Rel-7 | Ingbert |  |
| 1335 | 497 | (Small) Technical Enhancements and Improvements for Rel-7 | milestone | 0d? | 2007-03-26 A | 2007-03-26 A | 100% | 2007-03-26 | 2007-03-26 | 0d? | start no earlier than 2007-03-26 | All |  |  | TEI7 |  |  | Rel-7 | All |  |
| 1336 | 498 | Test - (Small) Technical Enhancements and Improvements for Rel-7 |  | 389d? | 2006-06-02 A | 2007-11-28 A | 100% | 2006-06-02 | 2007-11-28 | 389d? | finish no earlier than 2010-06-04 | R5 | 3112h | 3112h | TEI7_Test |  |  | Rel-7 | Ingbert |  |
| 1337 | 499 | **Deleted - PS domain and IMS support for IMS Emergency sessions** |  | 63.69d? | 2006-06-23 A | 2006-09-21 A | 100% | 2006-06-23 | 2006-09-21 | 63.69d? |  | S2 |  |  | IMS-EMER | Nokia | curt.c.wong@nokia.com | Rel-7 | Maurice | SP-30 |
| 1338 | 499.1 | Deleted - IMS aspects to support IMS Emergency sessions | milestone | 0d? | 2006-06-23 A | 2006-09-21 A | 100% | 2006-06-23 | 2006-09-21 | 0d? | start no earlier than 2006-06-23 | S2 |  |  | IMS-EMER | Nokia | curt.c.wong@nokia.com | Rel-7 | Maurice | SP-30 |
| 1339 | 499.2 | Deleted - PS domain aspects to support IMS Emergency sessions | milestone | 0d? | 2006-06-23 A | 2006-09-21 A | 100% | 2006-06-23 | 2006-09-21 | 0d? | start no earlier than 2006-06-23 | S2 |  |  | IMS-EMER | Nokia | curt.c.wong@nokia.com | Rel-7 | Maurice | SP-30 |
| 1340 | 16.7 | **Deleted - IMS Local services** |  | 0d? | 2006-01-06 A | 2006-01-06 A | 100% | 2006-01-06 | 2006-01-06 | 0d? |  | S2 |  |  | IMSLocal |  |  | Rel-7 | Maurice | SP-28 |
| 1341 | 16.7.1 | Deleted - Stage 2 | milestone | 0d | 2006-01-06 A | 2006-01-06 A | 100% | 2006-01-06 | 2006-01-06 | 0d | start no earlier than 2006-01-06 | S2 |  |  | IMSLocal |  |  | Rel-7 | Maurice | SP-26 |
| 1342 | 500.2 | Deleted - Stage 3 for IMS Local services | milestone | 0d? | 2006-01-06 A | 2006-01-06 A | 100% | 2006-01-06 | 2006-01-06 | 0d? | finish no earlier than 2006-01-06 | C1 |  |  | IMSLocal | Lucent | Keith Drage (drage@alcatel-lucent.com) | Rel-7 | Frederic | SP-25 |
| 1343 | 501 | Deleted - IMS Phase 3 | milestone | 0d? | 2006-01-06 A | 2006-01-06 A | 100% | 2006-01-06 | 2006-01-06 | 0d? | start no earlier than 2006-01-06 | S2 |  |  |  |  |  | Rel-7 | Maurice | SP-25 |
| 1344 | 502 | Deleted - Improvements of Radio Interface | milestone | 0d? | 2004-09-15 A | 2004-09-15 A | 100% | 2004-09-15 | 2004-09-15 | 0d? | start no earlier than 2004-09-15 | RP |  |  | RInImp |  |  | Rel-7 | Issam | SP-24 |
| 1345 | 503 | Deleted: Generic User Profile Phase 2 | milestone | 0d | 2005-08-08 A | 2006-06-30 A | 100% | 2005-08-08 | 2006-06-30 | 0d |  | C4 |  |  |  |  |  | Rel-7 | Kimmo | SP-27 |
| 1346 | 30.4 | Deleted - Stage 3 - Common objects | milestone | 0d | 2005-08-08 A | 2006-06-30 A | 100% | 2005-08-08 | 2006-06-30 | 0d | finish no earlier than 2006-06-30 | C4 |  |  |  |  |  | Rel-7 | Kimmo | SP-27 |
| 1347 | 505 | Release 7 Studies |  | 841d? | 2004-06-28 A | 2007-09-17 A | 100% | 2004-06-28 | 2007-09-17 | 841d? |  | CP,GP,RP,SP | 6728h | 6728h |  |  |  | Rel-7 | All |  |
| 1348 | 506 | Study on Enhancement of E2E QoS |  | 281.4d? | 2004-06-28 A | 2005-09-15 A | 100% | 2004-06-28 | 2005-09-15 | 281.4d? | finish no earlier than 2005-12-01 | S2 | 2251.2h | 2251.2h | QoS7 | Huawei | Robert Jaksa | Rel-7 | Maurice |  |
| 1349 | 507 | Study on SOAP/HTTP IRP Solution Sets |  | 330d? | 2005-09-02 A | 2006-12-07 A | 100% | 2005-09-02 | 2006-12-07 | 330d? | finish no earlier than 2006-12-07 | S5 | 2640h | 2640h | OAM7-NIM-XML | Nortel | Suzèle Lariven (lariven@nortel.com) | Rel-7 | Dionisio |  |
| 1350 | 508 | Study on Itf-N Implementation Conformance Statement (ICS) template |  | 400d? | 2005-09-02 A | 2007-03-15 A | 100% | 2005-09-02 | 2007-03-15 | 400d? | finish no earlier than 2007-03-15 | S5 | 3200h | 3200h | OAM7-NIM-ICS | China Mobile | Li Yewen (liyewen@chinamobile.com) | Rel-7 | Dionisio |  |
| 1351 | 509 | Study on IRP Information Model |  | 400d? | 2005-09-02 A | 2007-03-15 A | 100% | 2005-09-02 | 2007-03-15 | 400d? | finish no earlier than 2007-03-15 | S5 | 3200h | 3200h | OAM7-NIM-IM | Motorola | trevor.pirt@motorola.com | Rel-7 | Dionisio |  |
| 1352 | 510 | Study on Bandwidth Saving at Nb Interface with IP transport |  | 261d? | 2006-03-10 A | 2007-03-09 A | 100% | 2006-03-10 | 2007-03-09 | 261d? | finish no earlier than 2007-03-09 | C3 | 2088h | 2088h | BSNbIP | Siemens | Thomas.Belling@siemens.com | Rel-7 | Jiwan |  |
| 1353 | 511 | Study on Routeing of MT-SMS via the HPLMN |  | 301d? | 2005-10-07 A | 2006-12-01 A | 100% | 2005-10-07 | 2006-12-01 | 301d? | finish no earlier than 2006-12-01 | C4 | 2408h | 2408h | SMS7 | Vodafone | Nick.Russell@vodafone.com | Rel-7 | Kimmo |  |
| 1354 | 512 | Study on the TCAPsec Gateway concept |  | 96d? | 2005-10-28 A | 2006-03-10 A | 100% | 2005-10-28 | 2006-03-10 | 96d? | finish no earlier than 2006-03-10 | C4 | 768h | 768h | SEC7-TCAP | Siemens | Ulrich.wiehe@gksag.de | Rel-7 | Kimmo |  |
| 1355 | 513 | Study on using M2PA in 3GPP network |  | 318d? | 2006-03-22 A | 2007-06-08 A | 100% | 2006-03-22 | 2007-06-08 | 318d? | finish no earlier than 2007-06-08 | C4 | 2544h | 2544h | FS-M2PA | China Mobile | zhaoyuyi@chinamobile.com | Rel-7 | Kimmo |  |

Notes:
- 1319: GP#35 completed / Text3: 45.001, 45.002, 45.003, 45.005, 45.010, 43.055, 43.064, 44.060, 51.010-1, 51.021
- 1320: GP#35 completed / Text3: 45.001, 45.002, 45.003, 45.005, 45.010, 43.055, 43.064, 44.060, 51.010-1, 51.021
- 1321: GP#35 completed / Text3: 45.001, 45.002, 45.003, 45.005, 45.010, 43.055, 43.064, 44.060, 51.010-1, 51.021
- 1322: GP#33 completed / Text3: 43.318, 44.318, 43.129, 25.306, 24.008, 44.060, 25.331, 51.010
- 1323: GP#39 completed
- 1324: GP#35 completed / Text3: 43.055, 43.064
- 1325: GP#37 completed / Text3: 45.001, 45.002, 45.003, 45.004, 45.008
- 1326: GP#35 completed / Text3: 24.008, 44.018, 44.060
- 1327: GP#39 completed / Text3: 45.005
- 1328: GP#43 completed / Text3: 51.021
- 1329: GP#50 completed / Text3: 51.010
- 1330: GP#38 completed
- 1331: GP#35 completed / Text3: 43.055, 43.064
- 1332: GP#38 completed / Text3: 24.008, 44.018, 44.060, 45.001, 45.002, 45.003, 45.004, 45.005, 45.008
- 1333: GP#42 completed / Text3: 51.021
- 1334: GP#50 completed / Text3: 51.010
- 1335: -
- 1336: -
- 1337: Approved at SP#29 / Text3: 23.867, 23.abc, 23.060, 23.002, 23.271
- 1338: Approved at SP#29 / Text3: 23.867, 23.abc, 23.060, 23.002, 23.271
- 1339: Approved at SP#29 / Text3: 23.867, 23.abc, 23.060, 23.002, 23.271
- 1340: - / Text3: 23.228
- 1341: DAB - Not yet required in SA2 as it exists in previous releases
- 1342: -
- 1343: -
- 1344: Stage 2 description of Interim conclusion
- 1345: Created at TSG#27 by A. Sultan because of the move to Rel-7 of "Common Objects".
- 1346: No progress in CN4#26. This have to be moved to Rel-7. It was deleted from WID / Text3: 24.241
- 1347: -
- 1348: - / Text3: 23.802
- 1349: SP#34 completed / Text3: 32.809
- 1350: SP#35 completed / Text3: 32.812
- 1351: SP#35 completed / Text3: 32.810
- 1352: Moved to FS at CT32 (in line with slides) / Text3: 29.814
- 1353: Previously known as "Study of a SMS Centre for MT SMS" / Text3: 23.840
- 1354: TR 29.800 content moved to TS 29.204 under implementation WI UID_310005 TCAPsec Gateway / Text3: 29.800
- 1355: - / Text3: 29.801

| ID | WBS | Task | Type | Duration | Start | Finish | Complete | Baseline start | Baseline finish | Baseline duration | Constraint | Resources | Work | Actual work | Text1 | Text3 | Text4 | Text5 | Text6 | Text8 | Text11 | Text12 |
| --- | --- | --- | --- | --- | --- | --- | --- | --- | --- | --- | --- | --- | --- | --- | --- | --- | --- | --- | --- | --- | --- | --- |
| 1356 | 514 | **Study on Support of (G)MSC-S - (G)MSC-S Nc Interface based on the SIP-I protocol** |  | 350d? | 2006-05-15 A | 2007-09-14 A | 100% | 2006-05-15 | 2007-09-14 | 350d? |  | C4,C3 | 5000h | 5000h | NcSIP | 29.802 | Vodafone | david.hutton@vodafone.com | Rel-7 | Kimmo |  |  |
| 1357 | 514.1 | CT4 aspects of NcSIP |  | 275d? | 2006-05-15 A | 2007-06-01 A | 100% | 2006-05-15 | 2007-06-01 | 275d? | finish no earlier than 2007-06-01 | C4 | 2200h | 2200h | NcSIP | 29.802 | Vodafone | david.hutton@vodafone.com | Rel-7 | Kimmo |  |  |
| 1358 | 514.2 | CT3 aspects of NcSIP |  | 350d? | 2006-05-15 A | 2007-09-14 A | 100% | 2006-05-15 | 2007-09-14 | 350d? | finish no earlier than 2007-09-14 | C3 | 2800h | 2800h | NcSIP | 29.802 | Ericsson | ragnar.huslende@ericsson.com | Rel-7 | Jiwan |  |  |
| 1359 | 515 | Study on Evolved UTRA and UTRAN |  | 458d? | 2004-12-15 A | 2006-09-15 A | 100% | 2004-12-15 | 2006-09-15 | 458d? | finish no earlier than 2006-09-15 | RP | 3664h | 3664h | RANFS-Evo | 25.912 | NTT DoCoMo | nakamurata@NTTDOCOMO.CO.JP | Rel-7 | Issam | RP-060472 |  |
| 1360 | 516 | Study on Performance Evaluation of the UE behaviour in high speed trains with speeds up to 350 kmph |  | 328d? | 2005-03-15 A | 2006-06-15 A | 100% | 2005-03-15 | 2006-06-15 | 328d? | finish no earlier than 2006-06-15 | R4 | 2624h | 2624h | RANFS-HSTrains | none | Vodafone | Mike.vogel@vodafone.com,tim.frost@vodafone.com | Rel-7 | Issam | RP-060412 |  |
| 1361 | 517 | Study on UTRA Tower Mounted Amplifier (FDD) |  | 195d? | 2005-06-15 A | 2006-03-14 A | 100% | 2005-06-15 | 2006-03-14 | 195d? | finish no earlier than 2006-03-15 | R4 | 1560h | 1560h | RANFS-TMA | 25.818 | Ericsson | Klas.Sjerling@ericsson.com | Rel-7 | Issam | RP-060035 |  |
| 1362 | 518 | Study on Continuous connectivity for packet data users |  | 132d? | 2005-03-15 A | 2005-09-14 A | 100% | 2005-03-15 | 2005-09-14 | 132d? | finish no earlier than 2005-09-15 | R1 | 1056h | 1056h | RANFS-cont-packet | none | Siemens | joerg.gustrau@siemens.com | Rel-7 | Patrick | RP-050427 |  |
| 1363 | 519 | Study on Improvement of the Multimedia Broadcast Multicast Service (MBMS) in UTRAN |  | 262d? | 2005-12-15 A | 2006-12-15 A | 100% | 2005-12-15 | 2006-12-15 | 262d? | finish no earlier than 2006-12-15 | R2 | 2096h | 2096h | RANFS-MBMSImp | 25.905 | LG Electronics | leego@lge.com | Rel-7 | Joern | RP-060692 |  |
| 1364 | 520 | Study on Performance Improvements in Small Cells using HSDPA/EDCH |  | 131d? | 2005-12-15 A | 2006-06-15 A | 100% | 2005-12-15 | 2006-06-15 | 131d? | finish no earlier than 2006-06-15 | R4 | 1048h | 1048h | SMALLCELLS | none | Cingular | Marc Grant | Rel-7 | Issam | RP-060263 |  |
| 1365 | 521 | Study on Further Improved Performance Requirements for UMTS/HSDPA UE (FDD) |  | 383d? | 2005-12-15 A | 2007-06-04 A | 100% | 2005-12-15 | 2007-06-04 | 383d? | finish no earlier than 2007-06-04 | R4 | 3064h | 3064h | RANFS-IC | 25.963 | Cingular | Marc Grant | Rel-7 | Issam | RP-070499 |  |
| 1366 | 522 | Study on Scope of future FDD HSPA Evolution |  | 394d? | 2006-03-15 A | 2007-09-17 A | 100% | 2006-03-15 | 2007-09-17 | 394d? | finish no earlier than 2007-09-17 | RP | 3152h | 3152h | RANFS-HSPAEvo | 25.999 | Cingular | Don Zelmer (dz1069@att.com) | Rel-7 | Issam | RP-070533 |  |
| 1367 | 523 | Study on Dynamically reconfiguring a FDD UE receiver to reduce power consumption when desired Quality of Service is met | milestone | 0d? | 2007-06-22 A | 2007-06-22 A | 100% | 2007-06-22 | 2007-06-22 | 0d? |  | R4 |  |  | FSUEPow | 25.906 | Nokia | Chris.callender@nokia.com, tiina.s.koskinen@nokia.com | Rel-7 | Issam | RP-070534 |  |
| 1368 | 524 | Study on Future GERAN Evolution |  | 486d? | 2005-04-08 A | 2007-02-16 A | 100% | 2005-04-08 | 2007-02-16 | 486d? | finish no earlier than 2007-02-16 | GP | 3888h | 3888h | FGE | 45.912 | Nokia | eddie.riddington@nokia.com | Rel-7 | Paolo |  |  |
| 1369 | 525 | Study on GAN Enhancements | milestone | 0d? | 2007-08-31 A | 2007-08-31 A | 100% | 2007-08-31 | 2007-08-31 | 0d? | start no earlier than 2007-08-31 | GP |  |  | EGAN | 43.902 | T-Mobile | janne.linkola@t-mobile.com | Rel-7 | Paolo |  |  |
| 1370 | 526 | Deleted - Study on LCS architecture for I-WLAN (covered by 32108) | milestone | 0d? | 2006-12-08 A | 2006-12-08 A | 100% | 2006-12-08 | 2006-12-08 | 0d? | start no earlier than 2006-12-08 | S2 |  |  | IMS-SE |  | LG Electronics | Donghee Shim dhshim@lge.com ; phede@lge.com | Rel-7 | Maurice |  | SP-33 |
| 1371 | 527 | Deleted - IMS security extensions (covered by UID33027) | milestone | 0d? | 2005-12-08 A | 2005-12-08 A | 100% | 2005-12-08 | 2005-12-08 | 0d? | start no earlier than 2005-12-08 | S3 |  |  | IMS-SE |  | Ericsson | Bengt.Sahlin@ericsson.com | Rel-7 | Dionisio |  | SP-30 |
| 1372 | 528 | **Deleted - Study on applicability of GALILEO for LCS** |  | 0d? | 2005-06-30 A | 2005-06-30 A | 100% | 2005-06-30 | 2005-06-30 | 0d? |  | S2 |  |  | Galileo |  |  |  | Rel-7 | Maurice |  | SP-25 |
| 1373 | 528.1 | Deleted - TR on Stage 2 | milestone | 0d? | 2005-06-30 A | 2005-06-30 A | 100% | 2005-06-30 | 2005-06-30 | 0d? | finish no earlier than 2005-06-30 | S2 |  |  | Galileo |  |  |  | Rel-7 | Maurice |  | SP-25 |
| 1374 | 528.2 | Deleted - GERAN review of the TR | milestone | 0d? | 2005-06-30 A | 2005-06-30 A | 100% | 2005-06-30 | 2005-06-30 | 0d? | start no earlier than 2005-06-30 | GP |  |  | Galileo |  |  |  | Rel-7 | Paolo |  | SP-26 |
| 1375 | 529 | Deleted - Study on Stage 2 (IMS services using CS bearers) |  | 316d? | 2004-06-28 A | 2005-09-12 A | 100% | 2004-06-28 | 2005-09-12 | 316d? | finish no earlier than 2005-09-12 | S2 | 2528h | 2528h | IRTSD-IMSCS | 23.899 | Nortel | Mark Watson | Rel-7 | Maurice |  | SP-30 |
| 1376 | 530 | **Deleted - VoIMS bearer related enhancements** |  | 0d? | 2006-07-21 A | 2006-07-21 A | 100% | 2006-07-21 | 2006-07-21 | 0d? |  | S2 |  |  | VoIMS |  |  |  | Rel-7 | Maurice |  | SP-32 |
| 1377 | 530.1 | Deleted - Study on enhancement of radio performance for VoIMS | milestone | 0d? | 2006-07-21 A | 2006-07-21 A | 100% | 2006-07-21 | 2006-07-21 | 0d? | start no earlier than 2006-07-21 | S2 |  |  | VoIMS | 23.807 | Nortel | Laurence Lautier (lautierl@nortel.com) | Rel-7 | Maurice |  | SP-32 |
| 1378 | 531 | Deleted - Study on IMS enhancements and optimizations for real time communication. |  | 430d? | 2005-10-10 A | 2007-06-01 A | 100% | 2005-10-10 | 2007-06-01 | 430d? | finish no earlier than 2007-06-01 | S2 | 3440h | 3440h | IMS-RT | 23.818 | Ericsson | stephen.terrill@ericsson.com | Rel-7 | Maurice |  | SP-35 |
| 1379 | 532 | Deleted - Study on Terminating Session handling |  | 255d? | 2006-01-09 A | 2006-12-29 A | 100% | 2006-01-09 | 2006-12-29 | 255d? | finish no earlier than 2006-12-29 | S2 | 2040h | 2040h | CSIterm | 23.819 | Samsung |  | Rel-7 | Maurice |  | SP-32 |
| 1380 | 533 | Deleted - Study on Transferring of emergency call data – in-band modem solution (moved to Rel-8) | milestone | 0d? | 2007-06-22 A | 2007-06-22 A | 100% | 2007-06-22 | 2007-06-22 | 0d? | start no earlier than 2007-06-22 | S4 |  |  | eCALLIBMS | 26.967 | Airbiquity | lhong@airbiquity.com | Rel-7 | Paolo |  | SP-38 |
| 1381 | 534 | Deleted - Study on IRP usage scenarios |  | 330d? | 2005-09-02 A | 2006-12-07 A | 100% | 2005-09-02 | 2006-12-07 | 330d? | finish no earlier than 2006-12-07 | S5 | 2640h | 2640h | OAM-Study | 32.8xy | Lucent |  | Rel-7 | Dionisio |  | SP-32 |
| 1382 | 535 | Deleted - Study on Interference Cancellation for UTRA FDD UE (covered by UID 20053) |  | 1d? | 2007-03-28 A | 2007-03-28 A | 100% | 2007-03-28 | 2007-03-28 | 1d? | start no earlier than 2007-03-28 | R4 | 8h | 8h | RANFS-InterfCanc |  |  |  | Rel-7 | Issam |  | SP-38 |
| 1383 | 536 | Deleted - Study on enhanced support of Video Telephony | milestone | 0d? | 2006-06-30 A | 2006-06-30 A | 100% | 2006-06-30 | 2006-06-30 | 0d? | start no earlier than 2006-06-30 | GP |  |  | VIDGER |  | Ericsson | stefan.g.eriksson@ericsson.com | Rel-7 | Paolo |  | SP-32 |
| 1384 | 537 | Release 6 Features |  | 915d? | 2002-06-28 A | 2005-12-30 A | 100% | 2002-06-28 | 2005-12-30 | 915d? |  | NP,GP, RP,SP,TP | 7320h | 7320h |  |  |  |  | Rel-6 | All |  |  |

Notes:
- 1356: -
- 1357: -
- 1358: -
- 1359: RP#33 (Sep 2006) completed. SR in RP-060472
- 1360: RP#32 (Jun 2006) completed. SR in RP-060412
- 1361: RP#31 (Mar 2006) completed. SR in RP-060035
- 1362: RP#29 (Sep 2006) completed. SR in RP-050427
- 1363: RP#34 (Dec 2006) completed. SR in RP-060692
- 1364: RP#32 (Jun 2006) closed (no progress). SR in RP-060263
- 1365: RP#36 (May 2007) completed. SR in RP-070499
- 1366: RP#37 (Sep 2007) completed. SR in RP-070533
- 1367: RP#37 (Sep 2007) completed. SR in RP-070534
- 1368: GP#33 completed
- 1369: GP#35 completed
- 1370: -
- 1371: -
- 1372: -
- 1373: -
- 1374: -
- 1375: SP-30: S2 has no intention for TR completion
- 1376: Created by MCC to group all VoIMS related items, after consultation of chairs
- 1377: WID approved SP#28. SA2#52 stopped
- 1378: abandoned at 65%
- 1379: SP#32 Jun 2006 Study abandoned => spin-off Implementation work UID_320029
- 1380: SP-38 stopped
- 1381: -
- 1382: Deleted. Same as FS on Further Improved Performance Requirements for UMTS/HSDPA UE (FDD)
- 1383: FS CLOSED at G#28 (no input)
- 1384: -

| ID | WBS | Task | Type | Duration | Start | Finish | Complete | Baseline start | Baseline finish | Baseline duration | Constraint | Resources | Work | Actual work | Text1 | Text6 | Text4 | Text5 | Text8 | Text3 | Text7 | Text10 | Text12 |
| --- | --- | --- | --- | --- | --- | --- | --- | --- | --- | --- | --- | --- | --- | --- | --- | --- | --- | --- | --- | --- | --- | --- | --- |
| 1385 | 8 | **Rel-6 Improvements of Radio Interface** |  | 1645d? | 2000-08-14 A | 2006-12-01 A | 100% | 2000-08-14 | 2006-12-01 | 1645d? |  | R2,R4,R5 | 55624h | 55624h | RInImp | Rel-6 |  |  |  |  |  |  |  |
| 1386 | 538.1 | Improved support of IMS Realtime Services using HSDPA/EDCH |  | 197d? | 2005-03-15 A | 2005-12-14 A | 100% | 2005-03-15 | 2005-12-14 | 197d? | finish no earlier than 2005-12-14 | R2 | 1576h | 1576h | RInImp-IMSRealTime | Rel-6 | Cingular | Don Zelmer (dz1069@att.com) | Joern |  |  |  |  |
| 1387 | 538.2 | Improving Receiver Performance Requirements for the FDD UE |  | 401d | 2002-03-08 A | 2003-09-19 A | 100% | 2002-03-08 | 2003-09-19 | 401d | start no earlier than 2002-03-08 | R4 | 3208h | 3208h | RInImp-UERecPerf | Rel-6 | Intel | shimon.moshavi@INTEL.COM | Issam | 25.101 |  |  |  |
| 1388 | 8.2 | **Base station classification for FDD** |  | 603d | 2000-08-14 A | 2002-12-04 A | 100% | 2000-08-14 | 2002-12-04 | 603d |  | R4 | 9648h | 9648h | RInImp-BSClass | Rel-6 |  |  | Issam |  |  |  |  |
| 1389 | 8.2.1 | FDD Base station classification |  | 603d | 2000-08-14 A | 2002-12-04 A | 100% | 2000-08-14 | 2002-12-04 | 603d | finish no earlier than 2002-12-04 | R4 | 4824h | 4824h | RInImp-BSClass-FDD | Rel-6 | Nokia | antti.toskala@nokia.com | Issam | 25.104, 25.141 |  |  |  |
| 1390 | 538.4 | UMTS-850 |  | 266d | 2002-12-06 A | 2003-12-12 A | 100% | 2002-12-06 | 2003-12-12 | 266d | finish no earlier than 2003-12-15 | R4 | 2128h | 2128h | RInImp-UMTS850 | Rel-6 | Cingular | Don Zelmer (dz1069@att.com) | Issam | 25.101, 25.104, 25.133, 25.141, 25.307, 25.331, 25.942 |  |  |  |
| 1391 | 538.5 | DS-CDMA introduction in the 800 MHz band |  | 196d | 2003-03-14 A | 2003-12-12 A | 100% | 2003-03-14 | 2003-12-12 | 196d | finish no earlier than 2003-12-15 | R4 | 1568h | 1568h | RInImp-UMTS800 | Rel-6 | NTT DoCoMo | Takehiro Nakamura (nakamurata@nttdocomo.co.jp) | Issam | 25.101, 25.104, 25.133, 25.141, 25.307, 25.331 |  |  |  |
| 1392 | 538.6 | UMTS 1.7/2.1 GHz | milestone | 0d? | 2003-03-14 A | 2003-03-14 A | 100% | 2003-03-14 | 2003-03-14 | 0d? |  | R4 |  |  | RInImp-UMTS1721 | Rel-6 | Nokia | jussi.numminen@NOKIA.COM | Issam | 25.101, 25.104, 25.133, 25.141, 25.307, 25.331 |  |  |  |
| 1393 | 538.7 | Conformance Test Aspects – UMTS 1.7/2.1 GHz Band |  | 191d? | 2006-03-10 A | 2006-12-01 A | 100% | 2006-03-10 | 2006-12-01 | 191d? | finish no earlier than 2006-12-01 | R5 | 1528h | 1528h | RInImp-UMTS1721_Test | Rel-6 | Motorola | carolyn.taylor@motorola.com | Ingbert | TS34.121, TS34.108 |  |  |  |
| 1394 | 538.8 | **Improved Receiver Performance Requirements for HSDPA** |  | 711d | 2003-09-19 A | 2006-06-09 A | 100% | 2003-09-19 | 2006-06-09 | 711d |  | R4,R5 | 22808h | 22808h | RInImp-HSPerf | Rel-6 | Nokia | jussi.numminen@NOKIA.COM | Issam |  |  |  |  |
| 1395 | 538.8.1 | Improved Minimum Performance Requirements for HSDPA UE categories 7 and 8 |  | 453d | 2004-09-15 A | 2006-06-09 A | 100% | 2004-09-15 | 2006-06-09 | 453d |  | R4 | 3624h | 3624h | RInImp-HSPerf-10code | Rel-6 | Nokia | jussi.numminen@nokia.com | Issam | 25.101 |  |  |  |
| 1396 | 538.8.2 | Testing of Improved Minimum Performance for HSDPA |  | 650d | 2003-09-19 A | 2006-03-16 A | 100% | 2003-09-19 | 2006-03-16 | 650d | finish no earlier than 2006-03-16 | R5 | 5200h | 5200h | RInImp-HSPerf-10Code_Test | Rel-6 | Motorola | carolyn.taylor@motorola.com | Ingbert | 34.108, 34.121, 34.122, 34.123-1, 34.123-2, 34.123-3 | TSG | 19/9/2003 |  |
| 1397 | 538.8.3 | Performance Requirements of Receive Diversity for HSDPA |  | 387d | 2003-12-15 A | 2005-06-07 A | 100% | 2003-12-15 | 2005-06-07 | 387d |  | R4 | 3096h | 3096h | RInImp-HSPerf-RxDiv | Rel-6 | NTT DoCoMo | Takehiro Nakamura (nakamurata@nttdocomo.co.jp) | Issam | 25.101 |  |  |  |
| 1398 | 538.8.4 | Testing of Performance of Receiver diversity for HSDPA |  | 650d | 2003-09-19 A | 2006-03-16 A | 100% | 2003-09-19 | 2006-03-16 | 650d | finish no earlier than 2006-03-16 | R5 | 5200h | 5200h | RInImp-HSPerf-RxDiv_Test | Rel-6 | Motorola | carolyn.taylor@motorola.com | Ingbert | 34.108, 34.121, 34.122, 34.123-1, 34.123-2, 34.123-3 | TSG | 19/9/2003 |  |
| 1399 | 539 | **Rel-6 RAN Feasibility Studies** |  | 1196d? | 2000-08-14 A | 2005-03-14 A | 100% | 2000-08-14 | 2005-03-14 | 1196d? |  | RP | 43048h | 43048h |  | Rel-6 |  |  |  |  |  |  |  |
| 1400 | 539.1 | FS of the improved access to UE measurement data for CRNC to support TDD RRM |  | 270d? | 2002-12-06 A | 2003-12-18 A | 100% | 2002-12-06 | 2003-12-18 | 270d? | finish no earlier than 2003-09-19 | R3 | 2160h | 2160h | RANimp-RRMopt-FSUEMsD | Rel-6 | Interdigital | jim.miller@interdigital.com | Juha | 25.801, 25.423 |  | SP-24 |  |
| 1401 | 539.2 | FS on Radio link performance enhancements |  | 1067d | 2000-08-14 A | 2004-09-14 A | 100% | 2000-08-14 | 2004-09-14 | 1067d | finish no earlier than 2004-09-14 | R1 | 8536h | 8536h | RInImp-Rlperf | Rel-6 | Nokia | antti.toskala@nokia.com | Patrick | 25.899 |  |  |  |
| 1402 | 539.3 | FS on Improvement of inter-frequency and inter-system measurements for 1.28 Mcps TDD |  | 461d | 2001-12-14 A | 2003-09-19 A | 100% | 2001-12-14 | 2003-09-19 | 461d | start no earlier than 2001-12-14 | R1 | 3688h | 3688h | RInImp-IfIsMLCR | Rel-6 | Samsung | Li Xiao Qiang (xqli@samsung.co.kr) | Patrick | 25.888 |  |  |  |
| 1403 | 539.4 | FS for the analysis of OFDM for UTRAN enhancement |  | 526d | 2002-06-10 A | 2004-06-14 A | 100% | 2002-06-10 | 2004-06-14 | 526d | start no earlier than 2002-06-10 | R1 | 4208h | 4208h | RInImp-FSOFDM | Rel-6 | Nortel | Sarah Boumendil | Patrick | 25.892 |  |  |  |
| 1404 | 539.5 | FS on Uplink Enhancements for Dedicated Transport Channels |  | 396d | 2002-09-06 A | 2004-03-12 A | 100% | 2002-09-06 | 2004-03-12 | 396d | finish no earlier than 2004-03-12 | R1 | 3168h | 3168h | RInImp-FSUpDTrCh | Rel-6 | Nokia | Karri.Ranta-aho@nsn.com | Patrick | 25.896 |  |  |  |
| 1405 | 539.6 | FS on Analysis on Higher Chip Rates for UTRA TDD evolutions |  | 528d | 2002-09-06 A | 2004-09-14 A | 100% | 2002-09-06 | 2004-09-14 | 528d | finish no earlier than 2004-09-14 | R1 | 4224h | 4224h | RInImp-FSVHCRTDD | Rel-6 | IPWireless | mbeale@ipwireless.com | Patrick | 25.895 |  |  |  |
| 1406 | 539.7 | FS on Low Output Powers for general purpose FDD BSs |  | 128d | 2003-06-13 A | 2004-03-12 A | 100% | 2003-06-13 | 2004-03-12 | 128d | finish no earlier than 2004-03-12 | R3 | 1024h | 1024h | RInImp-FSLoPw | Rel-6 | Telefónica | Ana Burgos (burgos_a@tsm.es) | Juha | 25.807 |  |  |  |
| 1407 | 539.8 | FS on Uplink enhancements for UTRA TDD |  | 462d | 2003-06-06 A | 2005-03-14 A | 100% | 2003-06-06 | 2005-03-14 | 462d | finish no earlier than 2005-03-14 | R1 | 3696h | 3696h | RInImp-FSUpEnhTDD | Rel-6 | Interdigital | Marian.Rudolf@InterDigital.com | Patrick | 25.804 |  |  |  |
| 1408 | 8.8 | FS on UE antenna efficiency test methods performance requirements (2) |  | 131d | 2002-03-08 A | 2002-09-06 A | 100% | 2002-03-08 | 2002-09-06 | 131d | finish no earlier than 2002-09-06 | R4 | 1048h | 1048h | RInImp-UEAnTM2 | Rel-6 | Allgon | Alf Ahlström (alf.ahlstrom@pwav.com) | Issam |  |  |  |  |
| 1409 | 9.4 | Deleted - FS on the evolution of the UTRAN architecture |  | 592d | 2002-09-09 A | 2004-12-14 A | 100% | 2002-09-09 | 2004-12-14 | 592d | finish no earlier than 2004-12-15 | R3 | 4736h | 4736h | RANimp-FSEvo | Rel-6 | Nokia | woonhee.hwang@nsn.com, Antti.Toskala@nokia.com | Juha |  |  |  | RP-26 |

Notes:
- 1385: -
- 1386: -
- 1387: -
- 1388: -
- 1389: -
- 1390: Introduction of UMTS850 (Band V) in 25.307
- 1391: Introduction of UMTS800 in 25.307
- 1392: Introduction of UMTS1700/2100 (Band IV)
- 1393: -
- 1394: -
- 1395: Approved at RP#25 as RP-040375
- 1396: -
- 1397: -
- 1398: -
- 1399: -
- 1400: -
- 1401: Study finished at RP#25
- 1402: -
- 1403: -
- 1404: -
- 1405: Study finished at RP#25
- 1406: -
- 1407: -
- 1408: The RInImp-UEAnTM FS was re-opened at TSG RP#15 upon request from WG4
- 1409: Study Closed, work will continue within the FS on evolved UTRA and UTRAN

| ID | WBS | Task | Type | Duration | Start | Finish | Complete | Baseline start | Baseline finish | Baseline duration | Constraint | Deadline | Resources | Work | Actual work | Text1 | Text4 | Text5 | Text6 | Text3 | Text8 | Text7 | Text9 | Text10 | Text12 |
| --- | --- | --- | --- | --- | --- | --- | --- | --- | --- | --- | --- | --- | --- | --- | --- | --- | --- | --- | --- | --- | --- | --- | --- | --- | --- |
| 1410 | 540 | **FDD Enhanced Uplink** |  | 915d | 2004-03-15 A | 2007-09-14 A | 100% | 2004-03-15 | 2007-09-14 | 915d |  |  | R2,R1,R3,R4,R5 | 20520h | 20520h | EDCH | Ericsson | Joakim Bergström | Rel-6 |  |  |  |  |  |  |
| 1411 | 540.1 | FDD Enhanced Uplink - Stage 2 |  | 197d | 2004-03-15 A | 2004-12-14 A | 100% | 2004-03-15 | 2004-12-14 | 197d | finish no earlier than 2004-12-14 |  | R2 | 1576h | 1576h | EDCH-Stage2 |  |  | Rel-6 | 25.309 | Joern |  |  |  |  |
| 1412 | 540.2 | FDD Enhanced Uplink - Physical Layer |  | 261d | 2004-03-15 A | 2005-03-14 A | 100% | 2004-03-15 | 2005-03-14 | 261d | finish no earlier than 2005-03-14 |  | R1 | 2088h | 2088h | EDCH-Phys | Nokia | Karri.Ranta-aho@nsn.com | Rel-6 | 25.211, 25.212, 25.213, 25.214, 25.215 | Patrick |  |  |  |  |
| 1413 | 540.3 | FDD Enhanced Uplink - Layer 2 and 3 Protocol Aspects |  | 261d | 2004-03-15 A | 2005-03-14 A | 100% | 2004-03-15 | 2005-03-14 | 261d | finish no earlier than 2005-03-14 |  | R2 | 2088h | 2088h | EDCH-L23 | Ericsson | Joakim Bergström | Rel-6 | 25.301, 25.302, 25.306, 25.321, 25.331 | Joern |  |  |  |  |
| 1414 | 540.4 | FDD Enhanced Uplink - UTRAN Iub/Iur Protocol Aspects |  | 261d | 2004-03-15 A | 2005-03-14 A | 100% | 2004-03-15 | 2005-03-14 | 261d | finish no earlier than 2005-03-14 |  | R3 | 2088h | 2088h | EDCH-IurIub | Nortel | Saso Stojanovski | Rel-6 | 25.401, 25.420, 25.423, 25.430, 25.433 | Juha |  |  |  |  |
| 1415 | 540.5 | FDD Enhanced Uplink - RF Radio Transmission/ Reception, System Performance Requirements and Conformance Testing |  | 74d | 2004-03-15 A | 2004-06-24 A | 100% | 2004-03-15 | 2004-06-24 | 74d |  |  | R4 | 592h | 592h | EDCH-RF | Ericsson | thomas.unshelm@ericsson.com | Rel-6 | 25.101, 25.104, 25.133, 25.141 | Issam |  |  |  |  |
| 1416 | 540.6 | Conformance Test Aspects – FDD Enhanced Uplink |  | 596d | 2005-06-03 A | 2007-09-14 A | 100% | 2005-06-03 | 2007-09-14 | 596d | finish no earlier than 2007-09-14 | 2006-06-02 | R5 | 4768h | 4768h | EDCH_Test | Ericsson | Leif.Mattisson@ericsson.com | Rel-6 | 34.108, 34.109, 34.121, 34.123-1, 34.123-2, 34.123-3 | Ingbert | TSG | BB | Fri 03/06/05 |  |
| 1417 | 541 | **Rel-6 RAN improvements** |  | 656d? | 2002-09-09 A | 2005-03-14 A | 100% | 2002-09-09 | 2005-03-14 | 656d? |  |  | RP,S5 | 19904h | 19904h | RANimp |  |  | Rel-6 |  |  |  |  |  |  |
| 1418 | 9.2 | **RAB support enhancement** |  | 522d? | 2003-03-14 A | 2005-03-14 A | 100% | 2003-03-14 | 2005-03-14 | 522d? |  |  | R2 | 9360h | 9360h | RANimp-RABSE | Nokia | Jussi Kähtävä (juha.mikola@nokia.com) | Rel-6 | 25.862 | Joern |  |  |  |  |
| 1419 | 541.1.1 | Optimization of downlink channelisation code utilisation |  | 262d | 2004-03-12 A | 2005-03-14 A | 100% | 2004-03-12 | 2005-03-14 | 262d | finish no earlier than 2005-03-14 |  | R1 | 2096h | 2096h | RANimp-RABSE-CodeOptFDD | Nortel | Sarah Boumendil | Rel-6 |  | Patrick |  |  |  |  |
| 1420 | 541.1.2 | optimization of channelisation code utilisation for 3.84 Mcps TDD |  | 261d | 2004-03-15 A | 2005-03-14 A | 100% | 2004-03-15 | 2005-03-14 | 261d | finish no earlier than 2005-03-15 |  | R1 | 2088h | 2088h | RANimp-RABSE-CodOptTDD | IPWireless | Nicholas Anderson | Rel-6 |  | Patrick |  |  |  |  |
| 1421 | 541.1.3 | HS-DPCCH ACK/NACK Enhancement |  | 65d? | 2004-09-15 A | 2004-12-14 A | 100% | 2004-09-15 | 2004-12-14 | 65d? | finish no earlier than 2004-12-15 |  | R1 | 520h | 520h | RANimp-RABSE-ACKNACK | Nokia | Jussi Kähtävä (juha.mikola@nokia.com) | Rel-6 | 25.212, 25.214, 24.331, 25.433 | Patrick |  |  |  |  |
| 1422 | 541.1.4 | Deleted - Iu enhancements for IMS support in RAN |  | 320d? | 2003-03-14 A | 2004-06-03 A | 100% | 2003-03-14 | 2004-06-03 | 320d? | start no earlier than 2003-03-14 |  | R3 | 2560h | 2560h | RANimp-RABSE-IuEnhIMS | Nortel | Philippe.Godin@nortelnetworks.com | Rel-6 |  | Juha |  |  |  | RP-24 |
| 1423 | 541.1.5 | Deleted - Improvement of RRM across RNS and RNS/BSS | milestone | 0d? | 2003-12-05 A | 2003-12-05 A | 100% | 2003-12-05 | 2003-12-05 | 0d? | finish no earlier than 2003-12-05 |  | R3 |  |  | RANimp-RRM1 | Nokia | antti.toskala@nokia.com | Rel-6 |  | Juha |  |  |  | RP-23 |
| 1424 | 9.1 | Beamforming Enhancements |  | 66d | 2003-09-19 A | 2003-12-19 A | 100% | 2003-09-19 | 2003-12-19 | 66d | finish no earlier than 2004-03-12 |  | R1 | 528h | 528h | RANimp-BFE | Nokia | Jussi Kähtävä (juha.mikola@nokia.com) | Rel-6 | 24.215, 25.423, 25.425, 25.433, 25.435 | Patrick |  |  |  |  |
| 1425 | 541.3 | **Rel6 RRM optimization for Iur and Iub** |  | 126d | 2003-09-19 A | 2004-03-12 A | 100% | 2003-09-19 | 2004-03-12 | 126d |  |  | R3 | 2016h | 2016h | RANimp-RRMopt | Ericsson | Gert-Jan.van.Lieshout@eln.ericsson.se | Rel-6 |  | Juha |  |  |  |  |
| 1426 | 541.3.1 | Improved access to UE measurement data for CRNC to support TDD RRM |  | 126d | 2003-09-19 A | 2004-03-12 A | 100% | 2003-09-19 | 2004-03-12 | 126d | finish no earlier than 2004-03-15 |  | R3 | 1008h | 1008h | RANimp-RRMopt-UEMsD | Interdigital | jim.miller@interdigital.com | Rel-6 | 25.423 | Juha |  |  |  | RP-22 |
| 1427 | 541.4 | **Remote Control of Electrical Tilting Antennas** |  | 395d? | 2003-03-14 A | 2004-09-16 A | 100% | 2003-03-14 | 2004-09-16 | 395d? |  |  | R3,S5 | 4304h | 4304h | RANimp-TiltAnt | Vodafone | Andreas.Hauser@vodafone.com | Rel-6 |  | Juha |  |  |  |  |
| 1428 | 541.4.1 | Tilting Antenna - RAN aspects |  | 393d? | 2003-03-14 A | 2004-09-14 A | 100% | 2003-03-14 | 2004-09-14 | 393d? | finish no earlier than 2004-09-14 |  | R3 | 3144h | 3144h | RANimp-TiltAnt | Vodafone | Andreas.Hauser@vodafone.com | Rel-6 | 25.460, 25.461, 25.462, 25.463 | Juha |  |  |  |  |
| 1429 | 541.4.2 | OAM&P impacts |  | 145d | 2004-02-27 A | 2004-09-16 A | 100% | 2004-02-27 | 2004-09-16 | 145d | finish no earlier than 2004-09-16 |  | S5 | 1160h | 1160h | RANimp-TiltAnt-OAM | Vodafone | Adrian.Neal@vodafone.com | Rel-6 | 32.804, 32.64x | Dionisio |  |  | SP-24 |  |
| 1430 | 541.5 | Network Assisted Cell Change (NACC) from UTRAN to GERAN - network-side aspects |  | 462d? | 2002-09-09 A | 2004-06-15 A | 100% | 2002-09-09 | 2004-06-15 | 462d? | finish no earlier than 2004-06-15 |  | R3 | 3696h | 3696h | RANimp-NACC | Vodafone | Brendan.McWilliams@gb.vodafone.co.uk | Rel-6 |  | Juha |  |  |  |  |
| 1431 | 12 | **Location Services enhancements 2** |  | 1024d? | 2001-01-15 A | 2004-12-16 A | 100% | 2001-01-15 | 2004-12-16 | 1024d? |  |  | S2,S5,N4,RP | 78152h | 78152h | LCS2 |  |  | Rel-6 | 23.271 | Maurice |  |  |  |  |
| 1432 | 12.1 | **Improvement on Le interface** |  | 653d? | 2002-06-17 A | 2004-12-15 A | 100% | 2002-06-17 | 2004-12-15 | 653d? |  |  | S2 | 9872h | 9872h | LCS2 |  |  | Rel-6 |  | Maurice |  |  |  |  |
| 1433 | 542.1.1 | Stage 2 for Improvement on Le interface |  | 331d? | 2002-06-17 A | 2003-09-22 A | 100% | 2002-06-17 | 2003-09-22 | 331d? | start no earlier than 2002-06-17 |  | S2 | 2648h | 2648h | LCS2 |  |  | Rel-6 |  | Maurice |  |  |  |  |
| 1434 | 542.1.2 | Stage 3 - impacts MLP (Mobile Location Protocol) |  | 250d? | 2004-01-01 A | 2004-12-15 A | 100% | 2004-01-01 | 2004-12-15 | 250d? | finish no earlier than 2004-12-15 |  | OMA | 2000h | 2000h | LCS2 |  | OMA-LIAISON@mail.openmobilealliance.org | Rel-6 |  |  |  |  |  |  |

Notes:
- 1410: -
- 1411: -
- 1412: -
- 1413: -
- 1414: -
- 1415: -
- 1416: -
- 1417: Generic feature
- 1418: building block without particular end date
- 1419: -
- 1420: WIDS modified in RP#26, RP-040551
- 1421: Approved at RP#25 as RP-040390
- 1422: Closed RP#24 due to the lack of progress
- 1423: abandoned RP-23
- 1424: -
- 1425: -
- 1426: -
- 1427: -
- 1428: Finished at RP#25
- 1429: SP#25 09/2004 completed
- 1430: -
- 1431: -
- 1432: -
- 1433: -
- 1434: Updated according to SP-040232

| ID | WBS | Task | Type | Duration | Start | Finish | Complete | Baseline start | Baseline finish | Baseline duration | Constraint | Resources | Work | Actual work | Text1 | Text6 | Text8 | Text5 | Text4 | Text12 |
| --- | --- | --- | --- | --- | --- | --- | --- | --- | --- | --- | --- | --- | --- | --- | --- | --- | --- | --- | --- | --- |
| 1435 | 12.2 | **Enhanced support for anonymity and user privacy** |  | 638d? | 2002-07-08 A | 2004-12-15 A | 100% | 2002-07-08 | 2004-12-15 | 638d? |  | S2 | 9144h | 9144h | LCS2 | Rel-6 | Maurice |  |  |  |
| 1436 | 542.2.1 | Stage 2 for Enhanced support for anonymity and user privacy |  | 255d? | 2002-07-08 A | 2003-06-27 A | 100% | 2002-07-08 | 2003-06-27 | 255d? | finish no earlier than 2003-06-27 | S2 | 2040h | 2040h | LCS2 | Rel-6 | Maurice |  |  |  |
| 1437 | 542.2.2 | Stage 3 - impacts MLP and RLP |  | 250d? | 2004-01-01 A | 2004-12-15 A | 100% | 2004-01-01 | 2004-12-15 | 250d? | finish no earlier than 2004-12-15 | OMA | 2000h | 2000h | LCS2 | Rel-6 |  | OMA-LIAISON@mail.openmobilealliance.org |  |  |
| 1438 | 12.3 | **Enhanced inter-GMLC interface** |  | 648d? | 2002-06-24 A | 2004-12-15 A | 100% | 2002-06-24 | 2004-12-15 | 648d? |  | S2 | 9704h | 9704h | LCS2 | Rel-6 | Maurice |  |  |  |
| 1439 | 542.3.1 | Stage 2 for Enhanced inter-GMLC interface |  | 315d? | 2002-06-24 A | 2003-09-05 A | 100% | 2002-06-24 | 2003-09-05 | 315d? | finish no earlier than 2003-09-05 | S2 | 2520h | 2520h | LCS2 | Rel-6 | Maurice |  |  |  |
| 1440 | 542.3.2 | Stage 3 - definition of RLP and PCP |  | 250d? | 2004-01-01 A | 2004-12-15 A | 100% | 2004-01-01 | 2004-12-15 | 250d? | finish no earlier than 2004-12-15 | OMA | 2000h | 2000h | LCS2 | Rel-6 |  | OMA-LIAISON@mail.openmobilealliance.org |  |  |
| 1441 | 12.4 | **Location Services support for IMS public identities** |  | 473d? | 2003-02-24 A | 2004-12-15 A | 100% | 2003-02-24 | 2004-12-15 | 473d? |  | S2 | 7704h | 7704h | LCS2 | Rel-6 | Maurice |  |  |  |
| 1442 | 542.4.1 | Stage 2 for Location Services support for IMS public identities |  | 240d? | 2003-02-24 A | 2004-01-23 A | 100% | 2003-02-24 | 2004-01-23 | 240d? | finish no earlier than 2004-01-23 | S2 | 1920h | 1920h | LCS2 | Rel-6 | Maurice |  |  |  |
| 1443 | 542.4.2 | OMA Stage 3 for Location Services support for IMS public identities - impacts MLP, RLP and PCP |  | 250d? | 2004-01-01 A | 2004-12-15 A | 100% | 2004-01-01 | 2004-12-15 | 250d? | finish no earlier than 2004-12-15 | OMA | 2000h | 2000h | LCS2 | Rel-6 |  | OMA-LIAISON@mail.openmobilealliance.org |  |  |
| 1444 | 12.5 | **New area event for location service triggering reports** |  | 663d? | 2002-06-03 A | 2004-12-15 A | 100% | 2002-06-03 | 2004-12-15 | 663d? |  | S2 | 11416h | 11416h | LCS2 | Rel-6 | Maurice |  |  |  |
| 1445 | 542.5.1 | Stage 2 for New area event for location service triggering reports |  | 280d? | 2002-06-03 A | 2003-06-27 A | 100% | 2002-06-03 | 2003-06-27 | 280d? | finish no earlier than 2003-06-27 | S2 | 2240h | 2240h | LCS2 | Rel-6 | Maurice |  |  |  |
| 1446 | 542.5.2 | Stage 3 for UE-CN signalling |  | 234d? | 2003-10-09 A | 2004-08-31 A | 100% | 2003-10-09 | 2004-08-31 | 234d? | start no earlier than 2003-10-09 | N4 | 1872h | 1872h | LCS2 | Rel-6 | Kimmo |  |  |  |
| 1447 | 542.5.3 | Stage 3 for New area event for location service triggering reports - impacts MLP, RLP and PCP |  | 250d? | 2004-01-01 A | 2004-12-15 A | 100% | 2004-01-01 | 2004-12-15 | 250d? | finish no earlier than 2004-12-15 | OMA | 2000h | 2000h | LCS2 | Rel-6 |  | OMA-LIAISON@mail.openmobilealliance.org |  |  |
| 1448 | 12.7 | **UE positioning for Location Services enhancements 2** |  | 957d? | 2001-01-15 A | 2004-09-14 A | 100% | 2001-01-15 | 2004-09-14 | 957d? |  | RP | 18480h | 18480h | LCS2-UEpos | Rel-6 | Issam |  |  |  |
| 1449 | 12.8 | Open SMLC-SRNC Interface within the UTRAN to support UTRAN Rel4 positioning methods |  | 700d? | 2001-01-15 A | 2003-09-19 A | 100% | 2001-01-15 | 2003-09-19 | 700d? | finish no earlier than 2003-09-19 | R2 | 5600h | 5600h | LCS-Rel4Pos | Rel-6 | Joern | Meik.Kottkamp@siemens.com | Siemens |  |
| 1450 | 542.6.2 | A-GPS minimum performance specification |  | 333d? | 2003-06-06 A | 2004-09-14 A | 100% | 2003-06-06 | 2004-09-14 | 333d? | finish no earlier than 2004-09-14 | R4 | 2664h | 2664h | LCS-UEPos-AGPSPerf | Rel-6 | Issam | donglin.shen@attws.com | AT&T Wireless |  |
| 1451 | 12.7.2 | FS on Enhancements to OTDOA Positioning using advanced blanking methods |  | 320d | 2002-07-01 A | 2003-09-19 A | 100% | 2002-07-01 | 2003-09-19 | 320d | finish no earlier than 2003-09-19 | R2 | 2560h | 2560h | LCS2-UEpos-FSBlank | Rel-6 | Joern | david.bartlett@cursor-system.com | Cambridge Positioning Systems |  |
| 1452 | 542.6.4 | Deleted - UE positioning enhancements - other methods | milestone | 0d? | 2003-09-26 A | 2003-09-26 A | 100% | 2003-09-26 | 2003-09-26 | 0d? | finish no earlier than 2003-09-26 | R2 |  |  | LCS2-UEpos-enh | Rel-6 | Joern | Meik.Kottkamp@siemens.com | Siemens | RP-24 |
| 1453 | 542.7 | LCS charging |  | 455d? | 2003-03-21 A | 2004-12-16 A | 100% | 2003-03-21 | 2004-12-16 | 455d? | start no earlier than 2003-03-21 | S5 | 3640h | 3640h | LCS2-CH | Rel-6 | Dionisio | alain.bibas@orange-ft.com | France Telecom |  |
| 1454 | 14 | **Rel-6 Security enhancements** |  | 1018d? | 2001-01-03 A | 2004-11-26 A | 100% | 2001-01-03 | 2004-11-26 | 1018d? |  | S3 | 28824h | 28824h | SEC1 | Rel-6 | Dionisio | Peter.Howard@vodafone.com | Vodafone |  |
| 1455 | 14.1 | **Enhanced HE control of security (including positive authentication reporting)** |  | 712d | 2001-01-03 A | 2003-09-25 A | 100% | 2001-01-03 | 2003-09-25 | 712d |  | S3 | 14064h | 14064h | SEC1 | Rel-6 | Dionisio | Peter.Howard@vodafone.com | Vodafone |  |
| 1456 | 14.1.1 | Deleted - SEC1 Stage 2 (Enhanced HE control of security) |  | 378d | 2001-01-03 A | 2002-06-14 A | 100% | 2001-01-03 | 2002-06-14 | 378d | finish no earlier than 2002-06-14 | S3 | 3024h | 3024h | SEC1 | Rel-6 | Dionisio |  |  | SP-16 |
| 1457 | 14.1.3 | **Rel-6 Network Domain Security** |  | 334d | 2002-06-17 A | 2003-09-25 A | 100% | 2002-06-17 | 2003-09-25 | 334d |  | S3 | 5344h | 5344h | SEC1-NDS | Rel-6 | Dionisio | Geir-myrdahl.koien@telenor.com | Telenor |  |
| 1458 | 14.1.3.1 | Rel-6 IP network layer security (NDS/IP) |  | 334d | 2002-06-17 A | 2003-09-25 A | 100% | 2002-06-17 | 2003-09-25 | 334d | finish no earlier than 2003-09-25 | S3 | 2672h | 2672h | SEC1-NDS-IP | Rel-6 | Dionisio |  |  |  |
| 1459 | 543.2 | Network Domain Security; Authentication Framework (NDS/AF) |  | 521d? | 2002-02-15 A | 2004-02-13 A | 100% | 2002-02-15 | 2004-02-13 | 521d? | finish no earlier than 2004-02-13 | S3 | 4168h | 4168h | SEC1-NDS-AF | Rel-6 | Dionisio | tommi.viitanen@nokia.com | Nokia |  |
| 1460 | 543.3 | Key Management of group keys for Voice Group Call Services |  | 306d | 2003-09-26 A | 2004-11-26 A | 100% | 2003-09-26 | 2004-11-26 | 306d | finish no earlier than 2004-11-26 | S3 | 2448h | 2448h | SECGKYV | Rel-6 | Dionisio | benno.tietz@vodafone.com | Vodafone |  |
| 1461 | 544 | Network Domain Security; MAP application layer security (NDS/MAPsec) |  | 127d? | 2004-07-06 A | 2004-12-29 A | 100% | 2004-07-06 | 2004-12-29 | 127d? | finish no earlier than 2003-12-26 | S3 | 1016h | 1016h | MAPSEC | Rel-6 | Dionisio | Peter.Howard@vodafone.com | Vodafone |  |

Notes:
- 1435: -
- 1436: -
- 1437: Updated according to SP-040232
- 1438: -
- 1439: -
- 1440: Updated according to SP-040232
- 1441: -
- 1442: -
- 1443: Updated according to SP-040232
- 1444: -
- 1445: -
- 1446: 31/10/2003 work has started. Current stage 3 fullfills the requirements of stage 2. ......
- 1447: Updated according to SP-040232
- 1448: -
- 1449: - / Text3: 25.305, 25.401, 25.450, 25.452, 25.453
- 1450: Finished at RP#25 / Text3: 25.171
- 1451: -
- 1452: building block without particular end date
- 1453: SP#26 12/2004 completed / Text3: 32.271
- 1454: SP#9 approved WID
- 1455: SP#9 approved WID S3-000490 (Enhanced home control of security by HE) / Text3: 33.102
- 1456: Marked as stopped 12/2008
- 1457: SP#9 approved WID S3-000606 (Network Domain Security) / Text3: 33.102, 33.103, 33.105
- 1458: SP#9 approved WID S3-000626 (Access security for IP-based services) / Text3: 33.210
- 1459: SP#19 approved WID / Text3: 33.810
- 1460: - / Text3: 42.068, 43.068, 44.068, 42.069, 43.069, 44.069, 31.102, 24.008, 48.008, 42.009, 43.020
- 1461: SP#19 approved WID. Marked as closed 12/2008 (was marked 20% complete) / Text3: 33.200

| ID | WBS | Task | Duration | Start | Finish | Complete | Baseline start | Baseline finish | Baseline duration | Constraint | Resources | Work | Actual work | Text1 | Text4 | Text5 | Text6 | Text8 | Text3 | Text10 |
| --- | --- | --- | --- | --- | --- | --- | --- | --- | --- | --- | --- | --- | --- | --- | --- | --- | --- | --- | --- | --- |
| 1462 | 545 | **3GPP Enablers for services like Push to Talk over Cellular (PoC)** | 459d? | 2003-09-08 A | 2005-06-09 A | 100% | 2003-09-08 | 2005-06-09 | 459d? |  | S2,S4,S5 | 10696h | 10696h | PoC | Ericsson | Shabnam Sultana | Rel-6 | Maurice |  |  |
| 1463 | 545.1 | Feasibility Study on 3GPP Enablers for services like Push to Talk over Cellular (PoC) | 322d? | 2003-09-08 A | 2004-11-30 A | 100% | 2003-09-08 | 2004-11-30 | 322d? | finish no earlier than 2004-11-30 | S2 | 2576h | 2576h | PoC | Ericsson | Shabnam Sultana | Rel-6 | Maurice | 23.979 | SP-24 |
| 1464 | 545.2 | Dependencies on OMA PoC | 303d? | 2004-01-01 A | 2005-02-28 A | 100% | 2004-01-01 | 2005-02-28 | 303d? | finish no earlier than 2004-12-30 | OMA | 2424h | 2424h | PoC |  | OMA-LIAISON@mail.openmobilealliance.org | Rel-6 |  |  | SP-24 |
| 1465 | 545.3 | Selection of one or more PoC codec(s) for PoC | 69d? | 2004-09-13 A | 2004-12-16 A | 100% | 2004-09-13 | 2004-12-16 | 69d? | start no earlier than 2004-09-13 | S4 | 552h | 552h | PoC |  |  | Rel-6 | Paolo | 26.235, 26.236 | SP-25 |
| 1466 | 545.4 | PoC charging | 184d? | 2004-09-27 A | 2005-06-09 A | 100% | 2004-09-27 | 2005-06-09 | 184d? | finish no earlier than 2005-06-09 | S5 | 1472h | 1472h | PoC-CH | Siemens | Gerald.Goermer@nsn.com | Rel-6 | Dionisio | 32.272 |  |
| 1467 | 546 | Study on Interworking aspects and migration scenarios for IPv4 based IMS Implementations | 210d? | 2003-09-08 A | 2004-06-25 A | 100% | 2003-09-08 | 2004-06-25 | 210d? | finish no earlier than 2004-06-25 | S2 | 1680h | 1680h | IPv4IMS | Siemens | Alexander Milinski | Rel-6 | Maurice | 23.981 |  |
| 1468 | 16.3 | **Interoperability and Commonality between IMS using different IP-connectivity Networks** | 325d? | 2002-09-16 A | 2003-12-12 A | 100% | 2002-09-16 | 2003-12-12 | 325d? |  | S2 | 9176h | 9176h | IMSCOOP |  |  | Rel-6 | Maurice | 23.864 |  |
| 1469 | 16.3.1 | Stage 2 for Interoperability | 272d | 2002-09-16 A | 2003-09-30 A | 100% | 2002-09-16 | 2003-09-30 | 272d | finish no earlier than 2003-09-30 | S2 | 2176h | 2176h | IMSCOOP | Nokia | balazs.bertenyi@nsn.com | Rel-6 | Maurice | 23.864 |  |
| 1470 | 547.2 | Stage 2 for commonality | 265d? | 2002-09-16 A | 2003-09-19 A | 100% | 2002-09-16 | 2003-09-19 | 265d? | start no earlier than 2002-09-16 | S2 | 2120h | 2120h | IMSCOOP | Nokia | balazs.bertenyi@nsn.com | Rel-6 | Maurice | 23.864 |  |
| 1471 | 16.3.2 | Stage 3 for Interoperability and Commonality between IMS using different IP-connectivity Networks | 305d | 2002-10-14 A | 2003-12-12 A | 100% | 2002-10-14 | 2003-12-12 | 305d | finish no earlier than 2003-12-12 | N1 | 2440h | 2440h | IMSCOOP | Lucent | Keith Drage (drage@alcatel-lucent.com) | Rel-6 | Frederic |  |  |
| 1472 | 19 | **Rel-6 MExE enhancements** | 326d | 2002-03-08 A | 2003-06-06 A | 100% | 2002-03-08 | 2003-06-06 | 326d |  | T2 | 7328h | 7328h | MEXE6 |  |  | Rel-6 | Kimmo |  |  |
| 1473 | 19.1 | MExE Rel-6 Improvements and Investigations | 264d | 2002-03-08 A | 2003-03-12 A | 100% | 2002-03-08 | 2003-03-12 | 264d | finish no earlier than 2003-03-12 | T2 | 2112h | 2112h | MEXE6-ENHANC | TTPCom | Lars Brenk ( (lsb_ttpcom@HOTMAIL.COM) | Rel-6 | Kimmo |  |  |
| 1474 | 19.2 | MExE Run-Time Independent Framework Feasibility Study | 326d | 2002-03-08 A | 2003-06-06 A | 100% | 2002-03-08 | 2003-06-06 | 326d | finish no earlier than 2003-06-06 | T2 | 2608h | 2608h | MEXE6-RTIF | Nokia Siemens Networks | balazs.bertenyi@nokia.com | Rel-6 | Kimmo | 22.857 |  |
| 1475 | 21 | Subscription Management | 650d | 2002-09-20 A | 2005-03-17 A | 100% | 2002-09-20 | 2005-03-17 | 650d | finish no earlier than 2005-03-17 | S5 | 5200h | 5200h | SuM | T-Mobile | istvan.aba@t-mobile.at | Rel-6 | Dionisio | 32.140/1, 32.171/2/5, 32.803 |  |
| 1476 | 25 | **Enhanced A/Gb feasibility study** | 51d? | 2002-08-30 A | 2002-11-08 A | 100% | 2002-08-30 | 2002-11-08 | 51d? |  | GP | 3264h | 3264h | AGbEnFS | Vodafone | jose-luis.carrizo@vodafone.co.uk | Rel-6 | Paolo | None |  |
| 1477 | 25.1 | **Feasibility study on A/Gb enhancements** | 51d? | 2002-08-30 A | 2002-11-08 A | 100% | 2002-08-30 | 2002-11-08 | 51d? |  | G2 | 2856h | 2856h | AGbEnFS-FS | Vodafone | jose-luis.carrizo@vodafone.co.uk | Rel-6 | Gert | None |  |
| 1478 | 25.1.1 | Requirements for the support of conversational services | 51d | 2002-08-30 A | 2002-11-08 A | 100% | 2002-08-30 | 2002-11-08 | 51d | finish no earlier than 2002-11-08 | GP | 408h | 408h | AGbEnFS-FS |  |  | Rel-6 | Paolo | None |  |
| 1479 | 550.1.2 | Identification of the different building blocks for the provision of conversational services on the existing A/Gb protocol stack | 51d? | 2002-08-30 A | 2002-11-08 A | 100% | 2002-08-30 | 2002-11-08 | 51d? | finish no earlier than 2002-11-08 | GP | 408h | 408h | AGbEnFS-FS |  |  | Rel-6 | Paolo | None |  |
| 1480 | 550.1.3 | Outline of impact and feasibility of these building blocks and their different solutions | 51d? | 2002-08-30 A | 2002-11-08 A | 100% | 2002-08-30 | 2002-11-08 | 51d? | finish no earlier than 2002-11-08 | GP | 408h | 408h | AGbEnFS-FS |  |  | Rel-6 | Paolo | None |  |
| 1481 | 25.1.4 | Impact on 3GPP architecture and requirement to co-ordinatge with other TSGs (CN, SA) | 51d | 2002-08-30 A | 2002-11-08 A | 100% | 2002-08-30 | 2002-11-08 | 51d | finish no earlier than 2002-11-08 | GP | 408h | 408h | AGbEnFS-FS |  |  | Rel-6 | Paolo | None |  |
| 1482 | 25.1.5 | Standardisation effort | 51d | 2002-08-30 A | 2002-11-08 A | 100% | 2002-08-30 | 2002-11-08 | 51d | finish no earlier than 2002-11-08 | GP | 408h | 408h | AGbEnFS-FS |  |  | Rel-6 | Paolo | None |  |
| 1483 | 25.1.6 | Dependency to other features of Enhanced A/Gb feasibility study | 51d | 2002-08-30 A | 2002-11-08 A | 100% | 2002-08-30 | 2002-11-08 | 51d | finish no earlier than 2002-11-08 | GP | 408h | 408h | AGbEnFS-FS |  |  | Rel-6 | Paolo | None |  |
| 1484 | 26 | **Flexible Layer One for GERAN** | 1171d | 2000-01-03 A | 2004-06-25 A | 100% | 2000-01-03 | 2004-06-25 | 1171d |  | GP,S3 | 71551h | 71551h | FLOGER | Nokia | benoist.sebire@nokia.com | Rel-6 | Paolo |  |  |
| 1485 | 26.1 | **Realisation of a Flexible Layer One** | 1126d | 2000-01-03 A | 2004-04-23 A | 100% | 2000-01-03 | 2004-04-23 | 1126d |  | GP | 42816h | 42816h | FLOGER-Real | Nokia | benoist.sebire@nokia.com | Rel-6 | Paolo |  |  |
| 1486 | 26.1.1 | Technical Report on Realisation of a Flexible Layer One | 471d | 2002-04-19 A | 2004-02-06 A | 100% | 2002-04-19 | 2004-02-06 | 471d | finish no earlier than 2004-02-06 | GP | 3768h | 3768h | FLOGER-Real | Nokia | benoist.sebire@nokia.com | Rel-6 | Paolo |  |  |
| 1487 | 26.1.2 | Architecture in 45.001 and 43.051 | 526d | 2002-04-19 A | 2004-04-23 A | 100% | 2002-04-19 | 2004-04-23 | 526d | finish no earlier than 2004-04-23 | G1 | 4208h | 4208h | FLOGER-Real | Nokia | benoist.sebire@nokia.com | Rel-6 | Paolo |  |  |
| 1488 | 26.1.3 | Multiplexing in 45.002 | 526d | 2002-04-19 A | 2004-04-23 A | 100% | 2002-04-19 | 2004-04-23 | 526d | finish no earlier than 2004-04-23 | G1 | 4208h | 4208h | FLOGER-Real | Nokia | benoist.sebire@nokia.com | Rel-6 | Paolo |  |  |
| 1489 | 26.1.4 | Channel Coding in 45.003 for Realisation of a Flexible Layer One | 526d | 2002-04-19 A | 2004-04-23 A | 100% | 2002-04-19 | 2004-04-23 | 526d | finish no earlier than 2004-04-23 | G1 | 4208h | 4208h | FLOGER-Real | Nokia | benoist.sebire@nokia.com | Rel-6 | Paolo |  |  |
| 1490 | 26.1.5 | Performance Requirements in 45.005 for Realisation of a Flexible Layer One | 1126d | 2000-01-03 A | 2004-04-23 A | 100% | 2000-01-03 | 2004-04-23 | 1126d | finish no earlier than 2004-04-23 | G1 | 9000h | 9000h | FLOGER-Real | Nokia | benoist.sebire@nokia.com | Rel-6 | Paolo |  |  |
| 1491 | 26.1.6 | Radio subsystem link control in 45.008 for Realisation of a Flexible Layer One | 526d | 2002-04-19 A | 2004-04-23 A | 100% | 2002-04-19 | 2004-04-23 | 526d | finish no earlier than 2004-04-23 | G1 | 4208h | 4208h | FLOGER-Real | Nokia | benoist.sebire@nokia.com | Rel-6 | Paolo |  |  |
| 1492 | 26.1.7 | Requirements in 44.004 | 526d | 2002-04-19 A | 2004-04-23 A | 100% | 2002-04-19 | 2004-04-23 | 526d | finish no earlier than 2004-04-23 | G2 | 4208h | 4208h | FLOGER-Real | Nokia | benoist.sebire@nokia.com | Rel-6 | Gert |  |  |

Notes:
- 1462: -
- 1463: -
- 1464: Updated according to SP-040232
- 1465: Completed
- 1466: SP#28 06/2005 completed
- 1467: -
- 1468: -
- 1469: No contributions assumed that no more will be done in 3GPP hence work may need to be done in 3GPP2
- 1470: -
- 1471: -
- 1472: -
- 1473: -
- 1474: -
- 1475: SP#27 03/2005 completed
- 1476: -
- 1477: -
- 1478: -
- 1479: -
- 1480: -
- 1481: -
- 1482: -
- 1483: -
- 1484: -
- 1485: -
- 1486: -
- 1487: -
- 1488: -
- 1489: -
- 1490: -
- 1491: -
- 1492: -

| ID | WBS | Task | Type | Duration | Start | Finish | Complete | Baseline start | Baseline finish | Baseline duration | Constraint | Resources | Work | Actual work | Text1 | Text4 | Text5 | Text6 | Text8 | Text3 | Text12 | Text10 |
| --- | --- | --- | --- | --- | --- | --- | --- | --- | --- | --- | --- | --- | --- | --- | --- | --- | --- | --- | --- | --- | --- | --- |
| 1493 | 26.2 | **Signalling and protocol support for a Flexible Layer One** |  | 571d | 2002-04-19 A | 2004-06-25 A | 100% | 2002-04-19 | 2004-06-25 | 571d |  | G2 | 13704h | 13704h | FLOGER-SigPro | Nokia | benoist.sebire@nokia.com | Rel-6 | Gert |  |  |  |
| 1494 | 26.2.1 | Modifications to RLC/MAC in 44.060 and 44.160 |  | 571d | 2002-04-19 A | 2004-06-25 A | 100% | 2002-04-19 | 2004-06-25 | 571d | finish no earlier than 2004-06-25 | G2 | 4568h | 4568h | FLOGER-SigPro | Nokia | benoist.sebire@nokia.com | Rel-6 | Gert |  |  |  |
| 1495 | 26.2.2 | Modifications to RRC in 44.118 and 44.018 |  | 571d | 2002-04-19 A | 2004-06-25 A | 100% | 2002-04-19 | 2004-06-25 | 571d | finish no earlier than 2004-06-25 | G2 | 4568h | 4568h | FLOGER-SigPro | Nokia | benoist.sebire@nokia.com | Rel-6 | Gert |  |  |  |
| 1496 | 26.3 | **Security for a Flexible Layer One** |  | 356d | 2002-04-19 A | 2003-08-29 A | 100% | 2002-04-19 | 2003-08-29 | 356d |  | S3, G2 | 5663.03h | 5663.03h | FLOGER-SecFLO | Nokia | benoist.sebire@nokia.com | Rel-6 | Dionisio |  |  |  |
| 1497 | 26.3.1 | Ciphering in 44.060, 44.160, 44.018, 44.118 |  | 356d | 2002-04-19 A | 2003-08-29 A | 100% | 2002-04-19 | 2003-08-29 | 356d | finish no earlier than 2003-08-29 | S3, G2 | 2848h | 2848h | FLOGER-SecFLO | Nokia | benoist.sebire@nokia.com | Rel-6 | Dionisio | 44.060, 44.160, 44.018, 44.118 |  |  |
| 1498 | 26.4 | **Deleted - GERAN MS Conformance test for the Flexible Layer One - DELETE** |  | 0d | 2004-02-06 A | 2004-02-06 A | 100% | 2004-02-06 | 2004-02-06 | 0d |  | G4,G5 |  |  | FLOGER-Msconf | Nokia | benoist.sebire@nokia.com | Rel-6 | Paolo |  | GP-27 |  |
| 1499 | 26.4.1 | Deleted at TSG #27 - MS Test in 51.010 | milestone | 0d | 2004-02-06 A | 2004-02-06 A | 100% | 2004-02-06 | 2004-02-06 | 0d | finish no earlier than 2004-02-06 | G4,G5 |  |  | FLOGER-Msconf | Nokia | benoist.sebire@nokia.com | Rel-6 | Paolo |  | GP-22 |  |
| 1500 | 26.5 | **Deleted - GERAN BTS Conformance test for the Flexible Layer One - DELETE** |  | 0d | 2004-02-06 A | 2004-02-06 A | 100% | 2004-02-06 | 2004-02-06 | 0d |  | G3new |  |  | FLOGER-BTSconf | Nokia | benoist.sebire@nokia.com | Rel-6 | Ingbert |  | GP-27 |  |
| 1501 | 26.5.1 | Deleted at TGS #27 - BTS Test in 51.021 - DELETE | milestone | 0d | 2004-02-06 A | 2004-02-06 A | 100% | 2004-02-06 | 2004-02-06 | 0d | finish no earlier than 2004-02-06 | G3new |  |  | FLOGER-BTSconf | Nokia | benoist.sebire@nokia.com | Rel-6 | Ingbert |  | GP-22 |  |
| 1502 | 27 | Uplink TDOA feasibility study |  | 151d | 2001-11-30 A | 2002-06-28 A | 100% | 2001-11-30 | 2002-06-28 | 151d | finish no earlier than 2002-06-28 | GP | 1208h | 1208h | TDOAF | TruePosition | Bob Gross (rlgross@trueposition.com) | Rel-6 | Paolo | 45.811 |  |  |
| 1503 | 35 | **QoS Improvements** |  | 628d? | 2002-07-15 A | 2004-12-08 A | 100% | 2002-07-15 | 2004-12-08 | 628d? |  | S2,N3 | 13128h | 13128h | QoS1 | Nokia |  | Rel-6 | Maurice | 23.107, 23.207, 23.221 |  |  |
| 1504 | 35.1 | FS on Dynamic Policy control enhancements for end-to-end QoS |  | 465d | 2002-07-15 A | 2004-04-23 A | 100% | 2002-07-15 | 2004-04-23 | 465d | finish no earlier than 2004-04-23 | S2 | 3720h | 3720h | QoS1 | Nortel | Claire Mousset | Rel-6 | Maurice | 23.917 withdrawn (Contents all in 23.207) |  |  |
| 1505 | 553.2 | Definition of the Gq interface |  | 214d? | 2003-07-01 A | 2004-04-23 A | 100% | 2003-07-01 | 2004-04-23 | 214d? | finish no earlier than 2004-04-23 | S2 | 1712h | 1712h | QoS1 |  | Janne Rinne | Rel-6 | Maurice | 23.207 |  |  |
| 1506 | 553.3 | Gq interface specification for Dynamic Policy control enhancements – Stage 3 |  | 334d | 2003-08-29 A | 2004-12-08 A | 100% | 2003-08-29 | 2004-12-08 | 334d | finish no earlier than 2004-12-08 | N3 | 2672h | 2672h | QoS1 | Nokia | Anna.Sillanpaai@nokia.com | Rel-6 | Gwiho | 29.207, 29.208, 29.209 |  |  |
| 1507 | 36 | **Subscriber certificates** |  | 728d? | 2002-02-25 A | 2004-12-08 A | 100% | 2002-02-25 | 2004-12-08 | 728d? |  | S3,S2,N1,N4,T3,OMA | 12888h | 12888h | SEC1-SC | Nokia | valtteri.niemi@nokia.com | Rel-6 | Dionisio |  |  |  |
| 1508 | 36.1 | Stage 1 of Subscriber certificates |  | 144d | 2002-02-25 A | 2002-09-12 A | 100% | 2002-02-25 | 2002-09-12 | 144d | finish no earlier than 2002-09-12 | S3 | 1152h | 1152h | SEC1-SC | Nokia | valtteri.niemi@nokia.com | Rel-6 | Dionisio | new (33.220, 33.221, 33.222, 33.246, 33.919) |  |  |
| 1509 | 36.2 | Architecture review |  | 24d | 2002-10-14 A | 2002-11-14 A | 100% | 2002-10-14 | 2002-11-14 | 24d | finish no earlier than 2002-11-14 | S2 | 192h | 192h | SEC1-SC | Nokia |  | Rel-6 | Maurice |  |  |  |
| 1510 | 554.3 | Stage 3 for Subscriber certificates |  | 313d? | 2003-09-19 A | 2004-11-30 A | 100% | 2003-09-19 | 2004-11-30 | 313d? | finish no earlier than 2004-11-30 | N4,T3 | 2504h | 2504h | SEC1-SC | Nokia | Lauri Laitinen | Rel-6 | Kimmo | 23.003, 23.008, 29.109, 29.230, T3 31.102, 31.103, 31.111 |  |  |
| 1511 | 554.4 | Stage 3 Ua & Ub interfaces |  | 288d? | 2003-11-03 A | 2004-12-08 A | 100% | 2003-11-03 | 2004-12-08 | 288d? | finish no earlier than 2004-12-08 | N1 | 2304h | 2304h | SEC1-SC | Nokia |  | Rel-6 | Frederic | 24.109 |  |  |
| 1512 | 554.5 | OMA dependencies on Subscriber certificates |  | 114d? | 2004-01-01 A | 2004-06-08 A | 100% | 2004-01-01 | 2004-06-08 | 114d? | finish no earlier than 2004-06-08 | OMA | 912h | 912h | SEC1-SC | Nokia | OMA-LIAISON@mail.openmobilealliance.org | Rel-6 |  |  |  | SP-24 |
| 1513 | 39 | **Addition of frequency bands to GSM (TAPS)** |  | 676d | 2002-06-28 A | 2005-01-28 A | 100% | 2002-06-28 | 2005-01-28 | 676d |  | GP | 16640h | 16640h | TAPS | Nokia | Torben Themsen | Rel-6 | Paolo |  |  |  |
| 1514 | 39.1 | **Addition of frequency bands to GSM – Changes to core specs** |  | 26d | 2002-11-15 A | 2002-12-20 A | 100% | 2002-11-15 | 2002-12-20 | 26d |  | G1 | 416h | 416h | TAPS-Specs | Nokia | Torben Themsen | Rel-6 | Paolo |  |  |  |
| 1515 | 39.1.1 | Changes to core specs |  | 26d | 2002-11-15 A | 2002-12-20 A | 100% | 2002-11-15 | 2002-12-20 | 26d | finish no earlier than 2002-12-20 | G1 | 208h | 208h | TAPS-Specs | Nokia | Torben Themsen | Rel-6 | Paolo |  |  |  |
| 1516 | 39.2 | **Deleted - Addition of frequency bands to GSM – Changes for conformance tests** |  | 676d | 2002-06-28 A | 2005-01-28 A | 100% | 2002-06-28 | 2005-01-28 | 676d |  | G4 | 10816h | 10816h | TAPS-Conf | Nokia | Torben Themsen | Rel-6 | Paolo |  | GP-23 |  |
| 1517 | 39.2.1 | Deleted - 51.010-1 Add testing |  | 676d | 2002-06-28 A | 2005-01-28 A | 100% | 2002-06-28 | 2005-01-28 | 676d | finish no earlier than 2005-01-28 | G4 | 5408h | 5408h | TAPS-Conf | Nokia | Torben Themsen | Rel-6 | Paolo |  | GP-23 |  |

Notes:
- 1493: -
- 1494: -
- 1495: -
- 1496: -
- 1497: -
- 1498: -
- 1499: -
- 1500: -
- 1501: -
- 1502: -
- 1503: -
- 1504: -
- 1505: -
- 1506: [DAB - 25.05.04] - Delayed to Sept - possibly Dec 2004
- 1507: SP#14 approved WID
- 1508: -
- 1509: -
- 1510: Finished in CN4#26
- 1511: -
- 1512: Updated according to SP-040420
- 1513: -
- 1514: -
- 1515: -
- 1516: -
- 1517: -

| ID | WBS | Task | Duration | Start | Finish | Complete | Baseline start | Baseline finish | Baseline duration | Constraint | Resources | Work | Actual work | Text1 | Text4 | Text5 | Text6 | Text8 | Text12 |
| --- | --- | --- | --- | --- | --- | --- | --- | --- | --- | --- | --- | --- | --- | --- | --- | --- | --- | --- | --- |
| 1518 | 40 | **Seamless support of streaming services in A/Gb mode** | 1426d? | 2000-01-03 A | 2005-06-17 A | 100% | 2000-01-03 | 2005-06-17 | 1426d? |  | GP,S3 | 58656h | 58656h | SSStrea | Vodafone | José Luis Carrizo Martínez | Rel-6 | Paolo |  |
| 1519 | 40.1 | **Identification of requirements for streaming** | 46d? | 2003-06-27 A | 2003-08-29 A | 100% | 2003-06-27 | 2003-08-29 | 46d? |  | G1 | 736h | 736h | SSStrea | Vodafone | José Luis Carrizo Martínez | Rel-6 | Paolo |  |
| 1520 | 556.1.1 | Requirements for streaming | 46d? | 2003-06-27 A | 2003-08-29 A | 100% | 2003-06-27 | 2003-08-29 | 46d? | finish no earlier than 2003-08-29 | G1 | 368h | 368h | SSStrea | Vodafone | José Luis Carrizo Martínez | Rel-6 | Paolo |  |
| 1521 | 40.2 | **Performance study of cell change mechanisms** | 956d? | 2000-01-03 A | 2003-08-29 A | 100% | 2000-01-03 | 2003-08-29 | 956d? |  | G1 | 30568h | 30568h | SSStrea | Vodafone | José Luis Carrizo Martínez | Rel-6 | Paolo |  |
| 1522 | 556.2.1 | Performance of NACC | 956d? | 2000-01-03 A | 2003-08-29 A | 100% | 2000-01-03 | 2003-08-29 | 956d? | finish no earlier than 2003-08-29 | G1 | 7640h | 7640h | SSStrea | Vodafone | José Luis Carrizo Martínez | Rel-6 | Paolo |  |
| 1523 | 556.2.2 | Performance of cell change in DTM for the PS domain | 956d? | 2000-01-03 A | 2003-08-29 A | 100% | 2000-01-03 | 2003-08-29 | 956d? | finish no earlier than 2003-08-29 | G1 | 7640h | 7640h | SSStrea | Vodafone | José Luis Carrizo Martínez | Rel-6 | Paolo |  |
| 1524 | 556.2.3 | Handover for Seamless support of streaming services in A/Gb mode | 956d? | 2000-01-03 A | 2003-08-29 A | 100% | 2000-01-03 | 2003-08-29 | 956d? | finish no earlier than 2003-08-29 | G1 | 7640h | 7640h | SSStrea | Vodafone | José Luis Carrizo Martínez | Rel-6 | Paolo |  |
| 1525 | 40.3 | **Reduction of service interruption times and packet loss during mobility procedures** | 516d? | 2003-06-27 A | 2005-06-17 A | 100% | 2003-06-27 | 2005-06-17 | 516d? |  | G2 | 10800h | 10800h | SSStrea | Vodafone | José Luis Carrizo Martínez | Rel-6 | Gert |  |
| 1526 | 556.3.1 | optimizations of existing mechanisms/procedures | 106d? | 2003-06-27 A | 2003-11-21 A | 100% | 2003-06-27 | 2003-11-21 | 106d? | finish no earlier than 2003-11-21 | G2 | 848h | 848h | SSStrea | Vodafone | José Luis Carrizo Martínez | Rel-6 | Gert |  |
| 1527 | 556.3.2 | Inter-system NACC | 106d? | 2003-06-27 A | 2003-11-21 A | 100% | 2003-06-27 | 2003-11-21 | 106d? | finish no earlier than 2003-11-21 | G2 | 848h | 848h | SSStrea | Vodafone | José Luis Carrizo Martínez | Rel-6 | Gert |  |
| 1528 | 556.3.3 | PS Handover (within GERAN and between GERAN and UTRAN) | 516d? | 2003-06-27 A | 2005-06-17 A | 100% | 2003-06-27 | 2005-06-17 | 516d? | finish no earlier than 2003-11-21 | G2 | 4128h | 4128h | SSStrea | Vodafone | José Luis Carrizo Martínez | Rel-6 | Gert |  |
| 1529 | 556.3.4 | Dependency to other features of Reduction of service interruption times and packet loss during mobility procedures | 106d? | 2003-06-27 A | 2003-11-21 A | 100% | 2003-06-27 | 2003-11-21 | 106d? | finish no earlier than 2003-11-21 | G2 | 848h | 848h | SSStrea | Vodafone | José Luis Carrizo Martínez | Rel-6 | Gert |  |
| 1530 | 40.5 | **Deleted - MS conformance testing for Seamless support of streaming services in A/Gb mode** | 31d? | 2003-12-19 A | 2004-01-30 A | 100% | 2003-12-19 | 2004-01-30 | 31d? |  | G3new | 248h | 248h | SSStrea | Vodafone | José Luis Carrizo Martínez | Rel-6 | Ingbert | GP-27 |
| 1531 | 556.4.1 | Deleted - MS conformance tests for Seamless support of streaming services in A/Gb mode | 31d? | 2003-12-19 A | 2004-01-30 A | 100% | 2003-12-19 | 2004-01-30 | 31d? | finish no earlier than 2004-01-30 | G4,G5 | 248h | 248h | SSStrea | Vodafone | José Luis Carrizo Martínez | Rel-6 | Ingbert | GP-27 |
| 1532 | 556.5 | GERAN A/Gb mode security enhancements | 612d? | 2002-09-26 A | 2005-01-28 A | 100% | 2002-09-26 | 2005-01-28 | 612d? | finish no earlier than 2005-01-28 | S3 | 4896h | 4896h | SSStrea | Vodafone | peter.howard@vodafone.com | Rel-6 | Dionisio |  |
| 1533 | 41 | Performance characterisation of default codecs for PS conversational multimedia application | 455d | 2002-09-13 A | 2004-06-10 A | 100% | 2002-09-13 | 2004-06-10 | 455d | finish no earlier than 2004-06-10 | S4 | 3640h | 3640h | CODCAR | Nokia | pasi.s.ojala@nokia.com | Rel-6 | Paolo |  |
| 1534 | 44 | **Rel-6 Operations, Administration, Maintenance and Provisioning (OAM&P)** | 652d? | 2002-09-12 A | 2005-03-11 A | 100% | 2002-09-12 | 2005-03-11 | 652d? |  | S5 | 32299.5h | 32299.5h | OAM | Motorola |  | Rel-6 | Dionisio |  |
| 1535 | 44.1 | Principles, high level Requirements and Architecture | 526d | 2002-09-12 A | 2004-09-16 A | 100% | 2002-09-12 | 2004-09-16 | 526d | finish no earlier than 2004-09-16 | S5 | 4208h | 4208h | OAM-AR | Motorola |  | Rel-6 | Dionisio |  |
| 1536 | 44.2 | Performance Management | 591d | 2002-09-12 A | 2004-12-16 A | 100% | 2002-09-12 | 2004-12-16 | 591d | finish no earlier than 2004-12-16 | S5 | 4728h | 4728h | OAM-PM | Nortel |  | Rel-6 | Dionisio |  |
| 1537 | 44.4 | Network Infrastructure Management | 591d | 2002-09-12 A | 2004-12-16 A | 100% | 2002-09-12 | 2004-12-16 | 591d | finish no earlier than 2004-12-16 | S5 | 4728h | 4728h | OAM-NIM | Ericsson | thomas.tovinger@ericsson.com | Rel-6 | Dionisio |  |
| 1538 | 44.5 | **Rel-6 Trace Management** | 646d? | 2002-09-20 A | 2005-03-11 A | 100% | 2002-09-20 | 2005-03-11 | 646d? |  | S5,N4,R3 | 13541.9h | 13541.9h | OAM-Trace | Nokia | kari.t.ronka@nokia.com | Rel-6 | Dionisio |  |
| 1539 | 558.4.1 | Subscriber and UE trace management | 585d | 2002-09-20 A | 2004-12-16 A | 100% | 2002-09-20 | 2004-12-16 | 585d | finish no earlier than 2004-12-16 | S5 | 4680h | 4680h | OAM-Trace | Nokia | kari.t.ronka@nokia.com | Rel-6 | Dionisio |  |
| 1540 | 558.4.2 | Subscriber and equipment trace in UTRAN | 268d? | 2003-06-06 A | 2004-06-15 A | 100% | 2003-06-06 | 2004-06-15 | 268d? | finish no earlier than 2004-06-15 | R3 | 2144h | 2144h | OAM-Trace-RAN | Nortel | Yann Sehedi (sehedic@nortelnetworks.com) | Rel-6 | Juha |  |
| 1541 | 558.4.3 | Trace Management, Stage3 | 193.74d? | 2004-06-09 A | 2005-03-11 A | 100% | 2004-06-09 | 2005-03-11 | 193.74d? | finish no earlier than 2005-03-11 | N4 | 1549.92h | 1549.92h | OAM-Trace | Nokia | seppo.kauntola@nokia.com | Rel-6 | Kimmo |  |

Notes:
- 1518: -
- 1519: -
- 1520: -
- 1521: -
- 1522: -
- 1523: -
- 1524: -
- 1525: Completed at GERP#17
- 1526: -
- 1527: -
- 1528: -
- 1529: -
- 1530: Marked as stopped 10/2009
- 1531: Marked as stopped 10/2009
- 1532: SP#19 approved WID / Text3: 33.102
- 1533: - / Text3: 26.935
- 1534: SP#26: Updated WID SP-040766 was SP-020445. Completion delayed 12/04->03/05 due to OAM-Trace in CN1/4.
- 1535: SP#25 09/2004 completed / Text3: 32.101, 32.102
- 1536: SP#26 12/2004 completed / Text3: 32.401, 32.403, 52.402, 32.411, 32.412, 32.413, 32.432, 32.435, 32.436
- 1537: SP#26 12/2004 completed / Text3: 32.150/1/2, 32.805, 32.111-5, 32.313/4, 32.331/2/3/4/5, 32.341/2/3/4, 32.351/2/3/4, 32.361/2/3/4, 32.371/2/3/4, 32.804, 32.675, 32.690, 32.695, 32.71/2/3/4/5, 32.741/2/3/4/5
- 1538: SP#26 12/2004 SA5 completed 12/04. Signalling Based Trace Activation for IMS (SIP) moved to Rel-7. Reason: CN1 cannot complete 24.229 trace without IETF dependency => estimate 05/2005.
- 1539: SP#26 12/2004 completed / Text3: 32.421, 32.422, 32.423, 52.008
- 1540: - / Text3: 25.413, 25.420, 25.423
- 1541: - / Text3: 23.205, 29.232, 29.060, 29.002, 29.228

| ID | WBS | Task | Duration | Start | Finish | Complete | Baseline start | Baseline finish | Baseline duration | Constraint | Resources | Work | Actual work | Text1 | Text4 | Text5 | Text6 | Text8 | Text3 | Text10 | Text12 |
| --- | --- | --- | --- | --- | --- | --- | --- | --- | --- | --- | --- | --- | --- | --- | --- | --- | --- | --- | --- | --- | --- |
| 1542 | 559 | **Rel-6 Charging Management** | 666d? | 2002-11-21 A | 2005-06-09 A | 100% | 2002-11-21 | 2005-06-09 | 666d? |  | S5 | 55320h | 55320h | CH | T-Mobile | karl-heinz.nenner@t-mobile.de | Rel-6 | Dionisio |  |  |  |
| 1543 | 559.1 | Charging architecture and principles | 390d? | 2003-03-21 A | 2004-09-16 A | 100% | 2003-03-21 | 2004-09-16 | 390d? | start no earlier than 2003-03-21 | S5 | 3120h | 3120h | CH |  |  | Rel-6 | Dionisio | 32.240 |  |  |
| 1544 | 559.2 | Charging Data Record (CDR) file format and transfer | 260d? | 2003-03-21 A | 2004-03-18 A | 100% | 2003-03-21 | 2004-03-18 | 260d? | start no earlier than 2003-03-21 | S5 | 2080h | 2080h | CH |  |  | Rel-6 | Dionisio | 32.297 |  |  |
| 1545 | 559.3 | CDR parameter description | 580d? | 2003-03-21 A | 2005-06-09 A | 100% | 2003-03-21 | 2005-06-09 | 580d? | finish no earlier than 2005-06-09 | S5 | 4640h | 4640h | CH |  |  | Rel-6 | Dionisio | 32.298 |  |  |
| 1546 | 559.4 | Diameter charging applications | 390d? | 2003-03-21 A | 2004-09-16 A | 100% | 2003-03-21 | 2004-09-16 | 390d? | start no earlier than 2003-03-21 | S5 | 3120h | 3120h | CH |  |  | Rel-6 | Dionisio | 32.299 |  |  |
| 1547 | 559.5 | Online Charging System (OCS) architecture study | 130d? | 2003-03-21 A | 2003-09-18 A | 100% | 2003-03-21 | 2003-09-18 | 130d? | start no earlier than 2003-03-21 | S5 | 1040h | 1040h | CH |  |  | Rel-6 | Dionisio | 32.815 |  |  |
| 1548 | 559.6 | OCS: Applications and interfaces | 455d? | 2003-03-21 A | 2004-12-16 A | 100% | 2003-03-21 | 2004-12-16 | 455d? | start no earlier than 2003-03-21 | S5 | 3640h | 3640h | CH |  |  | Rel-6 | Dionisio | 32.296 |  |  |
| 1549 | 559.7 | **Charging Management for Bearer level** | 390d? | 2003-03-21 A | 2004-09-16 A | 100% | 2003-03-21 | 2004-09-16 | 390d? |  | S5 | 11440h | 11440h | CH-BC | Nokia | Benni ALEXANDER | Rel-6 | Dionisio |  |  |  |
| 1550 | 559.7.1 | CS domain charging | 260d? | 2003-03-21 A | 2004-03-18 A | 100% | 2003-03-21 | 2004-03-18 | 260d? | start no earlier than 2003-03-21 | S5 | 2080h | 2080h | CH |  |  | Rel-6 | Dionisio | 32.250 |  |  |
| 1551 | 559.7.2 | PS domain charging | 390d? | 2003-03-21 A | 2004-09-16 A | 100% | 2003-03-21 | 2004-09-16 | 390d? | start no earlier than 2003-03-21 | S5 | 3120h | 3120h | CH |  |  | Rel-6 | Dionisio | 32.251 |  |  |
| 1552 | 559.7.3 | CDR transfer | 390d? | 2003-03-21 A | 2004-09-16 A | 100% | 2003-03-21 | 2004-09-16 | 390d? | start no earlier than 2003-03-21 | S5 | 3120h | 3120h | CH |  |  | Rel-6 | Dionisio | 32.295 |  |  |
| 1553 | 559.8 | Charging Management for the IMS | 455d? | 2003-03-21 A | 2004-12-16 A | 100% | 2003-03-21 | 2004-12-16 | 455d? | finish no earlier than 2004-12-16 | S5 | 3640h | 3640h | IMS2-CH | Ericsson | Patrik TEPPO | Rel-6 | Dionisio | 32.260 |  |  |
| 1554 | 559.9 | Charging Management for the Service domain | 580d? | 2003-03-21 A | 2005-06-09 A | 100% | 2003-03-21 | 2005-06-09 | 580d? | finish no earlier than 2005-06-09 | S5 | 4640h | 4640h | CH | Siemens | Gerald.Goermer@nsn.com | Rel-6 | Dionisio | 32.252, 32.270, 32.271, 32.272 |  |  |
| 1555 | 559.10 | **Overall architectural aspects of IP flow based bearer level charging** | 602d? | 2002-11-21 A | 2005-03-11 A | 100% | 2002-11-21 | 2005-03-11 | 602d? |  | S2 | 12632h | 12632h | CH-FBC |  |  | Rel-6 | Maurice | 23.125 |  |  |
| 1556 | 559.10.1 | Overall definition of FBC architecture | 334d? | 2002-11-21 A | 2004-03-02 A | 100% | 2002-11-21 | 2004-03-02 | 334d? | start no earlier than 2002-11-21 | S2 | 2672h | 2672h | CH-FBC |  |  | Rel-6 | Maurice |  | SP-24 |  |
| 1557 | 559.10.2 | Study on providing policy control with FBC | 130d? | 2004-02-02 A | 2004-07-30 A | 100% | 2004-02-02 | 2004-07-30 | 130d? | start no earlier than 2004-02-01 | S2 | 1040h | 1040h | CH-FBC |  |  | Rel-6 | Maurice |  | SP-24 |  |
| 1558 | 559.10.3 | Gx interface for flow based charging | 223d? | 2004-02-02 A | 2004-12-08 A | 100% | 2004-02-02 | 2004-12-08 | 223d? | start no earlier than 2004-02-01 | N3 | 1784h | 1784h | CH-FBC | Nokia | juha.a.rasanen@nokia.com | Rel-6 | Gwiho | 29.210 | SP-25 |  |
| 1559 | 559.10.4 | Rx interface for flow based charging | 290d? | 2004-02-02 A | 2005-03-11 A | 100% | 2004-02-02 | 2005-03-11 | 290d? | finish no earlier than 2005-03-11 | N3 | 2320h | 2320h | CH-FBC | Nortel | Javier Gonzalez Gallego | Rel-6 | Gwiho | 29.209 | SP-25 |  |
| 1560 | 13 | **Rel-6 UICC/USIM enhancements and interworking** | 1164d? | 2000-09-25 A | 2005-03-10 A | 100% | 2000-09-25 | 2005-03-10 | 1164d? |  | T3 | 43088h | 43088h | USAT1 |  |  | Rel-6 | Xavier |  |  |  |
| 1561 | 13.1 | **UICC API** | 777d | 2002-03-20 A | 2005-03-10 A | 100% | 2002-03-20 | 2005-03-10 | 777d |  | T3 | 15024h | 15024h | USAT1-API |  |  | Rel-6 | Xavier |  |  |  |
| 1562 | 13.1.1 | Rel-6 Java API Test specification | 59d | 2002-03-20 A | 2002-06-10 A | 100% | 2002-03-20 | 2002-06-10 | 59d | finish no earlier than 2002-09-20 | T3 | 472h | 472h | USAT1-API | Microelectrónica Española | Mario Pérez | Rel-6 | Xavier |  |  |  |
| 1563 | 560.1.2 | 2G/3G Java Card™ API based applet interworking | 255d | 2003-03-17 A | 2004-03-05 A | 100% | 2003-03-17 | 2004-03-05 | 255d | finish no earlier than 2004-02-19 | T3 | 2040h | 2040h | USAT1-API | Oberthur Card Systems | Stéphane Andrau | Rel-6 | Xavier |  |  |  |
| 1564 | 560.1.3 | (U)SIM API for Java Card Testing | 519d | 2003-03-17 A | 2005-03-10 A | 100% | 2003-03-17 | 2005-03-10 | 519d | finish no earlier than 2005-03-10 | T3 | 4152h | 4152h | USAT1-API | Axalto | Christophe Begassat (cbegassat@axalto.com) | Rel-6 | Xavier | 31.213 |  |  |
| 1565 | 13.1.2 | Deleted - Java API Test specification (TS 43.019 Rel-5) | 268d | 2002-05-30 A | 2003-06-09 A | 100% | 2002-05-30 | 2003-06-09 | 268d | finish no earlier than 2003-09-17 | T3 | 2144h | 2144h | USAT1-API | Microelectrónica Española | Mario Pérez | Rel-6 | Xavier |  |  | TP-20 |

Notes:
- 1542: SP#28 Target 09/2005 for WLAN Charging 32.252
- 1543: SP#25 09/2004 completed
- 1544: SP#23 03/2004 completed
- 1545: SP#28 06/2005 completed
- 1546: SP#25 09/2004 completed
- 1547: SP#21 09/2003 completed
- 1548: SP#26 12/2004 completed
- 1549: SP#28 Target 09/2005 for WLAN Charging 32.252
- 1550: SP#23 03/2004 completed
- 1551: SP#25 09/2004 completed
- 1552: SP#25 09/2004 completed
- 1553: SP#26 12/2004 completed
- 1554: SP#26: Updated WID SP-040778 was SP-030050. Target completion 06/2005. Consisting of MMS-CH, LCS-CH, WLAN-CH, POC-CH, MBMS-CH
- 1555: -
- 1556: -
- 1557: -
- 1558: -
- 1559: -
- 1560: -
- 1561: 8/3/2001: test spec is based on R99 core spec, so deleted from Workplan
- 1562: -
- 1563: -
- 1564: -
- 1565: MOVED to Rel-5 WP

| ID | WBS | Task | Type | Duration | Start | Finish | Complete | Baseline start | Baseline finish | Baseline duration | Constraint | Resources | Work | Actual work | Text1 | Text4 | Text5 | Text6 | Text8 | Text3 | Text12 |
| --- | --- | --- | --- | --- | --- | --- | --- | --- | --- | --- | --- | --- | --- | --- | --- | --- | --- | --- | --- | --- | --- |
| 1566 | 560.2 | **Rel-6 USIM toolkit enhancements** |  | 1160d? | 2000-09-25 A | 2005-03-04 A | 100% | 2000-09-25 | 2005-03-04 | 1160d? |  | T3 | 21848h | 21848h | USAT1-API-MULTOS | Aspects Software | Neil Livingston | Rel-6 | Xavier |  |  |
| 1567 | 560.2.1 | **C SIM API** |  | 525d | 2000-09-25 A | 2002-09-27 A | 100% | 2000-09-25 | 2002-09-27 | 525d |  | T3 | 9960h | 9960h | USAT1-API-MULTOS | Aspects Software | Neil Livingston | Rel-6 | Xavier | 31.101, 31.102, 31.103, 31.111, 31.113, new 31.115, 31.116 |  |
| 1568 | 560.2.1.1 | Specification of C SIM API |  | 525d | 2000-09-25 A | 2002-09-27 A | 100% | 2000-09-25 | 2002-09-27 | 525d | finish no earlier than 2002-09-27 | T3 | 4200h | 4200h | USAT1-API-MULTOS | Aspects Software | Neil Livingston | Rel-6 | Xavier |  |  |
| 1569 | 560.2.1.2 | Test specification for C SIM API |  | 195d | 2001-01-01 A | 2001-09-28 A | 100% | 2001-01-01 | 2001-09-28 | 195d | finish no earlier than 2001-09-28 | T3 | 1560h | 1560h | USAT1-API-MULTOS | Aspects Software | Neil Livingston | Rel-6 | Xavier |  |  |
| 1570 | 560.2.2 | USIM application toolkit Conformance Test Specification for Mobile Equipments |  | 326d? | 2003-12-05 A | 2005-03-04 A | 100% | 2003-12-05 | 2005-03-04 | 326d? | start no earlier than 2003-12-05 | T3 | 2608h | 2608h | USAT1-API-MULTOS | Gemplus | Eric.laffont@gemplus.com | Rel-6 | Xavier | 31.124 |  |
| 1571 | 561 | AMR-WB extension for high audio quality |  | 779d | 2002-12-13 A | 2005-12-07 A | 100% | 2002-12-13 | 2005-12-07 | 779d | finish no earlier than 2005-12-07 | S4 | 6232h | 6232h | AMRWB+ | Nokia | janne.m.vainio@nokia.com | Rel-6 | Paolo | 26.290, 26.304, 26.273, 26.274, 26.412, 26.936 |  |
| 1572 | 562 | Codec Enhancements for Packet Switched Conversational Multimedia Applications |  | 198d? | 2004-03-16 A | 2004-12-16 A | 100% | 2004-03-16 | 2004-12-16 | 198d? | finish no earlier than 2004-12-16 | S4 | 1584h | 1584h | CEPSCM | Nokia | miska.hannuksela@nokia.com | Rel-6 | Paolo | 26.235, 26.236 |  |
| 1573 | 563 | 3G-324M Improvements |  | 198d? | 2004-03-16 A | 2004-12-16 A | 100% | 2004-03-16 | 2004-12-16 | 198d? | finish no earlier than 2004-12-16 | S4 | 1584h | 1584h | 3G-324MI | Ericsson | bo.burman@ericsson.com | Rel-6 | Paolo | 26.111, 26.911 |  |
| 1574 | 564 | Single Antenna Receiver Interference Cancellation (SAIC) |  | 420.92d? | 2002-11-15 A | 2004-06-25 A | 100% | 2002-11-15 | 2004-06-25 | 420.92d? | finish no earlier than 2004-08-27 | GP,G1 | 3367.36h | 3367.36h | SAIC | Cingular | Marc Grant | Rel-6 | Paolo | 45.903 |  |
| 1575 | 565 | **Enhancement of dialled service for CAMEL** |  | 199d | 2003-03-28 A | 2003-12-31 A | 100% | 2003-03-28 | 2003-12-31 | 199d |  | S1,N2,N4 | 3184h | 3184h | EDCAMEL | Samsung | craig.bishop@samsung.com | Rel-6 | Alain | 22.078 |  |
| 1576 | 565.1 | Stages 2 and 3 for Enhancement of dialled service for CAMEL |  | 199d | 2003-03-28 A | 2003-12-31 A | 100% | 2003-03-28 | 2003-12-31 | 199d | finish no earlier than 2003-09-19 | N2,N4 | 1592h | 1592h | EDCAMEL | Samsung | Richard Brook | Rel-6 | Kimmo | 23.008, 23.016, 23.018, 23.078, 29.002, 29.078 |  |
| 1577 | 566 | Study on Bandwidth and resource savings in CS networks |  | 273d? | 2003-06-01 A | 2004-06-16 A | 100% | 2003-06-01 | 2004-06-16 | 273d? | finish no earlier than 2004-06-16 | S2 | 2184h | 2184h | BARS |  |  | Rel-6 | Maurice | 23.977 |  |
| 1578 | 567 | **Multiple TBF in A/Gb mode** |  | 736d? | 2002-04-05 A | 2005-01-28 A | 100% | 2002-04-05 | 2005-01-28 | 736d? |  | GP,G2 | 17600h | 17600h | MULTBF | Ericsson | gunnar.mildh@era.ericsson.se | Rel-6 | Paolo |  |  |
| 1579 | 567.1 | **Multiple TBF in A/Gb mode - Core** |  | 366d? | 2002-04-05 A | 2003-08-29 A | 100% | 2002-04-05 | 2003-08-29 | 366d? |  | GP,G2 | 11712h | 11712h | MULTBF-Agbmode | Ericsson | gunnar.mildh@era.ericsson.se | Rel-6 | Paolo |  |  |
| 1580 | 567.1.1 | Multiple TBF Concept paper |  | 366d? | 2002-04-05 A | 2003-08-29 A | 100% | 2002-04-05 | 2003-08-29 | 366d? | finish no earlier than 2003-08-29 | GP,G2 | 2928h | 2928h | MULTBF-Agbmode |  |  | Rel-6 | Paolo |  |  |
| 1581 | 567.1.2 | Multiple TBF Stage 2 (43.064) CRs |  | 366d? | 2002-04-05 A | 2003-08-29 A | 100% | 2002-04-05 | 2003-08-29 | 366d? | finish no earlier than 2003-08-29 | GP,G2 | 2928h | 2928h | MULTBF-Agbmode |  |  | Rel-6 | Paolo |  |  |
| 1582 | 567.1.3 | Multiple TBF Stage 3 (44.060) CRs |  | 366d? | 2002-04-05 A | 2003-08-29 A | 100% | 2002-04-05 | 2003-08-29 | 366d? | finish no earlier than 2003-08-29 | GP,G2 | 2928h | 2928h | MULTBF-Agbmode |  |  | Rel-6 | Paolo |  |  |
| 1583 | 567.2 | Deleted - Multiple TBF in A/Gb mode – MS testing | milestone | 0d? | 2005-01-28 A | 2005-01-28 A | 100% | 2005-01-28 | 2005-01-28 | 0d? | start no earlier than 2005-01-28 | G3new |  |  | MULTBF-Testing | Ericsson | gunnar.mildh@era.ericsson.se | Rel-6 | Paolo |  | GP-27 |
| 1584 | 568 | **Alignment between the test-regimes for GERAN capable MS** |  | 526d? | 2003-08-29 A | 2005-09-02 A | 100% | 2003-08-29 | 2005-09-02 | 526d? |  | G3new | 4208h | 4208h | ALTERE | Ericsson | anthony.toubassi@sonyericsson.com | Rel-6 | Ingbert |  |  |
| 1585 | 568.1 | Determine the controversial test cases in the different test regimes and align them with 3GPP GERAN test specifications. Such test cases to be added to TS 51.010. |  | 526d? | 2003-08-29 A | 2005-09-02 A | 100% | 2003-08-29 | 2005-09-02 | 526d? | finish no earlier than 2005-09-02 | G3new | 4208h | 4208h | ALTERE-TC |  |  | Rel-6 | Ingbert |  |  |
| 1586 | 569 | Addition of U-TDOA in the CS domain |  | 111d? | 2003-11-21 A | 2004-04-23 A | 100% | 2003-11-21 | 2004-04-23 | 111d? | finish no earlier than 2004-04-23 | GP | 888h | 888h | UTDOACS | TruePosition | Bob Gross, Rhys Robinson (rlgross@trueposition.com) | Rel-6 | Paolo |  |  |
| 1587 | 570 | Addition of U-TDOA in the PS domain |  | 361d? | 2003-06-27 A | 2004-11-12 A | 100% | 2003-06-27 | 2004-11-12 | 361d? | finish no earlier than 2004-11-12 | GP | 2888h | 2888h | UTDOAPS | TruePosition | Bob Gross, Rhys Robinson (rlgross@trueposition.com) | Rel-6 | Paolo |  |  |
| 1588 | 571 | **Downlink Advanced Receiver Performance** |  | 466d? | 2003-11-21 A | 2005-09-02 A | 100% | 2003-11-21 | 2005-09-02 | 466d? |  | GP | 19160h | 19160h | DARP | Nokia | tommy.bysted@nokia.com | Rel-6 | Paolo |  |  |
| 1589 | 571.1 | DARP test scenarios |  | 201d? | 2003-11-21 A | 2004-08-27 A | 100% | 2003-11-21 | 2004-08-27 | 201d? | finish no earlier than 2004-08-27 | GP | 1608h | 1608h | DARP-TS | Nokia | tommy.bysted@nokia.com | Rel-6 | Paolo |  |  |

Notes:
- 1566: -
- 1567: -
- 1568: -
- 1569: -
- 1570: -
- 1571: TR tbc by Sept. 05
- 1572: -
- 1573: -
- 1574: -
- 1575: -
- 1576: -
- 1577: -
- 1578: GP#17 Nov 2003 Moved from Rel-5 UID_50058 MULTBF (Only Multiple TBF Concept paper produced in Rel-5)
- 1579: -
- 1580: -
- 1581: -
- 1582: -
- 1583: -
- 1584: -
- 1585: -
- 1586: Completed, except for potential LMU performance specs
- 1587: -
- 1588: -
- 1589: -

| ID | WBS | Task | Type | Duration | Start | Finish | Complete | Baseline start | Baseline finish | Baseline duration | Constraint | Resources | Work | Actual work | Text1 | Text4 | Text5 | Text6 | Text8 | Text12 | Text3 |
| --- | --- | --- | --- | --- | --- | --- | --- | --- | --- | --- | --- | --- | --- | --- | --- | --- | --- | --- | --- | --- | --- |
| 1590 | 571.2 | **DARP for GMSK modulated voice services** |  | 201d? | 2004-02-06 A | 2004-11-12 A | 100% | 2004-02-06 | 2004-11-12 | 201d? |  | GP | 4824h | 4824h | DARP-GMSK | Nokia | tommy.bysted@nokia.com | Rel-6 | Paolo |  |  |
| 1591 | 571.2.1 | Performance requirements in 45.005 for DARP for GMSK modulated voice services |  | 201d? | 2004-02-06 A | 2004-11-12 A | 100% | 2004-02-06 | 2004-11-12 | 201d? | finish no earlier than 2004-11-12 | GP | 1608h | 1608h | DARP-GMSK-Perf |  |  | Rel-6 | Paolo |  |  |
| 1592 | 571.2.2 | Radio subsystem link control in 45.008 for DARP for GMSK modulated voice services |  | 201d? | 2004-02-06 A | 2004-11-12 A | 100% | 2004-02-06 | 2004-11-12 | 201d? | finish no earlier than 2004-11-12 | GP | 1608h | 1608h | DARP-GMSK-LC |  |  | Rel-6 | Paolo |  |  |
| 1593 | 571.3 | **DARP for GPRS and EGPRS MCS1-MCS4** |  | 201d? | 2004-02-06 A | 2004-11-12 A | 100% | 2004-02-06 | 2004-11-12 | 201d? |  | GP | 4824h | 4824h | DARP-GPRSE | Nokia | tommy.bysted@nokia.com | Rel-6 | Paolo |  |  |
| 1594 | 571.3.1 | Performance requirements in 45.005 for DARP for GPRS and EGPRS MCS1-MCS4 |  | 201d? | 2004-02-06 A | 2004-11-12 A | 100% | 2004-02-06 | 2004-11-12 | 201d? | finish no earlier than 2004-11-12 | GP | 1608h | 1608h | DARP-GPRSE-Perf |  |  | Rel-6 | Paolo |  |  |
| 1595 | 571.3.2 | Radio subsystem link control in 45.008 for DARP for GPRS and EGPRS MCS1-MCS4 |  | 201d? | 2004-02-06 A | 2004-11-12 A | 100% | 2004-02-06 | 2004-11-12 | 201d? | finish no earlier than 2004-11-12 | GP | 1608h | 1608h | DARP-GPRSE-LC |  |  | Rel-6 | Paolo |  |  |
| 1596 | 571.4 | DARP Capability signalling |  | 256d? | 2003-11-21 A | 2004-11-12 A | 100% | 2003-11-21 | 2004-11-12 | 256d? | finish no earlier than 2004-11-12 | GP | 2048h | 2048h | DARP-CAPSIG | Nokia | tommy.bysted@nokia.com | Rel-6 | Paolo |  |  |
| 1597 | 571.5 | GERAN MS Conformance test for DARP |  | 266d? | 2004-08-27 A | 2005-09-02 A | 100% | 2004-08-27 | 2005-09-02 | 266d? | finish no earlier than 2005-06-24 | G3new | 2128h | 2128h | ARP-ConfTest | Nokia | tommy.bysted@nokia.com | Rel-6 | Ingbert |  |  |
| 1598 | 572 | **Reduction of PS service interruption in Dual Transfer Mode** |  | 416d? | 2003-11-21 A | 2005-06-24 A | 100% | 2003-11-21 | 2005-06-24 | 416d? |  | G2 | 8360h | 8360h | PSintDTM | Siemens | toby.proctor@roke.co.uk | Rel-6 | Gert |  |  |
| 1599 | 572.1 | Use case and requirement definition |  | 111d? | 2003-11-21 A | 2004-04-23 A | 100% | 2003-11-21 | 2004-04-23 | 111d? | finish no earlier than 2004-04-23 | G2 | 888h | 888h | PSintDTM-Req | Siemens | toby.proctor@roke.co.uk | Rel-6 | Gert |  |  |
| 1600 | 572.2 | Performance Study of Current Procedures |  | 111d? | 2003-11-21 A | 2004-04-23 A | 100% | 2003-11-21 | 2004-04-23 | 111d? | start no earlier than 2003-11-21 | G2 | 888h | 888h | PSintDTM-Perf | Siemens | toby.proctor@roke.co.uk | Rel-6 | Gert |  |  |
| 1601 | 572.3 | Reduction of service interruption times and packet loss during Dual Transfer Mode and mobility procedures |  | 146d? | 2004-04-23 A | 2004-11-12 A | 100% | 2004-04-23 | 2004-11-12 | 146d? | finish no earlier than 2004-11-12 | G2 | 1168h | 1168h | PSintDTM-Reduct | Siemens | toby.proctor@roke.co.uk | Rel-6 | Gert |  |  |
| 1602 | 572.4 | Deleted - MS Conformance testing - Reduction of PS service interruption in DTM |  | 261d? | 2004-06-25 A | 2005-06-24 A | 100% | 2004-06-25 | 2005-06-24 | 261d? | finish no earlier than 2005-06-24 | G3new | 2088h | 2088h | PSintDTM-ConfMS |  |  | Rel-6 | Ingbert | GP-25 |  |
| 1603 | 572.5 | Deleted - BTS Conformance testing - Reduction of PS service interruption in DTM | milestone | 0d? | 2005-06-24 A | 2005-06-24 A | 100% | 2005-06-24 | 2005-06-24 | 0d? | finish no earlier than 2005-06-24 | G3new |  |  | PSintDTM-ConfBTS |  |  | Rel-6 | Ingbert | GP-25 |  |
| 1604 | 573 | CAMEL prepay interworking with SCUDIF |  | 216.3d | 2003-12-08 A | 2004-10-05 A | 100% | 2003-12-08 | 2004-10-05 | 216.3d |  | N4,N3,S1 | 1730.4h | 1730.4h | SCCAMEL | Nokia | Keijo.Palviainen@Nokia.Com | Rel-6 | Kimmo |  | 22.078, 23.078, 29.078, 29.002, 23.172 |
| 1605 | 574 | Reorganisation of CS Data Specifications |  | 14d? | 2004-11-19 A | 2004-12-08 A | 100% | 2004-11-19 | 2004-12-08 | 14d? | finish no earlier than 2004-12-24 | N3 | 112h | 112h | CS Data | Siemens | Thomas.Belling@nsn.com | Rel-6 | Gwiho |  | 23.910, 29.007, new 23.202 |
| 1606 | 575 | **Generic Access to A/Gb Interface (GAAI)** |  | 411d? | 2004-06-25 A | 2006-01-20 A | 100% | 2004-06-25 | 2006-01-20 | 411d? |  | GP | 9160h | 9160h | GAAI | Motorola |  | Rel-6 | Paolo |  |  |
| 1607 | 575.1 | FS on GAAI |  | 46d? | 2004-06-25 A | 2004-08-27 A | 100% | 2004-06-25 | 2004-08-27 | 46d? | finish no earlier than 2004-08-27 | GP | 368h | 368h | GAAG | Motorola |  | Rel-6 | Paolo |  | 43.901 |
| 1608 | 575.2 | GAAI – Stage 2 |  | 161d? | 2004-08-27 A | 2005-04-08 A | 100% | 2004-08-27 | 2005-04-08 | 161d? | finish no earlier than 2005-04-08 | GP | 1288h | 1288h | GAAI-Stage2 | Ericsson | jari.vikberg@ericsson.com | Rel-6 | Paolo |  | 43.318 |
| 1609 | 575.3 | GAAI – Stage 3 |  | 161d? | 2004-08-27 A | 2005-04-08 A | 100% | 2004-08-27 | 2005-04-08 | 161d? | finish no earlier than 2005-04-08 | GP | 1288h | 1288h | GAAI-Stage3 |  |  | Rel-6 | Paolo |  | 44.318 |
| 1610 | 575.4 | MS Conformance Test for GAAI |  | 366d? | 2004-08-27 A | 2006-01-20 A | 100% | 2004-08-27 | 2006-01-20 | 366d? | finish no earlier than 2006-01-20 | GP | 2928h | 2928h | GAAI-CT |  |  | Rel-6 | Ingbert |  |  |
| 1611 | 576 | **Support of PS Handover for GERAN A/Gb mode** |  | 473d? | 2003-11-03 A | 2005-08-24 A | 100% | 2003-11-03 | 2005-08-24 | 473d? |  | GP,G2 | 11352h | 11352h | SPSHAGB | Ericsson | gunnar.hedby@ericsson.com | Rel-6 | Paolo |  |  |
| 1612 | 576.1 | Stage 2 for Support of PS Handover for GERAN A/Gb mode |  | 473d? | 2003-11-03 A | 2005-08-24 A | 100% | 2003-11-03 | 2005-08-24 | 473d? | finish no earlier than 2005-09-02 | GP,G2 | 3784h | 3784h | SPSHAGB-Stage2 | Ericsson | gunnar.hedby@ericsson.com | Rel-6 | Paolo |  | 43.129 |
| 1613 | 576.2 | PS handover for Support of PS Handover for GERAN A/Gb mode |  | 473d? | 2003-11-03 A | 2005-08-24 A | 100% | 2003-11-03 | 2005-08-24 | 473d? | finish no earlier than 2005-09-02 | GP,G2 | 3784h | 3784h | SPSHAGB-PSHO | Ericsson | gunnar.hedby@ericsson.com | Rel-6 | Paolo |  |  |
| 1614 | 576.3 | Definition of radio resource management functionality for Support of PS Handover for GERAN A/Gb mode |  | 473d? | 2003-11-03 A | 2005-08-24 A | 100% | 2003-11-03 | 2005-08-24 | 473d? | finish no earlier than 2005-09-02 | GP,G2 | 3784h | 3784h | SPSHAGB-RRM | Ericsson | gunnar.hedby@ericsson.com | Rel-6 | Paolo |  |  |
| 1615 | 577 | Study on (U)SIM Security Reuse by Peripheral Devices on Local Interfaces |  | 127d? | 2003-07-03 A | 2003-12-26 A | 100% | 2003-07-03 | 2003-12-26 | 127d? | finish no earlier than 2003-12-26 | S3 | 1016h | 1016h |  | Toshiba | Raziq Yaqub (ryaqub@tari.toshiba.com) | Rel-6 | Dionisio |  | 33.817 |
| 1616 | 578 | Study on Security for early IMS |  | 127d? | 2004-10-01 A | 2005-03-28 A | 100% | 2004-10-01 | 2005-03-28 | 127d? | finish no earlier than 2003-12-26 | S3 | 1016h | 1016h | SEC-IMS | Vodafone | Peter.Howard@vodafone.com | Rel-6 | Dionisio |  | 33.978 |
| 1617 | 579 | (Small) Technical Enhancements and Improvements for Rel-6 | milestone | 0d? | 2006-06-02 A | 2006-06-02 A | 100% | 2006-06-02 | 2006-06-02 | 0d? |  | All |  |  | TEI6 |  |  | Rel-6 | all |  |  |
| 1618 | 580 | Test - (Small) Technical Enhancements and Improvements for Rel-6 |  | 503d? | 2006-06-02 A | 2008-05-06 A | 100% | 2006-06-02 | 2008-05-06 | 503d? | start no earlier than 2006-06-02 | R5,T1 | 4024h | 4024h | TEI6_Test |  |  | Rel-6 | Ingbert |  | 34.108,34.121-1/2,34.122,34.123-1/2/3 |
| 1619 | 581 | Deleted - Enhancements of VGCS in public networks for communication of public authority officials |  | 7d? | 2005-08-24 A | 2005-09-02 A | 100% | 2005-08-24 | 2005-09-02 | 7d? | start no earlier than 2005-08-24 | GP,G2 | 56h | 56h | EVGCS | Siemens | kenneth.isaacs@roke.co.uk | Rel-6 | Paolo | GP-26 | 44.018, 44.068, 48.008 |

Notes:
- 1590: -
- 1591: -
- 1592: -
- 1593: -
- 1594: -
- 1595: -
- 1596: -
- 1597: -
- 1598: -
- 1599: -
- 1600: -
- 1601: -
- 1602: -
- 1603: -
- 1604: -
- 1605: Created at TSG#27 as 100 % complete
- 1606: -
- 1607: Feasibility Study
- 1608: -
- 1609: -
- 1610: Marked as closed 12/2008 (was marked 90% complete)
- 1611: Replaces SCSAGB- Originally Started Nov 2003 as GP-030443
- 1612: Replaces SCSAGB-Stage2
- 1613: Replaces SCSAGB-PSH
- 1614: Replaces SCSAGB-RRM
- 1615: SP#20 approved WID
- 1616: SP#24 approved WID. SP#46 withdrawn TR 33.978 from Rel-8 onwards
- 1617: "Joker" WI, to be used for a Rel 6 CR not related to any feature and with very limited impact on the system. Moved in from Stoyan/Testing WP
- 1618: "Joker" WI, to be used for small modifications applicable to Rel 4 conformance testing
- 1619: GP#26 moved to Rel-7 as UID_11045 Enhancements of VGCS in public networks for communication of public authority officials

| ID | WBS | Task | Type | Duration | Start | Finish | Complete | Baseline start | Baseline finish | Baseline duration | Constraint | Resources | Work | Actual work | Text1 | Text4 | Text5 | Text6 | Text8 | Text12 | Text3 | Text7 | Text10 |
| --- | --- | --- | --- | --- | --- | --- | --- | --- | --- | --- | --- | --- | --- | --- | --- | --- | --- | --- | --- | --- | --- | --- | --- |
| 1620 | 582 | **Deleted - Support of Conversational Services in A/Gb mode via the PS domain** |  | 64d? | 2003-11-21 A | 2004-02-19 A | 100% | 2003-11-21 | 2004-02-19 | 64d? |  | GP,N1 | 1024h | 1024h | SCSAGB | Ericsson | David Bladsjö (david.bladsjo@ericsson.com) | Rel-6 | Paolo | GP-18 |  |  |  |
| 1621 | 582.1 | Deleted - Creation of a TR | milestone | 0d? | 2003-11-21 A | 2003-11-21 A | 100% | 2003-11-21 | 2003-11-21 | 0d? | start no earlier than 2003-11-21 | GP |  |  | SCSAGB-TR | Ericsson | David Bladsjö (david.bladsjo@ericsson.com) | Rel-6 | Paolo | GP-17 |  |  |  |
| 1622 | 582.2 | Deleted - Stage 2 | milestone | 0d? | 2003-11-21 A | 2003-11-21 A | 100% | 2003-11-21 | 2003-11-21 | 0d? | finish no earlier than 2003-11-21 | GP |  |  | SCSAGB-Stage2 | Ericsson | David Bladsjö (david.bladsjo@ericsson.com) | Rel-6 | Paolo | GP-17 |  |  |  |
| 1623 | 582.3 | Deleted - Radio Channel Support | milestone | 0d? | 2003-11-21 A | 2003-11-21 A | 100% | 2003-11-21 | 2003-11-21 | 0d? | finish no earlier than 2003-11-21 | GP |  |  | SCSAGB-RCS | Ericsson | David Bladsjö (david.bladsjo@ericsson.com) | Rel-6 | Paolo | GP-17 |  |  |  |
| 1624 | 582.4 | Deleted - Definition of radio resource management functionality | milestone | 0d? | 2003-11-21 A | 2003-11-21 A | 100% | 2003-11-21 | 2003-11-21 | 0d? | finish no earlier than 2003-11-21 | GP |  |  | SCSAGB-RRM | Ericsson | David Bladsjö (david.bladsjo@ericsson.com) | Rel-6 | Paolo | GP-17 |  |  |  |
| 1625 | 582.5 | Deleted - replaced by 50561 - PS Handover |  | 64d | 2003-11-21 A | 2004-02-19 A | 100% | 2003-11-21 | 2004-02-19 | 64d | start no earlier than 2003-11-21 | GP,N1 | 512h | 512h | SCSAGB-PSH | Ericsson | David Bladsjö (david.bladsjo@ericsson.com) | Rel-6 | Paolo | GP-18 |  |  |  |
| 1626 | 582.6 | Deleted - Modifications to FLO | milestone | 0d? | 2003-11-21 A | 2003-11-21 A | 100% | 2003-11-21 | 2003-11-21 | 0d? | finish no earlier than 2003-11-21 | GP |  |  | SCSAGB-FLO | Ericsson | David Bladsjö (david.bladsjo@ericsson.com) | Rel-6 | Paolo | RP-29 |  |  |  |
| 1627 | 583 | Deleted - Rel-6 Evolutions of the transport in the UTRAN | milestone | 0d | 2003-12-31 A | 2003-12-31 A | 100% | 2003-12-31 | 2003-12-31 | 0d | start no earlier than 2003-12-31 | RP |  |  | ETRAN | Alcatel | Francois Courau | Rel-6 | Issam | RP-22 |  |  |  |
| 1628 | 584 | Release 5 Features |  | 325d? | 2001-03-30 A | 2002-06-28 A | 100% | 2001-03-30 | 2002-06-28 | 325d? |  | NP,GP, RP,SP,TP | 2600h | 2600h |  |  |  | Rel-5 | All |  |  |  |  |
| 1629 | 75 | IP transport in the UTRAN |  | 445d | 2000-07-17 A | 2002-03-29 A | 100% | 2000-07-17 | 2002-03-29 | 445d | finish no earlier than 2002-03-29 | R3 | 3560h | 3560h | ETRAN-IPtrans | Alcatel | Nicolas Drevon | Rel-5 | Juha |  |  |  |  |
| 1630 | 76 | FS on Usage of SUA |  | 205d | 2001-03-12 A | 2001-12-21 A | 100% | 2001-03-12 | 2001-12-21 | 205d | finish no earlier than 2001-12-21 | N4 | 1640h | 1640h | SS7IP |  |  | Rel-5 | Kimmo |  |  |  |  |
| 1631 | 77 | **High Speed Downlink Packet Access** |  | 1550d? | 2001-04-02 A | 2007-03-09 A | 100% | 2001-04-02 | 2007-03-09 | 1550d? |  | R2,R5 | 31488h | 31488h | HSDPA | Motorola | Ravi Kuchibhotla | Rel-5 | Joern |  |  |  |  |
| 1632 | 77.1 | Physical Layer for High Speed Downlink Packet Access |  | 257d | 2001-04-05 A | 2002-03-29 A | 100% | 2001-04-05 | 2002-03-29 | 257d | finish no earlier than 2002-03-29 | R1 | 2056h | 2056h | HSDPA-Phys | Motorola | Amitabha Ghosh (qa0047@email.mot.com) | Rel-5 | Patrick |  |  |  |  |
| 1633 | 77.2 | Layer 2 and 3 aspects |  | 257d | 2001-04-05 A | 2002-03-29 A | 100% | 2001-04-05 | 2002-03-29 | 257d | finish no earlier than 2002-03-29 | R2 | 2056h | 2056h | HSDPA-L23 | Motorola | Ravi Kuchibhotla | Rel-5 | Joern |  |  |  |  |
| 1634 | 77.3 | Iub/Iur protocol aspects - for High Speed Downlink Packet Access |  | 260d | 2001-04-02 A | 2002-03-29 A | 100% | 2001-04-02 | 2002-03-29 | 260d | finish no earlier than 2002-03-29 | R3 | 2080h | 2080h | HSDPA-IubIur | Motorola | Mike Diesen | Rel-5 | Juha |  |  |  |  |
| 1635 | 77.4 | RF Radio Transmission/ Reception, System Performance Requirements and Conformance Testing |  | 565d | 2001-04-09 A | 2003-06-06 A | 100% | 2001-04-09 | 2003-06-06 | 565d | finish no earlier than 2003-06-06 | R4 | 4520h | 4520h | HSDPA-RF | Motorola | Howard Benn | Rel-5 | Issam |  |  |  |  |
| 1636 | 587.5 | Conformance Testing of HSDPA |  | 786d | 2003-09-19 A | 2006-09-22 A | 100% | 2003-09-19 | 2006-09-22 | 786d | finish no earlier than 2006-09-22 | R5 | 6288h | 6288h | HSDPA_Test | Motorola | carolyn.taylor@motorola.com | Rel-5 | Ingbert |  | 34.108, 34.121, 34.122, 34.123-1, 34.123-2, 34.123-3 | TSG | 19/9/2003 |
| 1637 | 587.6 | Conformance Testing of HCR TDD HSDPA |  | 261d? | 2006-03-10 A | 2007-03-09 A | 100% | 2006-03-10 | 2007-03-09 | 261d? | finish no earlier than 2007-03-09 | R5 | 2088h | 2088h | HSDPA_HCRTDD_Test | IPWireless | drichards@ipwireless.com | Rel-5 | Ingbert |  | 34.108, 34.122, 34.123-1, 34.123-2, 34.123-3 |  |  |
| 1638 | 78 | **Rel-5 Improvements of Radio Interface** |  | 535d | 2000-08-14 A | 2002-08-30 A | 100% | 2000-08-14 | 2002-08-30 | 535d |  | RP | 30376h | 30376h | RInImp |  |  | Rel-5 |  |  |  |  |  |
| 1639 | 78.1 | **Base station classification for TDD** |  | 480d | 2000-08-14 A | 2002-06-14 A | 100% | 2000-08-14 | 2002-06-14 | 480d |  | R4 | 9208h | 9208h | RInImp-BSClass | Nokia | antti.toskala@nokia.com | Rel-5 | Issam |  |  |  |  |
| 1640 | 78.1.1 | TDD Base station classification |  | 410d | 2000-08-14 A | 2002-03-08 A | 100% | 2000-08-14 | 2002-03-08 | 410d | finish no earlier than 2002-03-08 | R4 | 3280h | 3280h | RInImp-BSClass-TDD | Nokia | antti.toskala@nokia.com | Rel-5 | Issam |  |  |  |  |
| 1641 | 78.1.2 | Base Station Classification for 1.28 Mcps TDD option |  | 261d | 2001-06-15 A | 2002-06-14 A | 100% | 2001-06-15 | 2002-06-14 | 261d | finish no earlier than 2002-06-14 | R4 | 2088h | 2088h | RInImp-BSClass-LCRTDD | Siemens | Meik.Kottkamp@siemens.com | Rel-5 | Issam |  |  |  |  |
| 1642 | 78.2 | Enhancement on the DSCH hard split mode |  | 271d | 2001-03-16 A | 2002-03-29 A | 100% | 2001-03-16 | 2002-03-29 | 271d | finish no earlier than 2002-03-29 | R1 | 2168h | 2168h | RInImp-DSCHhsp | Samsung | Jaeyoel KIM | Rel-5 | Patrick |  |  |  |  |
| 1643 | 78.3 | Hybrid ARQ II/III |  | 355d | 2000-08-21 A | 2001-12-28 A | 100% | 2000-08-21 | 2001-12-28 | 355d | finish no earlier than 2001-12-28 | R2 | 2840h | 2840h | RInImp-HARQ | Siemens | armin.sitte@siemens.com | Rel-5 | Joern | RP-14 |  |  |  |
| 1644 | 78.4 | FS on USTS |  | 355d | 2000-08-14 A | 2001-12-21 A | 100% | 2000-08-14 | 2001-12-21 | 355d | finish no earlier than 2001-12-21 | R1 | 2840h | 2840h | RInImp-USTS | SK Telecom | D. Kim | Rel-5 | Patrick |  |  |  |  |
| 1645 | 78.5 | FS on UE antenna efficiency test method performance requirements |  | 255d | 2000-09-25 A | 2001-09-14 A | 100% | 2000-09-25 | 2001-09-14 | 255d | finish no earlier than 2001-09-14 | R4 | 2040h | 2040h | RInImp-UEAnTM | Allgon | O. Edvardsson | Rel-5 | Issam |  |  |  |  |
| 1646 | 78.6 | FS on the re-introduction of the downlink SIR measurement |  | 200d | 2001-03-12 A | 2001-12-14 A | 100% | 2001-03-12 | 2001-12-14 | 200d | finish no earlier than 2001-12-14 | R4 | 1600h | 1600h | RInImp-SIR | Ericsson | Torgny.Palenius@ericsson.com | Rel-5 | Issam |  |  |  |  |
| 1647 | 78.7 | FS on mitigating the effect of CPICH interference at the UE |  | 255d | 2001-03-19 A | 2002-03-08 A | 100% | 2001-03-19 | 2002-03-08 | 255d | finish no earlier than 2002-03-08 | R4 | 2040h | 2040h | RInImp-CPICH_Intf | Intel | shimon.moshavi@INTEL.COM | Rel-5 | Issam |  |  |  |  |

Notes:
- 1620: -
- 1621: -
- 1622: Started
- 1623: Not started
- 1624: Not started
- 1625: Started
- 1626: Not started
- 1627: Generic feature
- 1628: -
- 1629: -
- 1630: -
- 1631: -
- 1632: -
- 1633: -
- 1634: -
- 1635: -
- 1636: -
- 1637: -
- 1638: -
- 1639: -
- 1640: -
- 1641: -
- 1642: -
- 1643: Stopped at RP#14; work on this task was performed as part of High Speed Downlink Packet Access feature
- 1644: -
- 1645: -
- 1646: -
- 1647: -

| ID | WBS | Task | Duration | Start | Finish | Complete | Baseline start | Baseline finish | Baseline duration | Constraint | Deadline | Resources | Work | Actual work | Text6 | Text8 | Text12 | Text1 | Text4 | Text5 | Text3 | Text10 |
| --- | --- | --- | --- | --- | --- | --- | --- | --- | --- | --- | --- | --- | --- | --- | --- | --- | --- | --- | --- | --- | --- | --- |
| 1648 | 78.8 | **Deleted - Conformance Test Spec. improvements in Radio Interface** | 140d | 2002-02-18 A | 2002-08-30 A | 100% | 2002-02-18 | 2002-08-30 | 140d |  |  | T1 | 3360h | 3360h | Rel-5 | Ingbert | TP-17 |  |  |  |  |  |
| 1649 | 78.8.1 | Deleted - Testing improvement of inter-frequency and inter-system measurement | 140d | 2002-02-18 A | 2002-08-30 A | 100% | 2002-02-18 | 2002-08-30 | 140d | finish no earlier than 2002-08-30 |  | T1 | 1120h | 1120h | Rel-5 | Ingbert | TP-17 |  |  |  |  |  |
| 1650 | 78.8.2 | Deleted - Testing Hybrid ARQ II/III | 140d | 2002-02-18 A | 2002-08-30 A | 100% | 2002-02-18 | 2002-08-30 | 140d | finish no earlier than 2002-08-30 |  | T1 | 1120h | 1120h | Rel-5 | Ingbert | TP-17 |  |  |  |  |  |
| 1651 | 79 | **Rel-5 RAN improvements** | 1561d? | 2001-03-16 A | 2007-03-09 A | 100% | 2001-03-16 | 2007-03-09 | 1561d? |  |  | RP | 49424h | 49424h | Rel-5 |  |  | RANimp |  |  |  |  |
| 1652 | 79.1 | **RRM optimization for Iur and Iub** | 318d | 2001-03-16 A | 2002-06-04 A | 100% | 2001-03-16 | 2002-06-04 | 318d |  |  | R3 | 8904h | 8904h | Rel-5 | Juha |  | RANimp-RRMopt | Ericsson | Gert-Jan.van.Lieshout@eln.ericsson.se |  |  |
| 1653 | 79.1.1 | Iur common transport channel efficiency optimization | 271d | 2001-03-16 A | 2002-03-29 A | 100% | 2001-03-16 | 2002-03-29 | 271d | finish no earlier than 2002-03-29 |  | R3 | 2168h | 2168h | Rel-5 | Juha |  | RANimp-RRMopt-ctc | Ericsson | Shahrokh Amirijoo |  |  |
| 1654 | 79.1.2 | Iur neighbouring cell reporting efficiency optimization | 271d | 2001-03-16 A | 2002-03-29 A | 100% | 2001-03-16 | 2002-03-29 | 271d | finish no earlier than 2002-03-29 |  | R3 | 2168h | 2168h | Rel-5 | Juha |  | RANimp-RRMopt-ncr | Ericsson | Shahrokh Amirijoo |  |  |
| 1655 | 79.1.3 | FS Introduction of direct transport bearers between SRNC and Node-B | 253d | 2001-06-15 A | 2002-06-04 A | 100% | 2001-06-15 | 2002-06-04 | 253d | finish no earlier than 2002-06-28 |  | R3 | 2024h | 2024h | Rel-5 | Juha |  | RAN-imp-RRMopt-DTB | Ericsson | Risto Sepponen |  |  |
| 1656 | 79.2 | RL Timing Adjustment | 271d | 2001-03-16 A | 2002-03-29 A | 100% | 2001-03-16 | 2002-03-29 | 271d | finish no earlier than 2002-03-29 |  | R3 | 2168h | 2168h | Rel-5 | Juha |  | RANimp-RLTA | Ericsson | Elena Voltolina |  |  |
| 1657 | 79.3 | Separation of resource reservation and radio link activation | 271d | 2001-03-16 A | 2002-03-29 A | 100% | 2001-03-16 | 2002-03-29 | 271d | finish no earlier than 2002-03-29 |  | R3 | 2168h | 2168h | Rel-5 | Juha |  | RANimp-SepRR | Ericsson | Gert-Jan.van.Lieshout@eln.ericsson.se |  |  |
| 1658 | 79.4 | FS SRNS Relocation Procedure Enhancement | 318d | 2001-06-15 A | 2002-09-03 A | 100% | 2001-06-15 | 2002-09-03 | 318d | finish no earlier than 2002-09-06 |  | R3 | 2544h | 2544h | Rel-5 | Juha |  | RANimp-SRNS | Nokia | Olivier Guyot |  |  |
| 1659 | 79.5 | FS Improvement of Radio Resource Management across RNS and RNS/PSS | 201d | 2001-03-16 A | 2001-12-21 A | 100% | 2001-03-16 | 2001-12-21 | 201d | finish no earlier than 2001-12-21 |  | R3 | 1608h | 1608h | Rel-5 | Juha |  | RANimp-ImpRRM | Nokia | antti.toskala@nokia.com |  |  |
| 1660 | 79.6 | Re-arrangements of Iub transport bearers | 271d | 2001-03-16 A | 2002-03-29 A | 100% | 2001-03-16 | 2002-03-29 | 271d | finish no earlier than 2002-03-29 |  | R3 | 2168h | 2168h | Rel-5 | Juha |  | RANimp-TTPS | Nokia | antti.toskala@nokia.com |  |  |
| 1661 | 79.7 | RAB support enhancement for Rel-5 | 325d | 2001-04-02 A | 2002-06-28 A | 100% | 2001-04-02 | 2002-06-28 | 325d |  |  | R2 | 2600h | 2600h | Rel-5 | Joern |  | RANimp-RABSE5 | Nokia | Juha Mikola |  |  |
| 1662 | 16.5.1 | Testing of ROHC performance | 391d | 2005-09-09 A | 2007-03-09 A | 100% | 2005-09-09 | 2007-03-09 | 391d | finish no earlier than 2007-03-09 | 2006-06-02 | R5 | 3128h | 3128h | Rel-5 | Ingbert |  | RANimp-RABSE5_Test | Nokia | jarkko.hellsten@nokia.com | 34.108, 34.123-1, 34.123-2, 34.123-3 | Fri 11/03/05 |
| 1663 | 79.8 | Beamforming requirements for UE | 61d | 2001-09-21 A | 2001-12-14 A | 100% | 2001-09-21 | 2001-12-14 | 61d | finish no earlier than 2001-12-14 |  | R1 | 488h | 488h | Rel-5 | Patrick |  | RANimp-BFR-UE | Nokia | Jussi Kähtävä (juha.mikola@nokia.com) |  |  |
| 1664 | 79.9 | Support of Site Selection Diversity Transmission in UTRAN | 123d | 2001-12-14 A | 2002-06-04 A | 100% | 2001-12-14 | 2002-06-04 | 123d | finish no earlier than 2002-06-04 |  | R1 | 984h | 984h | Rel-5 | Patrick |  | RANimp-SSDT | NEC |  |  |  |
| 1665 | 79.10 | Node B Synchronisation for 1.28 Mcps TDD | 271d | 2001-03-16 A | 2002-03-29 A | 100% | 2001-03-16 | 2002-03-29 | 271d | finish no earlier than 2002-03-29 |  | R1 | 2168h | 2168h | Rel-5 | Patrick |  | RANimp-NBSLCR | CATT | Jinling HU |  |  |
| 1666 | 79.12 | **Deleted - Conformance Test Aspects - RAN Improvements** | 565d? | 2002-01-01 A | 2004-03-01 A | 100% | 2002-01-01 | 2004-03-01 | 565d? |  |  | T1 | 8008h | 8008h | Rel-5 | Ingbert | TP-23 |  |  |  | 0% |  |
| 1667 | 79.12.1 | Deleted - Testing Radio access bearer support enhancements | 175d | 2002-01-01 A | 2002-09-02 A | 100% | 2002-01-01 | 2002-09-02 | 175d | finish no earlier than 2002-09-02 |  | T1 | 1400h | 1400h | Rel-5 | Ingbert | TP-17 |  |  |  |  |  |
| 1668 | 589.12.2 | Deleted - General changes to TS34.121 and TS34.122 corresponding to release 5 | 261d? | 2003-03-03 A | 2004-03-01 A | 100% | 2003-03-03 | 2004-03-01 | 261d? | finish no earlier than 2004-03-01 |  | T1 | 2088h | 2088h | Rel-5 | Ingbert | TP-23 | RANimp-test |  |  | 34.108, 34.121, 34.122 |  |
| 1669 | 80 | UTRAN Sharing in Connected Mode | 197d | 2001-12-03 A | 2002-09-03 A | 100% | 2001-12-03 | 2002-09-03 | 197d | finish no earlier than 2002-09-06 |  | R3 | 1576h | 1576h | Rel-5 | Juha |  | NETSHARE | Ericsson | Martin Israelsson |  |  |
| 1670 | 85 | **Rel-5 MExE enhancements** | 250d | 2001-03-26 A | 2002-03-08 A | 100% | 2001-03-26 | 2002-03-08 | 250d |  |  | T2 | 2880h | 2880h | Rel-5 | Kimmo |  | MEXE5 |  |  |  |  |
| 1671 | 85.1 | MExE Rel-5 Improvements and Investigations | 110d | 2001-03-26 A | 2002-03-08 A | 100% | 2001-03-26 | 2002-03-08 | 110d | finish no earlier than 2001-12-17 |  | T2 | 880h | 880h | Rel-5 | Kimmo |  | MEXE5-ENHANC | Motorola | Mark Cataldo | 22.057, 23.057 |  |

Notes:
- 1648: Marked as stopped 12/2008
- 1649: Marked as stopped 12/2008
- 1650: Marked as stopped 12/2008
- 1651: -
- 1652: -
- 1653: -
- 1654: -
- 1655: FS was closed and introduction of WI not agreed at RAN #16
- 1656: -
- 1657: -
- 1658: -
- 1659: FS was closed and WI was introduced at RAN #14
- 1660: -
- 1661: RFC 3095 context relocation
- 1662: -
- 1663: -
- 1664: RP-020356
- 1665: -
- 1666: Marked as stopped 12/2008
- 1667: Marked as stopped 12/2008
- 1668: Marked as stopped 12/2008
- 1669: Formerly 'Shared Network support in connected mode', renamed at RAN #16.
- 1670: -
- 1671: -

| ID | WBS | Task | Duration | Start | Finish | Predecessors | Complete | Baseline start | Baseline finish | Baseline duration | Constraint | Resources | Work | Actual work | Text1 | Text6 | Text8 | Text3 | Text4 | Text5 | Text12 |
| --- | --- | --- | --- | --- | --- | --- | --- | --- | --- | --- | --- | --- | --- | --- | --- | --- | --- | --- | --- | --- | --- |
| 1672 | 11 | **Rel-5 Terminal interfaces** | 223d | 2001-05-14 A | 2002-03-20 A |  | 100% | 2001-05-14 | 2002-03-20 | 223d |  | T2 | 3568h | 3568h | TI | Rel-5 | Kimmo |  |  |  |  |
| 1673 | 87 | Terminal local model enhancements | 223d | 2001-05-14 A | 2002-03-20 A |  | 100% | 2001-05-14 | 2002-03-20 | 223d | finish no earlier than 2002-03-20 | T2 | 1784h | 1784h | TLM5 | Rel-5 |  | 23.227 |  |  |  |
| 1674 | 89 | **Rel-5 Security enhancements** | 615d | 2000-02-21 A | 2002-06-28 A |  | 100% | 2000-02-21 | 2002-06-28 | 615d |  | S3 | 29974.9h | 29974.9h |  | Rel-5 | Dionisio |  | Vodafone | Peter.Howard@vodafone.com |  |
| 1675 | 89.1 | **Rel-5 Network Domain Security** | 615d | 2000-02-21 A | 2002-06-28 A |  | 100% | 2000-02-21 | 2002-06-28 | 615d |  | S3 | 25054.9h | 25054.9h | SEC1-NDS | Rel-5 | Dionisio | new 33.200 (exists also for Rel-4) | Telenor | Geir-myrdahl.koien@telenor.com |  |
| 1676 | 89.1.3 | Rel-5 IP network layer security (NDS/IP) | 457d | 2000-06-15 A | 2002-03-15 A |  | 100% | 2000-06-15 | 2002-03-15 | 457d | finish no earlier than 2002-03-15 | S3 | 3656h | 3656h | SEC1-NDS-IP | Rel-5 | Dionisio | new 33.210 | Telenor | Geir-myrdahl.koien@telenor.com |  |
| 1677 | 89.1.1 | **Deleted - Control plane protection in core network (e.g., GTP, CAP, MAP/IP, provided by IPsec)** | 541d | 2000-05-12 A | 2002-06-07 A |  | 100% | 2000-05-12 | 2002-06-07 | 541d |  | S3 | 7118.9h | 7118.9h |  | Rel-5 | Dionisio |  |  |  | SP-16 |
| 1678 | 89.1.1.1 | Deleted - Main aspects of User plane protection in core network (e.g., provided by IPsec) | 290d | 2000-05-12 A | 2001-06-21 A |  | 100% | 2000-05-12 | 2001-06-21 | 290d | finish no earlier than 2001-06-21 | S3 | 2320h | 2320h |  | Rel-5 | Dionisio |  |  |  | SP-12 |
| 1679 | 89.1.1.2 | Deleted - Integration of GTP signalling security architecture - for User plane protection in core network (e.g., provided by IPsec) | 191d | 2001-09-14 A | 2002-06-07 A |  | 100% | 2001-09-14 | 2002-06-07 | 191d | finish no earlier than 2002-06-07 | N4 | 1528h | 1528h |  | Rel-5 | Kimmo |  |  |  | NP-16 |
| 1680 | 89.1.2 | **Deleted - User plane protection in core network (e.g., provided by IPsec)** | 615d | 2000-02-21 A | 2002-06-28 A |  | 100% | 2000-02-21 | 2002-06-28 | 615d |  | S3 | 9360h | 9360h |  | Rel-5 | Dionisio |  |  |  | SP-16 |
| 1681 | 89.1.2.1 | Deleted -Main aspects of User plane protection in core network (e.g., provided by IPsec) | 349d | 2000-02-21 A | 2001-06-21 A |  | 100% | 2000-02-21 | 2001-06-21 | 349d | finish no earlier than 2001-06-21 | S3 | 2792h | 2792h |  | Rel-5 | Dionisio |  |  |  | SP-12 |
| 1682 | 89.1.2.2 | Deleted - Integration of GTP signalling security architecture - for User plane protection in core network (e.g., provided by IPsec) | 206d | 2001-09-14 A | 2002-06-28 A |  | 100% | 2001-09-14 | 2002-06-28 | 206d | finish no earlier than 2002-06-28 | N4 | 1648h | 1648h |  | Rel-5 | Kimmo |  |  |  | NP-16 |
| 1683 | 90 | **Intra Domain Connection of RAN Nodes to Multiple CN Nodes** | 455d | 2000-10-02 A | 2002-06-28 A |  | 100% | 2000-10-02 | 2002-06-28 | 455d |  | S2,N1,N4,R3,GP | 15672h | 15672h | IUFLEX | Rel-5 | Alain | 23.236 | Ericsson | stephen.terrill@ericsson.com |  |
| 1684 | 90.1 | Overall System Architecture for Intra Domain Connection of RAN Nodes to Multiple CN Nodes | 188d | 2001-01-03 A | 2001-09-21 A |  | 100% | 2001-01-03 | 2001-09-21 | 188d | finish no earlier than 2001-06-01 | S2 | 1504h | 1504h |  | Rel-5 | Maurice |  |  |  |  |
| 1685 | 90.2 | Stage 3: RAN node selecting CN node | 130d | 2001-09-24 A | 2002-03-22 A | 1684 | 100% | 2001-09-24 | 2002-03-22 | 130d | finish no earlier than 2002-03-22 | R3 | 1040h | 1040h |  | Rel-5 | Juha |  | Vodafone | Brendan.McWilliams@gb.vodafone.co.uk |  |
| 1686 | 90.3 | N1 work for Intra Domain Connection of RAN Nodes to Multiple CN Nodes | 205d | 2001-09-17 A | 2002-06-28 A |  | 100% | 2001-09-17 | 2002-06-28 | 205d | start no earlier than 2001-09-17 | N1 | 1640h | 1640h |  | Rel-5 | Frederic | 24.008 and check 29.018 |  |  |  |
| 1687 | 90.4 | N4 work for Intra Domain Connection of RAN Nodes to Multiple CN Nodes | 375d | 2000-10-02 A | 2002-03-08 A |  | 100% | 2000-10-02 | 2002-03-08 | 375d | finish no earlier than 2002-03-15 | N4 | 3000h | 3000h |  | Rel-5 | Kimmo |  |  |  |  |
| 1688 | 90.5 | **GERAN work for Intra Domain Connection of RAN Nodes to Multiple CN Nodes** | 101d | 2002-02-08 A | 2002-06-28 A |  | 100% | 2002-02-08 | 2002-06-28 | 101d |  | GP | 4848h | 4848h | IDCRAN-GERAN | Rel-5 | Paolo |  | Ericsson | ingemar.backlund@era.ericsson.se |  |
| 1689 | 90.5.1 | Stage 2 (changes to ) | 101d | 2002-02-08 A | 2002-06-28 A |  | 100% | 2002-02-08 | 2002-06-28 | 101d | finish no earlier than 2002-06-28 | G1 | 808h | 808h |  | Rel-5 | Paolo |  |  |  |  |
| 1690 | 90.5.2 | 43.051 Introduction of support for IDNNS in GERAN Iu mode | 101d | 2002-02-08 A | 2002-06-28 A |  | 100% | 2002-02-08 | 2002-06-28 | 101d | finish no earlier than 2002-06-28 | G1 | 808h | 808h |  | Rel-5 | Paolo |  |  |  |  |
| 1691 | 90.5.3 | Stage 3 (changes to ) | 101d | 2002-02-08 A | 2002-06-28 A |  | 100% | 2002-02-08 | 2002-06-28 | 101d | finish no earlier than 2002-06-28 | G2 | 808h | 808h |  | Rel-5 | Gert |  |  |  |  |
| 1692 | 90.5.4 | 48.016 Use of Gb interface concepts when a network applies IDNNS | 101d | 2002-02-08 A | 2002-06-28 A |  | 100% | 2002-02-08 | 2002-06-28 | 101d | finish no earlier than 2002-06-28 | G2 | 808h | 808h |  | Rel-5 | Gert |  |  |  |  |
| 1693 | 90.5.5 | 48.018 Include MSC/VLR identity in CS IMSI paging | 101d | 2002-02-08 A | 2002-06-28 A |  | 100% | 2002-02-08 | 2002-06-28 | 101d | finish no earlier than 2002-06-28 | G2 | 808h | 808h |  | Rel-5 | Gert |  |  |  |  |
| 1694 | 91 | **Deleted - GERAN improvements 3 (new transport layer on interface A)** | 446d | 2001-04-06 A | 2002-12-20 A |  | 100% | 2001-04-06 | 2002-12-20 | 446d |  | GP | 14272h | 14272h | GEIMP3 | Rel-5 | Paolo |  |  |  |  |
| 1695 | 91.1 | **Deleted - Evolution of the transport for A** | 446d | 2001-04-06 A | 2002-12-20 A |  | 100% | 2001-04-06 | 2002-12-20 | 446d |  | GP | 10704h | 10704h | GEIMP3-EtA | Rel-5 | Paolo |  |  |  | GP-12 |
| 1696 | 91.1.1 | Deleted - Definition of a new A/Ater interface Transport Layer option based on the Iu Interface Transport Layer | 446d | 2001-04-06 A | 2002-12-20 A |  | 100% | 2001-04-06 | 2002-12-20 | 446d | finish no earlier than 2002-12-20 | GP | 3568h | 3568h |  | Rel-5 | Paolo |  |  |  | GP-12 |
| 1697 | 91.1.2 | Deleted - Adaptation of the Layer 3 BSSMAP procedures as required | 446d | 2001-04-06 A | 2002-12-20 A |  | 100% | 2001-04-06 | 2002-12-20 | 446d | finish no earlier than 2002-12-20 | GP | 3568h | 3568h |  | Rel-5 | Paolo |  |  |  | GP-12 |

Notes:
- 1672: -
- 1673: -
- 1674: Added BB UE authentication and rapporteur added. TO BE DELETED
- 1675: SP#9 approved WID SP-000420 (S3-000606 Network domain security). S3#17: All due in Rel5. (WI Update at S3#18). Replaced by NDS-IP and NDS-MAP. TO BE DELETED OR MOVED TO HISTORY FILE
- 1676: SP#12 WID updated SP-000420 (S3-000606) =>SP-010326 (S3-010286)
- 1677: Marked as stopped 12/2008
- 1678: TO BE DELETED. Marked as stopped 12/2008
- 1679: Waiting for input from SA3!.... Marked as stopped 12/2008
- 1680: TO BE DELETED. Marked as stopped 12/2008
- 1681: -
- 1682: 14/02/2002 requirements are not clear/not received...Marked as closed 12/2008 (was marked 95 complete)
- 1683: No clear indication on the end date. Put to Rel5 by AS.
- 1684: -
- 1685: Not identified
- 1686: -
- 1687: DAB 12.12.01 - % complete to 66% / 14/02/02 Work completed
- 1688: Accept changes Gb over IP
- 1689: -
- 1690: -
- 1691: -
- 1692: Closed, accept changes for Gb over IP
- 1693: -
- 1694: Terminated - not standardized. Marked as stopped 12/2008
- 1695: TERMINATED - NOT STANDARDIZED. Marked as stopped 12/2008
- 1696: TERMINATED - NOT STANDARDIZED. Marked as stopped 12/2008
- 1697: TERMINATED - NOT STANDARDIZED. Marked as stopped 12/2008

| ID | WBS | Task | Duration | Start | Finish | Predecessors | Complete | Baseline start | Baseline finish | Baseline duration | Constraint | Resources | Work | Actual work | Text1 | Text4 | Text6 | Text8 | Text5 |
| --- | --- | --- | --- | --- | --- | --- | --- | --- | --- | --- | --- | --- | --- | --- | --- | --- | --- | --- | --- |
| 1698 | 92 | **Rel-5 Charging Management & Operations, Administration, Maintenance and Provisioning (OAM&P)** | 264d | 2001-09-10 A | 2002-09-12 A |  | 100% | 2001-09-10 | 2002-09-12 | 264d |  | S5 | 9976h | 9976h | OAM | VoiceStream, Motorola | Rel-5 | Dionisio |  |
| 1699 | 92.1 | Rel5 Principles, high level Requirements and Architecture | 205d | 2001-09-17 A | 2002-06-28 A |  | 100% | 2001-09-17 | 2002-06-28 | 205d | finish no earlier than 2002-06-28 | S5 | 1640h | 1640h | OAM-AR/PR | Motorola | Rel-5 | Dionisio |  |
| 1700 | 92.2 | Rel5 Performance Management | 259d | 2001-09-17 A | 2002-09-12 A |  | 100% | 2001-09-17 | 2002-09-12 | 259d | finish no earlier than 2002-09-12 | S5 | 2072h | 2072h | OAM-PM | Nortel | Rel-5 | Dionisio |  |
| 1701 | 92.3 | Rel-5 Charging Management | 264d | 2001-09-10 A | 2002-09-12 A |  | 100% | 2001-09-10 | 2002-09-12 | 264d | finish no earlier than 2002-09-12 | S5 | 2112h | 2112h | OAM-CH | T-Mobile | Rel-5 | Dionisio | Karl-Heinz.Nenner@T-MOBILE.DE |
| 1702 | 92.4 | Rel5 Network Infrastructure Management | 255d | 2001-09-21 A | 2002-09-12 A |  | 100% | 2001-09-21 | 2002-09-12 | 255d | finish no earlier than 2002-09-12 | S5 | 2040h | 2040h | OAM-NIM | Ericsson | Rel-5 | Dionisio | thomas.tovinger@ericsson.com |
| 1703 | 93 | **GERAN enhancements for streaming services 1 (RLC enhancements)** | 430d | 2000-11-06 A | 2002-06-28 A |  | 100% | 2000-11-06 | 2002-06-28 | 430d |  | GP | 8944h | 8944h |  |  | Rel-5 | Paolo |  |
| 1704 | 93.1 | Concept for GERAN enhancements for streaming services 1 (RLC enhancements) | 258d | 2000-11-06 A | 2001-10-31 A |  | 100% | 2000-11-06 | 2001-10-31 | 258d | finish no earlier than 2001-10-31 | GP | 2064h | 2064h |  |  | Rel-5 | Paolo |  |
| 1705 | 93.2 | RLC protocol enhancement (SDU Discard) | 430d | 2000-11-06 A | 2002-06-28 A |  | 100% | 2000-11-06 | 2002-06-28 | 430d | finish no earlier than 2002-06-28 | GP | 3440h | 3440h |  |  | Rel-5 | Paolo |  |
| 1706 | 94 | **GERAN enhancements for streaming services 2 (usage of ECSD)** | 430d | 2000-11-06 A | 2002-06-28 A |  | 100% | 2000-11-06 | 2002-06-28 | 430d |  | GP | 19840h | 19840h |  | Ericsson | Rel-5 | Paolo | Frank Muller |
| 1707 | 94.1 | Usage of ECSD Concept | 380d | 2000-11-06 A | 2002-04-19 A |  | 100% | 2000-11-06 | 2002-04-19 | 380d | finish no earlier than 2002-04-19 | GP | 3040h | 3040h |  |  | Rel-5 | Paolo |  |
| 1708 | 94.2 | Stage 2 for GERAN enhancements for streaming services 2 (usage of ECSD) | 380d | 2000-11-06 A | 2002-04-19 A |  | 100% | 2000-11-06 | 2002-04-19 | 380d | finish no earlier than 2002-04-19 | GP | 3040h | 3040h |  |  | Rel-5 | Paolo |  |
| 1709 | 94.3 | Stage 3 for GERAN enhancements for streaming services 2 (usage of ECSD) | 430d | 2000-11-06 A | 2002-06-28 A |  | 100% | 2000-11-06 | 2002-06-28 | 430d | finish no earlier than 2002-06-28 | GP | 3440h | 3440h |  |  | Rel-5 | Paolo |  |
| 1710 | 94.4 | RLC PDU formats | 430d | 2000-11-06 A | 2002-06-28 A |  | 100% | 2000-11-06 | 2002-06-28 | 430d | finish no earlier than 2002-06-28 | GP | 3440h | 3440h |  |  | Rel-5 | Paolo |  |
| 1711 | 94.5 | MAC header | 430d | 2000-11-06 A | 2002-06-28 A |  | 100% | 2000-11-06 | 2002-06-28 | 430d | finish no earlier than 2002-06-28 | GP | 3440h | 3440h |  |  | Rel-5 | Paolo |  |
| 1712 | 95 | **GERAN/UTRAN interface evolution 1 (evolution of Iu PS)** | 476d | 2000-09-01 A | 2002-06-28 A |  | 100% | 2000-09-01 | 2002-06-28 | 476d |  | GP,R3 | 10688h | 10688h | GERUEV1 | SBC | Rel-5 | Paolo | Marc Grant |
| 1713 | 95.1 | **Evolution of Iu ps** | 476d | 2000-09-01 A | 2002-06-28 A |  | 100% | 2000-09-01 | 2002-06-28 | 476d |  | GP,R3 | 7248h | 7248h | GERUEV1-IuPS |  | Rel-5 | Paolo |  |
| 1714 | 95.1.1 | Identification of GERAN requirements on Iu ps | 326d | 2000-09-01 A | 2001-11-30 A |  | 100% | 2000-09-01 | 2001-11-30 | 326d | finish no earlier than 2001-11-30 | GP,R3 | 2608h | 2608h | GERUEV1-IuPS |  | Rel-5 | Paolo |  |
| 1715 | 95.1.2 | Update of Evolution of Iu ps specifications | 150d | 2001-12-03 A | 2002-06-28 A | 1714 | 100% | 2001-12-03 | 2002-06-28 | 150d | finish no earlier than 2002-06-28 | GP,R3 | 1200h | 1200h | GERUEV1-IuPS |  | Rel-5 | Paolo |  |
| 1716 | 96 | **GERAN/UTRAN interface evolution 2 (evolution of Iu CS)** | 476d | 2000-09-01 A | 2002-06-28 A |  | 100% | 2000-09-01 | 2002-06-28 | 476d |  | GP,R3 | 12816h | 12816h | GERUEV2 |  | Rel-5 | Paolo |  |
| 1717 | 96.1 | **Evolution of Iu cs** | 476d | 2000-09-01 A | 2002-06-28 A |  | 100% | 2000-09-01 | 2002-06-28 | 476d |  | GP,R3 | 10016h | 10016h | GERUEV2-IuCS | Lucent | Rel-5 | Paolo | Krishna Balachandran |
| 1718 | 96.1.1 | Identification of GERAN requirements on Iu cs | 426d | 2000-09-01 A | 2002-06-24 A |  | 100% | 2000-09-01 | 2002-06-24 | 426d | finish no earlier than 2002-04-19 | GP,R3 | 3408h | 3408h | GERUEV2-IuCS |  | Rel-5 | Paolo |  |
| 1719 | 96.1.2 | Update of Evolution of Iu cs specifications | 476d | 2000-09-01 A | 2002-06-28 A |  | 100% | 2000-09-01 | 2002-06-28 | 476d | finish no earlier than 2002-06-28 | GP,R3 | 3808h | 3808h | GERUEV2-IuCS |  | Rel-5 | Paolo |  |
| 1720 | 97 | **End to End QoS for PS Domain including IMS** | 480d | 2000-08-28 A | 2002-06-28 A |  | 100% | 2000-08-28 | 2002-06-28 | 480d |  | S2,S5,N3 | 10592h | 10592h | E2EQoS | Ericsson | Rel-5 | Maurice | Johnson.oyama@era.ericcson.se |
| 1721 | 97.1 | E2E QoSConcept and Architecture | 178d | 2001-01-03 A | 2001-09-07 A |  | 100% | 2001-01-03 | 2001-09-07 | 178d | finish no earlier than 2001-09-07 | S2 | 1424h | 1424h |  |  | Rel-5 | Maurice |  |
| 1722 | 97.2 | E2E QoS interworking | 465d | 2000-08-28 A | 2002-06-07 A |  | 100% | 2000-08-28 | 2002-06-07 | 465d | finish no earlier than 2002-06-07 | N3 | 3720h | 3720h | E2EQoS-IW | Lucent | Rel-5 | Gwiho | Daisuke Yokota (yokota@lucent.com) |
| 1723 | 97.3 | QoS Management (Provisioning and Monitoring) | 201d | 2001-09-21 A | 2002-06-28 A |  | 100% | 2001-09-21 | 2002-06-28 | 201d | finish no earlier than 2002-06-28 | S5 | 1608h | 1608h | E2EQoS-OAM | VoiceStream, Motorola | Rel-5 | Dionisio |  |

Notes:
- 1698: -
- 1699: - / Text3: 32.101, 32.102
- 1700: - / Text3: 32.4xy, 52.402
- 1701: - / Text3: 32.200, 32.205, 32.215, 32.225, 32.235
- 1702: - / Text3: 32.6xy, 32.3xy
- 1703: -
- 1704: -
- 1705: -
- 1706: AWS, Nokia, Ericsson, Nortel, Siemens, Motorola, Vodafone
- 1707: -
- 1708: -
- 1709: -
- 1710: -
- 1711: -
- 1712: SBC, Motorola, Nokia, Ericsson, Nortel
- 1713: -
- 1714: -
- 1715: -
- 1716: -
- 1717: Lucent, Ericsson, AWS, Nortel
- 1718: -
- 1719: -
- 1720: -
- 1721: - / Text3: 23.207
- 1722: [DAB - 30/07/02] - % complete to 95% (if we exclude Diffserv). Marked as closed 12/2008 (was marked 95% complete) / Text3: 29.208, 29.207, 27.060, 29.061, 24.008, 24.228, , 24.229, 29.060, 29.163
- 1723: - / Text3: 32-series

| ID | WBS | Task | Duration | Start | Finish | Complete | Baseline start | Baseline finish | Baseline duration | Constraint | Resources | Work | Actual work | Text1 | Text6 | Text8 | Text12 | Text3 | Text4 | Text5 |
| --- | --- | --- | --- | --- | --- | --- | --- | --- | --- | --- | --- | --- | --- | --- | --- | --- | --- | --- | --- | --- |
| 1724 | 99 | **GERAN Inter BSC NACC improvements over the Gb Interface** | 215d | 2001-09-03 A | 2002-06-28 A | 100% | 2001-09-03 | 2002-06-28 | 215d |  | GP | 8200h | 8200h | GERNACC | Rel-5 | Paolo |  |  |  |  |
| 1725 | 99.1 | **Modification of core network protocols for GERAN Inter BSC NACC over Gb Interface** | 165d | 2001-09-03 A | 2002-04-19 A | 100% | 2001-09-03 | 2002-04-19 | 165d |  | N4,S2 | 4064h | 4064h | GERNACC-Cnmod | Rel-5 | Kimmo |  |  |  |  |
| 1726 | 99.1.1 | Stage 2 - Concept | 43d | 2001-09-03 A | 2001-10-31 A | 100% | 2001-09-03 | 2001-10-31 | 43d | finish no earlier than 2001-10-31 | N4,S2 | 344h | 344h |  | Rel-5 | Kimmo |  |  |  |  |
| 1727 | 99.1.2 | Stage 2 - 23.060 change - Definition of Inter BSC NACC | 165d | 2001-09-03 A | 2002-04-19 A | 100% | 2001-09-03 | 2002-04-19 | 165d | finish no earlier than 2002-04-19 | N4,S2 | 1320h | 1320h |  | Rel-5 | Kimmo |  |  |  |  |
| 1728 | 99.1.3 | Stage 3 (changes to TS 29.060) | 135d | 2001-09-03 A | 2002-03-08 A | 100% | 2001-09-03 | 2002-03-08 | 135d | finish no earlier than 2002-03-08 | N4 | 1080h | 1080h |  | Rel-5 | Kimmo |  |  |  |  |
| 1729 | 99.2 | **Modification of Gb protocols for GERAN Inter BSC NACC over Gb Interface** | 151d | 2001-11-30 A | 2002-06-28 A | 100% | 2001-11-30 | 2002-06-28 | 151d |  | GP | 2416h | 2416h | GERNACC-Gbmod | Rel-5 | Paolo |  |  |  |  |
| 1730 | 99.2.1 | Stage 3 (changes to TS 48.018) | 151d | 2001-11-30 A | 2002-06-28 A | 100% | 2001-11-30 | 2002-06-28 | 151d | finish no earlier than 2002-06-28 | GP | 1208h | 1208h |  | Rel-5 | Paolo |  |  |  |  |
| 1731 | 100 | **Enhanced Power Control** | 540d | 2001-11-26 A | 2003-12-19 A | 100% | 2001-11-26 | 2003-12-19 | 540d |  | GP | 12840h | 12840h | EPC | Rel-5 | Paolo |  |  |  |  |
| 1732 | 100.1 | Realization of Enhanced power control and signalling support | 5d | 2001-11-26 A | 2001-11-30 A | 100% | 2001-11-26 | 2001-11-30 | 5d | finish no earlier than 2001-11-30 | GP | 40h | 40h |  | Rel-5 | Paolo |  |  |  |  |
| 1733 | 100.2 | Deleted - GERAN MS Conformance test for Enhanced Power Control | 530d | 2001-12-10 A | 2003-12-19 A | 100% | 2001-12-10 | 2003-12-19 | 530d | finish no earlier than 2003-12-19 | GP | 4240h | 4240h |  | Rel-5 | Paolo | GP-17 |  |  |  |
| 1734 | 100.3 | Deleted - GERAN BTS Conformance test for Enhanced Power Control | 530d | 2001-12-10 A | 2003-12-19 A | 100% | 2001-12-10 | 2003-12-19 | 530d | finish no earlier than 2003-12-19 | GP | 4240h | 4240h |  | Rel-5 | Paolo | GP-17 |  |  |  |
| 1735 | 101 | **8PSK AMR HR** | 530d | 2001-12-10 A | 2003-12-19 A | 100% | 2001-12-10 | 2003-12-19 | 530d |  | GP | 21080h | 21080h | 8PSK-AH | Rel-5 | Paolo |  |  |  |  |
| 1736 | 101.1 | **Definition of channel coding, performance requirements and signalling support** | 145d | 2001-12-10 A | 2002-06-28 A | 100% | 2001-12-10 | 2002-06-28 | 145d |  | GP | 10440h | 10440h |  | Rel-5 | Paolo |  |  |  |  |
| 1737 | 101.1.1 | Concept | 145d | 2001-12-10 A | 2002-06-28 A | 100% | 2001-12-10 | 2002-06-28 | 145d | finish no earlier than 2002-06-28 | GP | 1160h | 1160h |  | Rel-5 | Paolo |  |  |  |  |
| 1738 | 101.1.2 | Changes to 44.018 | 145d | 2001-12-10 A | 2002-06-28 A | 100% | 2001-12-10 | 2002-06-28 | 145d | finish no earlier than 2002-06-28 | G2 | 1160h | 1160h |  | Rel-5 | Gert |  |  |  |  |
| 1739 | 101.1.3 | Changes to 45.001 | 145d | 2001-12-10 A | 2002-06-28 A | 100% | 2001-12-10 | 2002-06-28 | 145d | finish no earlier than 2002-06-28 | G1 | 1160h | 1160h |  | Rel-5 | Paolo |  |  |  |  |
| 1740 | 101.1.4 | Changes to 45.002 | 145d | 2001-12-10 A | 2002-06-28 A | 100% | 2001-12-10 | 2002-06-28 | 145d | finish no earlier than 2002-06-28 | G1 | 1160h | 1160h |  | Rel-5 | Paolo |  |  |  |  |
| 1741 | 101.1.5 | Changes to 45.003 | 145d | 2001-12-10 A | 2002-06-28 A | 100% | 2001-12-10 | 2002-06-28 | 145d | finish no earlier than 2002-06-28 | G1 | 1160h | 1160h |  | Rel-5 | Paolo |  |  |  |  |
| 1742 | 101.1.6 | Changes to 45.005 | 145d | 2001-12-10 A | 2002-06-28 A | 100% | 2001-12-10 | 2002-06-28 | 145d | finish no earlier than 2002-06-28 | G1 | 1160h | 1160h |  | Rel-5 | Paolo |  |  |  |  |
| 1743 | 101.1.7 | Changes to 24.008 | 145d | 2001-12-10 A | 2002-06-28 A | 100% | 2001-12-10 | 2002-06-28 | 145d | finish no earlier than 2002-06-28 | G2 | 1160h | 1160h |  | Rel-5 | Gert |  |  |  |  |
| 1744 | 101.1.8 | Changes to 48.058 | 145d | 2001-12-10 A | 2002-06-28 A | 100% | 2001-12-10 | 2002-06-28 | 145d | finish no earlier than 2002-06-28 | G2 | 1160h | 1160h |  | Rel-5 | Gert |  |  |  |  |
| 1745 | 101.2 | Deleted - GERAN MS Conformance test for 8PSK HR | 530d | 2001-12-10 A | 2003-12-19 A | 100% | 2001-12-10 | 2003-12-19 | 530d | finish no earlier than 2003-12-19 | GP | 4240h | 4240h |  | Rel-5 | Paolo | GP-17 |  |  |  |
| 1746 | 101.3 | GERAN BTS Conformance test for 8PSK HR | 270d | 2001-12-10 A | 2002-12-20 A | 100% | 2001-12-10 | 2002-12-20 | 270d | finish no earlier than 2002-12-20 | GP | 2160h | 2160h |  | Rel-5 | Paolo |  |  |  |  |
| 1747 | 102 | Service Change and UDI Fallback | 175d | 2001-10-08 A | 2002-06-07 A | 100% | 2001-10-08 | 2002-06-07 | 175d | finish no earlier than 2002-06-07 | N3 | 1400h | 1400h | SCUDIF | Rel-5 | Gwiho |  | 29.007, 27.001, 24.008 | Ericsson | Rune.Werner.Wiik@ericsson.no |

Notes:
- 1724: -
- 1725: -
- 1726: -
- 1727: -
- 1728: IP 30/11/01: Input awaited from GERAN2 to CN4 / 17 May Work complete 100%
- 1729: -
- 1730: -
- 1731: -
- 1732: Completed 11/2001
- 1733: Not started. Marked as stopped 12/2008
- 1734: Not started. Marked as stopped 12/2008
- 1735: Completed for Rel-5
- 1736: -
- 1737: -
- 1738: -
- 1739: -
- 1740: -
- 1741: -
- 1742: -
- 1743: -
- 1744: -
- 1745: Marked as stopped 12/2008
- 1746: -
- 1747: -

| ID | WBS | Task | Type | Duration | Start | Finish | Complete | Baseline start | Baseline finish | Baseline duration | Constraint | Resources | Work | Actual work | Text1 | Text4 | Text5 | Text6 | Text8 | Text12 |
| --- | --- | --- | --- | --- | --- | --- | --- | --- | --- | --- | --- | --- | --- | --- | --- | --- | --- | --- | --- | --- |
| 1748 | 103 | **Rel-5 USIM toolkit enhancements** |  | 865d | 2000-06-05 A | 2003-09-26 A | 100% | 2000-06-05 | 2003-09-26 | 865d |  | T3 | 24352h | 24352h | USAT1-Interpr | G & D | Michael Meyer | Rel-5 | Xavier |  |
| 1749 | 103.1 | Deleted - Test specification for USIM toolkit security mechanisms |  | 349d | 2002-05-28 A | 2003-09-26 A | 100% | 2002-05-28 | 2003-09-26 | 349d | finish no earlier than 2003-09-26 | T3 | 2792h | 2792h |  | Gemplus | Sophie Viallet | Rel-5 | Xavier | TP-21 |
| 1750 | 103.2 | **Protocol Standardisation of a SIM Toolkit Interpreter** |  | 688d | 2000-06-05 A | 2003-01-22 A | 100% | 2000-06-05 | 2003-01-22 | 688d |  | T3 | 12512h | 12512h | USAT1-Interpr | G & D | Michael Meyer | Rel-5 | Xavier |  |
| 1751 | 103.2.1 | Stage 1 for Protocol Standardisation of a SIM Toolkit Interpreter |  | 205d | 2000-06-05 A | 2001-03-16 A | 100% | 2000-06-05 | 2001-03-16 | 205d | finish no earlier than 2001-03-16 | T3 | 1640h | 1640h | USAT1-Interpr |  |  | Rel-5 | Xavier |  |
| 1752 | 103.2.2 | Stage 2 and 3 |  | 308d | 2001-01-03 A | 2002-03-08 A | 100% | 2001-01-03 | 2002-03-08 | 308d | finish no earlier than 2002-03-08 | T3 | 2464h | 2464h | USAT1-Interpr |  |  | Rel-5 | Xavier |  |
| 1753 | 103.2.3 | Test specification for Protocol Standardisation of a SIM Toolkit Interpreter |  | 363d | 2001-09-03 A | 2003-01-22 A | 100% | 2001-09-03 | 2003-01-22 | 363d | finish no earlier than 2003-01-22 | T3 | 2904h | 2904h | USAT1-Interpr | Gemplus | Gérald MAUNIER | Rel-5 | Xavier |  |
| 1754 | 103.4 | **(U)SIM API** |  | 133d | 2002-03-20 A | 2002-09-20 A | 100% | 2002-03-20 | 2002-09-20 | 133d |  | T3 | 2128h | 2128h | USAT1-API | Microelectrónica Española | Mario Pérez | Rel-5 | Xavier |  |
| 1755 | 103.4.1 | Rel-5 Java API Test specification |  | 133d | 2002-03-20 A | 2002-09-20 A | 100% | 2002-03-20 | 2002-09-20 | 133d | finish no earlier than 2002-09-20 | T3 | 1064h | 1064h | USAT1-API | Microelectrónica Española | Mario Pérez | Rel-5 | Xavier |  |
| 1756 | 104 | (Small) Technical Enhancements and Improvements for Rel-5 | milestone | 0d? | 2000-01-03 A | 2000-01-03 A | 100% | 2000-01-03 | 2000-01-03 | 0d? |  | All |  |  | TEI5 |  |  | Rel-5 | all |  |
| 1757 | 608 | Test - (Small) Technical Enhancements and Improvements for Rel-5 |  | 2349d? | 2000-01-03 A | 2008-12-31 A | 100% | 2000-01-03 | 2008-12-31 | 2349d? | finish no earlier than 2008-12-31 | R5,T1 | 18792h | 18792h | TEI5_Test |  |  | Rel-5 | Ingbert |  |
| 1758 | 106 | **User Equipment Management** |  | 267d | 2001-06-21 A | 2002-06-28 A | 100% | 2001-06-21 | 2002-06-28 | 267d |  | S5 | 3752h | 3752h | UEM | Vodafone | john.mudge@vf.vodafone.co.uk | Rel-5 | Dionisio |  |
| 1759 | 106.1 | FS on User Equipment (UE) Management |  | 267d | 2001-06-21 A | 2002-06-28 A | 100% | 2001-06-21 | 2002-06-28 | 267d | finish no earlier than 2002-06-28 | S5 | 2136h | 2136h | OAM-UEM | Vodafone | john.mudge@vf.vodafone.co.uk | Rel-5 | Dionisio |  |
| 1760 | 107 | **Flow control supporting an MS with multiple data flows with different QoS over the Gb interface** |  | 50d | 2002-06-24 A | 2002-08-30 A | 100% | 2002-06-24 | 2002-08-30 | 50d |  | GP | 1288h | 1288h | FlowCon | Ericsson | ingemar.backlund@era.ericsson.se | Rel-5 | Paolo |  |
| 1761 | 107.1 | **Update of stage 2 specifications** |  | 50d | 2002-06-24 A | 2002-08-30 A | 100% | 2002-06-24 | 2002-08-30 | 50d |  | GP | 808h | 808h |  |  |  | Rel-5 | Paolo |  |
| 1762 | 107.1.1 | Concept document 23.060 (changes to) |  | 46d | 2002-06-28 A | 2002-08-30 A | 100% | 2002-06-28 | 2002-08-30 | 46d | finish no earlier than 2002-08-30 | S2 | 368h | 368h |  |  |  | Rel-5 | Maurice |  |
| 1763 | 107.1.2 | Flow Control |  | 5d | 2002-06-24 A | 2002-06-28 A | 100% | 2002-06-24 | 2002-06-28 | 5d | finish no earlier than 2002-06-28 | GP | 40h | 40h |  |  |  | Rel-5 | Paolo |  |
| 1764 | 107.2 | **Modification of BSSGP protocol** |  | 5d | 2002-06-24 A | 2002-06-28 A | 100% | 2002-06-24 | 2002-06-28 | 5d |  | GP | 80h | 80h |  | Ericsson | ingemar.backlund@era.ericsson.se | Rel-5 | Paolo |  |
| 1765 | 107.2.1 | Stage 3 (changes to 48.018) |  | 5d | 2002-06-24 A | 2002-06-28 A | 100% | 2002-06-24 | 2002-06-28 | 5d | finish no earlier than 2002-06-28 | G2 | 40h | 40h |  |  |  | Rel-5 | Gert |  |
| 1766 | 108 | **Deleted - Multiple TBF in A/Gb mode - Phase 1** |  | 421d | 2002-04-19 A | 2003-11-28 A | 100% | 2002-04-19 | 2003-11-28 | 421d |  | GP | 17480h | 17480h | MULTBF | Ericsson | gunnar.mildh@era.ericsson.se | Rel-5 | Paolo | GP-17 |
| 1767 | 108.1 | **Deleted - Multiple TBF in A/Gb mode - Core** |  | 351d | 2002-04-19 A | 2003-08-22 A | 100% | 2002-04-19 | 2003-08-22 | 351d |  | GP | 8112h | 8112h | MULTBF-Agbmode |  |  | Rel-5 | Paolo | GP-17 |
| 1768 | 108.1.1 | Deleted - Multiple TBF Concept paper |  | 351d | 2002-04-19 A | 2003-08-22 A | 100% | 2002-04-19 | 2003-08-22 | 351d | finish no earlier than 2003-08-22 | GP | 2808h | 2808h | MULTBF-Agbmode |  |  | Rel-5 | Paolo | GP-17 |
| 1769 | 108.1.2 | Deleted - Multiple TBF Stage 2 (43.064) CRs |  | 156d | 2002-04-19 A | 2002-11-22 A | 100% | 2002-04-19 | 2002-11-22 | 156d | finish no earlier than 2002-11-22 | G1 | 1248h | 1248h | MULTBF-Agbmode |  |  | Rel-5 | Paolo | GP-12 |
| 1770 | 108.1.3 | Deleted - Multiple TBF Stage 3 (44.060) CRs |  | 156d | 2002-04-19 A | 2002-11-22 A | 100% | 2002-04-19 | 2002-11-22 | 156d | finish no earlier than 2002-11-22 | G2 | 1248h | 1248h | MULTBF-Agbmode |  |  | Rel-5 | Gert | GP-12 |
| 1771 | 108.2 | **Deleted - Multiple TBF in A/Gb mode - Phase 1 – MS testing** |  | 375d | 2002-06-24 A | 2003-11-28 A | 100% | 2002-06-24 | 2003-11-28 | 375d |  | GP | 6000h | 6000h |  | Ericsson | ingemar.backlund@era.ericsson.se | Rel-5 | Paolo | GP-17 |
| 1772 | 108.2.1 | Deleted - MS conformance tests for Multiple TBF in A/Gb mode |  | 375d | 2002-06-24 A | 2003-11-28 A | 100% | 2002-06-24 | 2003-11-28 | 375d | finish no earlier than 2003-11-28 | G4 | 3000h | 3000h |  |  |  | Rel-5 | Paolo | GP-17 |

Notes:
- 1748: -
- 1749: Marked as stopped 12/2008
- 1750: 28/5/2001: T3-19 proposed that since the stage 2 and 3 will not be presented to TP-12 for approval as expected, the WI will be moved to rel-5, with completion expected at TP-13. / Text3: 27.103
- 1751: 5/10/2001: Stage one comepeted at TP-12.
- 1752: 5/10/2001: TS 31.112 and 31.113 approved at TP-13. TS 31.114 to be presented to TP-14.
- 1753: 5/10/2001: Work started on test specification. Marked as closed 12/2008 (was marked 12% complete)
- 1754: 8/3/2001: test spec is based on R99 core spec, so deleted from Workplan
- 1755: -
- 1756: "Joker" WI, to be used for a Rel 5 CR not related to any feature and with very limited impact on the system
- 1757: "Joker" WI, to be used for small modifications applicable to Rel 5 conformance testing. Moved in from Stoyan/testing WP. / Text3: 34.108, 34.109, 34.121-1, 34.121-2, 34.122, 34.123-1, 34.123-2, 34.123-3, 34.171, 34.229-1, 34.229-2, 34.229-3
- 1758: - / Text3: 32.802
- 1759: - / Text3: 32.802
- 1760: 50101 -> 50201
- 1761: 50102 -> 50202
- 1762: -
- 1763: 50103 -> 50203
- 1764: -
- 1765: -
- 1766: GP#17 Nov 2003 Moved to Rel-6 as UID_50600 MULTBF (Only Multiple TBF Concept paper produced in Rel-5)
- 1767: Marked as closed 12/2008 (was marked 26% complete)
- 1768: Marked as closed 12/2008 (was marked 50% complete)
- 1769: Marked as stopped 12/2008
- 1770: Marked as stopped 12/2008
- 1771: 08/08: duplicate UID_50106=-> 50206. Marked as stopped 12/2008
- 1772: Not started. Marked as stopped 12/2008

| ID | WBS | Task | Duration | Start | Finish | Complete | Baseline start | Baseline finish | Baseline duration | Constraint | Resources | Work | Actual work | Text1 | Text4 | Text5 | Text6 | Text8 |
| --- | --- | --- | --- | --- | --- | --- | --- | --- | --- | --- | --- | --- | --- | --- | --- | --- | --- | --- |
| 1773 | 109 | **Alignment of 3G functional split and Iu** | 922d | 2000-06-08 A | 2003-12-19 A | 100% | 2000-06-08 | 2003-12-19 | 922d |  | GP | 126664h | 126664h | GER3GAL | Ericsson | Frank Muller | Rel-5 | Paolo |
| 1774 | 109.1 | **GERAN user / control plane** | 540d | 2000-08-07 A | 2002-08-30 A | 100% | 2000-08-07 | 2002-08-30 | 540d |  | GP | 36232h | 36232h | GER3GAL-GUCOPL | Ericsson | Frank Muller | Rel-5 | Paolo |
| 1775 | 109.1.1 | **Alignment with UMTS bearer concept** | 540d | 2000-08-07 A | 2002-08-30 A | 100% | 2000-08-07 | 2002-08-30 | 540d |  | GP | 24952h | 24952h |  |  |  | Rel-5 | Paolo |
| 1776 | 109.1.1.1 | Enhanced power control - for Alignment with UMTS bearer concept | 1d | 2001-08-31 A | 2001-08-31 A | 100% | 2001-08-31 | 2001-08-31 | 1d | finish no earlier than 2001-08-31 | GP | 8h | 8h |  |  |  | Rel-5 | Paolo |
| 1777 | 109.1.1.2 | Stage 2 - for Alignment with UMTS bearer concept | 235d | 2000-08-07 A | 2001-06-29 A | 100% | 2000-08-07 | 2001-06-29 | 235d | finish no earlier than 2001-06-29 | GP | 1880h | 1880h |  |  |  | Rel-5 | Paolo |
| 1778 | 109.1.1.3 | Adoption of the UTRAN PDCP | 295d | 2000-11-06 A | 2001-12-21 A | 100% | 2000-11-06 | 2001-12-21 | 295d | finish no earlier than 2001-12-21 | GP | 2360h | 2360h |  |  |  | Rel-5 | Paolo |
| 1779 | 109.1.1.4 | Development of RLC / MAC | 261d | 2001-08-31 A | 2002-08-30 A | 100% | 2001-08-31 | 2002-08-30 | 261d | finish no earlier than 2002-08-30 | GP | 2088h | 2088h |  |  |  | Rel-5 | Paolo |
| 1780 | 109.1.1.5 | Development of GERAN RRC | 266d | 2001-06-22 A | 2002-06-28 A | 100% | 2001-06-22 | 2002-06-28 | 266d | finish no earlier than 2002-06-28 | GP | 2128h | 2128h |  |  |  | Rel-5 | Paolo |
| 1781 | 109.1.1.6 | Ciphering and integrity protection concept paper | 166d | 2001-08-31 A | 2002-04-19 A | 100% | 2001-08-31 | 2002-04-19 | 166d | finish no earlier than 2002-04-19 | GP | 1328h | 1328h |  |  |  | Rel-5 | Paolo |
| 1782 | 109.1.1.7 | Multiple TBF or equivalent Concept paper | 116d | 2001-08-31 A | 2002-02-08 A | 100% | 2001-08-31 | 2002-02-08 | 116d | finish no earlier than 2002-02-08 | GP | 928h | 928h |  |  |  | Rel-5 | Paolo |
| 1783 | 109.1.1.8 | Paging concept | 166d | 2001-08-31 A | 2002-04-19 A | 100% | 2001-08-31 | 2002-04-19 | 166d | finish no earlier than 2002-04-19 | GP | 1328h | 1328h |  |  |  | Rel-5 | Paolo |
| 1784 | 109.1.1.9 | Dedicated Physical subchannels, includes traffic and control channels | 66d | 2001-08-31 A | 2001-11-30 A | 100% | 2001-08-31 | 2001-11-30 | 66d | finish no earlier than 2001-11-30 | GP | 528h | 528h |  |  |  | Rel-5 | Paolo |
| 1785 | 109.1.1.10 | Iu support and broadcast concept | 166d | 2001-08-31 A | 2002-04-19 A | 100% | 2001-08-31 | 2002-04-19 | 166d | finish no earlier than 2002-04-19 | GP | 1328h | 1328h |  |  |  | Rel-5 | Paolo |
| 1786 | 109.1.1.11 | Impact of using RLC instead of LAPDm concept | 116d | 2001-08-31 A | 2002-02-08 A | 100% | 2001-08-31 | 2002-02-08 | 116d | finish no earlier than 2002-02-08 | GP | 928h | 928h |  |  |  | Rel-5 | Paolo |
| 1787 | 109.1.1.12 | Contention resolution, mobile station identity, and access concept | 66d | 2001-08-31 A | 2001-11-30 A | 100% | 2001-08-31 | 2001-11-30 | 66d | finish no earlier than 2001-11-30 | GP | 528h | 528h |  |  |  | Rel-5 | Paolo |
| 1788 | 109.1.1.13 | PDCP concept | 166d | 2001-08-31 A | 2002-04-19 A | 100% | 2001-08-31 | 2002-04-19 | 166d | finish no earlier than 2002-04-19 | GP | 1328h | 1328h |  |  |  | Rel-5 | Paolo |
| 1789 | 109.1.1.14 | Downlink delayed TBF release | 261d | 2001-08-31 A | 2002-08-30 A | 100% | 2001-08-31 | 2002-08-30 | 261d | finish no earlier than 2002-08-30 | GP | 2088h | 2088h |  |  |  | Rel-5 | Paolo |
| 1790 | 109.1.1.15 | Add transparent RLC Concept | 116d | 2001-08-31 A | 2002-02-08 A | 100% | 2001-08-31 | 2002-02-08 | 116d | finish no earlier than 2002-02-08 | GP | 928h | 928h |  |  |  | Rel-5 | Paolo |
| 1791 | 109.1.1.16 | Handover concept | 116d | 2001-08-31 A | 2002-02-08 A | 100% | 2001-08-31 | 2002-02-08 | 116d | finish no earlier than 2002-02-08 | GP | 928h | 928h |  |  |  | Rel-5 | Paolo |
| 1792 | 109.1.2 | **Physical layer alignment with UMTS bearer concept** | 280d | 2000-11-06 A | 2001-11-30 A | 100% | 2000-11-06 | 2001-11-30 | 280d |  | GP | 6960h | 6960h |  |  |  | Rel-5 | Paolo |
| 1793 | 109.1.2.1 | PDTCH/TCH in 45.003 | 155d | 2000-11-06 A | 2001-06-08 A | 100% | 2000-11-06 | 2001-06-08 | 155d | finish no earlier than 2001-06-08 | GP | 1240h | 1240h |  |  |  | Rel-5 | Paolo |
| 1794 | 109.1.2.2 | Control channels in 45.003 | 155d | 2000-11-06 A | 2001-06-08 A | 100% | 2000-11-06 | 2001-06-08 | 155d | finish no earlier than 2001-06-08 | GP | 1240h | 1240h |  |  |  | Rel-5 | Paolo |
| 1795 | 109.1.2.3 | Receiver performance in 45.005 for PDTCH/TCH and control channels | 280d | 2000-11-06 A | 2001-11-30 A | 100% | 2000-11-06 | 2001-11-30 | 280d | finish no earlier than 2001-11-30 | GP | 2240h | 2240h |  |  |  | Rel-5 | Paolo |
| 1796 | 109.2 | **Iu rg interface** | 430d | 2000-11-06 A | 2002-06-28 A | 100% | 2000-11-06 | 2002-06-28 | 430d |  | GP,RP | 39560h | 39560h | GER3GAL-Iurg | Ericsson | Frank Muller | Rel-5 | Paolo |
| 1797 | 109.2.1 | **Inter BSS interface** | 430d | 2000-11-06 A | 2002-06-28 A | 100% | 2000-11-06 | 2002-06-28 | 430d |  | GP,RP | 20640h | 20640h |  |  |  | Rel-5 | Paolo |
| 1798 | 109.2.1.1 | Identification of requirements for Inter BSS interface | 430d | 2000-11-06 A | 2002-06-28 A | 100% | 2000-11-06 | 2002-06-28 | 430d | finish no earlier than 2002-06-28 | GP | 3440h | 3440h |  |  |  | Rel-5 | Paolo |
| 1799 | 109.2.1.2 | Stage 2 for Inter BSS interface | 430d | 2000-11-06 A | 2002-06-28 A | 100% | 2000-11-06 | 2002-06-28 | 430d | finish no earlier than 2002-06-28 | GP | 3440h | 3440h |  |  |  | Rel-5 | Paolo |
| 1800 | 109.2.1.3 | Adoption of relevant parts from Iur - for Inter BSS interface | 430d | 2000-11-06 A | 2002-06-28 A | 100% | 2000-11-06 | 2002-06-28 | 430d | finish no earlier than 2002-06-28 | GP | 3440h | 3440h |  |  |  | Rel-5 | Paolo |
| 1801 | 109.2.1.4 | Complementation with GERAN specifics - for Inter BSS interface | 430d | 2000-11-06 A | 2002-06-28 A | 100% | 2000-11-06 | 2002-06-28 | 430d | finish no earlier than 2002-06-28 | GP | 3440h | 3440h |  |  |  | Rel-5 | Paolo |
| 1802 | 109.2.1.5 | Stage 3 for Inter BSS interface | 430d | 2000-11-06 A | 2002-06-28 A | 100% | 2000-11-06 | 2002-06-28 | 430d | finish no earlier than 2002-06-28 | GP | 3440h | 3440h |  |  |  | Rel-5 | Paolo |

Notes:
- 1773: AWS, Nokia, Ericsson, Nortel, Siemens, Vodafone
- 1774: AWS, Nokia, Ericsson, Nortel, Siemens, Vodafone
- 1775: -
- 1776: -
- 1777: -
- 1778: Responsible is GERAN; RAN WG2 help may be needed.
- 1779: -
- 1780: -
- 1781: -
- 1782: -
- 1783: -
- 1784: -
- 1785: -
- 1786: -
- 1787: -
- 1788: -
- 1789: -
- 1790: -
- 1791: -
- 1792: -
- 1793: -
- 1794: -
- 1795: -
- 1796: AWS, Nokia, Ericsson, Nortel, Siemens, Vodafone
- 1797: -
- 1798: -
- 1799: -
- 1800: -
- 1801: -
- 1802: -

| ID | WBS | Task | Duration | Start | Finish | Complete | Baseline start | Baseline finish | Baseline duration | Constraint | Resources | Work | Actual work | Text6 | Text8 | Text12 | Text1 | Text4 | Text5 |
| --- | --- | --- | --- | --- | --- | --- | --- | --- | --- | --- | --- | --- | --- | --- | --- | --- | --- | --- | --- |
| 1803 | 109.2.2 | **Inter BSS-RNS interface** | 430d | 2000-11-06 A | 2002-06-28 A | 100% | 2000-11-06 | 2002-06-28 | 430d |  | GP,RP | 15480h | 15480h | Rel-5 | Paolo |  |  |  |  |
| 1804 | 109.2.2.1 | Identification of requirements for Inter BSS-RNS interface | 430d | 2000-11-06 A | 2002-06-28 A | 100% | 2000-11-06 | 2002-06-28 | 430d | start no earlier than 2000-11-06 | GP,R3 | 3440h | 3440h | Rel-5 | Paolo |  |  |  |  |
| 1805 | 109.2.2.2 | Stage 2 for Inter BSS-RNS interface | 430d | 2000-11-06 A | 2002-06-28 A | 100% | 2000-11-06 | 2002-06-28 | 430d | finish no earlier than 2002-06-28 | GP,R3 | 3440h | 3440h | Rel-5 | Paolo |  |  |  |  |
| 1806 | 109.2.2.3 | Adoption of relevant parts from Iur - for Inter BSS-RNS interface | 430d | 2000-11-06 A | 2002-06-28 A | 100% | 2000-11-06 | 2002-06-28 | 430d | finish no earlier than 2002-06-28 | GP,R3 | 3440h | 3440h | Rel-5 | Paolo |  |  |  |  |
| 1807 | 109.2.2.4 | Complementation with GERAN specifics - for Inter BSS-RNS interface | 107.5d | 2002-01-30 A | 2002-06-28 A | 100% | 2002-01-30 | 2002-06-28 | 107.5d | finish no earlier than 2002-06-28 | GP,R3 | 860h | 860h | Rel-5 | Paolo |  |  |  |  |
| 1808 | 109.2.2.5 | Stage 3 for Inter BSS-RNS interface | 107.5d | 2002-01-30 A | 2002-06-28 A | 100% | 2002-01-30 | 2002-06-28 | 107.5d | finish no earlier than 2002-06-28 | GP,R3 | 860h | 860h | Rel-5 | Paolo |  |  |  |  |
| 1809 | 109.3 | **Voice over GERAN PS and CS concept** | 430d | 2000-11-06 A | 2002-06-28 A | 100% | 2000-11-06 | 2002-06-28 | 430d |  | GP,R3 | 18520h | 18520h | Rel-5 | Paolo |  |  |  |  |
| 1810 | 109.3.1 | Architecture for A, Iu cs and Iu ps | 430d | 2000-11-06 A | 2002-06-28 A | 100% | 2000-11-06 | 2002-06-28 | 430d | finish no earlier than 2002-06-28 | GP,R3 | 3440h | 3440h | Rel-5 | Paolo |  |  |  |  |
| 1811 | 109.3.2 | Transcoder position/operation | 115d | 2000-11-06 A | 2001-04-13 A | 100% | 2000-11-06 | 2001-04-13 | 115d | finish no earlier than 2001-04-13 | GP | 920h | 920h | Rel-5 | Paolo |  |  |  |  |
| 1812 | 109.3.3 | Handover for Voice over GERAN PS and CS | 430d | 2000-11-06 A | 2002-06-28 A | 100% | 2000-11-06 | 2002-06-28 | 430d | finish no earlier than 2002-06-28 | GP,R3 | 3440h | 3440h | Rel-5 | Paolo |  |  |  |  |
| 1813 | 109.3.4 | RTP payload | 430d | 2000-11-06 A | 2002-06-28 A | 100% | 2000-11-06 | 2002-06-28 | 430d | finish no earlier than 2002-06-28 | GP,R3 | 3440h | 3440h | Rel-5 | Paolo |  |  |  |  |
| 1814 | 109.3.5 | Codec renegotiation concept | 365d | 2000-11-06 A | 2002-03-29 A | 100% | 2000-11-06 | 2002-03-29 | 365d | finish no earlier than 2002-03-29 | GP,R3 | 2920h | 2920h | Rel-5 | Paolo |  |  |  |  |
| 1815 | 109.3.6 | LA | 115d | 2000-11-06 A | 2001-04-13 A | 100% | 2000-11-06 | 2001-04-13 | 115d | finish no earlier than 2001-04-13 | GP | 920h | 920h | Rel-5 | Paolo |  |  |  |  |
| 1816 | 109.4 | **Deleted - GERAN MS Conformance test for GERAN interface evolution** | 660d | 2001-06-11 A | 2003-12-19 A | 100% | 2001-06-11 | 2003-12-19 | 660d |  | GP | 10560h | 10560h | Rel-5 | Paolo | GP-17 |  |  |  |
| 1817 | 109.4.1 | Deleted - MS test for GERAN interface evolution | 660d | 2001-06-11 A | 2003-12-19 A | 100% | 2001-06-11 | 2003-12-19 | 660d | finish no earlier than 2003-12-19 | GP | 5280h | 5280h | Rel-5 | Paolo | GP-17 |  |  |  |
| 1818 | 109.5 | **GERAN BSS Conformance test for GERAN interface evolution** | 922d | 2000-06-08 A | 2003-12-19 A | 100% | 2000-06-08 | 2003-12-19 | 922d |  | GP | 14752h | 14752h | Rel-5 | Paolo |  |  |  |  |
| 1819 | 109.5.1 | Deleted - BSS test | 922d | 2000-06-08 A | 2003-12-19 A | 100% | 2000-06-08 | 2003-12-19 | 922d | finish no earlier than 2003-12-19 | GP | 7376h | 7376h | Rel-5 | Paolo | GP-17 |  |  |  |
| 1820 | 110 | **GERAN support for IMS** | 690d | 2000-05-01 A | 2002-12-20 A | 100% | 2000-05-01 | 2002-12-20 | 690d |  | GP | 35998.4h | 35998.4h | Rel-5 | Paolo |  | GERIMS | Nokia | Shkumbin Hamiti |
| 1821 | 110.1 | **GERAN Header adaptation** | 690d | 2000-05-01 A | 2002-12-20 A | 100% | 2000-05-01 | 2002-12-20 | 690d |  | GP,S2,RP | 12302.8h | 12302.8h | Rel-5 | Paolo |  | GERIMS-HEADAPT | Nokia | Shkumbin Hamiti |
| 1822 | 110.1.1 | Definition of compression and removal modes for PDCP protocol | 15.05d | 2000-05-01 A | 2000-06-09 A | 100% | 2000-05-01 | 2000-06-09 | 15.05d | finish no earlier than 2000-09-01 | GP,S2,RP | 120.4h | 120.4h | Rel-5 | Paolo |  |  |  |  |
| 1823 | 110.1.2 | Conceptual description in stage 2 | 393d | 2000-05-01 A | 2001-10-31 A | 100% | 2000-05-01 | 2001-10-31 | 393d | finish no earlier than 2001-10-31 | GP,S2,RP | 3144h | 3144h | Rel-5 | Paolo |  |  |  |  |
| 1824 | 110.1.3 | Necessary changes on stage 3 regarding header removal | 439.8d | 2000-11-06 A | 2002-12-20 A | 100% | 2000-11-06 | 2002-12-20 | 439.8d | finish no earlier than 2002-12-20 | GP,S2,RP | 3518.4h | 3518.4h | Rel-5 | Paolo |  |  |  |  |
| 1825 | 110.2 | **Deleted - GERAN Radio access bearer design for IMS** | 430d | 2000-11-06 A | 2002-06-28 A | 100% | 2000-11-06 | 2002-06-28 | 430d |  | GP,S2,RP | 9287.6h | 9287.6h | Rel-5 | Paolo | GP-10 | GERIMS-RABDES | Nokia | Shkumbin Hamiti |
| 1826 | 110.2.1 | **Deleted - MuM control signalling for conversational multimedia services** | 430d | 2000-11-06 A | 2002-06-28 A | 100% | 2000-11-06 | 2002-06-28 | 430d |  | GP,S2,RP | 5847.6h | 5847.6h | Rel-5 | Paolo | GP-10 |  |  |  |
| 1827 | 110.2.1.1 | Deleted - Identification of requirements for MuM control signalling for conversational multimedia services | 330d | 2000-11-06 A | 2002-02-08 A | 100% | 2000-11-06 | 2002-02-08 | 330d | finish no earlier than 2002-02-08 | GP,S2,RP | 2640h | 2640h | Rel-5 | Paolo | GP-08 |  |  |  |
| 1828 | 110.2.1.2 | Deleted - Necessary modifications due to SIP | 40d | 2002-05-06 A | 2002-06-28 A | 100% | 2002-05-06 | 2002-06-28 | 40d | finish no earlier than 2002-06-28 | GP,S2,RP | 320h | 320h | Rel-5 | Paolo | GP-10 |  |  |  |

Notes:
- 1803: -
- 1804: -
- 1805: -
- 1806: -
- 1807: -
- 1808: -
- 1809: -
- 1810: -
- 1811: -
- 1812: -
- 1813: -
- 1814: -
- 1815: -
- 1816: Not started. Marked as stopped 12/2008
- 1817: Not started. Marked as stopped 12/2008
- 1818: Not started. Marked as stopped 12/2008
- 1819: Not started. Marked as stopped 12/2008
- 1820: AWS, Nokia, Ericsson, Nortel, Siemens, Motorola
- 1821: AWS, Nokia, Ericsson, Nortel, Siemens, Motorola
- 1822: -
- 1823: -
- 1824: -
- 1825: TERMINATED - NOT STANDARDIZED. Marked as stopped 12/2008
- 1826: TERMINATED - NOT STANDARDIZED. Marked as stopped 12/2008
- 1827: TERMINATED - NOT STANDARDIZED
- 1828: TERMINATED - NOT STANDARDIZED

| ID | WBS | Task | Duration | Start | Finish | Complete | Baseline start | Baseline finish | Baseline duration | Constraint | Resources | Work | Actual work | Text1 | Text4 | Text5 | Text6 | Text8 | Text12 | Text3 |
| --- | --- | --- | --- | --- | --- | --- | --- | --- | --- | --- | --- | --- | --- | --- | --- | --- | --- | --- | --- | --- |
| 1829 | 110.3 | **Deleted - GERAN MS Conformance test for support of IMS** | 400d | 2001-06-11 A | 2002-12-20 A | 100% | 2001-06-11 | 2002-12-20 | 400d |  | GP | 6400h | 6400h | GERIMS-MSconf | Nokia | Shkumbin Hamiti | Rel-5 | Paolo | GP-12 |  |
| 1830 | 110.3.1 | Deleted - MS test for support of IMS | 400d | 2001-06-11 A | 2002-12-20 A | 100% | 2001-06-11 | 2002-12-20 | 400d | finish no earlier than 2002-12-20 | G4 | 3200h | 3200h |  |  |  | Rel-5 | Paolo | GP-12 |  |
| 1831 | 110.4 | Deleted - GERAN BTS Conformance test for support of IMS | 400d | 2001-06-11 A | 2002-12-20 A | 100% | 2001-06-11 | 2002-12-20 | 400d |  | GP | 3200h | 3200h | GERIMS-BTSconf | Nokia | Shkumbin Hamiti | Rel-5 | Paolo | GP-12 |  |
| 1832 | 614 | MS Conformance Testing of Dual Transfer Mode | 65d? | 2002-11-11 A | 2003-02-07 A | 100% | 2002-11-11 | 2003-02-07 | 65d? | finish no earlier than 2003-02-07 | G4,G5 | 520h | 520h | MSCTDTM | Vodafone | Dave Fox | Rel-5 | Paolo |  |  |
| 1833 | 615 | **Handling of early Ues** | 911d? | 2000-01-03 A | 2003-06-27 A | 100% | 2000-01-03 | 2003-06-27 | 911d? |  | S2 | 4488h | 4488h | LATE_UE |  |  | Rel-5 | Maurice |  |  |
| 1834 | 615.1 | Feasibility Study on Handling of early Ues | 50d? | 2002-10-07 A | 2002-12-13 A | 100% | 2002-10-07 | 2002-12-13 | 50d? | finish no earlier than 2002-12-13 | S2 | 400h | 400h |  |  |  | Rel-5 | Maurice |  |  |
| 1835 | 615.2 | Stage 2 for Handling of early Ues | 125d? | 2003-01-06 A | 2003-06-27 A | 100% | 2003-01-06 | 2003-06-27 | 125d? | start no earlier than 2003-01-06 | S2 | 1000h | 1000h |  |  |  | Rel-5 | Maurice |  |  |
| 1836 | 615.3 | FS for the Early Mobile Handling in UTRAN | 195d | 2002-09-09 A | 2003-06-06 A | 100% | 2002-09-09 | 2003-06-06 | 195d | finish no earlier than 2003-06-06 | R2 | 1560h | 1560h | FSEarlyUE | Vodafone | alan.law@vodafone.com | Rel-5 | Joern |  |  |
| 1837 | 615.4 | Note: Stage 3 RAN part not shown | 1d | 2000-01-03 A | 2000-01-03 A | 100% | 2000-01-03 | 2000-01-03 | 1d |  | RP | 8h | 8h |  |  |  | Rel-5 |  |  |  |
| 1838 | 616 | Release 4 Features | 326d? | 2000-01-03 A | 2001-03-30 A | 100% | 2000-01-03 | 2001-03-30 | 326d? |  | NP,GP, RP,SP,TP | 2608h | 2608h |  |  |  | Rel-4 | All |  |  |
| 1839 | 15 | **Miscellaneous UE Conformance Testing Activities** | 958d | 2001-04-02 A | 2004-12-01 A | 100% | 2001-04-02 | 2004-12-01 | 958d |  | T1 | 36360h | 36360h | MISTST1 |  |  | Rel-4 | Ingbert |  |  |
| 1840 | 15.1 | Optimization of Test Time, RF Aspects (FDD) | 508d | 2001-09-24 A | 2003-09-03 A | 100% | 2001-09-24 | 2003-09-03 | 508d | finish no earlier than 2003-09-03 | T1 | 4064h | 4064h | MISTST1-OpFDD |  |  | Rel-4 | Ingbert |  | 34.121 |
| 1841 | 15.2 | Optimization of Test Time, RF Aspects (TDD) | 508d | 2001-09-24 A | 2003-09-03 A | 100% | 2001-09-24 | 2003-09-03 | 508d | finish no earlier than 2003-09-03 | T1 | 4064h | 4064h | MISTST1-OpTDD |  |  | Rel-4 | Ingbert |  | 34.122 |
| 1842 | 15.3 | Extensions to R99 Test cases | 139.4w | 2001-04-02 A | 2003-12-02 A | 100% | 2001-04-02 | 2003-12-02 | 139.4w | finish no earlier than 2003-12-02 | T1 | 5576h | 5576h | MISTST1-Ext |  |  | Rel-4 | Ingbert |  | 34.123 p 1,2 |
| 1843 | 15.4 | Extension to R99 Test cases - TTCN | 439d | 2002-06-28 A | 2004-03-03 A | 100% | 2002-06-28 | 2004-03-03 | 439d | finish no earlier than 2004-03-03 | T1 | 3512h | 3512h |  |  |  | Rel-4 | Ingbert |  |  |
| 1844 | 15.5 | Creation of R99 TCs for TDD - prose | 719d | 2001-10-01 A | 2004-07-01 A | 100% | 2001-10-01 | 2004-07-01 | 719d | finish no earlier than 2004-07-01 | T1 | 5752h | 5752h | MISTST1-TDD |  |  | Rel-4 | Ingbert |  | 34.123-1 |
| 1845 | 15.6 | Deleted - Creation of R99 TCs for TDD - TTCN | 587d | 2002-09-03 A | 2004-12-01 A | 100% | 2002-09-03 | 2004-12-01 | 587d | finish no earlier than 2004-12-01 | T1 | 4696h | 4696h |  |  |  | Rel-4 | Ingbert | TP-26 |  |
| 1846 | 15.7 | Deleted - Review all other work items for impact on new or exiting 34 series specs. | 25.8w | 2002-07-02 A | 2002-12-27 A | 100% | 2002-07-02 | 2002-12-27 | 25.8w | finish no earlier than 2002-12-27 | T1 | 1032h | 1032h | MISTST1 |  |  | Rel-4 | Ingbert | TP-18 | 34.121,122,123,125 |
| 1847 | 47 | Transparent End-to-End PS mobile streaming application | 253d | 2000-04-03 A | 2001-03-21 A | 100% | 2000-04-03 | 2001-03-21 | 253d | finish no earlier than 2000-12-29 | S4 | 2024h | 2024h | PSTREAM |  |  | Rel-4 | Paolo |  | 26.233, 26.234 |
| 1848 | 49 | **Transcoder-Free Operation** | 326d | 2000-01-03 A | 2001-03-30 A | 100% | 2000-01-03 | 2001-03-30 | 326d |  | N4,S2,N1 | 10448h | 10448h | TrFO |  |  | Rel-4 | Kimmo |  |  |
| 1849 | 49.1 | **Out-of-Band Transcoder Control solution** | 326d | 2000-01-03 A | 2001-03-30 A | 100% | 2000-01-03 | 2001-03-30 | 326d |  | N4 | 8448h | 8448h | TrFO-OoBTC | NEC | Toshiyuki Tamura (tamurato@aj.jp.nec.com) | Rel-4 | Kimmo |  |  |
| 1850 | 49.1.1 | implementation in UTRAN | 145d | 2000-09-11 A | 2001-03-30 A | 100% | 2000-09-11 | 2001-03-30 | 145d | finish no earlier than 2001-03-30 | R3 | 1160h | 1160h | TrFO-OoBTC-UTRAN | Siemens | Alexander Vesely | Rel-4 | Juha |  | 25.401, 25.410, 25.413, 25.415, 23.153 |
| 1851 | 49.1.2 | Impact on architecture, Principles and Terminology | 211d | 2000-01-03 A | 2000-10-20 A | 100% | 2000-01-03 | 2000-10-20 | 211d | finish no earlier than 2000-10-20 | S2 | 1680h | 1680h | TrFO-OoBTC |  |  | Rel-4 | Maurice |  |  |
| 1852 | 49.1.3 | Codec Negotiation between UE and MSC | 125d | 2000-08-14 A | 2001-02-02 A | 100% | 2000-08-14 | 2001-02-02 | 125d | finish no earlier than 2001-02-02 | N1 | 1000h | 1000h | TrFO-OoBTC | Motorola | Andrew Howell | Rel-4 | Frederic |  | 24.008, 23.009, 23.108, (29.002) |
| 1853 | 49.1.4 | Codec Negotiation inter MSC | 125d | 2000-07-03 A | 2000-12-22 A | 100% | 2000-07-03 | 2000-12-22 | 125d | finish no earlier than 2000-12-22 | N4 | 1000h | 1000h | TrFO-OoBTC |  |  | Rel-4 | Kimmo |  |  |
| 1854 | 49.1.5 | Bearer establishment inter MSC | 125d | 2000-07-03 A | 2000-12-22 A | 100% | 2000-07-03 | 2000-12-22 | 125d | finish no earlier than 2000-12-22 | N4 | 1000h | 1000h | TrFO-OoBTC |  |  | Rel-4 | Kimmo |  | 23.153 |

Notes:
- 1829: TERMINATED - NOT STANDARDIZED. Marked as stopped 12/2008
- 1830: TERMINATED - NOT STANDARDIZED. Marked as stopped 12/2008
- 1831: TERMINATED - NOT STANDARDIZED. Marked as stopped 12/2008
- 1832: Needed to complete DTM (R99)
- 1833: -
- 1834: -
- 1835: -
- 1836: -
- 1837: -
- 1838: -
- 1839: -
- 1840: It is believed that the current R99 test spec. can be optimised for faster overall test times. Marked as stopped 12/2008 (was 70% complete)
- 1841: It is believed that the current R99 test spec. can be optimised for faster overall test times
- 1842: Further test coverage of the R99 specification to cover supplementry services. Marked as stopped 12/2008 (was 70% complete)
- 1843: Marked as closed 12/2008 (was marked 50% complete)
- 1844: Marked as closed 12/2008 (was marked 50% complete)
- 1845: Marked as stopped 12/2008
- 1846: Marked as stopped 12/2008
- 1847: -
- 1848: Lead given to CN4 from CN / [DAB 28/11/00]
- 1849: -
- 1850: moved according to NP-000575
- 1851: e.g. study cascading TrFO/TFO/TrFO
- 1852: the link to NP-000085has been deleted because refering to a R99 status sheet / One common set of codec negotiation procedures will be specified as in ID1656.
- 1853: Bearer establishment inter MSC. TS 23.153 R99 part complete. capabilities moved to annex + list of open issues
- 1854: Bearer establishment inter MSC. TS 23.153 R99 part complete. capabilities moved to annex. / See NP-000127 / Open issues: / Handling of Conference Calls; / Handling of Multi Party Supplementary Services; / Handling of Handover UMTS to GSM; / Handling of Sending a ...

| ID | WBS | Task | Duration | Start | Finish | Complete | Baseline start | Baseline finish | Baseline duration | Constraint | Resources | Work | Actual work | Text1 | Text6 | Text8 | Text4 | Text5 |
| --- | --- | --- | --- | --- | --- | --- | --- | --- | --- | --- | --- | --- | --- | --- | --- | --- | --- | --- |
| 1855 | 49.2 | **Speech Transcoder: Location and Control at the UMTS Core Network Border** | 125d | 2000-04-10 A | 2000-09-29 A | 100% | 2000-04-10 | 2000-09-29 | 125d |  | S2 | 2000h | 2000h | TrFO-STLC | Rel-4 | Maurice |  |  |
| 1856 | 49.2.1 | Transcoder at Edge | 125d | 2000-04-10 A | 2000-09-29 A | 100% | 2000-04-10 | 2000-09-29 | 125d | finish no earlier than 2000-09-29 | NP | 1000h | 1000h | TrFO-STLC | Rel-4 | Kimmo |  |  |
| 1857 | 50 | **GERAN improvements 1 (Gb over IP)** | 225d | 2000-05-09 A | 2001-03-19 A | 100% | 2000-05-09 | 2001-03-19 | 225d |  | GP | 6472h | 6472h | GEIMP1 | Rel-4 | Paolo |  |  |
| 1858 | 50.1 | **Gb over IP (Ip-fication of Gb)** | 225d | 2000-05-09 A | 2001-03-19 A | 100% | 2000-05-09 | 2001-03-19 | 225d |  | GP | 4672h | 4672h | GbIP | Rel-4 | Paolo |  |  |
| 1859 | 50.1.1 | Concept of Gb over IP (Ip-fication of Gb) | 134d | 2000-05-09 A | 2000-11-10 A | 100% | 2000-05-09 | 2000-11-10 | 134d |  | GP | 1072h | 1072h |  | Rel-4 | Paolo |  |  |
| 1860 | 50.1.2 | Changes to 08.16, 08.18 | 225d | 2000-05-09 A | 2001-03-19 A | 100% | 2000-05-09 | 2001-03-19 | 225d |  | GP | 1800h | 1800h |  | Rel-4 | Paolo |  |  |
| 1861 | 51 | **GERAN improvements 2 (NACC)** | 677d | 2000-11-06 A | 2003-06-10 A | 100% | 2000-11-06 | 2003-06-10 | 677d |  | GP | 19224h | 19224h | GEIMP2 | Rel-4 | Paolo |  |  |
| 1862 | 51.1 | **Gb enhancements** | 155d | 2000-11-06 A | 2001-06-08 A | 100% | 2000-11-06 | 2001-06-08 | 155d |  | GP | 7440h | 7440h | Gben | Rel-4 | Paolo |  |  |
| 1863 | 51.1.1 | **Intra BSC NACC (Network Assisted Cell Change)** | 155d | 2000-11-06 A | 2001-06-08 A | 100% | 2000-11-06 | 2001-06-08 | 155d |  | GP | 6200h | 6200h |  | Rel-4 | Paolo |  |  |
| 1864 | 51.1.1.1 | Concept | 155d | 2000-11-06 A | 2001-06-08 A | 100% | 2000-11-06 | 2001-06-08 | 155d | finish no earlier than 2001-06-08 | GP | 1240h | 1240h |  | Rel-4 | Paolo |  |  |
| 1865 | 51.1.1.2 | Changes in 03.64 | 155d | 2000-11-06 A | 2001-06-08 A | 100% | 2000-11-06 | 2001-06-08 | 155d | finish no earlier than 2001-06-08 | GP | 1240h | 1240h |  | Rel-4 | Paolo |  |  |
| 1866 | 51.1.1.3 | Changes in 04.60 | 155d | 2000-11-06 A | 2001-06-08 A | 100% | 2000-11-06 | 2001-06-08 | 155d | finish no earlier than 2001-06-08 | GP | 1240h | 1240h |  | Rel-4 | Paolo |  |  |
| 1867 | 51.1.1.4 | Changes in 44.008 | 155d | 2000-11-06 A | 2001-06-08 A | 100% | 2000-11-06 | 2001-06-08 | 155d | finish no earlier than 2001-06-08 | GP | 1240h | 1240h |  | Rel-4 | Paolo |  |  |
| 1868 | 51.3 | **MS conformance test for Intra BSC NACC** | 398d | 2001-11-30 A | 2003-06-10 A | 100% | 2001-11-30 | 2003-06-10 | 398d |  | GP | 6368h | 6368h | GEIMP2-Msconf | Rel-4 | Paolo |  |  |
| 1869 | 51.3.1 | Changes in 51.010 | 398d | 2001-11-30 A | 2003-06-10 A | 100% | 2001-11-30 | 2003-06-10 | 398d | finish no earlier than 2003-12-19 | G5,G4 | 3184h | 3184h |  | Rel-4 | Paolo |  |  |
| 1870 | 52 | **GERAN improvements 4 (Delayed TBF)** | 105d | 2001-01-15 A | 2001-06-08 A | 100% | 2001-01-15 | 2001-06-08 | 105d |  | GP | 3960h | 3960h | GEIMP4 | Rel-4 | Paolo |  |  |
| 1871 | 52.1 | **Gb enhancements 2** | 105d | 2001-01-15 A | 2001-06-08 A | 100% | 2001-01-15 | 2001-06-08 | 105d |  | GP | 3120h | 3120h | GEIMP4-Gben2 | Rel-4 | Paolo |  |  |
| 1872 | 52.1.1 | Stage 2 for Gb enhancements 2 | 105d | 2001-01-15 A | 2001-06-08 A | 100% | 2001-01-15 | 2001-06-08 | 105d | finish no earlier than 2001-06-08 | GP | 840h | 840h |  | Rel-4 | Paolo |  |  |
| 1873 | 52.1.2 | **Stage 3 (changes in 44.060)** | 60d | 2001-01-15 A | 2001-04-06 A | 100% | 2001-01-15 | 2001-04-06 | 60d |  | G2 | 1440h | 1440h |  | Rel-4 | Gert |  |  |
| 1874 | 52.1.2.1 | Definition of enhanced countdown procedure | 60d | 2001-01-15 A | 2001-04-06 A | 100% | 2001-01-15 | 2001-04-06 | 60d | finish no earlier than 2001-04-06 | G2 | 480h | 480h |  | Rel-4 | Gert |  |  |
| 1875 | 52.1.2.2 | Definition of enhanced TBF release procedure | 60d | 2001-01-15 A | 2001-04-06 A | 100% | 2001-01-15 | 2001-04-06 | 60d | finish no earlier than 2001-04-06 | G2 | 480h | 480h |  | Rel-4 | Gert |  |  |
| 1876 | 52.1.2.3 | Definition of USF=FREE type polling mechanism on PDCH | 60d | 2001-01-15 A | 2001-04-06 A | 100% | 2001-01-15 | 2001-04-06 | 60d | finish no earlier than 2001-04-06 | G2 | 480h | 480h |  | Rel-4 | Gert |  |  |
| 1877 | 53 | **Low Chip Rate TDD option** | 880d | 2000-07-19 A | 2003-12-02 A | 100% | 2000-07-19 | 2003-12-02 | 880d |  | R1 | 27488h | 27488h | LCRTDD | Rel-4 | Patrick | CWTS | G. Yang |
| 1878 | 53.1 | Physical layer for Low Chip Rate TDD option | 183d | 2000-07-19 A | 2001-03-30 A | 100% | 2000-07-19 | 2001-03-30 | 183d | finish no earlier than 2001-03-30 | R1 | 1464h | 1464h | LCRTDD-Phys | Rel-4 | Patrick | CWTS | G. Yang |
| 1879 | 53.2 | Layer 2 and layer 3 protocol aspects | 183d | 2000-07-19 A | 2001-03-30 A | 100% | 2000-07-19 | 2001-03-30 | 183d | finish no earlier than 2001-03-30 | R2 | 1464h | 1464h | LCRTDD-L23 | Rel-4 | Joern | CWTS | Y. Liu |
| 1880 | 53.3 | RF radio transmission/reception, system performance requirements and conformance testing | 165d | 2000-08-14 A | 2001-03-30 A | 100% | 2000-08-14 | 2001-03-30 | 165d | finish no earlier than 2001-03-30 | R4 | 1320h | 1320h | LCRTDD-RF | Rel-4 | Issam | CWTS | D. Zhang |
| 1881 | 53.4 | UE radio access capability | 165d | 2000-08-14 A | 2001-03-30 A | 100% | 2000-08-14 | 2001-03-30 | 165d | finish no earlier than 2001-03-30 | R2 | 1320h | 1320h | LCRTDD-UErac | Rel-4 | Joern | CWTS | Y. Liu |
| 1882 | 53.5 | Iub/Iur protocol aspects - for Low Chip Rate TDD option | 165d | 2000-08-14 A | 2001-03-30 A | 100% | 2000-08-14 | 2001-03-30 | 165d | finish no earlier than 2001-03-30 | R3 | 1320h | 1320h | LCRTDD-IubIur | Rel-4 | Juha | CWTS | Y. Liu |

Notes:
- 1855: WI description and Tdoc S2-99352 / Speech Transcoder: Location and Control at the UMTS Core Network Border
- 1856: WI description and Tdoc S2-99352...
- 1857: -
- 1858: -
- 1859: -
- 1860: -
- 1861: -
- 1862: -
- 1863: -
- 1864: -
- 1865: -
- 1866: -
- 1867: -
- 1868: -
- 1869: az 05/08: duplicated UID_50099 => 50299. Marked as closed 12/2008 (was marked 50% complete)
- 1870: -
- 1871: -
- 1872: -
- 1873: -
- 1874: -
- 1875: -
- 1876: -
- 1877: -
- 1878: -
- 1879: -
- 1880: -
- 1881: -
- 1882: -

| ID | WBS | Task | Duration | Start | Finish | Predecessors | Complete | Baseline start | Baseline finish | Baseline duration | Constraint | Resources | Work | Actual work | Text6 | Text8 | Text3 | Text12 | Text1 | Text4 | Text5 |
| --- | --- | --- | --- | --- | --- | --- | --- | --- | --- | --- | --- | --- | --- | --- | --- | --- | --- | --- | --- | --- | --- |
| 1883 | 53.6 | **Low chiprate TDD interworking with GERAN** | 101d | 2000-09-01 A | 2001-01-19 A | 1882 | 100% | 2000-09-01 | 2001-01-19 | 101d |  | GP | 1616h | 1616h | Rel-4 | Paolo |  |  |  |  |  |
| 1884 | 53.6.1 | Handover and Cell Selection / Reselection to UTRA 1.28 Mcps TDD | 101d | 2000-09-01 A | 2001-01-19 A |  | 100% | 2000-09-01 | 2001-01-19 | 101d | finish no earlier than 2001-01-19 | GP | 808h | 808h | Rel-4 | Paolo |  |  |  |  |  |
| 1885 | 53.8 | **Conformance Test Aspects - Low Chip Rate TDD** | 577d | 2001-09-17 A | 2003-12-02 A | 1883 | 100% | 2001-09-17 | 2003-12-02 | 577d |  | T1 | 12088h | 12088h | Rel-4 | Ingbert |  |  |  |  |  |
| 1886 | 53.8.1 | Testing Layer 2 and layer 3 protocol aspects | 468d | 2001-09-17 A | 2003-07-02 A |  | 100% | 2001-09-17 | 2003-07-02 | 468d | finish no earlier than 2003-07-02 | T1 | 3744h | 3744h | Rel-4 | Ingbert | 34.123-1, 34.123-2 |  |  |  |  |
| 1887 | 53.8.2 | Deleted - Testing Layer 2 and layer 3 protocol aspects - TTCN | 261d | 2002-12-03 A | 2003-12-02 A |  | 100% | 2002-12-03 | 2003-12-02 | 261d | finish no earlier than 2003-12-02 | T1 | 2088h | 2088h | Rel-4 | Ingbert | 34.123-3 | TP-22 |  |  |  |
| 1888 | 53.8.3 | Testing RF Radio Transmission and Reception | 205d | 2001-09-17 A | 2002-06-28 A |  | 100% | 2001-09-17 | 2002-06-28 | 205d | finish no earlier than 2002-06-28 | T1 | 1640h | 1640h | Rel-4 | Ingbert |  |  |  |  |  |
| 1889 | 54 | **Enable bearer independent CS architecture** | 566d | 2000-01-03 A | 2002-03-01 A |  | 100% | 2000-01-03 | 2002-03-01 | 566d |  | S2,N3,N4 | 18952h | 18952h | Rel-4 | Maurice |  |  | CSSPLIT | Siemens | Alexander Milinski |
| 1890 | 54.1 | **Enable bearer-independent call control** | 425d | 2000-01-03 A | 2001-08-16 A |  | 100% | 2000-01-03 | 2001-08-16 | 425d |  | N4 | 12344h | 12344h | Rel-4 | Kimmo |  |  | CSSPLIT | Ericsson | Heinz-Peter.Keutmann@eed.ericsson.se |
| 1891 | 54.1.1 | Architecture and Stage 2 description | 181d | 2000-01-03 A | 2000-09-08 A |  | 100% | 2000-01-03 | 2000-09-08 | 181d | finish no earlier than 2000-09-08 | S2 | 1440h | 1440h | Rel-4 | Maurice | 23.002 |  | CSSPLIT |  |  |
| 1892 | 54.1.2 | Standardisation of protocols (control & user planes) over Nb interface | 64d | 2001-01-02 A | 2001-03-30 A |  | 100% | 2001-01-02 | 2001-03-30 | 64d | finish no earlier than 2001-03-30 | N3 | 512h | 512h | Rel-4 | Gwiho |  |  | CSSPLIT |  |  |
| 1893 | 54.1.3 | Standardisation of protocols over reference points between MSC server and Gateway MSC server | 130d | 2000-09-25 A | 2001-03-23 A |  | 100% | 2000-09-25 | 2001-03-23 | 130d | finish no earlier than 2001-03-23 | N4 | 1040h | 1040h | Rel-4 | Kimmo |  |  | CSSPLIT |  |  |
| 1894 | 54.1.4 | Standardisation of detailed stage 2 description | 180d | 2000-07-17 A | 2001-03-23 A |  | 100% | 2000-07-17 | 2001-03-23 | 180d | finish no earlier than 2001-03-23 | N4 | 1440h | 1440h | Rel-4 | Kimmo |  |  | CSSPLIT |  |  |
| 1895 | 54.1.5 | **Bearer control between MSC server and MGW** | 250d | 2000-09-01 A | 2001-08-16 A |  | 100% | 2000-09-01 | 2001-08-16 | 250d |  | N4 | 4512h | 4512h | Rel-4 | Kimmo |  |  | CSSPLIT |  |  |
| 1896 | 54.1.5.1 | stage 3 - protocol issues | 250d | 2000-09-01 A | 2001-08-16 A |  | 100% | 2000-09-01 | 2001-08-16 | 250d | finish no earlier than 2001-08-16 | N4 | 2000h | 2000h | Rel-4 | Kimmo |  |  |  |  |  |
| 1897 | 54.1.5.2 | stage 3 - parameter value issues | 64d | 2001-01-02 A | 2001-03-30 A |  | 100% | 2001-01-02 | 2001-03-30 | 64d | finish no earlier than 2001-03-30 | N3 | 512h | 512h | Rel-4 | Gwiho |  |  |  |  |  |
| 1898 | 54.4 | Deleted - Conformance Test Aspects - Enable bearer independent CS architecture | 260d | 2001-03-05 A | 2002-03-01 A |  | 100% | 2001-03-05 | 2002-03-01 | 260d |  | T1 | 2080h | 2080h | Rel-4 | Ingbert |  | TP-15 | CSSPLIT-TEST |  |  |
| 1899 | 55 | **MExE enhancements Rel-4** | 511d | 2000-01-03 A | 2001-12-14 A |  | 100% | 2000-01-03 | 2001-12-14 | 511d |  | T2,S3 | 19032h | 19032h | Rel-4 | Kimmo |  |  | MEXE |  |  |
| 1900 | 55.1 | **MExE Security Analysis Activity** | 474d | 2000-02-22 A | 2001-12-14 A |  | 100% | 2000-02-22 | 2001-12-14 | 474d |  | S3,T2 | 8464h | 8464h | Rel-4 | Dionisio |  |  | MEXE-SEC | BT | Andrew.Myers@bt.com |
| 1901 | 55.1.1 | Stage 3 for MExE Security | 370d | 2000-07-17 A | 2001-12-14 A |  | 100% | 2000-07-17 | 2001-12-14 | 370d | finish no earlier than 2001-12-14 | S3 | 2960h | 2960h | Rel-4 | Dionisio | 21.133, 33.102 |  | MEXE-SEC | BT | Andrew.Myers@bt.com |
| 1902 | 55.1.2 | Terminal aspects for MExE Security | 214d | 2000-02-22 A | 2000-12-15 A |  | 100% | 2000-02-22 | 2000-12-15 | 214d | finish no earlier than 2000-12-15 | T2 | 1712h | 1712h | Rel-4 |  | 23.057 |  | MEXE-SEC | BT | Andrew.Myers@bt.com |
| 1903 | 55.2 | **MExE Rel4 Improvements and Investigations** | 251d | 2000-01-03 A | 2000-12-15 A |  | 100% | 2000-01-03 | 2000-12-15 | 251d |  | T2 | 6480h | 6480h | Rel-4 | Kimmo | 22.057, 23.057 |  | MEXE-ENHANC | Motorola | Mark Cataldo |
| 1904 | 55.2.1 | 3rd MExE classmark | 251d | 2000-01-03 A | 2000-12-15 A |  | 100% | 2000-01-03 | 2000-12-15 | 251d | finish no earlier than 2000-12-15 | T2 | 2000h | 2000h | Rel-4 | Kimmo | 22.057, 23.057 |  |  | Motorola | Mark Cataldo |
| 1905 | 55.2.2 | FS on Secure download mechanism and capabilities to support SDR concepts | 225d | 2000-02-07 A | 2000-12-15 A |  | 100% | 2000-02-07 | 2000-12-15 | 225d | finish no earlier than 2000-12-15 | T2 | 1800h | 1800h | Rel-4 | Kimmo | 22.057, 23.057 |  |  | Motorola | Mark Cataldo |
| 1906 | 55.2.3 | FS on Support of MP3/MPEG4 content | 225d | 2000-02-07 A | 2000-12-15 A |  | 100% | 2000-02-07 | 2000-12-15 | 225d | finish no earlier than 2000-12-15 | T2 | 1800h | 1800h | Rel-4 | Kimmo | 22.057, 23.057 |  |  | Motorola | Mark Cataldo |

Notes:
- 1883: -
- 1884: -
- 1885: -
- 1886: Marked as closed 12/2008 (was marked 60% complete)
- 1887: Marked as stopped 12/2008
- 1888: duration set to 6 months (was 0), finish date set
- 1889: -
- 1890: DAB 12.12.01 should be 100% hence closed
- 1891: R00 stage 2 at least 80 % complete in TSGS #8 21.-23.6.2000
- 1892: -
- 1893: -
- 1894: -
- 1895: -
- 1896: -
- 1897: -
- 1898: Marked as stopped 12/2008
- 1899: -
- 1900: SP#12 updated WID
- 1901: -
- 1902: -
- 1903: -
- 1904: Additional features for MExE R2000
- 1905: -
- 1906: -

| ID | WBS | Task | Duration | Start | Finish | Complete | Baseline start | Baseline finish | Baseline duration | Constraint | Resources | Work | Actual work | Text1 | Text6 | Text8 | Text3 | Text4 | Text5 |
| --- | --- | --- | --- | --- | --- | --- | --- | --- | --- | --- | --- | --- | --- | --- | --- | --- | --- | --- | --- |
| 1907 | 56 | **Tandem Free aspects for 3G and between 2G and 3G systems** | 344d | 2000-02-22 A | 2001-06-15 A | 100% | 2000-02-22 | 2001-06-15 | 344d |  | S4 | 9696h | 9696h | TFO | Rel-4 | Paolo |  |  |  |
| 1908 | 56.1 | **Tandem Free AMR** | 344d | 2000-02-22 A | 2001-06-15 A | 100% | 2000-02-22 | 2001-06-15 | 344d |  | S4 | 6944h | 6944h | TFO-AMR | Rel-4 | Paolo |  |  |  |
| 1909 | 56.1.1 | Specification of Tandem Free AMR | 284d | 2000-02-22 A | 2001-03-23 A | 100% | 2000-02-22 | 2001-03-23 | 284d | start no earlier than 2000-02-22 | S4 | 2272h | 2272h |  | Rel-4 | Paolo | 28.062 |  |  |
| 1910 | 56.1.2 | **Impact of Tandem Free AMR on:** | 115d | 2001-01-08 A | 2001-06-15 A | 100% | 2001-01-08 | 2001-06-15 | 115d |  | NP | 1920h | 1920h |  | Rel-4 | Kimmo |  |  |  |
| 1911 | 56.1.2.1 | CN | 60d | 2001-03-26 A | 2001-06-15 A | 100% | 2001-03-26 | 2001-06-15 | 60d | finish no earlier than 2001-06-15 | NP | 480h | 480h |  | Rel-4 | Kimmo |  |  |  |
| 1912 | 56.1.2.2 | GERAN | 65d | 2001-01-08 A | 2001-04-06 A | 100% | 2001-01-08 | 2001-04-06 | 65d | finish no earlier than 2001-04-06 | GP | 520h | 520h |  | Rel-4 | Paolo |  |  |  |
| 1913 | 57 | **Advanced Speech Call Items enhancements_Rel-4** | 334d | 2000-12-03 A | 2002-03-14 A | 100% | 2000-12-03 | 2002-03-14 | 334d |  | N1 | 5925.6h | 5925.6h | ASCI | Rel-4 | Frederic |  | Nortel | sonia.garapaty@nortelnetworks.com |
| 1914 | 57.1 | Stage 2 for Advanced Speech Call Items enhancements_Rel-4 (ASCI) | 326.7d | 2000-12-03 A | 2002-03-14 A | 100% | 2000-12-03 | 2002-03-14 | 326.7d | finish no earlier than 2002-03-14 | N4 | 2613.6h | 2613.6h |  | Rel-4 | Kimmo | 23.067, 24.067 | Sagem | Vivien Perlic |
| 1915 | 57.2 | Stages 2 and 3 on A interface | 80d | 2000-12-03 A | 2001-03-23 A | 100% | 2000-12-03 | 2001-03-23 | 80d | finish no earlier than 2001-03-23 | N1 | 640h | 640h |  | Rel-4 | Frederic | 44.068, 44.069, 24.008 | Nortel | sonia.garapaty@nortelnetworks.com |
| 1916 | 58 | **700 MHz spectrum support** | 776d | 2000-01-03 A | 2002-12-20 A | 100% | 2000-01-03 | 2002-12-20 | 776d |  | GP | 20016h | 20016h | 700SS | Rel-4 | Paolo |  |  |  |
| 1917 | 58.1 | **GERAN support for the 700 MHz band** | 276d | 2000-01-03 A | 2001-01-19 A | 100% | 2000-01-03 | 2001-01-19 | 276d |  | GP | 8808h | 8808h |  | Rel-4 | Paolo |  |  |  |
| 1918 | 58.1.1 | Signalling support | 276d | 2000-01-03 A | 2001-01-19 A | 100% | 2000-01-03 | 2001-01-19 | 276d | finish no earlier than 2001-01-19 | GP | 2200h | 2200h |  | Rel-4 | Paolo |  |  |  |
| 1919 | 58.1.2 | Physical layer definitions - for GERAN support for the 700 MHz band | 276d | 2000-01-03 A | 2001-01-19 A | 100% | 2000-01-03 | 2001-01-19 | 276d | finish no earlier than 2001-01-19 | GP | 2200h | 2200h |  | Rel-4 | Paolo |  |  |  |
| 1920 | 58.1.3 | Receiver performance and RF budget | 276d | 2000-01-03 A | 2001-01-19 A | 100% | 2000-01-03 | 2001-01-19 | 276d | finish no earlier than 2001-01-19 | GP | 2200h | 2200h |  | Rel-4 | Paolo |  |  |  |
| 1921 | 58.2 | GERAN MS Conformance test for 700 MHz band | 175d | 2001-04-02 A | 2001-11-30 A | 100% | 2001-04-02 | 2001-11-30 | 175d |  | GP | 1400h | 1400h |  | Rel-4 | Paolo |  |  |  |
| 1922 | 58.3 | GERAN BTS Conformance test for 700 MHz band | 450d | 2001-04-02 A | 2002-12-20 A | 100% | 2001-04-02 | 2002-12-20 | 450d |  | GP | 3600h | 3600h |  | Rel-4 | Paolo |  |  |  |
| 1923 | 59 | Operator Determined Barring for Packet Oriented Services | 208d | 2000-06-01 A | 2001-03-19 A | 100% | 2000-06-01 | 2001-03-19 | 208d | finish no earlier than 2001-03-19 | NP | 1664h | 1664h | ODB | Rel-4 | Kimmo |  | NEC | Toshiyuki Tamura (tamurato@aj.jp.nec.com) |
| 1924 | 60 | **UMTS QoS Architecture for PS Domain** | 759d | 2000-01-03 A | 2002-11-27 A | 100% | 2000-01-03 | 2002-11-27 | 759d |  | S2,S5,R3,GP | 35600h | 35600h | QoSPS | Rel-4 | Maurice |  | Ericsson | Ina.widegren@era.ericsson.se |
| 1925 | 60.1 | Architecture | 153d | 2000-06-05 A | 2001-01-03 A | 100% | 2000-06-05 | 2001-01-03 | 153d | finish no earlier than 2001-01-03 | S2 | 1224h | 1224h |  | Rel-4 | Maurice | 23.107 |  |  |
| 1926 | 60.2 | Charging and OAM&P for QoS Management | 201d | 2001-09-21 A | 2002-06-28 A | 100% | 2001-09-21 | 2002-06-28 | 201d | finish no earlier than 2002-06-28 | S5 | 1608h | 1608h | QoSPS-OAM | Rel-4 | Dionisio | 32-series | VoiceStream, Motorola |  |
| 1927 | 60.3 | **RAB Quality of Service (re)Negotiation over Iu** | 155d | 2000-08-21 A | 2001-03-23 A | 100% | 2000-08-21 | 2001-03-23 | 155d |  | R3 | 3648h | 3648h | QoSPS-MAPEND-RABQoS | Rel-4 | Juha | 25.413 | Ericsson | anders.molander@ericsson.com |
| 1928 | 60.3.1 | RAB Quality of Service Negotiation over Iu | 155d | 2000-08-21 A | 2001-03-23 A | 100% | 2000-08-21 | 2001-03-23 | 155d | finish no earlier than 2001-03-23 | R3 | 1240h | 1240h | QoSPS-MAPEND-RABQoS-Negot | Rel-4 | Juha |  | Ericsson | anders.molander@ericsson.com |
| 1929 | 60.3.2 | RAB Quality of Service Negotiation over Iu during relocation | 16d | 2001-03-02 A | 2001-03-23 A | 100% | 2001-03-02 | 2001-03-23 | 16d | start no earlier than 2001-03-02 | R3 | 128h | 128h | QoSPS-MAPEND-RABQoS-NegotReloc | Rel-4 | Juha |  |  |  |
| 1930 | 60.3.3 | RAB Quality of Service Re-Negotiation over Iu | 130d | 2000-09-25 A | 2001-03-23 A | 100% | 2000-09-25 | 2001-03-23 | 130d | finish no earlier than 2001-03-23 | R3 | 1040h | 1040h | QoSPS-MAPEND-RABQoS-ReNegot | Rel-4 | Juha |  | Motorola | S. Irwin |

Notes:
- 1907: RAN and CN to verify no problems for GSM terminals roaming in 3G R99
- 1908: RAN and CN to verify UMTS_AMR_2 support
- 1909: -
- 1910: "Implementation" changed to "Impact on:" by A. Sultan (for better wording)
- 1911: RAN and CN to verify UMTS_AMR_2 support
- 1912: End date Modified from June to March to have it in Rel4
- 1913: Approved at CN#10
- 1914: CN4#11 30/11/02: no inputs received in CN4
- 1915: -
- 1916: -
- 1917: -
- 1918: -
- 1919: -
- 1920: -
- 1921: -
- 1922: -
- 1923: Completed WI missing from the P-plan Added for tracking
- 1924: -
- 1925: -
- 1926: -
- 1927: -
- 1928: -
- 1929: -
- 1930: -

| ID | WBS | Task | Duration | Start | Finish | Complete | Baseline start | Baseline finish | Baseline duration | Constraint | Resources | Work | Actual work | Text1 | Text6 | Text8 | Text12 | Text4 | Text5 | Text3 |
| --- | --- | --- | --- | --- | --- | --- | --- | --- | --- | --- | --- | --- | --- | --- | --- | --- | --- | --- | --- | --- |
| 1931 | 60.4 | **GERAN QoS Aspects - Handovers: maintenance of real-time QoS while moving between cells in the PLMN including inter-SGSN and SRNS relocation or possibly other mechanisms** | 501d | 2000-01-03 A | 2001-11-30 A | 100% | 2000-01-03 | 2001-11-30 | 501d |  | GP | 14456h | 14456h | GERQoS | Rel-4 | Paolo |  |  |  |  |
| 1932 | 60.4.1 | **Handover Concept for the PS domain** | 501d | 2000-01-03 A | 2001-11-30 A | 100% | 2000-01-03 | 2001-11-30 | 501d |  | GP | 10448h | 10448h |  | Rel-4 | Paolo |  |  |  |  |
| 1933 | 60.4.1.1 | Stable RT handover report 25.936 including header removal | 14d | 2000-01-03 A | 2000-01-19 A | 100% | 2000-01-03 | 2000-01-19 | 14d | start no earlier than 2000-01-03 | GP | 104h | 104h |  | Rel-4 | Paolo |  |  |  |  |
| 1934 | 60.4.1.2 | Update of stage 2 | 293d | 2000-01-03 A | 2001-02-13 A | 100% | 2000-01-03 | 2001-02-13 | 293d | finish no earlier than 2001-02-13 | GP | 2336h | 2336h |  | Rel-4 | Paolo |  |  |  |  |
| 1935 | 60.4.1.3 | Update of relevant stage 3 specs -> RRC | 501d | 2000-01-03 A | 2001-11-30 A | 100% | 2000-01-03 | 2001-11-30 | 501d | finish no earlier than 2001-11-30 | G2 | 4000h | 4000h |  | Rel-4 | Gert |  |  |  |  |
| 1936 | 60.5 | **Deleted - GERAN MS Conformance test for inter-system and intra-system Packet data real-time Handover** | 324d | 2001-08-31 A | 2002-11-27 A | 100% | 2001-08-31 | 2002-11-27 | 324d |  | G4,R3 | 12960h | 12960h | GERQoS-Mstest | Rel-4 | Paolo | GP-12 |  |  |  |
| 1937 | 60.5.1 | **Deleted - Handover for the PS domain** | 324d | 2001-08-31 A | 2002-11-27 A | 100% | 2001-08-31 | 2002-11-27 | 324d |  | G4,R3 | 10368h | 10368h |  | Rel-4 | Paolo | GP-12 |  |  |  |
| 1938 | 60.5.1.1 | Deleted - Stable RT handover report 25.936 including header removal | 324d | 2001-08-31 A | 2002-11-27 A | 100% | 2001-08-31 | 2002-11-27 | 324d | finish no earlier than 2002-11-27 | G4,R3 | 2592h | 2592h |  | Rel-4 | Paolo | GP-12 |  |  |  |
| 1939 | 60.5.1.2 | Deleted - Update of stage 2 | 324d | 2001-08-31 A | 2002-11-27 A | 100% | 2001-08-31 | 2002-11-27 | 324d | finish no earlier than 2002-11-27 | G4,R3 | 2592h | 2592h |  | Rel-4 | Paolo | GP-12 |  |  |  |
| 1940 | 60.5.1.3 | Deleted - Update of relevant stage 3 specs | 324d | 2001-08-31 A | 2002-11-27 A | 100% | 2001-08-31 | 2002-11-27 | 324d | finish no earlier than 2002-11-27 | G4,R3 | 2592h | 2592h |  | Rel-4 | Paolo | GP-12 |  |  |  |
| 1941 | 60.6 | PS-domain handover for real-time services | 155d | 2000-08-28 A | 2001-03-30 A | 100% | 2000-08-28 | 2001-03-30 | 155d | finish no earlier than 2001-03-30 | R3 | 1240h | 1240h | QoSPS-PSdoRTS | Rel-4 | Juha |  | Nokia | atte.lansisalmi@nokia.com |  |
| 1942 | 60.7 | Deleted - RAB QoS Renegotiation at Relocation | 58d | 2001-01-03 A | 2001-03-23 A | 100% | 2001-01-03 | 2001-03-23 | 58d | finish no earlier than 2001-03-23 | R3 | 464h | 464h |  | Rel-4 | Juha | RP-11 |  |  | 25.851, 25.946 |
| 1943 | 61 | (Small) Technical Enhancements and Improvements for Rel-4 | 326d? | 2000-01-03 A | 2001-03-30 A | 100% | 2000-01-03 | 2001-03-30 | 326d? |  | All | 2608h | 2608h | TEI4 | Rel-4 | all |  |  |  |  |
| 1944 | 632 | Test - (Small) Technical Enhancements and Improvements for Rel-4 | 326d? | 2000-01-03 A | 2001-03-30 A | 100% | 2000-01-03 | 2001-03-30 | 326d? | finish no earlier than 2008-12-31 | R5,T1 | 2608h | 2608h | TEI4_Test | Rel-4 | Ingbert |  |  |  |  |
| 1945 | 62 | **Rel-4 Evolutions of the transport in the UTRAN** | 525d | 2000-08-21 A | 2002-08-23 A | 100% | 2000-08-21 | 2002-08-23 | 525d |  | RP | 8600h | 8600h | ETRAN | Rel-4 | Issam |  | Alcatel | Francois Courau |  |
| 1946 | 62.1 | QoS optimization for AAL2 connections over Iub and Iur interfaces | 160d | 2000-08-21 A | 2001-03-30 A | 100% | 2000-08-21 | 2001-03-30 | 160d | finish no earlier than 2001-03-30 | R3 | 1280h | 1280h | ETRAN-QoSAAL2 | Rel-4 | Juha |  | Japan Telecom | T. Yoshimura |  |
| 1947 | 62.2 | Transport bearer modification procedure on Iub, Iur, and Iu | 130d | 2000-10-02 A | 2001-03-30 A | 100% | 2000-10-02 | 2001-03-30 | 130d | finish no earlier than 2001-03-30 | R3 | 1040h | 1040h | ETRAN-MigrMod | Rel-4 | Juha |  | Japan Telecom | T. Yoshimura |  |
| 1948 | 62.3 | **Deleted - Conformance Test Aspects of Rel-4 evolutions of the transport in UTRAN** | 130d | 2002-02-25 A | 2002-08-23 A | 100% | 2002-02-25 | 2002-08-23 | 130d |  | T1 | 2080h | 2080h |  | Rel-4 | Ingbert | TP-17 |  |  |  |
| 1949 | 62.3.1 | Deleted - Testing RAB support enhancements | 130d | 2002-02-25 A | 2002-08-23 A | 100% | 2002-02-25 | 2002-08-23 | 130d | finish no earlier than 2002-08-23 | T1 | 1040h | 1040h | CT-RABS? | Rel-4 | Ingbert | TP-17 |  |  | 34.108, 34. 121, 34.122, 34.123 p 1,2, 34.123 pt 3 |
| 1950 | 63 | **Rel-4 Evolutions of the transport in the CN** | 215d | 2000-05-29 A | 2001-03-23 A | 100% | 2000-05-29 | 2001-03-23 | 215d |  | N4,N1,N2,S2 | 7968h | 7968h | CNTRSP | Rel-4 | Kimmo |  |  |  |  |
| 1951 | 63.1 | **IP Transport of CN protocols (e.g. CAP, MAP)** | 77d | 2000-12-07 A | 2001-03-23 A | 100% | 2000-12-07 | 2001-03-23 | 77d |  | N4 | 2808h | 2808h | SS7IP | Rel-4 | Kimmo |  |  |  |  |
| 1952 | 63.1.1 | **Stage 3 for IP Transport of CN protocols (e.g. CAP, MAP)** | 77d | 2000-12-07 A | 2001-03-23 A | 100% | 2000-12-07 | 2001-03-23 | 77d |  | N4 | 2192h | 2192h |  | Rel-4 | Kimmo |  |  |  |  |
| 1953 | 63.1.1.1 | CAP | 77d | 2000-12-07 A | 2001-03-23 A | 100% | 2000-12-07 | 2001-03-23 | 77d | finish no earlier than 2001-03-23 | N2 | 616h | 616h |  | Rel-4 | Kimmo |  |  |  |  |
| 1954 | 63.1.1.2 | MAP | 77d | 2000-12-07 A | 2001-03-23 A | 100% | 2000-12-07 | 2001-03-23 | 77d | finish no earlier than 2001-03-23 | N4 | 616h | 616h |  | Rel-4 | Kimmo |  |  |  |  |
| 1955 | 63.1.1.3 | BSSAP+ | 43d | 2001-01-15 A | 2001-03-14 A | 100% | 2001-01-15 | 2001-03-14 | 43d | finish no earlier than 2001-03-14 | N1 | 344h | 344h | SS7IP-BSSAP+ | Rel-4 | Frederic |  |  |  |  |

Notes:
- 1931: -
- 1932: -
- 1933: -
- 1934: -
- 1935: -
- 1936: Still exist? To be clarified by GERAN4/5. Marked as stopped 12/2008
- 1937: Marked as stopped 12/2008
- 1938: Marked as stopped 12/2008
- 1939: Marked as stopped 12/2008
- 1940: Marked as stopped 12/2008
- 1941: -
- 1942: Marked as stopped 12/2008
- 1943: "Joker" WI, to be used for a Rel 4 CR not related to any feature and with very limited impact on the system
- 1944: "Joker" WI, to be used for small modifications applicable to Rel 4 conformance testing. Moved in from the Stoyan/Testing WP
- 1945: -
- 1946: -
- 1947: -
- 1948: Marked as stopped 12/2008
- 1949: Marked as stopped 12/2008
- 1950: -
- 1951: -
- 1952: -
- 1953: -
- 1954: -
- 1955: -

| ID | WBS | Task | Duration | Start | Finish | Complete | Baseline start | Baseline finish | Baseline duration | Constraint | Resources | Work | Actual work | Text4 | Text5 | Text6 | Text8 | Text1 | Text3 | Text12 |
| --- | --- | --- | --- | --- | --- | --- | --- | --- | --- | --- | --- | --- | --- | --- | --- | --- | --- | --- | --- | --- |
| 1956 | 63.2 | **FS on Transport and control separation in the PS CN domain** | 215d | 2000-05-29 A | 2001-03-23 A | 100% | 2000-05-29 | 2001-03-23 | 215d |  | S2 | 3440h | 3440h | Ericsson | Juan-Antonio.Ibanez@eed.ericsson.se | Rel-4 | Maurice |  |  |  |
| 1957 | 63.2.1 | Architectural impacts | 215d | 2000-05-29 A | 2001-03-23 A | 100% | 2000-05-29 | 2001-03-23 | 215d | finish no earlier than 2001-03-23 | S2 | 1720h | 1720h |  |  | Rel-4 | Maurice |  |  |  |
| 1958 | 64 | **Rel-4 Improvements of Radio Interface** | 700d | 2000-07-10 A | 2003-03-14 A | 100% | 2000-07-10 | 2003-03-14 | 700d |  | RP | 28624h | 28624h |  |  | Rel-4 |  | RInImp |  |  |
| 1959 | 64.1 | UTRA repeater specification (master) | 183d | 2000-07-10 A | 2001-03-21 A | 100% | 2000-07-10 | 2001-03-21 | 183d | finish no earlier than 2001-03-21 | R4 | 1464h | 1464h | Mikom, Allgon | T. Kummetz, Mikom; Alf Ahlström, Allgon | Rel-4 | Issam | RInImp-REP |  |  |
| 1960 | 64.2 | DSCH power control improvement in soft handover | 140d | 2000-09-11 A | 2001-03-23 A | 100% | 2000-09-11 | 2001-03-23 | 140d | finish no earlier than 2001-03-23 | R1 | 1120h | 1120h | Nokia | antti.toskala@nokia.com | Rel-4 | Patrick | RInImp-DSCHsho |  |  |
| 1961 | 64.3 | UMTS 1800 | 320d | 2000-09-25 A | 2001-12-14 A | 100% | 2000-09-25 | 2001-12-14 | 320d | finish no earlier than 2001-12-14 | R4 | 2560h | 2560h | Motorola | Howard Benn | Rel-4 | Issam | RInImp-UMTS18 |  |  |
| 1962 | 64.4 | UMTS 1900 | 195d | 2001-03-19 A | 2001-12-14 A | 100% | 2001-03-19 | 2001-12-14 | 195d | finish no earlier than 2001-12-14 | R4 | 1560h | 1560h | Motorola | Howard Benn | Rel-4 | Issam | RInImp-UMTS19 | 25.101 |  |
| 1963 | 64.5 | FS on High Speed downlink packet access | 155d | 2000-08-21 A | 2001-03-23 A | 100% | 2000-08-21 | 2001-03-23 | 155d | finish no earlier than 2001-03-23 | R2 | 1240h | 1240h | Motorola | Amitabha Ghosh (qa0047@email.mot.com) | Rel-4 | Joern | RInImp-HSDPA |  |  |
| 1964 | 64.6 | Deleted - FS on improved common DL channel for Cell-FACH state | 340d | 2000-09-11 A | 2001-12-28 A | 100% | 2000-09-11 | 2001-12-28 | 340d | finish no earlier than 2001-12-28 | R2 | 2720h | 2720h | GBT | J. Kwak | Rel-4 | Joern | RInImp-DLCFACH |  | RP-14 |
| 1965 | 64.7 | **Conformance Test Spec. Rel-4 improvements in Radio Interface** | 375d | 2001-10-08 A | 2003-03-14 A | 100% | 2001-10-08 | 2003-03-14 | 375d |  | T1 | 12360h | 12360h |  |  | Rel-4 | Ingbert |  |  |  |
| 1966 | 64.7.1 | Deleted - Testing Improved usage of downlink resource in FDD for CCTrCHs of dedicated type | 140d | 2002-02-18 A | 2002-08-30 A | 100% | 2002-02-18 | 2002-08-30 | 140d | finish no earlier than 2002-08-30 | T1 | 1120h | 1120h |  |  | Rel-4 | Ingbert |  |  | TP-17 |
| 1967 | 64.7.2 | Deleted - Testing Terminal Power saving features | 140d | 2002-02-18 A | 2002-08-30 A | 100% | 2002-02-18 | 2002-08-30 | 140d | finish no earlier than 2002-08-30 | T1 | 1120h | 1120h |  |  | Rel-4 | Ingbert |  |  | TP-17 |
| 1968 | 64.7.3 | Deleted - Testing DSCH power control improvement in soft handover | 140d | 2002-02-18 A | 2002-08-30 A | 100% | 2002-02-18 | 2002-08-30 | 140d | finish no earlier than 2002-08-30 | T1 | 1120h | 1120h |  |  | Rel-4 | Ingbert |  |  | TP-17 |
| 1969 | 64.7.4 | Testing UMTS 1800 | 180d | 2001-10-08 A | 2002-06-14 A | 100% | 2001-10-08 | 2002-06-14 | 180d | finish no earlier than 2002-06-14 | T1 | 1440h | 1440h |  |  | Rel-4 | Ingbert |  | 34.108, 34,121, 34.122, 34.123-1 |  |
| 1970 | 64.7.5 | Testing UMTS 1900 | 180d | 2001-10-08 A | 2002-06-14 A | 100% | 2001-10-08 | 2002-06-14 | 180d | finish no earlier than 2002-06-14 | T1 | 1440h | 1440h |  |  | Rel-4 | Ingbert |  | 34.108, 34,121, 34.122, 34.123-1 |  |
| 1971 | 64.7.6 | Testing UMTS 1800 - TTCN | 195d | 2002-06-17 A | 2003-03-14 A | 100% | 2002-06-17 | 2003-03-14 | 195d | finish no earlier than 2003-03-14 | T1 | 1560h | 1560h |  |  | Rel-4 | Ingbert |  | 34.123-3 |  |
| 1972 | 64.7.7 | Testing UMTS 1900 - TTCN | 195d | 2002-06-17 A | 2003-03-14 A | 100% | 2002-06-17 | 2003-03-14 | 195d | finish no earlier than 2003-03-14 | T1 | 1560h | 1560h |  |  | Rel-4 | Ingbert |  | 34.123-3 |  |
| 1973 | 65 | **Rel-4 RAN improvements** | 938d? | 2000-08-14 A | 2004-03-17 A | 100% | 2000-08-14 | 2004-03-17 | 938d? |  | RP | 29336h | 29336h |  |  | Rel-4 |  | RANimp |  |  |
| 1974 | 65.1 | Node B synchronization for TDD | 160d | 2000-08-14 A | 2001-03-23 A | 100% | 2000-08-14 | 2001-03-23 | 160d | finish no earlier than 2001-03-23 | R1 | 1280h | 1280h | Siemens | S. Oestreich | Rel-4 | Patrick | RANimp-NBsync |  |  |
| 1975 | 65.2 | RAB support enhancement for Rel-4 | 155d | 2000-08-21 A | 2001-03-23 A | 100% | 2000-08-21 | 2001-03-23 | 155d | finish no earlier than 2001-03-23 | R2 | 1240h | 1240h | Ericsson | M. Israelsson, A. Krishnarajah | Rel-4 | Joern | RANimp-RABSE |  |  |
| 1976 | 65.4 | **Deleted - Conformance Test Aspects - Rel-4 RAN Improvements** | 577d? | 2002-01-01 A | 2004-03-17 A | 100% | 2002-01-01 | 2004-03-17 | 577d? |  | T1 | 19312h | 19312h |  |  | Rel-4 | Ingbert |  |  | TP-23 |
| 1977 | 65.4.1 | Deleted - Testing Radio access bearer support enhancments | 175d | 2002-01-01 A | 2002-09-02 A | 100% | 2002-01-01 | 2002-09-02 | 175d | finish no earlier than 2002-09-02 | T1 | 1400h | 1400h |  |  | Rel-4 | Ingbert |  |  | TP-17 |
| 1978 | 65.4.2 | Deleted - Testing RAB support enhancements-Robust Header Compression | 332d | 2002-05-28 A | 2003-09-03 A | 100% | 2002-05-28 | 2003-09-03 | 332d | finish no earlier than 2003-09-03 | T1 | 2656h | 2656h |  |  | Rel-4 | Ingbert | RABimp-RoCH | 34.123-1, -2 | TP-21 |
| 1979 | 65.4.3 | Deleted - Testing RAB support enhancements-Robust Header Compression - TTCN | 472d | 2002-05-28 A | 2004-03-17 A | 100% | 2002-05-28 | 2004-03-17 | 472d | finish no earlier than 2004-03-17 | T1 | 3776h | 3776h |  |  | Rel-4 | Ingbert |  | 34.123-3 | TP-23 |
| 1980 | 65.4.4 | Testing of Extended Robut Header Compression | 270d | 2002-09-18 A | 2003-09-30 A | 100% | 2002-09-18 | 2003-09-30 | 270d | finish no earlier than 2003-09-30 | T1 | 2160h | 2160h |  |  | Rel-4 | Ingbert | Ext-RoHC | 34.123-1, -2 |  |
| 1981 | 65.4.5 | Deleted - Testing of Extended Robut Header Compression - TTCN | 325d | 2002-09-18 A | 2003-12-16 A | 100% | 2002-09-18 | 2003-12-16 | 325d | finish no earlier than 2003-12-16 | T1 | 2600h | 2600h |  |  | Rel-4 | Ingbert |  | 34.123-3 | TP-22 |
| 1982 | 636.3.6 | Deleted - General changes to TS34.121 corresponding to release 4 | 263d? | 2003-03-03 A | 2004-03-03 A | 100% | 2003-03-03 | 2004-03-03 | 263d? | finish no earlier than 2004-03-03 | T1 | 2104h | 2104h |  |  | Rel-4 | Ingbert | RANimp-test | 34.108, 34.121 | TP-23 |

Notes:
- 1956: -
- 1957: -
- 1958: -
- 1959: -
- 1960: -
- 1961: -
- 1962: -
- 1963: -
- 1964: Stopped at RP#14
- 1965: -
- 1966: Marked as stopped 12/2008
- 1967: Marked as stopped 12/2008
- 1968: Marked as stopped 12/2008
- 1969: -
- 1970: -
- 1971: -
- 1972: -
- 1973: -
- 1974: -
- 1975: 29 Nov 2000: split into ROHC and non-ROHC part; 5 Mar 2001: splitting off of ROHC for Rel-4 agreed by R2
- 1976: Marked as stopped 12/2008
- 1977: Marked as stopped 12/2008
- 1978: UID changed. Marked as stopped 12/2008
- 1979: UID changed. Marked as stopped 12/2008
- 1980: Marked as closed 12/2008 (was marked 15% complete)
- 1981: Marked as stopped 12/2008
- 1982: Marked as stopped 12/2008

| ID | WBS | Task | Duration | Start | Finish | Complete | Baseline start | Baseline finish | Baseline duration | Constraint | Resources | Work | Actual work | Text1 | Text6 | Text8 | Text3 | Text4 | Text5 | Text12 |
| --- | --- | --- | --- | --- | --- | --- | --- | --- | --- | --- | --- | --- | --- | --- | --- | --- | --- | --- | --- | --- |
| 1983 | 67 | **Rel-4 Terminal interfaces** | 315d | 2000-01-03 A | 2001-03-15 A | 100% | 2000-01-03 | 2001-03-15 | 315d |  | T2 | 14296h | 14296h | TI | Rel-4 | Kimmo |  |  |  |  |
| 1984 | 67.1 | **AT commands enhancements** | 314d | 2000-01-03 A | 2001-03-14 A | 100% | 2000-01-03 | 2001-03-14 | 314d |  | T2 | 5016h | 5016h | TI-ATC | Rel-4 | Kimmo | 27.007 |  |  |  |
| 1985 | 67.1.1 | Specification of AT commands for new services | 314d | 2000-01-03 A | 2001-03-14 A | 100% | 2000-01-03 | 2001-03-14 | 314d | finish no earlier than 2001-03-14 | T2 | 2504h | 2504h |  | Rel-4 | Kimmo | 27.007 |  |  |  |
| 1986 | 67.2 | **Wide Area Data Synchronization** | 314d | 2000-01-03 A | 2001-03-14 A | 100% | 2000-01-03 | 2001-03-14 | 314d |  | T2 | 5016h | 5016h | TI-WADS | Rel-4 | Kimmo |  |  |  |  |
| 1987 | 67.2.1 | Continues evolution of Synchronization protocol | 314d | 2000-01-03 A | 2001-03-14 A | 100% | 2000-01-03 | 2001-03-14 | 314d | finish no earlier than 2001-03-14 | T2 | 2504h | 2504h | TI-SYNC-EVOL | Rel-4 | Kimmo | 27.903, 27.103 |  |  |  |
| 1988 | 67.3 | Terminal local model | 218d | 2000-05-16 A | 2001-03-15 A | 100% | 2000-05-16 | 2001-03-15 | 218d | finish no earlier than 2001-03-15 | T2 | 1744h | 1744h | TLM | Rel-4 | Kimmo | 23.227 | Ericsson | Olga.Tome@ECS.ERICSSON.SE |  |
| 1989 | 69 | **Rel-4 UICC/(U)SIM enhancements and interworking** | 175d | 2000-07-24 A | 2001-03-23 A | 100% | 2000-07-24 | 2001-03-23 | 175d |  | T3 | 2800h | 2800h | UICC1 | Rel-4 | Xavier |  |  |  |  |
| 1990 | 69.1 | Common PCN Handset Specification (CPHS) | 175d | 2000-07-24 A | 2001-03-23 A | 100% | 2000-07-24 | 2001-03-23 | 175d | finish no earlier than 2001-03-23 | T3 | 1400h | 1400h | UICC1-CPHS | Rel-4 | Xavier | 27.103 | One2One |  |  |
| 1991 | 70 | **Rel-4 (U)SIM toolkit enhancements** | 210d | 2000-06-05 A | 2001-03-23 A | 100% | 2000-06-05 | 2001-03-23 | 210d |  | T3 | 3360h | 3360h | USAT1-LocLnk | Rel-4 | Xavier |  | Gemplus | Jean-Francois Rubon |  |
| 1992 | 70.1 | USAT local link | 210d | 2000-06-05 A | 2001-03-23 A | 100% | 2000-06-05 | 2001-03-23 | 210d | finish no earlier than 2001-03-23 | T3 | 1680h | 1680h | USAT1-LocLnk | Rel-4 | Xavier |  | Gemplus | Jean-Francois Rubon |  |
| 1993 | 71 | **Rel-4 Security enhancements** | 576d | 2000-01-03 A | 2002-03-15 A | 100% | 2000-01-03 | 2002-03-15 | 576d |  | S3,N4,N1 | 23640h | 23640h | SEC1 | Rel-4 | Dionisio |  | Vodafone | Peter.Howard@vodafone.com |  |
| 1994 | 54.2 | Rel-4 Lawful Interception | 155d | 2000-08-21 A | 2001-03-23 A | 100% | 2000-08-21 | 2001-03-23 | 155d | finish no earlier than 2001-03-23 | S3 | 1240h | 1240h | SEC1-LI | Rel-4 | Dionisio | 33.107 |  |  |  |
| 1995 | 71.1 | Evolution of GSM CS algorithms (e.g. A5/3 development and deployment) | 272d | 2000-01-03 A | 2001-01-15 A | 100% | 2000-01-03 | 2001-01-15 | 272d | finish no earlier than 2001-01-15 | S3 | 2168h | 2168h | SEC1-CSALGO1 | Rel-4 | Dionisio | 33.102, 33.103, 33.105 | DTI, BIS | cbrookson@iee.org |  |
| 1996 | 71.2 | **Evolution of GSM PS algorithms (e.g. GEA 2 deployment)** | 219d | 2000-02-22 A | 2000-12-22 A | 100% | 2000-02-22 | 2000-12-22 | 219d |  | S3,N4,N1 | 4272h | 4272h | SEC1-PSALGO1 | Rel-4 | Dionisio | 33.102, 33.103, 33.105 | DTI, BIS | cbrookson@iee.org |  |
| 1997 | 71.2.1 | Deleted - Main aspects of Evolution of GSM PS algorithms (e.g. GEA 2 deployment) | 199d | 2000-02-22 A | 2000-11-24 A | 100% | 2000-02-22 | 2000-11-24 | 199d | finish no earlier than 2000-11-24 | S3 | 1592h | 1592h | SEC1-PSALGO1 | Rel-4 | Dionisio |  | DTI, BIS | cbrookson@iee.org |  |
| 1998 | 71.2.2 | Impact on GTP | 200d | 2000-03-20 A | 2000-12-22 A | 100% | 2000-03-20 | 2000-12-22 | 200d | finish no earlier than 2000-12-22 | N4 | 1600h | 1600h | SEC1-PSALGO1 | Rel-4 | Kimmo |  | DTI, BIS | cbrookson@iee.org |  |
| 1999 | 71.2.3 | GEA capability indication in MS CM | 135d | 2000-06-19 A | 2000-12-22 A | 100% | 2000-06-19 | 2000-12-22 | 135d | finish no earlier than 2000-12-22 | N1 | 1080h | 1080h | SEC1-PSALGO1-GEACAP | Rel-4 | Frederic |  | Vodafone Airtouch | Duncan Mills |  |
| 2000 | 71.3 | **Deleted - MAP application layer security** | 576d | 2000-01-03 A | 2002-03-15 A | 100% | 2000-01-03 | 2002-03-15 | 576d |  | S3 | 11352h | 11352h | SEC1-MAPAL | Rel-4 | Dionisio |  |  |  | SP-15 |
| 2001 | 71.3.1 | Deleted - Main aspects of MAP application layer security | 199d | 2000-02-21 A | 2001-03-29 A | 100% | 2000-02-21 | 2001-03-29 | 199d | start no earlier than 2000-02-21 | S3 | 1592h | 1592h |  | Rel-4 | Dionisio |  |  |  | SP-11 |
| 2002 | 71.3.2 | Deleted - Other stage 3 aspects | 199d | 2000-02-22 A | 2000-11-24 A | 100% | 2000-02-22 | 2000-11-24 | 199d | finish no earlier than 2000-11-24 | N4 | 1592h | 1592h |  | Rel-4 | Kimmo |  |  |  | CP-10 |
| 2003 | 71.3.3 | Deleted - Visibility and Configurability of security | 576d | 2000-01-03 A | 2002-03-15 A | 100% | 2000-01-03 | 2002-03-15 | 576d | finish no earlier than 2002-03-15 | S3 | 4600h | 4600h | SEC1-VCS | Rel-4 | Dionisio |  | France Telecom | Sebastien.nguyenngoc@rd.francetelecom.com | SP-15 |
| 2004 | 72 | **Rel-4 Charging and OAM&P** | 221d | 2000-12-01 A | 2001-10-05 A | 100% | 2000-12-01 | 2001-10-05 | 221d |  | S5 | 10472h | 10472h | OAM | Rel-4 | Dionisio |  | VoiceStream, Motorola |  |  |
| 2005 | 72.1 | Rel4 Principles, high level Requirements and Architecture | 145d | 2000-12-01 A | 2001-06-21 A | 100% | 2000-12-01 | 2001-06-21 | 145d | finish no earlier than 2001-06-21 | S5 | 1160h | 1160h | OAM-AR/PR | Rel-4 | Dionisio | 32.101, 32.102 | Motorola, Telia | Michael.Truss@motorola.com, Tommy.R.Berggren@TELIA.SE |  |
| 2006 | 72.2 | Rel4 Performance Management | 216d | 2000-12-01 A | 2001-09-28 A | 100% | 2000-12-01 | 2001-09-28 | 216d | finish no earlier than 2001-06-21 | S5 | 1728h | 1728h |  | Rel-4 | Dionisio | 32.4xy, 52.402 | T-Mobile | karl-heinz.nenner@t-mobile.de |  |
| 2007 | 72.3 | Fault Management | 221d | 2000-12-01 A | 2001-10-05 A | 100% | 2000-12-01 | 2001-10-05 | 221d | finish no earlier than 2001-06-21 | S5 | 1768h | 1768h |  | Rel-4 | Dionisio | 32.111-1/4 | Lucent |  |  |
| 2008 | 72.4 | Configuration Management | 145d | 2000-12-01 A | 2001-06-21 A | 100% | 2000-12-01 | 2001-06-21 | 145d | finish no earlier than 2001-06-21 | S5 | 1160h | 1160h | OAM-CM | Rel-4 | Dionisio | 32.106-1/8 | Ericsson | thomas.tovinger@ericsson.com |  |
| 2009 | 72.5 | Rel-4 Charging Management | 216d | 2000-12-01 A | 2001-09-28 A | 100% | 2000-12-01 | 2001-09-28 | 216d | finish no earlier than 2001-06-21 | S5 | 1728h | 1728h | OAM-CH | Rel-4 | Dionisio | 32.200, 32.205, 32.215, 32.235 | T-Mobile | karl-heinz.nenner@t-mobile.de |  |
| 2010 | 72.6 | UTRAN Operations and Maintenance procedures | 145d | 2000-12-01 A | 2001-06-21 A | 100% | 2000-12-01 | 2001-06-21 | 145d | finish no earlier than 2001-06-21 | S5 | 1160h | 1160h | UOAM | Rel-4 | Dionisio | 32.800 | Mannesmann Mobilfunk | bert.boden@d2mannesmann.de |  |
| 2011 | 642 | Release 1999 Features | 261d? | 1999-01-01 A | 1999-12-31 A | 100% | 1999-01-01 | 1999-12-31 | 261d? |  | NP,SP,TP,SMG | 2088h | 2088h |  | R99 | All |  |  |  |  |

Notes:
- 1983: -
- 1984: -
- 1985: goal not completely achieved because of missing input
- 1986: AS: Rel5 changed to Rel4 according to SP#10 decision, milestone on testing added
- 1987: -
- 1988: -
- 1989: -
- 1990: 28/5/2001: CRs approved at TP-11. WI complete.
- 1991: -
- 1992: 25/5/2001:CR was approved at TP-11. WI is complete
- 1993: -
- 1994: Requirements capture: S3#14 (Aug 00), Feature specification: S3#15 (Sep 00), Definition of architecture. Should be included in general LI work mentioned above.
- 1995: SP#8 approved WID
- 1996: SP#8 approved WID
- 1997: Complete TSG#09 (09/2000). S3#17: Proposed for deletion. TO BE DELETED
- 1998: -
- 1999: -
- 2000: REPLACED BY NDS-MAP and NDS-IP. Completed Auto Key Management -> Rel-6. Marked as stopped 12/2008
- 2001: UID changed. Marked as stopped 12/2008
- 2002: UID changed. Marked as stopped 12/2008
- 2003: CR approved at SA3#21 awaiting comments from CN1. Marked as stopped 12/2008
- 2004: SP#13 approved WID
- 2005: -
- 2006: -
- 2007: -
- 2008: -
- 2009: -
- 2010: -
- 2011: -

| ID | WBS | Task | Duration | Start | Finish | Complete | Baseline start | Baseline finish | Baseline duration | Constraint | Resources | Work | Actual work | Text6 | Text8 | Text1 | Text12 |
| --- | --- | --- | --- | --- | --- | --- | --- | --- | --- | --- | --- | --- | --- | --- | --- | --- | --- |
| 2012 | 643 | **GSM Features** | 261d? | 1999-01-01 A | 1999-12-31 A | 100% | 1999-01-01 | 1999-12-31 | 261d? |  | S1,S2,SMG,T2,N1,N2,N3,N4 | 50112h | 50112h | R99 | Alain |  |  |
| 2013 | 643.1 | **Dual Transfer Mode within GSM and GPRS** | 261d? | 1999-01-01 A | 1999-12-31 A | 100% | 1999-01-01 | 1999-12-31 | 261d? |  | SMG,N1 | 6264h | 6264h | R99 | Frederic | DTM |  |
| 2014 | 643.1.1 | Class A Dual Transfer Mode | 261d? | 1999-01-01 A | 1999-12-31 A | 100% | 1999-01-01 | 1999-12-31 | 261d? | start no earlier than 1999-01-01 | SMG | 2088h | 2088h | R99 | Frederic | Class_A_Dual_Transfer_Mode_(DTM) |  |
| 2015 | 643.1.2 | Dual Transfer Mode | 261d? | 1999-01-01 A | 1999-12-31 A | 100% | 1999-01-01 | 1999-12-31 | 261d? | start no earlier than 1999-01-01 | SMG,N1 | 2088h | 2088h | R99 | Frederic | DTM |  |
| 2016 | 643.2 | **General Packet Radio Service enahancements** | 261d? | 1999-01-01 A | 1999-12-31 A | 100% | 1999-01-01 | 1999-12-31 | 261d? |  | S1,S2,SMG1,SMG2,SMG7,N1,N2,N3,N4,T2 | 8352h | 8352h | R99 | Alain | GPRS enhancements |  |
| 2017 | 643.2.1 | General Packet Radio Service | 261d? | 1999-01-01 A | 1999-12-31 A | 100% | 1999-01-01 | 1999-12-31 | 261d? | start no earlier than 1999-01-01 | S1,S2,SMG1,SMG2,SMG7,N1,N2,N3,N4,T2 | 2088h | 2088h | R99 | Alain | GPRS |  |
| 2018 | 643.2.2 | GPRS2 | 261d? | 1999-01-01 A | 1999-12-31 A | 100% | 1999-01-01 | 1999-12-31 | 261d? | start no earlier than 1999-01-01 | SMG1,N2 | 2088h | 2088h | R99 |  | GPRS2 |  |
| 2019 | 643.2.3 | GPRS Tunnelling Protocol enhancement | 261d? | 1999-01-01 A | 1999-12-31 A | 100% | 1999-01-01 | 1999-12-31 | 261d? | start no earlier than 1999-01-01 | N4,N2 | 2088h | 2088h | R99 | Kimmo | GTP_enhancement |  |
| 2020 | 643.3 | **Enhanced Data rates for GSM Evolution - Phase 1** | 261d? | 1999-01-01 A | 1999-12-31 A | 100% | 1999-01-01 | 1999-12-31 | 261d? |  | SMG2,SMG1,SMG3,SMG4,SMG7,SMG9,SMG10,N1,N3,T2 | 25056h | 25056h | R99 | Maurice | EDGE - Phase 1 |  |
| 2021 | 643.3.1 | Enhanced Data rates for GSM Evolution | 261d? | 1999-01-01 A | 1999-12-31 A | 100% | 1999-01-01 | 1999-12-31 | 261d? | start no earlier than 1999-01-01 | SMG2,SMG1,SMG3,SMG4,SMG7,SMG9,SMG10,N1,N3,T2 | 2088h | 2088h | R99 | Maurice | EDGE |  |
| 2022 | 643.3.2 | EDGE-Layer1 | 261d? | 1999-01-01 A | 1999-12-31 A | 100% | 1999-01-01 | 1999-12-31 | 261d? | start no earlier than 1999-01-01 | SMG2 | 2088h | 2088h | R99 |  | EDGE-Layer1 |  |
| 2023 | 643.3.3 | High Speed Circuit Switched Data | 261d? | 1999-01-01 A | 1999-12-31 A | 100% | 1999-01-01 | 1999-12-31 | 261d? | start no earlier than 1999-01-01 | SMG1,SMG2,SMG7 | 2088h | 2088h | R99 |  | HSCSD |  |
| 2024 | 643.3.4 | Enhanced Circuit Switched Data - Phase 1 | 261d? | 1999-01-01 A | 1999-12-31 A | 100% | 1999-01-01 | 1999-12-31 | 261d? | start no earlier than 1999-01-01 | S1,SMG | 2088h | 2088h | R99 | Alain | ECSD |  |
| 2025 | 643.3.5 | EDGE-Enhanced Circuit Switched Data | 261d? | 1999-01-01 A | 1999-12-31 A | 100% | 1999-01-01 | 1999-12-31 | 261d? | start no earlier than 1999-01-01 | SMG2 | 2088h | 2088h | R99 |  | EDGE-ECSD |  |
| 2026 | 643.3.6 | Enhanced GPRS - Phase 1 | 261d? | 1999-01-01 A | 1999-12-31 A | 100% | 1999-01-01 | 1999-12-31 | 261d? | start no earlier than 1999-01-01 | SMG,N1 | 2088h | 2088h | R99 |  | EGPRS |  |
| 2027 | 643.3.7 | EDGE-EGPRS | 261d? | 1999-01-01 A | 1999-12-31 A | 100% | 1999-01-01 | 1999-12-31 | 261d? | start no earlier than 1999-01-01 | SMG2 | 2088h | 2088h | R99 |  | EDGE-EGPRS |  |
| 2028 | 643.3.8 | Packet Flow Context (PFC) | 261d? | 1999-01-01 A | 1999-12-31 A | 100% | 1999-01-01 | 1999-12-31 | 261d? | start no earlier than 1999-01-01 | SMG2 | 2088h | 2088h | R99 |  | PFC |  |
| 2029 | 643.3.9 | Support for EGPRS in ANSI-136 networks and EDGE COMPACT | 261d? | 1999-01-01 A | 1999-12-31 A | 100% | 1999-01-01 | 1999-12-31 | 261d? | start no earlier than 1999-01-01 | SMG | 2088h | 2088h | R99 |  | EDGE-Compact |  |
| 2030 | 643.3.10 | EGPRS COMPACT | 261d? | 1999-01-01 A | 1999-12-31 A | 100% | 1999-01-01 | 1999-12-31 | 261d? | start no earlier than 1999-01-01 | SMG | 2088h | 2088h | R99 |  | EGPRS-Compact |  |
| 2031 | 643.3.11 | COMPACT | 261d? | 1999-01-01 A | 1999-12-31 A | 100% | 1999-01-01 | 1999-12-31 | 261d? | start no earlier than 1999-01-01 | SMG,N1 | 2088h | 2088h | R99 |  | COMPACT |  |
| 2032 | 643.4 | GSM_400 | 261d? | 1999-01-01 A | 1999-12-31 A | 100% | 1999-01-01 | 1999-12-31 | 261d? | start no earlier than 1999-01-01 | SMG2,SMG7,T2 | 2088h | 2088h | R99 | Paolo | GSM_400 |  |
| 2033 | 643.5 | GSM_450 | 261d? | 1999-01-01 A | 1999-12-31 A | 100% | 1999-01-01 | 1999-12-31 | 261d? | start no earlier than 1999-01-01 | SMG2 | 2088h | 2088h | R99 |  | GSM_450 |  |
| 2034 | 643.6 | GSM_700 | 261d? | 1999-01-01 A | 1999-12-31 A | 100% | 1999-01-01 | 1999-12-31 | 261d? | start no earlier than 1999-01-01 | SMG2 | 2088h | 2088h | R99 |  | GSM_700 |  |
| 2035 | 643.7 | Deleted - GERAN | 261d? | 1999-01-01 A | 1999-12-31 A | 100% | 1999-01-01 | 1999-12-31 | 261d? | start no earlier than 1999-01-01 | SMG2,S2 | 2088h | 2088h | R99 | Maurice | GERAN | SP-06 |

Notes:
- 2012: -
- 2013: WID on BSS co-ordination of Radio Resource allocation for class A GPRS services - GSM Radio Access (R99) / Text3: 03.55, 03.64, 04.18, 04.60, 05.01, 05.02, 05.08, 08.08, 23.060, 24.007, 24.008
- 2014: - / Text3: 05.10
- 2015: - / Text3: 03.55, 03.64, 04.18, 05.01, 05.02, 05.08, 24.008
- 2016: GPRS was introduced in Release 97. Release 99 brings a number of essential corrections e.g. on Downlink Power Control, Timing Advance procedure, Cell reselection delay time, PBCCH scheduling, PTCCH mapping, etc. / Text3: 05.02, 05.05, 05.08, 05.10, 05.50, 11.21, 23.064, 24.008, 24.060
- 2017: - / Text3: 02.60, 03.22, 03.64, 04.18, 04.60, 04.64, 04.65, 05.01, 05.02, 05.05, 05.08, 05.10, 08.08, 08.18, 11.10-1, 11.21, 22.041, 22.060, 23.003, 23.007, 23.060, 23.107, 23.122, 24.007, 24.008, 27.007, 27.060, 29.002, 29.016, 29.018, 29.060, 29.061
- 2018: Introduction of EGPRS (S1) + Introduction of Reserved Service Labels in the APN (N2) / Text3: 02.60, 23.003
- 2019: - / Text3: 23.003, 23.008, 29.060
- 2020: EDGE is independent of the frequency bands, so it can be deployed e.g. in 900 and 1900 MHz bands. The new physical layer based on 8-PSK modulation is introduced and EGPRS and ECSD facilitate the new modulation in single and multi slot constellation. / Text3: 10.59, 02.34, 02.60, 03.30, 05.10, 05.50, 11.26
- 2021: - / Text3: 02.34, 03.10, 03.20, 03.64, 04.03, 04.04, 04.06, 04.08, 04.18, 04.21, 04.22, 04.60, 04.64, 05.01, 05.02, 05.03, 05.04, 05.05, 05.08, 05.10, 05.50, 07.01, 07.02, 07.03, 08.08, 08.20, 08.58, 08.60, 09.07, 09.18, 11.10-1, 11.11, 11.21, 11.26, 23.034, 24.008,
- 2022: - / Text3: 05.05, 05.10, 05.50
- 2023: No additional features for R99. / Text3: 02.34, 04.18, 11.10-1
- 2024: ECSD supports both transparent and non-transparent services, up to 64 kbit/s and 57.6 kbit/s respectively. See Tdoc SMG2 670/99 ECSD Concept Evaluation for more info / Text3: 05.02, 08.58, 22.034
- 2025: - / Text3: 05.03
- 2026: - / Text3: 02.07, 03.64, 04.14, 04.18, 04.60, 05.05, 05.08, 24.008
- 2027: - / Text3: 05.03, 05.05, 05.08
- 2028: - / Text3: 04.18
- 2029: Support for EGPRS in ANSI-136 networks and EDGE Compact (for ANSI-136 networks only). COMPACT = Deployment of services in spectrum below 1 MHz / Text3: 03.22, 03.30, 03.64, 05.01, 05.02, 05.03, 05.05, 05.08, 05.10
- 2030: COMPACT = Deployment of services in spectrum below 1 MHz / Text3: 04.18, 05.02
- 2031: COMPACT = Deployment of services in spectrum below 1 MHz / Text3: 03.22, 04.18, 04.60, 05.08, 23.122, 24.008
- 2032: GSM in the 400 MHz bands allows to deploy GSM within frequency bands in the range 450 to 500 MHz, previously used for analogue cellular systems. See Tdoc SMG2 190/99 and 595/99 for further info. / Text3: 02.17, 03.22, 03.30, 04.04, 04.18, 04.60, 05.01, 05.02, 05.05, 05.08, 05.10, 05.50, 08.18, 08.58, 11.21, 24.008, 27.007
- 2033: - / Text3: 03.22, 03.30, 05.01, 05.05, 05.08
- 2034: - / Text3: 05.05
- 2035: No CR or new TS/TR approved under this WI / Text3: G2: 04.18 CR#A248 , 04.60 CR#B090

| ID | WBS | Task | Duration | Start | Finish | Complete | Baseline start | Baseline finish | Baseline duration | Constraint | Resources | Work | Actual work | Text1 | Text6 | Text8 |
| --- | --- | --- | --- | --- | --- | --- | --- | --- | --- | --- | --- | --- | --- | --- | --- | --- |
| 2036 | 644 | **Operations, Administration, Maintenance and Provisioning (OAM&P)** | 261d? | 1999-01-01 A | 1999-12-31 A | 100% | 1999-01-01 | 1999-12-31 | 261d? |  | S5 | 12528h | 12528h | OAM | R99 | Dionisio |
| 2037 | 644.1 | OAM Principles and High-level Requirements | 261d? | 1999-01-01 A | 1999-12-31 A | 100% | 1999-01-01 | 1999-12-31 | 261d? | start no earlier than 1999-01-01 | S5 | 2088h | 2088h | PR, Princs_&_Reqs_(PR) | R99 | Dionisio |
| 2038 | 644.2 | OAM Architecture | 261d? | 1999-01-01 A | 1999-12-31 A | 100% | 1999-01-01 | 1999-12-31 | 261d? | start no earlier than 1999-01-01 | S5 | 2088h | 2088h | OAMAR, AR, Telecom_Management_Arch_(AR) | R99 | Dionisio |
| 2039 | 644.3 | OAM Configuration Management | 261d? | 1999-01-01 A | 1999-12-31 A | 100% | 1999-01-01 | 1999-12-31 | 261d? | start no earlier than 1999-01-01 | S5 | 2088h | 2088h | OAMCM, CM | R99 | Dionisio |
| 2040 | 644.4 | OAM Fault Management | 261d? | 1999-01-01 A | 1999-12-31 A | 100% | 1999-01-01 | 1999-12-31 | 261d? | start no earlier than 1999-01-01 | S5 | 2088h | 2088h | OAMFM | R99 | Dionisio |
| 2041 | 644.5 | OAM Performance Management | 261d? | 1999-01-01 A | 1999-12-31 A | 100% | 1999-01-01 | 1999-12-31 | 261d? | start no earlier than 1999-01-01 | S5 | 2088h | 2088h | OAMPM, PM | R99 | Dionisio |
| 2042 | 645 | GPRS_Mobile_IP_interworking | 261d? | 1999-01-01 A | 1999-12-31 A | 100% | 1999-01-01 | 1999-12-31 | 261d? | start no earlier than 1999-01-01 | N3 | 2088h | 2088h | GPRS_Mobile_IP_interworking | R99 |  |
| 2043 | 646 | GSM/UMTS interworking | 261d? | 1999-01-01 A | 1999-12-31 A | 100% | 1999-01-01 | 1999-12-31 | 261d? | start no earlier than 1999-01-01 | N1,N2,N4,R3,S1,SMG | 2088h | 2088h | 2G3Ginterworking | R99 | Frederic |
| 2044 | 647 | Handover | 261d? | 1999-01-01 A | 1999-12-31 A | 100% | 1999-01-01 | 1999-12-31 | 261d? | start no earlier than 1999-01-01 | S1,SMG2,N1,N2,N4 | 2088h | 2088h | Handover | R99 | Alain |
| 2045 | 648 | 2G3Ghandover | 261d? | 1999-01-01 A | 1999-12-31 A | 100% | 1999-01-01 | 1999-12-31 | 261d? | start no earlier than 1999-01-01 | SMG2 | 2088h | 2088h | 2G3Ghandover | R99 |  |
| 2046 | 649 | Data & Data_CleanUp | 261d? | 1999-01-01 A | 1999-12-31 A | 100% | 1999-01-01 | 1999-12-31 | 261d? | start no earlier than 1999-01-01 | SMG1 | 2088h | 2088h | Data, Data_CleanUp | R99 |  |
| 2047 | 650 | Unstructured Supplementary Service Data | 261d? | 1999-01-01 A | 1999-12-31 A | 100% | 1999-01-01 | 1999-12-31 | 261d? | start no earlier than 1999-01-01 | SMG1,N4 | 2088h | 2088h | USSD | R99 | Kimmo |
| 2048 | 651 | Network Identity and Timezone (NITZ) | 261d? | 1999-01-01 A | 1999-12-31 A | 100% | 1999-01-01 | 1999-12-31 | 261d? | start no earlier than 1999-01-01 | SMG1,SMG3 | 2088h | 2088h | NITZ | R99 | Alain |
| 2049 | 652 | Packet Flow Management | 261d? | 1999-01-01 A | 1999-12-31 A | 100% | 1999-01-01 | 1999-12-31 | 261d? | start no earlier than 1999-01-01 | SMG2 | 2088h | 2088h | Packet_Flow_Management | R99 |  |
| 2050 | 653 | GPRS_Point-To-Multipoint Group call | 261d? | 1999-01-01 A | 1999-12-31 A | 100% | 1999-01-01 | 1999-12-31 | 261d? | start no earlier than 1999-01-01 | SMG1 | 2088h | 2088h | GPRS_PTMG | R99 |  |
| 2051 | 654 | **Call Forwarding** | 261d? | 1999-01-01 A | 1999-12-31 A | 100% | 1999-01-01 | 1999-12-31 | 261d? |  | SMG1,N2,N4 | 8352h | 8352h |  | R99 | Kimmo |
| 2052 | 654.1 | Call Forwarding enhancements | 261d? | 1999-01-01 A | 1999-12-31 A | 100% | 1999-01-01 | 1999-12-31 | 261d? | start no earlier than 1999-01-01 | N4,N2 | 2088h | 2088h | CF_enhancements | R99 | Kimmo |
| 2053 | 654.2 | Call_Forwarding | 261d? | 1999-01-01 A | 1999-12-31 A | 100% | 1999-01-01 | 1999-12-31 | 261d? | start no earlier than 1999-01-01 | SMG1,N2 | 2088h | 2088h | Call_Forwarding | R99 | Kimmo |
| 2054 | 654.3 | Call_Forwarding_Enhancements | 261d? | 1999-01-01 A | 1999-12-31 A | 100% | 1999-01-01 | 1999-12-31 | 261d? | start no earlier than 1999-01-01 | N4 | 2088h | 2088h | Call_Forwarding_Enhancements | R99 | Kimmo |
| 2055 | 655 | **Quality of Service** | 261d? | 1999-01-01 A | 1999-12-31 A | 100% | 1999-01-01 | 1999-12-31 | 261d? |  | S2,T2,N1,N2,N4 | 10440h | 10440h |  | R99 | Maurice |
| 2056 | 655.1 | End-to-end UMTS Quality of Service management | 261d? | 1999-01-01 A | 1999-12-31 A | 100% | 1999-01-01 | 1999-12-31 | 261d? | start no earlier than 1999-01-01 | S2,T2,N1,N2,N4 | 2088h | 2088h | QoS | R99 | Maurice |
| 2057 | 655.2 | End-to-end QoS for PS Domain including IMS | 261d? | 1999-01-01 A | 1999-12-31 A | 100% | 1999-01-01 | 1999-12-31 | 261d? | start no earlier than 1999-01-01 | S2 | 2088h | 2088h | E2EQoS | R99 | Maurice |
| 2058 | 655.3 | GPRS-enhanced_QoS | 261d? | 1999-01-01 A | 1999-12-31 A | 100% | 1999-01-01 | 1999-12-31 | 261d? | start no earlier than 1999-01-01 | T2 | 2088h | 2088h | GPRS-enhanced_QoS | R99 |  |
| 2059 | 655.4 | QoS_enhancements | 261d? | 1999-01-01 A | 1999-12-31 A | 100% | 1999-01-01 | 1999-12-31 | 261d? | start no earlier than 1999-01-01 | N2,N1,N4 | 2088h | 2088h | QoS_enhancements | R99 | Kimmo |
| 2060 | 656 | Support of Localised Service Area | 261d? | 1999-01-01 A | 1999-12-31 A | 100% | 1999-01-01 | 1999-12-31 | 261d? | start no earlier than 1999-01-01 | SMG2,SMG3,SMG7,N2 | 2088h | 2088h | SoLSA | R99 | Maurice |
| 2061 | 657 | Transcoder_location | 261d? | 1999-01-01 A | 1999-12-31 A | 100% | 1999-01-01 | 1999-12-31 | 261d? | start no earlier than 1999-01-01 | S2 | 2088h | 2088h | Transcoder_location | R99 | Maurice |
| 2062 | 658 | Antenna_test_methods | 261d? | 1999-01-01 A | 1999-12-31 A | 100% | 1999-01-01 | 1999-12-31 | 261d? | start no earlier than 1999-01-01 | SMG2 | 2088h | 2088h | Antenna_test_methods | R99 |  |

Notes:
- 2036: -
- 2037: - / Text3: 32.101
- 2038: - / Text3: 32.101, 32.102
- 2039: - / Text3: 32.106, 32.106-1, 32.106-2, 32.106-3, 32.106-4, 32.106-5, 32.106-6, 32.106-7, 32.106-8
- 2040: - / Text3: 32.111, 32.111-1, 32.111-2, 32.111-3, 32.111-4
- 2041: - / Text3: 12.04, 32.104
- 2042: - / Text3: 29.061
- 2043: - / Text3: 03.22, 04.18, 04.60, 05.02, 05.08, 05.10, 08.08, 08.18, 08.58, 09.08, 22.011, 23.003, 23.009, 23.014, 23.034, 23.122, 24.007, 24.008, 24.011, 24.080, 29.108
- 2044: - / Text3: 04.18, 08.08, 08.58, 22.129, 23.009, 29.002, 29.010
- 2045: - / Text3: 04.18, 04.60, 05.02, 05.08, 05.10, 08.08, 29.010
- 2046: - / Text3: 02.01, 02.02, 02.04, 02.34
- 2047: No additional features for R99. / Text3: 02.04, 02.90, 23.090, 29.002
- 2048: - / Text3: 02.42, 04.08
- 2049: - / Text3: 08.18
- 2050: - / Text3: 02.60
- 2051: -
- 2052: No additional features for R99. / Text3: 23.078, 23.079, 23.082, 29.002, 29.078
- 2053: - / Text3: 02.82, 29.002
- 2054: - / Text3: 23.082
- 2055: WID SMG 98-0781 End To End UMTS QoS Management
- 2056: WID SMG 98-0781 End To End UMTS QoS Management / Text3: 23.107, 23.907, 24.008
- 2057: - / Text3: 23.060, 23.170
- 2058: AT-commands for Enhanced QoS Support management / Text3: 27.007
- 2059: - / Text3: 23.008, 23.016, 24.008, 29.002, 29.060
- 2060: Mechanism which can be used as a platform for providing special tariffs and/or special set of service features for certain subscribers within a regionally restricted area or areas. No additional features for R99. / Text3: 04.08, 04.18, 08.08, 11.10-1, 29.002
- 2061: UE location identification: background information and associated primitives 2. Transcoder location at the core network and source depending coding belonging to the non-access stratum. / Text3: 23.110
- 2062: - / Text3: 03.30

| ID | WBS | Task | Duration | Start | Finish | Complete | Baseline start | Baseline finish | Baseline duration | Constraint | Resources | Work | Actual work | Text6 | Text8 |
| --- | --- | --- | --- | --- | --- | --- | --- | --- | --- | --- | --- | --- | --- | --- | --- |
| 2063 | 659 | **Codec** | 261d? | 1999-01-01 A | 1999-12-31 A | 100% | 1999-01-01 | 1999-12-31 | 261d? |  | S4 | 14616h | 14616h | R99 | Paolo |
| 2064 | 659.1 | Codec(s)_for_Multimedia_Telephony_Service | 261d? | 1999-01-01 A | 1999-12-31 A | 100% | 1999-01-01 | 1999-12-31 | 261d? | start no earlier than 1999-01-01 | S4 | 2088h | 2088h | R99 | Paolo |
| 2065 | 659.2 | QoS for Speech and Multimedia Codec | 261d? | 1999-01-01 A | 1999-12-31 A | 100% | 1999-01-01 | 1999-12-31 | 261d? | start no earlier than 1999-01-01 | S4 | 2088h | 2088h | R99 | Paolo |
| 2066 | 659.3 | Tandem Free Operation - Adaptive Multi-Rate codec types | 261d? | 1999-01-01 A | 1999-12-31 A | 100% | 1999-01-01 | 1999-12-31 | 261d? | start no earlier than 1999-01-01 | S4 | 2088h | 2088h | R99 | Paolo |
| 2067 | 659.4 | Noise Suppression for AMR | 261d? | 1999-01-01 A | 1999-12-31 A | 100% | 1999-01-01 | 1999-12-31 | 261d? | start no earlier than 1999-01-01 | S4 | 2088h | 2088h | R99 | Paolo |
| 2068 | 659.5 | Out-of-Band Transcoder | 261d? | 1999-01-01 A | 1999-12-31 A | 100% | 1999-01-01 | 1999-12-31 | 261d? | start no earlier than 1999-01-01 | N1 | 2088h | 2088h | R99 | Frederic |
| 2069 | 659.6 | Out-of-Band Transcoder Control | 261d? | 1999-01-01 A | 1999-12-31 A | 100% | 1999-01-01 | 1999-12-31 | 261d? | start no earlier than 1999-01-01 | N1 | 2088h | 2088h | R99 | Frederic |
| 2070 | 660 | Advanced Speech Call Items enhancements | 261d? | 1999-01-01 A | 1999-12-31 A | 100% | 1999-01-01 | 1999-12-31 | 261d? | start no earlier than 1999-01-01 | SMG1,SMG2,SMG3,SMG7,SMG9,N1,N4,S1,T2 | 2088h | 2088h | R99 | Alain |
| 2071 | 661 | Call Control improvements | 261d? | 1999-01-01 A | 1999-12-31 A | 100% | 1999-01-01 | 1999-12-31 | 261d? | start no earlier than 1999-01-01 | N1 | 2088h | 2088h | R99 | Frederic |
| 2072 | 662 | Multimedia | 261d? | 1999-01-01 A | 1999-12-31 A | 100% | 1999-01-01 | 1999-12-31 | 261d? | start no earlier than 1999-01-01 | N1,N3 | 2088h | 2088h | R99 | Frederic |
| 2073 | 663 | Sub-System Number allocation for RANAP, RNSAP | 261d? | 1999-01-01 A | 1999-12-31 A | 100% | 1999-01-01 | 1999-12-31 | 261d? | start no earlier than 1999-01-01 | N2 | 2088h | 2088h | R99 | Frederic |
| 2074 | 664 | Intranet / ISP access with DHCP end-to-end | 261d? | 1999-01-01 A | 1999-12-31 A | 100% | 1999-01-01 | 1999-12-31 | 261d? | start no earlier than 1999-01-01 | N3 | 2088h | 2088h | R99 | Gwiho |
| 2075 | 665 | Point_to_Multipoint_Services | 261d? | 1999-01-01 A | 1999-12-31 A | 100% | 1999-01-01 | 1999-12-31 | 261d? | start no earlier than 1999-01-01 | N3 | 2088h | 2088h | R99 | Gwiho |
| 2076 | 666 | Realtime_NT_FAX_in_UMTS | 261d? | 1999-01-01 A | 1999-12-31 A | 100% | 1999-01-01 | 1999-12-31 | 261d? | start no earlier than 1999-01-01 | N3 | 2088h | 2088h | R99 | Gwiho |
| 2077 | 667 | Gateway Location Register (GLR) - Mobile Application Part (MAP) specification | 261d? | 1999-01-01 A | 1999-12-31 A | 100% | 1999-01-01 | 1999-12-31 | 261d? | start no earlier than 1999-01-01 | N4 | 2088h | 2088h | R99 | Kimmo |
| 2078 | 668 | Multiple Subscriber Profile phase 2 | 261d? | 1999-01-01 A | 1999-12-31 A | 100% | 1999-01-01 | 1999-12-31 | 261d? | start no earlier than 1999-01-01 | S1,N4 | 2088h | 2088h | R99 | Alain |
| 2079 | 669 | Prepaging | 261d? | 1999-01-01 A | 1999-12-31 A | 100% | 1999-01-01 | 1999-12-31 | 261d? | start no earlier than 1999-01-01 | N2,N4 | 2088h | 2088h | R99 | Kimmo |
| 2080 | 670 | Re-definition of channel quality measure used for AMR link adaptation for Downlink Advanced Receiver Performance (DARP) MS | 261d? | 1999-01-01 A | 1999-12-31 A | 100% | 1999-01-01 | 1999-12-31 | 261d? | start no earlier than 1999-01-01 | SMG | 2088h | 2088h | R99 |  |
| 2081 | 671 | Harmonized Standard | 261d? | 1999-01-01 A | 1999-12-31 A | 100% | 1999-01-01 | 1999-12-31 | 261d? | start no earlier than 1999-01-01 | SMG2 | 2088h | 2088h | R99 |  |
| 2082 | 672 | Streamlining of specifications | 261d? | 1999-01-01 A | 1999-12-31 A | 100% | 1999-01-01 | 1999-12-31 | 261d? | start no earlier than 1999-01-01 | N3 | 2088h | 2088h | R99 | Gwiho |
| 2083 | 673 | R99_Service_Clean_up | 261d? | 1999-01-01 A | 1999-12-31 A | 100% | 1999-01-01 | 1999-12-31 | 261d? | start no earlier than 1999-01-01 | N3 | 2088h | 2088h | R99 | Gwiho |
| 2084 | 674 | **(Small) Technical Enhancements and Improvements for R99** | 261d? | 1999-01-01 A | 1999-12-31 A | 100% | 1999-01-01 | 1999-12-31 | 261d? |  | N3 | 6264h | 6264h | R99 | Gwiho |
| 2085 | 674.1 | TEI_[CS_Data] | 261d? | 1999-01-01 A | 1999-12-31 A | 100% | 1999-01-01 | 1999-12-31 | 261d? | start no earlier than 1999-01-01 | N3 | 2088h | 2088h | R99 | Gwiho |
| 2086 | 674.2 | TEI_[GPRS] | 261d? | 1999-01-01 A | 1999-12-31 A | 100% | 1999-01-01 | 1999-12-31 | 261d? | start no earlier than 1999-01-01 | N3 | 2088h | 2088h | R99 | Gwiho |

Notes:
- 2063: -
- 2064: - / Text1: Multimedia_Codec, CSM, WI2MMC, Codec(s)_for_CS_MM_Tel._Serv, Codec(s)_for_MM_Tel_Service, Codec_for_Multimedia_Telephony / Text3: 26.911, 26.104, 26.111
- 2065: - / Text1: QoS_for_Speech_&_MM_Codecs_/_AMR / Text3: 26.102, 26.912
- 2066: UMTS_AMR2 is default Codec Type in R99 dual_mode terminals / Text1: TFOAMR / Text3: 26.103
- 2067: Combination of the AMR speech codec and the Noise Suppression function. TS 06.77 and TR 06.78 only apply to GSM. They apply to UMTS from Rel-4 onwards, when they were converted to TS 26.077 and TR 26.078. / Text1: AMRNS / Text3: 06.77, 06.78
- 2068: Transcoder handling in the CN at inter-system handover and relocation + Introduction of UMTS AMR / Text1: OoBT / Text3: 23.009, 24.008
- 2069: 24.008 CR#0572 in NP-020220 was approved under this WI / Text1: OoBTC / Text3: 24.008 CR#0572 in NP-020220
- 2070: - / Text1: ASCI / Text3: 02.30, 02.68, 03.68, 03.69, 04.18, 08.08, 11.10-1, 11.11, 23.067, 23.094, 24.008, 24.067, 27.007, 29.002
- 2071: Minor improvements to 24.007 and 24.008 to increase the number of simultaneous calls/sessions from the present 7: the TI value is increased (NP-99441). / Text1: CC_Related_items / Text3: 24.007, 24.008
- 2072: - / Text1: Multimedia / Text3: 24.008, 27.001, 29.007
- 2073: Sub-System Number allocation for Radio Access Network Application Part, Radio Network Subsystem Application Part / Text1: SSN_allocation / Text3: 23.003
- 2074: Access to an Intranet/ISP with DHCP end to end / Text1: ISPaccess / Text3: 29.061
- 2075: Support for the IP-Multicast protocol / Text1: Point_to_Multipoint_Services / Text3: 29.061
- 2076: Asynchronous Interface for real-time NT Fax + Introduction of Asynchronous interface for Real-time non-transparent FAX / Text1: Realtime_NT_FAX_in_UMTS / Text3: 27.001, 27.003
- 2077: - / Text1: GLR / Text3: 29.120
- 2078: - / Text1: MSP2 / Text3: 22.097, 23.072, 23.083, 23.084, 23.091, 23.093, 23.097
- 2079: - / Text1: Prepaging / Text3: 23.018, 23.082, 29.002
- 2080: Re-definition of channel quality measure used for AMR link adaptation for DARP MS / Text3: 05.09
- 2081: - / Text1: HS / Text3: 13.21
- 2082: - / Text1: Streamlining / Text3: 27.060, 29.061
- 2083: - / Text1: R99_Service_Clean_up / Text3: 03.10, 27.001, 27.002, 27.003, 27.060, 29.007, 29.061
- 2084: - / Text1: TEI
- 2085: - / Text1: TEI_[CS_Data]
- 2086: - / Text1: TEI_[GPRS]

| ID | WBS | Task | Type | Duration | Start | Finish | Complete | Baseline start | Baseline finish | Baseline duration | Constraint | Resources | Work | Actual work | Text1 | Text3 | Text6 | Text8 | Text12 | Text4 | Text5 |
| --- | --- | --- | --- | --- | --- | --- | --- | --- | --- | --- | --- | --- | --- | --- | --- | --- | --- | --- | --- | --- | --- |
| 2087 | 675 | **R99 UE Conformance Testing** |  | 261d? | 1999-01-01 A | 1999-12-31 A | 100% | 1999-01-01 | 1999-12-31 | 261d? |  | R5,T1 | 4176h | 4176h | TEI_Test | 34.108, 34.121, 34.122, 34.123-1, 34.123-2, 34.123-3 | R99 | Ingbert |  |  |  |
| 2088 | 675.1 | Deleted - RTEI |  | 261d? | 1999-01-01 A | 1999-12-31 A | 100% | 1999-01-01 | 1999-12-31 | 261d? | start no earlier than 1999-01-01 | T1 | 2088h | 2088h | RTEI | 34.123-1 CR#0650, 0651, 34.123-3 CR#0148, 0149, 0150 | R99 | Ingbert | TP-06 |  |  |
| 2089 | 675.2 | Common test environments for User Equipment (UE); Conformance testing | milestone | 0d? | 1999-01-01 A | 1999-01-01 A | 100% | 1999-01-01 | 1999-01-01 | 0d? | start no earlier than 1999-01-01 | R5,T1 |  |  | TEI_Test | 34.108 | R99 | Ingbert |  |  |  |
| 2090 | 675.3 | Terminal conformance specification, Radio transmission and reception (FDD) | milestone | 0d? | 1999-01-01 A | 1999-01-01 A | 100% | 1999-01-01 | 1999-01-01 | 0d? | start no earlier than 1999-01-01 | R5,T1 |  |  | TEI_Test | 34.121 | R99 | Ingbert |  |  |  |
| 2091 | 675.4 | Terminal conformance specification, Radio transmission and reception (TDD) | milestone | 0d? | 1999-01-01 A | 1999-01-01 A | 100% | 1999-01-01 | 1999-01-01 | 0d? | start no earlier than 1999-01-01 | R5,T1 |  |  | TEI_Test | 34.122 | R99 | Ingbert |  |  |  |
| 2092 | 675.5 | UE conformance specification; Part 1: Protocol conformance specification | milestone | 0d? | 1999-01-01 A | 1999-01-01 A | 100% | 1999-01-01 | 1999-01-01 | 0d? | start no earlier than 1999-01-01 | R5,T1 |  |  | TEI_Test | 34.123-1 | R99 | Ingbert |  |  |  |
| 2093 | 675.6 | UE conformance specification; Part 2: Implementation Conformance Statement (ICS) specification | milestone | 0d? | 1999-01-01 A | 1999-01-01 A | 100% | 1999-01-01 | 1999-01-01 | 0d? | start no earlier than 1999-01-01 | R5,T1 |  |  | TEI_Test | 34.123-2 | R99 | Ingbert |  |  |  |
| 2094 | 675.7 | UE conformance specification; Part 3: Abstract test suites (ATSs) | milestone | 0d? | 1999-01-01 A | 1999-01-01 A | 100% | 1999-01-01 | 1999-01-01 | 0d? | start no earlier than 1999-01-01 | R5,T1 |  |  | TEI_Test | 34.123-3 | R99 | Ingbert |  |  |  |
| 2095 | 676 | Deleted - Dual Tone Multi-Frequency signalling : Support in the whole 3GPP system |  | 261d? | 1999-01-01 A | 1999-12-31 A | 100% | 1999-01-01 | 1999-12-31 | 261d? | start no earlier than 1999-01-01 | N1 | 2088h | 2088h | DTMF | 23.014 CR#0004 | R99 | Frederic | NP-06 |  |  |
| 2096 | 677 | Deleted - Intersystem_Change |  | 261d? | 1999-01-01 A | 1999-12-31 A | 100% | 1999-01-01 | 1999-12-31 | 261d? | start no earlier than 1999-01-01 | SMG | 2088h | 2088h | Intersystem_Change | 04.18 CR#A243 | R99 |  | SMG |  |  |
| 2097 | 678 | Deleted - Long_Forwardedto_Numbers |  | 261d? | 1999-01-01 A | 1999-12-31 A | 100% | 1999-01-01 | 1999-12-31 | 261d? | start no earlier than 1999-01-01 | N2 | 2088h | 2088h | Long_Forwardedto_Numbers | 29.002 | R99 | Kimmo | NP-06 |  |  |
| 2098 | 679 | Deleted - RANimp-FSEarlyUE |  | 261d? | 1999-01-01 A | 1999-12-31 A | 100% | 1999-01-01 | 1999-12-31 | 261d? | start no earlier than 1999-01-01 | R3 | 2088h | 2088h | RANimp-FSEarlyUE | 25.413 CR#0520, 0538, 0565, 0563, 0541, 0540, 0539, 0547 | R99 | Juha | RP-06 |  |  |
| 2099 | 680 | Release 1999 Studies |  | 261d? | 1999-01-01 A | 1999-12-31 A | 100% | 1999-01-01 | 1999-12-31 | 261d? |  | S1,T2 | 2088h | 2088h |  |  | R99 | Alain |  |  |  |
| 2100 | 681 | Combined GSM and Mobile IP mobility handling in UMTS IP CN |  | 261d? | 1999-01-01 A | 1999-12-31 A | 100% | 1999-01-01 | 1999-12-31 | 261d? | start no earlier than 1999-01-01 | S2 | 2088h | 2088h |  | 23.923 | R99 | Maurice |  |  |  |
| 2101 | 682 | UE Capabilities Requirements |  | 261d? | 1999-01-01 A | 1999-12-31 A | 100% | 1999-01-01 | 1999-12-31 | 261d? | start no earlier than 1999-01-01 | T2 | 2088h | 2088h | UCR | 21.904 | R99 |  |  |  |  |
| 2102 | 683 | Electrical safety requirements and regulations |  | 261d? | 1999-01-01 A | 1999-12-31 A | 100% | 1999-01-01 | 1999-12-31 | 261d? | start no earlier than 1999-01-01 | T2 | 2088h | 2088h |  | 34.907 | R99 |  |  |  |  |
| 2103 | 684 | Specific Absorbtion Rate (SAR) requirements and regulations in different regions |  | 261d? | 1999-01-01 A | 1999-12-31 A | 100% | 1999-01-01 | 1999-12-31 | 261d? | start no earlier than 1999-01-01 | T2 | 2088h | 2088h |  | 34.925 | R99 |  |  |  |  |
| 2104 | 685 | Multi-mode UE issues |  | 261d? | 1999-01-01 A | 1999-12-31 A | 100% | 1999-01-01 | 1999-12-31 | 261d? | start no earlier than 1999-01-01 | T2 | 2088h | 2088h |  | 21.810, 21.910 | R99 |  |  |  |  |
| 2105 | 686 | Provision of fax service in GSM and UMTS |  | 261d? | 1999-01-01 A | 1999-12-31 A | 100% | 1999-01-01 | 1999-12-31 | 261d? | start no earlier than 1999-01-01 | T2 | 2088h | 2088h |  | 22.945 | R99 |  |  | Ericsson | peter.bleckert@ericsson.com |
| 2106 | 687 | Separating Radio Resources and Mobility Management specific parts of the MS Classmark |  | 1d | 2000-01-03 A | 2000-01-03 A | 100% | 2000-01-03 | 2000-01-03 | 1d |  | T2 | 8h | 8h |  | 23.814 | R99 |  |  |  |  |

Notes:
- 2087: Specifies Conformance Tests for a 3G UE to be recognised as 3GPP-standard compliant. A 3GPP-external body, GCF (Global Certification Forum), delivers certificates to prove that a UE has correctly passed tests and is then conform to the 3GPP standard.
- 2088: No CR or new TS/TR approved under this WI
- 2089: -
- 2090: measurement procedures for the conformance test of the UE that contain transmitting characteristics, receiving characteristics and performance requirements in addition to requirements for support of RRM (Radio Resource Management) in FDD mode.
- 2091: measurement procedures for the conformance test of the UE that contain transmitting characteristics, receiving characteristics and performance requirements in addition to requirements for support of RRM (Radio Resource Management) in TDD mode.
- 2092: TS 34.123, composed of three parts, actually specifies the protocol conformance testing for the 3G UE. Part 1 describes the overall test structure.
- 2093: Part 2 contains the applicability of each test case defined as the Implementation Conformance Statement (ICS) proforma, in compliance with the relevant requirements, and in accordance with the relevant guidance given in ISO/IEC 9646-7 and ETS 300 406.
- 2094: Part 3 specifies the protocol conformance testing in TTCN for the 3G UE at the Uu interface. It defines the TTCN test specification and design considerations in Abstract Test Suites based on the test cases specified in prose in part 1.
- 2095: No CR or new TS/TR approved under this WI
- 2096: No CR or new TS/TR approved under this WI
- 2097: -
- 2098: No CR or new TS/TR approved under this WI
- 2099: -
- 2100: -
- 2101: Moved to CT1 at TSG-T closure
- 2102: Moved to RAN4 at TSG-T closure. TR summarizes differences between international and national standards relevant to IEC60950 and refers to regulations for conformity assessment due to different regulatory environments in different countries / regions.
- 2103: Moved to RAN4 at TSG-T closure.
- 2104: Moved to CT1 at TSG-T closure. Consequences on roaming capabilities and service availability (e.g. handover) of multi-mode UEs while roaming in various regions with various network configurations. Case studies for each of the possible scenarios in specs
- 2105: CP#27: Moved to C1 on closure of T2; see TP-050062. CP#28: C1->C3
- 2106: CP#27: change of WG as a result of closure of CN and T.
